# 3GPP_Release-2000

Schedule from MS Project, 1989-10-23 to 2010-03-12, A marks actual dates.

## Calendars

- Standard: Mon-Fri 08:00-12:00, 13:00-17:00; Sat-Sun off.

## Resources

| Resource |
| --- |
| NP |
| N1 |
| N2 |
| N3 |
| N4 |
| N5 |
| TP |
| T1 |
| T2 |
| T3 |
| RP |
| R1 |
| R2 |
| R3 |
| R4 |
| SP |
| S1 |
| S2 |
| S3 |
| S4 |
| S5 |
| PCG |
| GP |
| No |
| CN4 |
| ? |
| WG G2 |
| G2 |
| G1 |
| G4 |
| G3 |
| All |
| Generic |
| MLST |
| G5 |
| S3, G2 |
| WG T2 |
| GP,G1 |
| G4,G5 |
| OMA |
| GP-G2 |
| Yes |
| GP, |
| N4, |
| GP, N1 |
| CT5 |
| C5 |
| C1 |
| C4 |
| C3 |
| C6 |
| G1, |
| 4 |
| ct |
| c,s,r |
| CT,RAN,SA |
| G2, |
| G1, G3 |
| CT6 |
| CT1 |
| CT1, CT3, CT4 |
| C1, C3, C4 |
| CP |
| R5 |
| C |
| Rel-8 |
| GP, G2 |
| R1,R4 |
| S5,C1 |
| CT,RAN,SA,GERAN |
| S3,C1,C4 |
| 5 |
| S1,C1,C3,C4,S5 |
| S1,C1,C3,C5 |
| S1,C1,C3,C4 |
| S1,S5 |
| S2,S3 |
| RAN,SA |
| RP,S5 |
| S2,CT |
| S1,CT |
| S1,CT,GERAN |
| S1,C5 |
| S3,CT |
| S4,CT |
| C1,SA |
| S1,S2 |
| S1,S4 |
| S2,S2,S3,CT |
| S2,S3,CT |
| S1,CT,GX |
| S1,S4,CT |
| S2,S2,S3,S5,CT |
| S1,S2,CT |
| S1,S2,S3,CT |
| S1,S2,S3,S5CT |
| S1,S2,S3,S5,CT |
| S2,S5,CT |
| S4,S3 |
| S1,C1 |
| CP,C1 |
| C1,C3 |
| C1,C3,C4 |
| S1,S5,CT |
| C4,C3 |
| CP,RAN,SA,GERAN |
| S1,S2,S3,S5,CP |
| S2,S3,CP |
| S2,CP |
| S1,CP,GX |
| S1,CP |
| S1,S4,CP |
| S1,S2,CP |
| S1,S2,S3,CP |
| S2,S5,CP |
| S3,CP |
| S1,S5,CP |
| RAN,SA,GERAN |
| S1,S2,S3,S5,C1,C3,C4,C6 |
| S2,S3,C1,C3,C4 |
| S2,C4 |
| S2,C1,C3,C4 |
| S2,C1,C4 |
| S2,S3,C1,C4 |
| S1,C1,C4,G2 |
| C1,C4 |
| S1,C1,C3 |
| S1,S4,C1,C3,C4 |
| S1,S2,S3,C1,C3,C4 |
| S2,S5,C3 |
| S1,S2,C1,C4 |
| S2,C1 |
| S2,C1,C3 |
| S3,C1,C3,C4 |
| S1,S5,C1,C3,C4 |
| S2,C3,C4 |
| C3,C1 |
| R2,R4 |
| R2,R5 |
| RP,R5 |
| RP,S5,R5 |
| R1,R5 |
| S1,C1,R5 |
| S1,C1,S4,R5 |
| GERAN |
| G3new |
| G1, G3new |
| C4,C1,C3 |
| R1.R4 |
| R1, R4 |
| R2,R3 |
| C3,C4 |
| S4,C3 |
| S4,C3,C1,C4 |
| S1,S2,C1 |
| S1,S2<C1,C3,C4 |
| S1,S2,C1,C3,C4 |
| S5,C1,C3,C4 |
| GP,C4 |
| C4,C1 |
| S2,S1 |
| RP,SP,GP |
| RP,SP,CP,GP |
| CP,GP,RP,SP |
| GP,C4,S4 |
| S1,C1,C4 |
| S1,S2,C3,C1 |
| R2,R4,R3 |
| CP,GP, RP,SP |
| S2,S1,C1,S5 |
| S2,S1,C1 |
| S1,C1,S4 |
| S1,S2,GP,C4,R2 |
| S1,GP,R2 |
| S1,C6 |
| S1,S2,C1,S4 |
| S2,S3,S5,C1,C3,C4 |
| S2,S5,C1 |
| S2,S3,S5 |
| CP,GP, RP,SP,TP |
| S2,C4,C1 |
| S1,C1,C4,S3 |
| S2,S5 |
| S3,C1 |
| S3,C4 |
| S1,C4 |
| S2,S5,C3,C1 |
| S2,S1,S5,C1,C4 |
| S1,R1,C3 |
| S1,C1,R2 |
| S2,S1,C1,C4 |
| S1,C1,C6 |
| GP,S4,C4,C1,C3 |
| C3,C1,C4 |
| S1,C4,C1 |
| S1,S3 |
| S1,S2,S5,C3,C4 |
| R4,G1 |
| G1,R4 |
| RP,GP |
| R4,GP |
| R3,R2 |
| C6,RP,SP |
| R5,C6 |
| CP,RP,SP |
| RP,SP,CP |
| R3,S5 |
| S1,S2,RP |
| S1,S2,S5,RP |
| S2,S1,RP |
| Rel-9 |
| S3,C6 |
| S1,S2,S3,S5,RP |
| S2,S1,S3 |
| S1,S2,S3 |
| S1,S2,S3,S5 |
| C6,R5 |
| S1,S2,RP,GP |
| S1,S2,S4,S5,RP,GP |
| GP,G2 |
| GP,GP, N1 |
| GP,S2,G1,G2 |
| GP,R2,R3,S2,G1,G2 |
| GP,S2,S5,R2,R3,G2,G1 |
| GP,R3 |
| N4,S2 |
| GP,RP |
| GP,S2,RP |
| G5,G4 |
| G4,R3 |
| S2,R2,R4 |
| S1,S2,R2,R4 |
| GP,S5 |
| S1,S2,S5 |
| R4,R5 |
| R4,R2,R3,R5 |
| S2,S5,N4,RP |
| S1,S2,S3,S5,NP |
| S2,S4,S5 |
| T2,S1,S4,S5 |
| SP,RP |
| S2,RP |
| S1,S2,CP,G2 |
| CP,SP |
| S1,G2 |
| SP,CP |
| S1,S2,S5,C3 |

## Schedule

| ID | WBS | Task | Type | Duration | Start | Finish | Complete | Remaining | Baseline start | Baseline finish | Baseline duration | Total slack | Constraint | Resources | Work | Actual work | Text6 | Text1 | Text2 | Text4 | Text5 | Text7 | Text8 | Text3 |
| --- | --- | --- | --- | --- | --- | --- | --- | --- | --- | --- | --- | --- | --- | --- | --- | --- | --- | --- | --- | --- | --- | --- | --- | --- |
| 1 | 1 | Version 2009 Mar 24 |  | 2660d? | 1989-10-23 | 2000-01-03 |  |  | 1989-10-23 | 2000-01-03 | 2660d? | 2660d | finish no earlier than 2000-01-03 |  |  |  |  |  |  |  |  |  |  |  |
| 3 | 2 | "CTRL + a" to display all the 3GPP fields |  | 1d | 2000-01-03 | 2000-01-03 |  |  | 2000-01-03 | 2000-01-03 | 1d | 2659d | start no earlier than 2000-01-01 |  |  |  |  |  |  |  |  |  |  |  |
| 5 | 3 | Gantt: dark blue=done; light blue=to be done; grey: previous values; black=summary |  | 1d? | 2000-01-03 | 2000-01-03 |  |  | 2000-01-03 | 2000-01-03 | 1d? | 2659d | start no earlier than 2000-01-01 |  |  |  |  |  |  |  |  |  |  |  |
| 7 | 4 | Release 10 Features | milestone | 0d? | 2000-01-01 | 2000-01-01 |  |  | 2000-01-01 | 2000-01-01 | 0d? | 2660d |  | CP,SP |  |  | Rel-10 |  |  |  |  |  |  |  |
| 8 | 5 | **Network Selection for non-3GPP Access** |  | 526d? | 2007-12-06 | 2009-12-10 |  |  | 2007-12-06 | 2009-12-10 | 526d? | 66d |  | S1,C6 | 11740.8h |  | Rel-10 | N3GtoNSP | PCG-21 | Telefonica O2 | chris.friel@O2.com | SP-38 | Alain |  |
| 9 | 5.1 | Stage 1 for N3GtoNSP |  | 526d? | 2007-12-06 | 2009-12-10 |  |  | 2007-12-06 | 2009-12-10 | 526d? | 66d | finish no earlier than 2009-12-10 | S1 | 4208h |  | Rel-10 | N3GtoNSP | PCG-21 | Telefonica O2 | chris.friel@O2.com | SP-38 | Alain | 22.011 |
| 10 | 5.2 | CT6 issues for N3GtoNSP |  | 522d? | 2007-12-06 | 2009-12-04 |  |  | 2007-12-06 | 2009-12-04 | 522d? | 70d | finish no earlier than 2009-12-04 | C6 | 4176h |  | Rel-10 | N3GtoNSP | PCG-21 | Telefonica O2 | chris.friel@O2.com | SP-38 | Xavier | 22.234, 21.111, 31.101, 31.102, 31.103 |
| 11 | 6 | **Network Improvements for Machine-type Communications** |  | 186d? | 2008-09-18 A | 2009-06-04 | 35% | 120.9d? | 2008-09-18 | 2009-06-04 | 186d? | 201d |  | S1 | 2976h | 1041.6h | Rel-10 | NIMTC | PCG-21 | KPN | Toon Norp (toon.norp AT tno.nl) | SP-41 | Alain |  |
| 12 | 6.1 | Stage 1 for NIMTC |  | 186d? | 2008-09-18 A | 2009-06-04 | 35% | 120.9d? | 2008-09-18 | 2009-06-04 | 186d? | 201d | finish no earlier than 2009-06-04 | S1 | 1488h | 520.8h | Rel-10 | NIMTC | PCG-21 | KPN | Toon Norp (toon.norp AT tno.nl) | SP-41 | Alain | 22.368 |
| 13 | 7 | Release 10 Feasibility Studies | milestone | 0d? | 2000-01-01 | 2000-01-01 |  |  | 2000-01-01 | 2000-01-01 | 0d? | 2660d | start no earlier than 2000-01-01 | SP |  |  | Rel-10 |  |  |  |  |  |  |  |
| 14 | 8 | Study on Mobile Haptic Services |  | 261d? | 2009-03-12 | 2010-03-11 |  |  | 2009-03-12 | 2010-03-11 | 261d? | 1d | finish no earlier than 2010-03-11 | S1 | 2088h |  | Rel-10 | FS_Haptics | PCG-22 | SK Telecom | Donghee Shim | SP-43 | Alain | 22.9xy |
| 15 | 9 | Release 9 Features | milestone | 0d? | 2000-01-01 | 2000-01-01 |  |  | 2000-01-01 | 2000-01-01 | 0d? | 2660d |  | CP,GP,RP,SP |  |  | Rel-9 |  |  |  |  |  |  |  |
| 16 | 10 | **Services Alignment and Migration** |  | 467d? | 2006-12-06 A | 2008-09-18 A | 100% |  | 2006-12-06 | 2008-09-18 | 467d? |  |  | S1 | 7472h | 7472h | Rel-9 | ServAl |  | China Mobile | fenglingjuan@chinamobile.com | SP-33 | Alain |  |
| 17 | 10.1 | Stage 1 for ServAl |  | 467d? | 2006-12-06 A | 2008-09-18 A | 100% |  | 2006-12-06 | 2008-09-18 | 467d? |  | finish no earlier than 2008-12-11 | S1 | 3736h | 3736h | Rel-9 | ServAl | PCG-21 | China Mobile | fenglingjuan@chinamobile.com | SP-33 | Alain | 22.182 |
| 18 | 11 | **Registration in Densely-populated area (RED)** |  | 584d? | 2007-03-12 A | 2009-06-04 | 50% | 289.39d? | 2007-03-12 | 2009-06-04 | 584d? | 201d |  | S1,S2 | 8248h | 4160.9h | Rel-9 | RED |  | NTT DoCoMo | tanakai@nttdocomo.co.jp | SP-35 | Alain | WID identifies also impacted CT1 24.008, RAN2 25.331 |
| 19 | 11.1 | Stage 1 for RED |  | 4d? | 2007-03-12 A | 2007-03-15 A | 100% |  | 2007-03-12 | 2007-03-15 | 4d? |  | start no earlier than 2007-03-12 | S1 | 32h | 32h | Rel-9 | RED |  | NTT DoCoMo | takakurat@s1.nttdocomo.co.jp | SP-35 | Alain | 22.101 CR#0207 |
| 20 | 11.2 | Stage 2 for RED |  | 443d? | 2007-09-25 A | 2009-06-04 | 50% | 221.5d? | 2007-09-25 | 2009-06-04 | 443d? | 201d | finish no earlier than 2009-06-04 | S2 | 3544h | 1772h | Rel-9 | RED |  | NTT DoCoMo | tanakai@nttdocomo.co.jp | SP-37 | Maurice | 23.880, 23.002, 23.060, 23.221, 23.236 |
| 21 | 12 | **End-User Identity** |  | 334d? | 2007-09-03 A | 2008-12-11 A | 100% |  | 2007-09-03 | 2008-12-11 | 334d? |  |  | S1 | 5344h | 5344h | Rel-9 | EUI |  | Nokia Siemens Networks | Joerg Swetina (joerg.swetina@nw.neclab.eu) | SP-38 | Alain |  |
| 22 | 12.1 | Stage 1 for EUI |  | 334d? | 2007-09-03 A | 2008-12-11 A | 100% |  | 2007-09-03 | 2008-12-11 | 334d? |  | finish no earlier than 2008-12-11 | S1 | 2672h | 2672h | Rel-9 | EUI | PCG-21 | Nokia Siemens Networks | Joerg Swetina (joerg.swetina@nw.neclab.eu) | SP-38 | Alain | 21.905 |
| 23 | 13 | **Customized Ringing Signal** |  | 266d? | 2007-12-06 A | 2008-12-11 A | 100% |  | 2007-12-06 | 2008-12-11 | 266d? |  |  | S1 | 4256h | 4256h | Rel-9 | CRS | PCG-21 | SK Telecom, China Mobile | Donghee Shim (SK Telecom), Jianping Zheng (China Mobile) | SP-38 | Alain |  |
| 24 | 13.1 | Stage 1 for CRS |  | 266d? | 2007-12-06 A | 2008-12-11 A | 100% |  | 2007-12-06 | 2008-12-11 | 266d? |  | finish no earlier than 2008-12-11 | S1 | 2128h | 2128h | Rel-9 | CRS | PCG-21 | SK Telecom, China Mobile | Donghee Shim (SK Telecom), Jianping Zheng (China Mobile) | SP-38 | Alain | 22.183, 22.173 |
| 25 | 14 | **Public Warning System** |  | 266d? | 2007-12-06 A | 2008-12-11 A | 100% |  | 2007-12-06 | 2008-12-11 | 266d? |  |  | S1 | 4256h | 4256h | Rel-9 | PWS | PCG-21 | T-Mobile | Mark.Younge@t-mobile.com | SP-38 | Alain |  |
| 26 | 14.1 | Stage 1 for PWS |  | 266d? | 2007-12-06 A | 2008-12-11 A | 100% |  | 2007-12-06 | 2008-12-11 | 266d? |  | finish no earlier than 2008-12-11 | S1 | 2128h | 2128h | Rel-9 | PWS | PCG-21 | T-Mobile | Mark.Younge@t-mobile.com | SP-38 | Alain | 22.268 |
| 27 | 15 | **Enhancements to Multimedia Priority Service** |  | 584d? | 2006-03-13 A | 2008-06-05 A | 100% |  | 2006-03-13 | 2008-06-05 | 584d? |  |  | S1 | 4672h | 4672h | Rel-9 | ePRIOR | PCG-21 | Telcordia | jgarraha@telcordia.com | SP-39 | Alain |  |
| 28 | 15.1 | Stage 1 for ePRIOR |  | 584d? | 2006-03-13 A | 2008-06-05 A | 100% |  | 2006-03-13 | 2008-06-05 | 584d? |  | start no earlier than 2006-03-12 | S1 | 4672h | 4672h | Rel-9 | ePRIOR | PCG-21 | Telcordia | jgarraha@telcordia.com | SP-39 | Alain | 22.153, 22.278 |

Notes:
- 8: SA#42 moved to Rel-10. 01/09 MCC shifted target completion 12/08=>12/09
- 9: SA#42 moved to Rel-10. 01/09 MCC shifted target completion 12/08=>12/09
- 10: SA#42 moved to Rel-10. 01/09 MCC shifted target completion 12/08=>12/09
- 11: SA#42 moved to Rel-10
- 12: SA#42 moved to Rel-10
- 14: Haptic - human-machine tactile communication - could extend the service offerings and richness of mobile user experience beyond the current visual and auditory senses
- 16: SA#41 Stage 1 completed. Triggered by Study UID_370086 (FSServAl).
- 17: SA#41 completed
- 18: SA#35 Stage 1 completed. SA#40 SA2 moved to Rel-9.
- 19: SA#35 completed
- 20: SA#42 Target completion 09/08=>12/08=>06/09
- 21: SA#42 Stage 1 work closed at 5% completion due to lack of input (added only the EUI definition in 21.905)
- 22: SA#42 Stage 1 work closed at 5% completion due to lack of input (added only the EUI definition in 21.905)
- 23: SA#42 Stage 1 completed (need for Input in SA2). SA#41 WID updated SP-070875=>SP-080502
- 24: SA#42 completed.
- 25: SA#42 Stage 1 completed. Larger scope than Rel-8 Feature UID_370051 (ETWS). Triggered by TR 22.968 Study UID_320025 (FS_PWS).
- 26: SA#42 completed.
- 27: SA#40 Stage 1 completed. Continuation of Rel-8 Feature PRIOR UID_340044.
- 28: SA#40 completed

| ID | WBS | Task | Type | Duration | Start | Finish | Complete | Remaining | Baseline start | Baseline finish | Baseline duration | Total slack | Constraint | Resources | Work | Actual work | Text1 | Text2 | Text4 | Text5 | Text6 | Text7 | Text8 | Text11 |
| --- | --- | --- | --- | --- | --- | --- | --- | --- | --- | --- | --- | --- | --- | --- | --- | --- | --- | --- | --- | --- | --- | --- | --- | --- |
| 29 | 16 | **Support of Personal Area Networks and Enhancements to Personal Network Management** |  | 392d? | 2008-06-05 A | 2009-12-04 |  | 392d? | 2008-06-05 | 2009-12-04 | 392d? | 70d |  | S1,C1 | 6272h |  | PAN_EPNM | PCG-21 | Vodafone | armin.toepfer@vodafone.com | Rel-9 | SP-40 | Alain |  |
| 30 | 16.1 | Stage 1 for PAN_EPNM | milestone | 0d? | 2008-06-05 A | 2008-06-05 A | 100% |  | 2008-06-05 | 2008-06-05 | 0d? |  | finish no earlier than 2008-06-05 | S1 |  |  | PAN_EPNM | PCG-21 | Vodafone | armin.toepfer@vodafone.com | Rel-9 | SP-40 | Alain |  |
| 31 | 16.2 | Stage 2 for PAN_EPNM |  | 196d? | 2009-03-06 | 2009-12-04 |  |  | 2009-03-06 | 2009-12-04 | 196d? | 70d | finish no earlier than 2009-12-04 | C1 | 1568h |  | PAN_EPNM | PCG-22 | Huawei | Lili Yang (kadyyang@huawei.com) | Rel-9 | CP-43 | Frederic |  |
| 32 | 16.3 | Stage 3 for PAN_EPNM |  | 196d? | 2009-03-06 | 2009-12-04 |  |  | 2009-03-06 | 2009-12-04 | 196d? | 70d | finish no earlier than 2009-12-04 | C1 | 1568h |  | PAN_EPNM | PCG-22 | Huawei | Lili Yang (kadyyang@huawei.com) | Rel-9 | CP-43 | Frederic |  |
| 33 | 17 | **Multi-Media Telephony Service enhancements** |  | 396d? | 2008-06-05 A | 2009-12-10 | 26% | 294d? | 2008-06-05 | 2009-12-10 | 396d? | 66d |  | S1,S5 | 7392h | 1904h | eMMTel | PCG-21 | France Telecom | Philippe Lottin | Rel-9 | SP-40 | Alain |  |
| 34 | 17.1 | Stage 1 for eMMTel |  | 136d? | 2008-06-05 A | 2008-12-11 A | 100% |  | 2008-06-05 | 2008-12-11 | 136d? |  | start no earlier than 2008-06-05 | S1 | 1088h | 1088h | eMMTel | PCG-21 | France Telecom | Philippe Lottin | Rel-9 | SP-40 | Alain |  |
| 35 | 17.2 | Multimedia Telephony (MMTel) Service and Supplementary Services - Online Charging and completion for Offline Charging (all supplementary services) |  | 196d? | 2009-03-12 | 2009-12-10 |  |  | 2009-03-12 | 2009-12-10 | 196d? | 66d | finish no earlier than 2009-12-10 | S5 | 1568h |  | eMMTel-SS-CH | PCG-22 | Alcatel-Lucent | Maryse.Gardella@alcatel-lucent.fr | Rel-9 | SP-43 | Dionisio |  |
| 36 | 17.3 | Support of Real-time Transfer of Tariff Information (RTTI) in IMS charging |  | 196d? | 2009-03-12 | 2009-12-10 |  |  | 2009-03-12 | 2009-12-10 | 196d? | 66d | finish no earlier than 2009-12-10 | S5 | 1568h |  | IMSTSS-RTTI-CH | PCG-22 | Orange | Jean-Luc Garcia (jl.garcia@orange-ftgroup.com) | Rel-9 | SP-43 | Dionisio |  |
| 37 | 18 | **User Data Convergence** |  | 402d? | 2008-06-05 A | 2009-12-18 | 40% | 242.14d? | 2008-06-05 | 2009-12-18 | 402d? | 60d |  | S1,C4 | 4864h | 1088h | UDC | PCG-21 | China Mobile | lansizhong@chinamobile.com | Rel-9 | SP-40 | Alain |  |
| 38 | 18.1 | Stage 1 for UDC |  | 136d? | 2008-06-05 A | 2008-12-11 A | 100% |  | 2008-06-05 | 2008-12-11 | 136d? |  | start no earlier than 2008-06-05 | S1 | 1088h | 1088h | UDC | PCG-21 | China Mobile | lansizhong@chinamobile.com | Rel-9 | SP-40 | Alain |  |
| 39 | 18.2 | UDC Technical Realization (Stage 2) |  | 206d? | 2009-03-06 | 2009-12-18 |  |  | 2009-03-06 | 2009-12-18 | 206d? | 60d | finish no earlier than 2009-12-18 | C4 | 1648h |  | UDC-CN | PCG-22 | Ericsson | Emiliano Merino (emiliano.merino@ericsson.com) | Rel-9 | CP-43 | Kimmo |  |
| 40 | 19 | **Enhanced Home NodeB / eNodeB** |  | 396d? | 2008-06-05 A | 2009-12-10 | 18% | 325.97d? | 2008-06-05 | 2009-12-10 | 396d? | 66d |  | SP,RP | 22008h | 3891.82h | EHNB | PCG-21 | T-Mobile | michael.kurz@t-mobile.at | Rel-9 | SP-40 | Alain |  |
| 41 | 19.1 | Stage 1 for EHNB |  | 261d? | 2008-06-05 A | 2009-06-04 | 95% | 13.05d? | 2008-06-05 | 2009-06-04 | 261d? | 201d | finish no earlier than 2009-06-04 | S1 | 2088h | 1983.6h | EHNB | PCG-21 | T-Mobile | michael.kurz@t-mobile.at | Rel-9 | SP-40 | Alain |  |
| 42 | 19.2 | Architecture aspects of EHNB |  | 321d? | 2008-09-18 A | 2009-12-10 | 20% | 256.2d? | 2008-09-18 | 2009-12-10 | 321d? | 66d | finish no earlier than 2009-12-10 | S2 | 2568h | 518.4h | EHNB | PCG-21 | T-Mobile | Sebastian Speicher | Rel-9 | SP-41 | Maurice |  |
| 43 | 19.3 | IMS aspects of Architecture for Home NodeB |  | 206d? | 2008-12-11 A | 2009-09-24 | 25% | 154.5d? | 2008-12-11 | 2009-09-24 | 206d? | 121d | finish no earlier than 2009-09-24 | S2 | 1648h | 412h | EHNB-IMS | PCG-22 | Alcatel-Lucent | Nicolas Drevon | Rel-9 | SP-42 | Maurice |  |
| 44 | 19.4 | Security aspects of Enhanced Home NodeB / eNodeB |  | 261d? | 2008-12-11 A | 2009-12-10 | 20% | 208.8d? | 2008-12-11 | 2009-12-10 | 261d? | 66d | finish no earlier than 2009-12-10 | S3 | 2088h | 417.6h | EHNB-Sec | PCG-22 | Huawei | Marcus Wong (mwong@huawei.com) | Rel-9 | SP-42 | Dionisio |  |
| 45 | 19.5 | 3G Home NodeB Gateway OAM&P |  | 261d? | 2008-12-11 | 2009-12-10 |  |  | 2008-12-11 | 2009-12-10 | 261d? | 66d | finish no earlier than 2009-12-10 | S5 | 2088h |  | HNB-OAM_GW | PCG-22 | China Mobile | GangChen (chengang@chinamobile.com) | Rel-9 | SP-42 | Dionisio |  |
| 46 | 19.6 | 3G Home NodeB and LTE Home eNodeB OAM&P Type 1 definition |  | 196d? | 2009-03-12 | 2009-12-10 |  |  | 2009-03-12 | 2009-12-10 | 196d? | 66d | finish no earlier than 2009-12-10 | S5 | 1568h |  | HNB_eHNB-OAM_Type1 | PCG-22 | Huawei | Zou Lan (zlan@huawei.com) | Rel-9 | SP-43 | Dionisio |  |
| 47 | 19.7 | LTE FDD Home eNodeB RF Requirements |  | 261d? | 2008-12-05 | 2009-12-04 |  |  | 2008-12-05 | 2009-12-04 | 261d? | 70d | finish no earlier than 2009-12-04 | R4 | 2088h |  | HeNB-RF_FDD | PCG-22 | Motorola | Ying Cai (yingcai@motorola.com) | Rel-9 | RP-42 | Stefania | RP-090054 |
| 48 | 19.8 | LTE TDD Home eNodeB RF Requirements |  | 196d? | 2009-03-06 | 2009-12-04 |  |  | 2009-03-06 | 2009-12-04 | 196d? | 70d | finish no earlier than 2009-12-04 | R4 | 1568h |  | HeNB-RF_TDD | PCG-22 | China Mobile | Nan Li (linan@chinamobile.com) | Rel-9 | RP-43 | Stefania |  |
| 49 | 19.9 | Home NB and Home eNB enhancements - RAN3 aspects |  | 196d? | 2009-03-06 | 2009-12-04 |  |  | 2009-03-06 | 2009-12-04 | 196d? | 70d | finish no earlier than 2009-12-04 | R3 | 1568h |  | EHNB-RAN3 | PCG-22 | Alcatel-Lucent | Martin Warner (mw15@alcatel-lucent.com) | Rel-9 | RP-43 | Gert |  |
| 50 | 19.10 | Home NB and Home eNB enhancements - RAN2 aspects |  | 196d? | 2009-03-06 | 2009-12-04 |  |  | 2009-03-06 | 2009-12-04 | 196d? | 70d | finish no earlier than 2009-12-04 | R2 | 1568h |  | EHNB-RAN2 | PCG-22 | Huawei | Yang Xudong | Rel-9 | RP-43 | Joern |  |
| 51 | 20 | **Protection against Unsolicited Communication for IMS (PUCI)** |  | 186d? | 2008-09-18 A | 2009-06-04 | 47% | 98.05d? | 2008-09-18 | 2009-06-04 | 186d? | 201d |  | S1,S3 | 3464h | 1638.04h | PUCI | PCG-21 | NEC | Anand R. Prasad (anand@bq.jp.nec.com) | Rel-9 | SP-41 | Alain |  |
| 52 | 20.1 | Stage 1 for PUCI |  | 61d? | 2008-09-18 A | 2008-12-11 A | 100% |  | 2008-09-18 | 2008-12-11 | 61d? |  | finish no earlier than 2009-06-18 | S1 | 488h | 488h | PUCI | PCG-21 | NEC | Anand R. Prasad (anand@bq.jp.nec.com) | Rel-9 | SP-41 | Alain |  |
| 53 | 20.2 | SA3 work on PUCI |  | 186d? | 2008-09-18 A | 2009-06-04 | 30% | 130.2d? | 2008-09-18 | 2009-06-04 | 186d? | 201d | finish no earlier than 2009-06-04 | S3 | 1488h | 446.4h | PUCI | PCG-21 | NEC | Anand R. Prasad (anand@bq.jp.nec.com) | Rel-9 | SP-41 | Dionisio |  |

Notes:
- 29: SA#40 WID approved & Stage 1 completed
- 30: SA#40 Stage 1 completed / Text3: 22.259
- 31: Text3: 23.259
- 32: Text3: 24.259
- 33: SA#42 Stage 1 completed. SA#41 WID updated SP-080324=>SP-080503
- 34: SA#42 completed. SA#41 WID updated SP-080324=>SP-080503 / Text3: 22.173
- 35: Text3: 32.275, 32.298, 32.299
- 36: Linked to SA5 Rel-8 UID_380042 AoC support in IMS Charging (IMSTSS). SA3/CT3 coordination need on 29.658 (SIP transfer of tariff information) / Text3: 32.27x, 32.240, 32.280, 32.298, 32.299
- 37: SA#42 Stage 1 completed
- 38: SA#42 completed / Text3: 22.985, 22.101
- 39: Text3: TS 23.335 (User Data Convergence (UDC); Technical Realization and Information Flows)
- 40: SA#43 WID updated SP-080791=>SP-090197 to include RAN items/BBs
- 41: SA#43 Rel-9 exception to Jun 2009 on UICC handling. SA#42 Rel-9 extension to 03/09 / Text3: 22.220, 22.011
- 42: SA#42 completion target 06/09=>12/09 / Text3: 23.830 (Architecture Aspects of HNB/HeNB), 23.401, 23.402, 23.060
- 43: See also SP-080892 (SA#42 LS_out to SA2 on Guidance for 3GPP Packet Access Work in Rel-9) / Text3: 23.832, TS 23.xyz (IMS Aspects of Architecture for Home NodeBs)
- 44: Text3: 33.xyz (Security Aspects of Home NodeB / eNodeB)
- 45: 01/09: Acronym removed "LTEimp_" / Text3: 32.xx1, 32.xx2, 32.xx7
- 46: Text3: 32.yy1, 32.yy2, 32.yy3, 32.yy4, 32.581, 32.582, 32.583, 32.584
- 47: Text3: 36.9xx (LTE FDD Home eNodeB RF Requirements Work Item Technical Report), 36.104, 36.141
- 48: Text3: 36.9xx (LTE TDD Home eNodeB RF Requirements Work Item Technical Report), 36.104, 36.141
- 49: Text3: new TS (UTRAN Iuh Interface: User Plane Protocols), 25.413, 25.467, 25.467, 25.468, 25.469, 25.469, 36.401, 36.413
- 50: Text3: 25.304, 25.331, 25.367, 36.300, 36.304, 36.331
- 51: SA#42 Stage 1 completed. SA#41 SA3 WID approved (Stage 1 commitment in SA1 LS in SP-080523). Check related work in OMA Categorization Based Content Screening
- 52: SA#42 completed / Text3: 22.228
- 53: Text3: 33.837

| ID | WBS | Task | Duration | Start | Finish | Complete | Remaining | Baseline start | Baseline finish | Baseline duration | Total slack | Constraint | Resources | Work | Actual work | Text1 | Text2 | Text4 | Text5 | Text6 | Text7 | Text8 | Text11 |
| --- | --- | --- | --- | --- | --- | --- | --- | --- | --- | --- | --- | --- | --- | --- | --- | --- | --- | --- | --- | --- | --- | --- | --- |
| 54 | 21 | **IMS Services Centralization and Continuity** | 317d? | 2008-09-18 A | 2009-12-04 | 24% | 239.39d? | 2008-09-18 | 2009-12-04 | 317d? | 70d |  | S1,S2,C1 | 7568h | 1545.6h | IMS_SCC | PCG-21 | NEC | Joerg Swetina (joerg.swetina@nw.neclab.eu) | Rel-9 | SP-41 | Alain |  |
| 55 | 21.1 | Inter-Device Transfer – Requirements | 61d? | 2008-09-18 A | 2008-12-11 A | 100% |  | 2008-09-18 | 2008-12-11 | 61d? |  | finish no earlier than 2009-06-18 | S1 | 488h | 488h | IMS_SCC-IDT | PCG-21 | NEC | Joerg Swetina (joerg.swetina@nw.neclab.eu) | Rel-9 | SP-41 | Alain |  |
| 56 | 21.2 | IMS Service Continuity Enhancements: Service, Policy and Interactions | 186d? | 2008-09-18 A | 2009-06-04 | 20% | 148.8d? | 2008-09-18 | 2009-06-04 | 186d? | 201d | finish no earlier than 2009-06-04 | S2 | 1488h | 297.6h | IMS_SCC-SPI | PCG-21 | Huawei | HengLiang Zhang (hl_zhang@huawei.com) | Rel-9 | SP-41 | Maurice |  |
| 57 | 21.3 | IMS Centralized Services - Stage 2 | 186d? | 2008-09-18 A | 2009-06-04 | 30% | 130.2d? | 2008-09-18 | 2009-06-04 | 186d? | 201d | finish no earlier than 2009-06-04 | S2 | 1488h | 446.4h | IMS_SCC-ICS | PCG-21 | Alcatel-Lucent | Andy Bennett (andybennett@alcatel-lucent.com) | Rel-9 | SP-41 | Maurice |  |
| 58 | 21.4 | IMS Centralized Services support via I1 interface - Stage 3 | 196d? | 2009-03-06 | 2009-12-04 |  |  | 2009-03-06 | 2009-12-04 | 196d? | 70d | finish no earlier than 2009-12-04 | C1 | 1568h |  | IMS_SCC-ICS_I1 | PCG-22 | Huawei | Lili Yang(kadyyang@huawei.com) | Rel-9 | CP-43 | Frederic |  |
| 59 | 22 | **Enhancements of IMS Customized Alerting Tone (CAT) Service** | 261d? | 2008-12-05 A | 2009-12-04 | 20% | 208.8d? | 2008-12-05 | 2009-12-04 | 261d? | 70d |  | S1,C1 | 4176h | 835.2h | eCAT | PCG-22 |  |  | Rel-9 | CP-42 | Alain |  |
| 60 | 22.1 | Stage 3 Enhancements of IMS CAT Supplementary Service | 261d? | 2008-12-05 A | 2009-12-04 | 20% | 208.8d? | 2008-12-05 | 2009-12-04 | 261d? | 70d | finish no earlier than 2009-12-04 | C1 | 2088h | 417.6h | eCAT-SS | PCG-22 | China Mobile | Jiang Yi | Rel-9 | CP-42 | Frederic |  |
| 61 | 23 | **Service Specific Access Control in EPS** | 1d? | 2008-12-11 A | 2008-12-11 A | 100% |  | 2008-12-11 | 2008-12-11 | 1d? |  |  | S1 | 16h | 16h | SSAC | PCG-22 | NTT DoCoMo | Frederic Thepot (thepot@docomolab-euro.com) | Rel-9 | SP-42 | Alain |  |
| 62 | 23.1 | Stage 1 for SSAC | 1d? | 2008-12-11 A | 2008-12-11 A | 100% |  | 2008-12-11 | 2008-12-11 | 1d? |  | start no earlier than 2008-12-11 | S1 | 8h | 8h | SSAC | PCG-22 | NTT DoCoMo | Frederic Thepot (thepot@docomolab-euro.com) | Rel-9 | SP-42 | Alain |  |
| 63 | 24 | **Support for IMS Emergency Calls over GPRS and EPS** | 499d? | 2008-01-14 A | 2009-12-10 | 51% | 244.02d? | 2008-01-14 | 2009-12-10 | 499d? | 66d |  | SP,RP | 12168h | 5134.4h | IMS_EMER_GPRS_EPS | PCG-21 | Alcatel-Lucent | Deborah Barclay | Rel-9 | SP-38 | Maurice |  |
| 64 | 24.1 | Stage 1 of IMS_EMER_GPRS_EPS | 239d? | 2008-01-14 A | 2008-12-11 A | 100% |  | 2008-01-14 | 2008-12-11 | 239d? |  | finish no earlier than 2008-12-11 | S1 | 1912h | 1912h | IMS_EMER_GPRS_EPS | PCG-21 | Alcatel-Lucent | Deborah Barclay | Rel-9 | SP-38 | Alain |  |
| 65 | 24.2 | Stage 2 of IMS_EMER_GPRS_EPS | 364d? | 2008-01-14 A | 2009-06-04 | 80% | 72.8d? | 2008-01-14 | 2009-06-04 | 364d? | 201d | finish no earlier than 2009-06-04 | S2 | 2912h | 2329.6h | IMS_EMER_GPRS_EPS | PCG-21 | Alcatel-Lucent | Deborah Barclay | Rel-9 | SP-38 | Maurice |  |
| 66 | 24.3 | Security aspects of IMS_EMER_GPRS_EPS | 261d? | 2008-12-11 | 2009-12-10 |  |  | 2008-12-11 | 2009-12-10 | 261d? | 66d | finish no earlier than 2009-12-10 | S3 | 2088h |  | IMS_EMER_GPRS_EPS-Sec | PCG-22 | Alcatel-Lucent | Deborah Barclay | Rel-9 | SP-42 | Dionisio |  |
| 67 | 24.4 | SRVCC support for IMS Emergency Calls | 186d? | 2008-09-18 A | 2009-06-04 | 60% | 74.4d? | 2008-09-18 | 2009-06-04 | 186d? | 201d | finish no earlier than 2009-06-04 | S2 | 1488h | 892.8h | IMS_EMER_GPRS_EPS-SRVCC | PCG-21 | China Mobile | Yu Qing (Yuqing@chinamobile.com) | Rel-9 | SP-41 | Maurice |  |
| 68 | 24.5 | Support for IMS Emergency Calls over LTE | 206d? | 2008-12-05 | 2009-09-18 |  |  | 2008-12-05 | 2009-09-18 | 206d? | 125d | finish no earlier than 2009-09-18 | R2 | 1648h |  | IMS_EMER_LTE | PCG-22 | Alcatel-Lucent | Sudeep Palat (spalat@alcatel-lucent.com) | Rel-9 | RP-42 | Joern | RP-090052 |
| 69 | 25 | **LCS for LTE and EPS** | 392d? | 2008-06-05 A | 2009-12-04 | 29% | 277.57d? | 2008-06-05 | 2009-12-04 | 392d? | 70d |  | S2,RP | 9691.2h | 2929.6h | LCS_LTE_EPS | PCG-22 |  |  | Rel-9 | SP-43 | Maurice |  |
| 70 | 25.1 | **LCS Control Plane Solution for EPS** | 261d? | 2008-06-05 A | 2009-06-04 | 60% | 104.4d? | 2008-06-05 | 2009-06-04 | 261d? | 201d |  | S2 | 4176h | 2505.6h | LCS_EPS-CPS | PCG-21 | Polaris Wireless | Robert Gross | Rel-9 | SP-40 | Maurice |  |
| 71 | 25.1.1 | Stage 2 for LCS_CPS_EPS | 261d? | 2008-06-05 A | 2009-06-04 | 60% | 104.4d? | 2008-06-05 | 2009-06-04 | 261d? | 201d | finish no earlier than 2009-06-04 | S2 | 2088h | 1252.8h | LCS_EPS-CPS | PCG-21 | Polaris Wireless | Robert Gross | Rel-9 | SP-40 | Maurice |  |
| 72 | 25.2 | Positioning Support for LTE | 261d? | 2008-12-05 A | 2009-12-04 | 20% | 208d? | 2008-12-05 | 2009-12-04 | 261d? | 70d | finish no earlier than 2009-12-04 | R2,R4 | 2088h | 424h | LCS_LTE | PCG-22 | Qualcomm | Nathan Tenny (ntenny@qualcomm.com) | Rel-9 | RP-42 | Joern | RP-090053 |
| 73 | 25.3 | Network-Based Positioning Support for LTE | 196d? | 2009-03-06 | 2009-12-04 |  |  | 2009-03-06 | 2009-12-04 | 196d? | 70d | finish no earlier than 2009-12-04 | R2 | 1568h |  | LCS_LTE-NBPS | PCG-22 | TruePosition | Terry Brooks | Rel-9 | RP-43 | Joern |  |
| 74 | 26 | **MBMS support in EPS** | 396d? | 2008-06-05 A | 2009-12-10 | 13% | 343.17d? | 2008-06-05 | 2009-12-10 | 396d? | 66d |  | SP,RP | 8701.2h | 835.6h | MBMS_EPS | PCG-21 | China Mobile | Liu Hong (liuhongyfw@chinamobile.com) | Rel-9 | SP-40 | Maurice |  |
| 75 | 26.1 | Stage 2 for MBMS_EPS | 261d? | 2008-06-05 A | 2009-06-04 | 35% | 169.65d? | 2008-06-05 | 2009-06-04 | 261d? | 201d | finish no earlier than 2009-06-04 | S2 | 2088h | 730.8h | MBMS_EPS | PCG-21 | China Mobile | Liu Hong (liuhongyfw@chinamobile.com) | Rel-9 | SP-40 | Maurice |  |
| 76 | 26.2 | Security for MBMS_EPS | 126d? | 2008-12-11 A | 2009-06-04 | 10% | 112.9d? | 2008-12-11 | 2009-06-04 | 126d? | 201d | finish no earlier than 2009-06-04 | S3 | 1008h | 104.8h | MBMS_EPS | PCG-22 | China Mobile | Liu Hong (liuhongyfw@chinamobile.com) | Rel-9 | SP-42 | Dionisio |  |
| 77 | 26.3 | MBMS Charging in EPS | 200d? | 2009-03-06 | 2009-12-10 |  |  | 2009-03-06 | 2009-12-10 | 200d? | 66d | finish no earlier than 2009-12-10 | S5 | 1600h |  | MBMS_EPS | PCG-22 | ZTE | guo.wenjie1@zte.com.cn | Rel-9 | SP-43 | Dionisio |  |
| 78 | 26.4 | MBMS support in LTE | 196d? | 2009-03-06 | 2009-12-04 |  |  | 2009-03-06 | 2009-12-04 | 196d? | 70d | finish no earlier than 2009-12-04 | R2 | 1568h |  | MBMS_LTE | PCG-22 | Huawei |  | Rel-9 | RP-43 | Joern |  |

Notes:
- 54: SA#42 Stage 1 completed.
- 55: SA#42 completed / Text3: 22.101, 22.228
- 56: SA#43 TR 23.838 for Information / Text3: 23.838, 23.237, 23.292, 23.216
- 57: Text3: 23.883 (IMS Centralized Services study - Phase 2), 23.292
- 58: Text3: 24.294 (ICS Protocol via I1 Interface)
- 59: CT#42 umbrella Feature created to host CT1 CAT WI (Stage 1 in 22.182)
- 60: Enhance IMS CAT Supplementary Service as defined in 22.182 and TR 23.872 / Text3: 24.182
- 61: SA#42 Stage 1 completed (need for SA2 input). Triggered by Study UID_400036 on Service Specific Access Control in EPS (FS_SSAC)
- 62: SA#42 completed / Text3: 22.011 CR0136
- 63: SA#42 Stage 1 completed. WID updated SP-070820=>SP-080352=>SP-080844 (Add SA3 task).
- 64: SA#42 completed / Text3: 22.101
- 65: SA#43 TR 23.869 for Information/Approval / Text3: 23.869, 23.060, 23.167, 23.228, 23.271, 23.203, 23.401, 23.402, 23.221
- 66: SA#42 WID updated SP-080352=>SP-080844 (Add SA3 task) / Text3: 33.401, 33.402
- 67: SA#43 TR 23.870 for Information. WID updated SP-080562=>SP-090099 (added location continuity aspects) / Text3: 23.870, 23.216, 23.237
- 68: Text3: 36.331 (E-UTRA RRC Protocol specification). 36.413 (E-UTRA S1 Application Protocol)
- 70: Triggered by abandoned Study UID_380068 (FS_LCS_EPS). Linked to UID_380064 Feature IMS_EMER_GPRS_EPS.
- 71: SA#43 TR 23.891 for Information/Approval / Text3: 23.891, 23.271, 23.401, 23.402
- 72: UID_400038 (LCS Control Plane Solution for EPS) depends on this WI / Text3: 36.300, 36.331, 36.413, 36.133 (Add performance requirements for downlink terrestrial positioning), 36.214, possibly 3 new TS 36.xxx (UE positioning in E-UTRAN/ LTE Positioning Protocol/ RAN4 Requirements for Support of A-GNSS)
- 73: Text3: Possible new TS on Performance Requirements for LMU, 36.300, 36.331, 36.413, 36.995
- 74: SA#42 WID updated SP-080442=>SP-080737 (add SA3 task)
- 75: SA#42 WID updated SP-080442=>SP-080737 (add SA3 task) / Text3: 23.246
- 76: SA#42 WID updated SP-080442=>SP-080737 (add SA3 task) / Text3: 33.246
- 77: Text3: 32.273, 32.251, 32.298, 32.299
- 78: Stage 2/3 / Text3: 36.101, 36.104, 36.141, 36.300, 36.304, 36.321, 36.322, 36.323, 36.331, 36.413, 36.440, 36.441, 36.442, 36.444, 36.445, 36.446

| ID | WBS | Task | Duration | Start | Finish | Complete | Remaining | Baseline start | Baseline finish | Baseline duration | Total slack | Constraint | Resources | Work | Actual work | Text1 | Text2 | Text4 | Text6 | Text7 | Text8 |
| --- | --- | --- | --- | --- | --- | --- | --- | --- | --- | --- | --- | --- | --- | --- | --- | --- | --- | --- | --- | --- | --- |
| 79 | 27 | **Access Network Discovery and Selection Enhancements** | 126d? | 2008-12-11 A | 2009-06-04 | 65% | 44.1d? | 2008-12-11 | 2009-06-04 | 126d? | 201d |  | S2 | 1360.8h | 655.2h | eANDSF | PCG-22 | Motorola | Rel-9 | SP-42 | Maurice |
| 80 | 27.1 | Stage 2 for eANDSF | 126d? | 2008-12-11 A | 2009-06-04 | 65% | 44.1d? | 2008-12-11 | 2009-06-04 | 126d? | 201d | finish no earlier than 2009-06-04 | S2 | 1008h | 655.2h | eANDSF | PCG-22 | Motorola | Rel-9 | SP-42 | Maurice |
| 81 | 28 | **GTP-based S8 chaining** | 126d? | 2008-12-11 A | 2009-06-04 | 35% | 81.9d? | 2008-12-11 | 2009-06-04 | 126d? | 201d |  | S2 | 2016h | 705.6h | GTPchaining | PCG-22 | Huawei | Rel-9 | SP-42 | Maurice |
| 82 | 28.1 | Stage 2 for GTPchaining | 126d? | 2008-12-11 A | 2009-06-04 | 35% | 81.9d? | 2008-12-11 | 2009-06-04 | 126d? | 201d | finish no earlier than 2009-06-04 | S2 | 1008h | 352.8h | GTPchaining | PCG-22 | Huawei | Rel-9 | SP-42 | Maurice |
| 83 | 29 | Multiple PDN to the Same APN for PMIP-based Interfaces (Stage 2) | 61d? | 2009-03-12 | 2009-06-04 |  |  | 2009-03-12 | 2009-06-04 | 61d? | 201d | finish no earlier than 2009-06-04 | S2 | 488h |  | MUPSAP | PCG-22 | Samsung | Rel-9 | SP-43 | Maurice |
| 84 | 30 | Multi Access PDN Connectivity (Stage 2) | 61d? | 2009-03-12 | 2009-06-04 |  |  | 2009-03-12 | 2009-06-04 | 61d? | 201d | finish no earlier than 2009-06-04 | S2 | 488h |  | MAPCON | PCG-22 | Telecom Italia | Rel-9 | SP-43 | Maurice |
| 85 | 31 | Access Security Enhancements | 504d? | 2007-07-02 A | 2009-06-04 | 60% | 200.8d? | 2007-07-02 | 2009-06-04 | 504d? | 201d | finish no earlier than 2009-06-04 | S3 | 4032h | 2425.6h | ACCSEC2 |  | Ericsson | Rel-9 | SP-26 | Dionisio |
| 86 | 32 | **GBAPush enhancements** | 322d? | 2008-03-12 A | 2009-06-04 | 59% | 131.2d? | 2008-03-12 | 2009-06-04 | 322d? | 201d |  | S3 | 5152h | 3052.8h | eGBAPush |  | Ericsson | Rel-9 |  | Dionisio |
| 87 | 32.1 | SA3 part of eGBAPush (33.224) | 322d? | 2008-03-12 A | 2009-06-04 | 59% | 131.2d? | 2008-03-12 | 2009-06-04 | 322d? | 201d | finish no earlier than 2009-06-04 | S3 | 2576h | 1526.4h | eGBAPush | PCG-21 | Ericsson | Rel-9 | SP-39 | Dionisio |
| 88 | 33 | IMS Media Plane Security (Stage 2) | 196d? | 2009-03-12 | 2009-12-10 |  |  | 2009-03-12 | 2009-12-10 | 196d? | 66d | finish no earlier than 2009-12-10 | S3 | 1568h |  | MEDIASEC | PCG-22 | Vodafone | Rel-9 | SP-43 | Dionisio |
| 89 | 34 | **Timed Graphics** | 261d? | 2008-12-11 A | 2009-12-10 | 10% | 234.9d? | 2008-12-11 | 2009-12-10 | 261d? | 66d |  | S4 | 4176h | 417.6h | TG | PCG-22 | Ericsson | Rel-9 | SP-42 | Paolo |
| 90 | 34.1 | SA4 part of Timed Graphics | 261d? | 2008-12-11 A | 2009-12-10 | 10% | 234.9d? | 2008-12-11 | 2009-12-10 | 261d? | 66d | finish no earlier than 2009-12-10 | S4 | 2088h | 208.8h | TG | PCG-22 | Ericsson | Rel-9 | SP-42 | Paolo |
| 91 | 35 | Managing MTSI Media Adaptation | 196d? | 2009-03-12 | 2009-12-10 |  |  | 2009-03-12 | 2009-12-10 | 196d? | 66d | finish no earlier than 2009-12-10 | S4 | 1568h |  | M3A | PCG-22 | Samsung | Rel-9 | SP-43 | Paolo |
| 92 | 36 | PSS and MBMS extensions | 196d? | 2009-03-12 | 2009-12-10 |  |  | 2009-03-12 | 2009-12-10 | 196d? | 66d | finish no earlier than 2009-12-10 | S4 | 1568h |  | MBS_Ext | PCG-22 | Ericsson, Nokia | Rel-9 | SP-43 | Paolo |
| 93 | 37 | Improved Video Support for PSS and MBMS | 196d? | 2009-03-12 | 2009-12-10 |  |  | 2009-03-12 | 2009-12-10 | 196d? | 66d | finish no earlier than 2009-12-10 | S4 | 1568h |  | IVS | PCG-22 | Nokia | Rel-9 | SP-43 | Paolo |
| 94 | 38 | IMS based PSS and MBMS User Service extensions | 196d? | 2009-03-12 | 2009-12-10 |  |  | 2009-03-12 | 2009-12-10 | 196d? | 66d | start no earlier than 2009-03-12 | S4 | 1568h |  | IMS_PSS_MBMS_US_EXT | PCG-22 | Ericsson | Rel-9 | SP-43 | Paolo |
| 95 | 39 | **OAM&P 9** | 470d? | 2008-02-22 A | 2009-12-10 | 17% | 391.36d? | 2008-02-22 | 2009-12-10 | 470d? | 66d |  | S5 | 20848h | 4013.14h | OAM9 | PCG-22 |  | Rel-9 | SP-42 | Dionisio |
| 96 | 39.1 | **Network Infrastructure Management** | 206d? | 2008-12-11 | 2009-09-24 |  |  | 2008-12-11 | 2009-09-24 | 206d? | 121d |  | S5 | 3296h |  | OAM9-NIM | PCG-22 |  | Rel-9 | SP-42 | Dionisio |
| 97 | 39.1.1 | Software Management for Network Elements | 206d? | 2008-12-11 | 2009-09-24 |  |  | 2008-12-11 | 2009-09-24 | 206d? | 121d | finish no earlier than 2009-09-24 | S5 | 1648h |  | OAM9-NE_SWM | PCG-22 | Huawei, Nokia Siemens Networks | Rel-9 | SP-42 | Dionisio |
| 98 | 39.2 | **Performance Management** | 196d? | 2009-03-12 | 2009-12-10 |  |  | 2009-03-12 | 2009-12-10 | 196d? | 66d |  | S5 | 4704h |  | OAM9-PM | PCG-22 |  | Rel-9 | SP-42 | Dionisio |
| 99 | 39.2.1 | Enhancement of performance measurements for E-UTRAN | 196d? | 2009-03-12 | 2009-12-10 |  |  | 2009-03-12 | 2009-12-10 | 196d? | 66d | start no earlier than 2009-03-12 | S5 | 1568h |  | OAM9-PM | PCG-22 | Motorola,Huawei | Rel-9 | SP-43 | Dionisio |
| 100 | 39.2.2 | Enhancement of performance measurements for EPC | 196d? | 2009-03-12 | 2009-12-10 |  |  | 2009-03-12 | 2009-12-10 | 196d? | 66d | start no earlier than 2009-03-12 | S5 | 1568h |  | OAM9-PM | PCG-22 | China Mobile | Rel-9 | SP-43 | Dionisio |
| 101 | 39.3 | Trace | 196d? | 2009-03-12 | 2009-12-10 |  |  | 2009-03-12 | 2009-12-10 | 196d? | 66d | finish no earlier than 2009-12-10 | S5 | 1568h |  | OAM9-Trace | PCG-22 |  | Rel-9 | SP-42 | Dionisio |
| 102 | 39.4 | **Self-Organizing Networks (SON) - OAM aspects** | 470d? | 2008-02-22 A | 2009-12-10 | 45% | 258.5d? | 2008-02-22 | 2009-12-10 | 470d? | 66d |  | S5 | 7520h | 3384h | OAM9-SON | PCG-22 |  | Rel-9 | SP-43 | Dionisio |
| 103 | 39.4.1 | SON Self-Optimization & Self-Healing handling | 470d? | 2008-02-22 A | 2009-12-10 | 45% | 258.5d? | 2008-02-22 | 2009-12-10 | 470d? | 66d | finish no earlier than 2009-12-10 | S5 | 3760h | 1692h | LTE_SON-OAM | PCG-21 | Motorola, Huawei | Rel-9 | SP-39 | Dionisio |

Notes:
- 79: No new Rel-9 use cases defined. Expected to implement service requirements not covered in Rel-8 / Text5: Apostolis Salkintzis (salki@motorola.com)
- 80: Text3: 23.402, 23.002 / Text5: Apostolis Salkintzis (salki@motorola.com)
- 81: Stage 1 in UID_320022 Rel-8 Requirements for evolution of the 3GPP system architecture (AIPN-SAE): 22.278, 22.011, 22.246 / Text5: Haining Wang (wanghaining@huawei.com)
- 82: Text3: 23.402 (Chaining GTP-S8 based architecture and procedures) / Text5: Haining Wang (wanghaining@huawei.com)
- 83: Continue Rel-8 SAES Stage 2 UID_320005. In Rel-8, PMIP-based interfaces (i.e. PMIP-based S5/S8, S2a and S2b) do not support a feature using other equivalent interfaces (e.g. GTP-based S5/S8) available in Rel-8. Stage 1 in 22.278 (EPS Service requirements) / Text3: 23.060, 23.203, 23.401, 23.402 / Text5: erik.guttman@partner.samsung.com
- 84: Spin-off UID_410043 Study on Multi Access PDN connectivity and IP flow mobility. TR 23.861 proposes changes in 23.401/2 UE simultaneously connect to different PDNs through different access systems. Stage 1 in Rel-9 22.278 (6.2 - IP session control) / Text3: 23.401, 23.402 / Text5: ivano.guardini@telecomitalia.it
- 85: SA#42 moved to Rel-9. SA#26 approved WID (about improved GERAN security). / Text3: 33.102, 43.020 / Text5: Bengt.Sahlin@ericsson.com
- 86: SA#43 Umbrella Feature created to host 33.224, moved from Rel-8 to Rel-9 / Text5: Rolf Blom
- 87: SA#43 bring Rel-9 WID at SA#44. SA#42 TS 33.224 moved to Rel-9 (33.223 completed as Rel-8 under UID_390146) / Text3: 33.224 / Text5: Rolf Blom
- 88: SA#43 Stage 1 to be defined by SA3 in consultation with SA1 / Text3: 33.828, 33.xxx (Solutions for IMS media plane security) / Text5: Peter.Howard@vodafone.com
- 89: Provide graphics in parallel to a video stream (without requiring an umbrella scene descriptor such as 3GPP DIMS in TS 26.142) / Text5: clinton.priddle@ericsson.com
- 90: 26.xyz (Timed Graphics), 26.234, 26.140, 26.346, 26.244, 26.114, 26.245 / Text5: clinton.priddle@ericsson.com
- 91: Work to extend Rel-8 UID_34041 MTSI Video - Dynamic Rate Adaptation/Signalling of Image Size. Update speech/video adaptation algorithms used by network to control MTSI client terminal in congestion or poor transmission conditions. / Text3: 26.114 (IMS; Multimedia telephony; Media handling and interaction) / Text5: kyunghun.jung@samsung.com
- 92: Work to extend Rel-8 UID_34043 PSS_MBMS_OMTV (Extending PSS and MBMS User Services for optimized Mobile TV) & ensure compatibility with UID_34046 (IMS_PSS_MBMS_US) / Text3: 26.234 (Transparent end-to-end PSS; Protocols and codecs), 26.346 (MBMS; Protocols and codecs) / Text5: Clinton.Priddle@ericsson.com, imed.bouazizi@nokia.com
- 93: Add support for more advanced H.264 profiles and levels to match PSS and MBMS capabilities and larger screen sizes (e.g. H.264 Scalable Baseline Profile) / Text3: TR 26.9xx (Study on improved video for PSS and MBMS), 26.346 (MBMS; Protocols and Codecs, 26.234 (Transparent End-to-End PSS; Protocols and Codecs), 26.244 (Transparent End-to-End PSS; 3GPP File Format / Text5: imed.bouazizi@nokia.com
- 94: Work to extend Rel-8 UID_34046 (IMS_PSS_MBMS_US), SA2 UID_410034 IMSSCC-SPI (IMS Service Continuity Enhancements: Service, Policy and Interactions) / Text3: 26.237 (IMS based PSS and MBMS User Service; Protocols) / Text5: Markus Kampmann
- 95: SA#42 umbrella Feature created to host OAM WIs
- 96: SA#42 umbrella BB created to host OAM WIs
- 97: 02/09: WI Title changed on SA5 request from "Management of software entities residing in Network Elements" to "Software Management for Network Elements". The WI states: Telecommunication Management; Software Management (SWM) / Text3: 32.531, 32.532, 32.533, 32.537 / Text5: Bidipta Das (bidipta@huawei.com), Clemens Suerbaum (clemens.suerbaum@nsn.com)
- 98: SA#42 umbrella BB created to host OAM WIs
- 99: Text3: 32.425 / Text5: Yizhi Yao (yzyao@motorola.com),Lan Zou (zlan@huawei.com)
- 100: Text3: 32.426 / Text5: Li Jian (lijian@chinamobile.com), Liang Shuangchun (liangshuangchun@cmdi.chinamobile.com)
- 101: SA#42 umbrella BB created to host OAM WIs
- 102: SA#43 umbrella BB created to host OAM WIs
- 103: SA#43 WID updated SP-080067=>SP-090054. SA#42 moved to Rel-9 / Text3: 32.521, 32.522, 32.523 (SON Self-Optimization OAM), 32.5x1, 32.5x2, 32.5x3 (SON Self-Healing OAM) / Text5: Yizhi Yao (yzyao@motorola.com),Lan Zou (zlan@huawei.com)

| ID | WBS | Task | Duration | Start | Finish | Complete | Remaining | Baseline start | Baseline finish | Baseline duration | Total slack | Constraint | Resources | Work | Actual work | Text1 | Text4 | Text5 | Text6 | Text7 | Text8 | Text2 | Text11 |
| --- | --- | --- | --- | --- | --- | --- | --- | --- | --- | --- | --- | --- | --- | --- | --- | --- | --- | --- | --- | --- | --- | --- | --- |
| 104 | 40 | **Value-Added Services for Short Message Service** | 585d? | 2007-09-10 A | 2009-12-04 | 21% | 460d? | 2007-09-10 | 2009-12-04 | 585d? | 70d |  | S1,C4,C1 | 10880h | 2388.8h | VAS4SMS | China Mobile | Wu Bin (wubin@chinamobile.com) | Rel-9 | SP-37 | Alain |  |  |
| 105 | 40.1 | Stage 1 for VAS4SMS | 133d? | 2007-09-10 A | 2008-03-12 A | 100% |  | 2007-09-10 | 2008-03-12 | 133d? |  | finish no earlier than 2008-03-21 | S1 | 1064h | 1064h | VAS4SMS | China Mobile | Wu Bin (wubin@chinamobile.com) | Rel-9 | SP-37 | Alain |  |  |
| 106 | 40.2 | VAS4SMS Interface and Signalling Flow - CT4 aspects | 321d? | 2008-09-12 A | 2009-12-04 | 10% | 288.4d? | 2008-09-12 | 2009-12-04 | 321d? | 70d | finish no earlier than 2009-12-04 | C4 | 2568h | 260.8h | VAS4SMS | China Mobile | Wu Bin (wubin@chinamobile.com) | Rel-9 | CP-41 | Kimmo | PCG-21 |  |
| 107 | 40.3 | VAS4SMS Interface and Signalling Flow - CT1 aspects | 321d? | 2008-09-08 | 2009-12-04 |  |  | 2008-09-08 | 2009-12-04 | 321d? | 70d | finish no earlier than 2009-12-04 | C1 | 2568h |  | VAS4SMS | China Mobile | Wu Bin (wubin@chinamobile.com) | Rel-9 | CP-41 | Frederic | PCG-21 |  |
| 108 | 41 | Definition of 3GPP UICC services over the new high-speed interface | 520d? | 2007-12-10 A | 2009-12-04 | 15% | 441.25d? | 2007-12-10 | 2009-12-04 | 520d? | 70d | finish no earlier than 2009-12-04 | C6 | 4160h | 630h | UICCHS | Gemalto | jacques.seif@gemalto.com | Rel-9 | CP-38 | Xavier | PCG-21 |  |
| 109 | 42 | **CS-IBCF and CS-TrGW definition in 3GPP specifications** | 396d? | 2008-05-30 A | 2009-12-04 | 36% | 253.75d? | 2008-05-30 | 2009-12-04 | 396d? | 70d |  | C3,C4 | 9064h | 3256.03h | CS-IBCF | Telecom Italia | mauro.ficaccio@telecomitalia.it | Rel-9 | CP-40 | Gwiho | PCG-21 |  |
| 110 | 42.1 | CT3 aspects of CS-IBCF | 341d? | 2008-05-30 A | 2009-09-18 | 60% | 136.4d? | 2008-05-30 | 2009-09-18 | 341d? | 125d | finish no earlier than 2009-09-18 | C3 | 2728h | 1636.8h | CS-IBCF | Telecom Italia | mauro.ficaccio@telecomitalia.it | Rel-9 | CP-40 | Gwiho | PCG-21 |  |
| 111 | 42.2 | CT4 aspects of CS-IBCF | 396d? | 2008-05-30 A | 2009-12-04 | 15% | 335.85d? | 2008-05-30 | 2009-12-04 | 396d? | 70d | finish no earlier than 2009-12-04 | C4 | 3168h | 481.2h | CS-IBCF | Telecom Italia | mauro.ficaccio@telecomitalia.it | Rel-9 | CP-40 | Kimmo | PCG-21 |  |
| 112 | 43 | **IMS – Interconnection Border Control Function (IBCF) – Transition Gateway (TrGW); Ix Interface; Stage 3** | 321d? | 2008-09-12 A | 2009-12-04 | 36% | 205.64d? | 2008-09-12 | 2009-12-04 | 321d? | 70d |  | C4,C3 | 7062.4h | 2538.09h | IMS_IBCF | Alcatel-Lucent | Bruno.Landais@alcatel-lucent.fr | Rel-9 | CP-41 | Kimmo | PCG-21 |  |
| 113 | 43.1 | CT4 part of IMS_IBCF | 321d? | 2008-09-12 A | 2009-12-04 | 25% | 239.5d? | 2008-09-12 | 2009-12-04 | 321d? | 70d | finish no earlier than 2009-12-04 | C4 | 2568h | 652h | IMS_IBCF | Alcatel-Lucent | Bruno.Landais@alcatel-lucent.fr | Rel-9 | CP-41 | Kimmo | PCG-21 |  |
| 114 | 43.2 | CT3 part of IMS_IBCF | 240.8d? | 2008-09-12 A | 2009-09-18 | 50% | 120.4d? | 2008-09-12 | 2009-09-18 | 240.8d? | 125d | finish no earlier than 2009-09-18 | C3 | 1926.4h | 963.2h | IMS_IBCF | Alcatel-Lucent | Bruno.Landais@alcatel-lucent.fr | Rel-9 | CP-41 | Gwiho | PCG-21 |  |
| 115 | 44 | IMS Application Level Gateway Control Function (ALGCF) – IMS Access Media Gateway (IMA-MGW); Iq Interface; Stage 2 and Stage 3 | 321d? | 2008-09-12 A | 2009-12-04 | 15% | 272.1d? | 2008-09-12 | 2009-12-04 | 321d? | 70d | finish no earlier than 2009-12-04 | C4 | 2568h | 391.2h | IMS_AGCF | Alcatel-Lucent | bruno.landais@alcatel-lucent.fr | Rel-9 | CP-41 | Kimmo | PCG-21 |  |
| 116 | 45 | **Rel-9 Improvements of the Radio Interface** | 482.2d? | 2008-05-07 A | 2010-03-12 | 23% | 370.38d? | 2008-05-07 | 2010-03-12 | 482.2d? | 0d |  | RP,GP | 17587.6h | 3835.1h | RInImp9 |  |  | Rel-9 | RP-41 | Stefania | PCG-21 |  |
| 117 | 45.1 | LCR TDD UE OTA Performance Requirements | 266d? | 2008-09-12 A | 2009-09-18 | 60% | 106.4d? | 2008-09-12 | 2009-09-18 | 266d? | 125d | finish no earlier than 2009-09-18 | R4 | 2128h | 1276.8h | RInImp9-RFLCROTA | RITT | Wu Xiang (wuxiang@chinattl.com) | Rel-9 | RP-41 | Stefania | PCG-21 | RP-090046 |
| 118 | 45.2 | **RF requirements for Multicarrier and Multi-RAT BS** | 391d? | 2008-09-12 A | 2010-03-12 | 15% | 332.35d? | 2008-09-12 | 2010-03-12 | 391d? | 0d |  | R4,G1 | 8187.6h | 1228.14h | RInImp9-RFmulti | Ericsson | Johan Sköld (johan.skold@ericsson.com) | Rel-9 | RP-41 | Stefania | PCG-21 | RP-090045 |
| 119 | 45.2.1 | RAN4 part of RF requirements for Multicarrier and Multi RAT BS | 391d? | 2008-09-12 A | 2010-03-12 | 15% | 332.35d? | 2008-09-12 | 2010-03-12 | 391d? | 0d | finish no earlier than 2010-03-12 | R4 | 3128h | 469.2h | RInImp9-RFmulti | Ericsson | Johan Sköld (johan.skold@ericsson.com) | Rel-9 | RP-42 | Stefania | PCG-22 | RP-090045 |
| 120 | 45.2.2 | GERAN part of RF requirements for Multicarrier and Multi RAT BS | 261d? | 2008-11-21 A | 2009-11-20 | 15% | 221.85d? | 2008-11-21 | 2009-11-20 | 261d? | 80d | finish no earlier than 2009-11-20 | G1 | 2088h | 313.2h | RInImp9-Rfmulti-GERAN | Ericsson | mats.y.samuelsson@ericsson.com | Rel-9 | GP-40 | Paolo | PCG-22 |  |
| 121 | 45.3 | Extended UMTS/LTE 800 MHz | 126d? | 2008-05-07 A | 2009-05-29 | 60% | 50.4d? | 2008-05-07 | 2009-05-29 | 126d? | 205d | finish no earlier than 2009-05-29 | R4 | 1008h | 604.8h | RInImp9-UMTSLTE800 | NTT DoCoMo | Shingo Suwa (suwas@nttdocomo.co.jp) | Rel-9 | RP-42 | Stefania | PCG-22 | RP-090047 |
| 122 | 45.4 | UMTS/LTE 800 MHz for Europe | 196d? | 2009-03-06 | 2009-12-04 |  |  | 2009-03-06 | 2009-12-04 | 196d? | 70d | finish no earlier than 2009-12-04 | R4 | 1568h |  | RInImp9-UMTSLTE800EU | Ericsson | Olav Queseth (olav.queseth@ericsson.com) | Rel-9 | RP-43 | Stefania | PCG-22 |  |
| 123 | 45.5 | Performance requirement for LCR TDD with UE speeds up to 350 kph | 196d? | 2009-03-06 | 2009-12-04 |  |  | 2009-03-06 | 2009-12-04 | 196d? | 70d | finish no earlier than 2009-12-04 | R4 | 1568h |  | RInImp9-LCRTDD350 | CATT | Yuexia Song (songyuexia@datangmobile.cn) | Rel-9 | RP-43 | Stefania | PCG-22 |  |
| 124 | 46 | **Rel-9 RAN improvements** | 196d? | 2009-03-06 | 2009-12-04 |  |  | 2009-03-06 | 2009-12-04 | 196d? | 70d |  | RP | 9408h |  | RANimp |  |  | Rel-9 | RP-43 | Stefania | PCG-22 |  |
| 125 | 46.1 | Dual-Cell HSUPA | 196d? | 2009-03-06 | 2009-12-04 |  |  | 2009-03-06 | 2009-12-04 | 196d? | 70d | finish no earlier than 2009-12-04 | R1 | 1568h |  | RANimp-DC_HSUPA | Nokia Siemens Networks | Karri Ranta-aho | Rel-9 | RP-43 | Patrick | PCG-22 |  |
| 126 | 46.2 | Support for different bands for Dual-Cell HSDPA | 196d? | 2009-03-06 | 2009-12-04 |  |  | 2009-03-06 | 2009-12-04 | 196d? | 70d | finish no earlier than 2009-12-04 | R4 | 1568h |  | RANimp-MultiBand_DC_HSDPA | Nokia Siemens Networks | Tuomo Säynäjäkangas | Rel-9 | RP-43 | Stefania | PCG-22 |  |
| 127 | 46.3 | Combination of DC-HSDPA with MIMO | 196d? | 2009-03-06 | 2009-12-04 |  |  | 2009-03-06 | 2009-12-04 | 196d? | 70d | finish no earlier than 2009-12-04 | R1 | 1568h |  | RANimp-DC_MIMO | Ericsson | Johan Bergman | Rel-9 | RP-43 | Patrick | PCG-22 |  |
| 128 | 46.4 | UTRAN 2 ms TTI uplink range improvement | 196d? | 2009-03-06 | 2009-12-04 |  |  | 2009-03-06 | 2009-12-04 | 196d? | 70d | finish no earlier than 2009-12-04 | R1 | 1568h |  | RANimp-2mTTI_ULimp | Nokia Siemens Networks | Karri Ranta-aho (karri.ranta-aho@nsn.com) | Rel-9 | RP-43 | Patrick | PCG-22 |  |
| 129 | 46.5 | TxAA extension for non-MIMO UEs | 196d? | 2009-03-06 | 2009-12-04 |  |  | 2009-03-06 | 2009-12-04 | 196d? | 70d | finish no earlier than 2009-12-04 | R1 | 1568h |  | RANimp-TxAA_nonMIMO | Nokia | Arto Lehti (arto.lehti@nokia.com) | Rel-9 | RP-43 | Patrick | PCG-22 |  |

Notes:
- 104: SA#43 Feature moved to Rel-9. Stage 1 TS 22.142 promoted to Rel-9 and dismissed the Rel-8 version.
- 105: SA#39 completed. SA#43 Feature moved to Rel-9. Stage 1 TS 22.142 promoted to Rel-9 and dismissed the Rel-8 version. / Text3: 22.142
- 106: CT#43 moved to Rel-9. WID updated CP-080721=>CP-090021. CT#42 Rel-8 extension to 03/09 / Text3: 23.142, 29.002
- 107: CT#43 moved to Rel-9. WID updated CP-080721=>CP-090021. CT#42 Rel-8 extension to 03/09 / Text3: 23.040
- 108: CT#42 moved to Rel-9 / Text3: 31.xyz
- 109: CT#43 moved to Rel-9. WID updated CP-080577=>CP-090073. Rel-8 UID_380061 (Ipinterc) covers Stage 1 in SA1 22.101, 22.228. CT#42 Rel-8 extension to 03/09
- 110: CT#43 moved to Rel-9. WID updated CP-080577=>CP-090073. CT#42 Rel-8 extension to 03/09 / Text3: 29.235
- 111: CT#43 moved to Rel-9. WID updated CP-080577=>CP-090073. CT#42 Rel-8 extension to 03/09 / Text3: 29.238, 23.231, 29.232
- 112: CT#42 Rel-8 extension to 03/09. CT#43 moved to Rel-9. WID updated CP-080746=>CP-090019
- 113: CT#42 Rel-8 extension to 03/09. CT#43 moved to Rel-9. WID updated CP-080746=>CP-090019 / Text3: 29.238
- 114: CT#42 Rel-8 extension to 03/09. CT#43 moved to Rel-9. WID updated CP-080746=>CP-090019 / Text3: 29.162, 29.235
- 115: CT#42 Rel-8 extension to 03/09. CT#43 moved to Rel-9. WID updated CP-080723=>CP-090020 / Text3: 23.334, 29.334
- 116: RP#41 umbrella Feature created to host Rel-9 WIs
- 117: RP#43 Completion target 03/09=>09/09 / Text3: 25.8xy (LCR TDD UE OTA performance requiremen)
- 118: RP#42 WID updated RP-080758=>RP-081098
- 119: RP#42 WID updated RP-080758=>RP-081098 / Text3: 25.104, 25.105, 36.104, 45.005, XX.YYa (E-UA, UA and GSM/EDGE; Multi-Standard Radio (MSR) BS radio transmission and reception), XX.Yybb (BS conformance testing), XX.Yyc (RF requirements for Multicarrier and Multi-RAT BS)
- 120: GP#40 WID approved / Text3: 45.005, 51.021
- 121: RP#43 completion target 05/09 (R5 target 09/09) / Text3: 25.101, 25.104, 25.113, 25.133, 25.141, 34.124, 25.306, 25.307, 25.331, 25.461, 25.466, 36.101, 36.104, 36.113, 36.124, 36.133, 36.141, 36.331
- 122: Text3: TR xx.yyy (800MHz in the EU Work Item Technical report), 25.101, 25.104, 25.113, 25.133, 25.141, 34.124, 25.306, 25.307, 25.331, 25.461, 25.466, 36.101, 36.104, 36.113, 36.124, 36.133, 36.141, 36.331
- 123: Text3: 25.102, 25.105, 25.142
- 125: Text3: 25.211, 25.212, 25.213, 25.214, 25.215, 25.319, 25.306, 25.321, 25.331, 25.423, 25.433, 25.101, 25.104, 25.133
- 126: Text3: 25.101, 25.104, 25.133, 25.306, 25.308, 25.331, 25.423, 25.433
- 127: Text3: 25.101, 25.104, 25.211, 25.212, 25.213, 25.214, 25.215, 25.308, 25.321, 25.331, 25.423, 25.433, 26.306, 25.133
- 128: Text3: 25.212, 25.214, 25.321, 25.331, 25.133
- 129: Text3: 25.211, 25.212, 25.213, 25.214, 25.215, 25.308, 25.306, 25.321, 25.331, 25.423, 25.433, 25.101, 25.104

| ID | WBS | Task | Type | Duration | Start | Finish | Complete | Remaining | Baseline start | Baseline finish | Baseline duration | Total slack | Constraint | Resources | Work | Actual work | Text1 | Text2 | Text6 | Text7 | Text8 | Text4 | Text9 | Text12 | Text11 |
| --- | --- | --- | --- | --- | --- | --- | --- | --- | --- | --- | --- | --- | --- | --- | --- | --- | --- | --- | --- | --- | --- | --- | --- | --- | --- |
| 130 | 47 | **LTE improvements** |  | 261d? | 2009-03-06 | 2010-03-05 |  |  | 2009-03-06 | 2010-03-05 | 261d? | 5d |  | RP | 5744h |  | LTEimp | PCG-22 | Rel-9 | RP-42 | Stefania |  |  |  |  |
| 131 | 47.1 | LTE Pico NodeB RF Requirements |  | 261d? | 2009-03-06 | 2010-03-05 |  |  | 2009-03-06 | 2010-03-05 | 261d? | 5d | finish no earlier than 2010-03-05 | R4 | 2088h |  | LTEimp-Pico_eNB-RF | PCG-22 | Rel-9 | RP-43 | Stefania | Huawei |  |  |  |
| 132 | 47.2 | Enhanced Dual-Layer transmission for LTE |  | 196d? | 2009-03-06 | 2009-12-04 |  |  | 2009-03-06 | 2009-12-04 | 196d? | 70d | finish no earlier than 2009-12-04 | R1 | 1568h |  | LTEimp-eDL | PCG-22 | Rel-9 | RP-43 | Patrick | China Mobile |  |  |  |
| 133 | 48 | **Self-Organizing Networks (SON)** |  | 196d? | 2009-03-06 | 2009-12-04 |  |  | 2009-03-06 | 2009-12-04 | 196d? | 70d |  | R3 | 3136h |  | SON | PCG-22 | Rel-9 | SP-42 | Gert | Nokia Siemens Networks |  |  |  |
| 134 | 48.1 | SON |  | 196d? | 2009-03-06 | 2009-12-04 |  |  | 2009-03-06 | 2009-12-04 | 196d? | 70d | finish no earlier than 2009-12-04 | R3 | 1568h |  | SON | PCG-22 | Rel-9 | RP-43 | Gert | Nokia Siemens Networks |  |  |  |
| 135 | 49 | **Voice services over Adaptive Multi-user channels on One Slot** |  | 261d? | 2008-11-21 A | 2009-11-20 | 18% | 214.98d? | 2008-11-21 | 2009-11-20 | 261d? | 80d |  | GP | 6952h | 1225.75h | VAMOS | PCG-22 | Rel-9 | SP-42 | Paolo | Nokia Siemens Networks, China Mobile |  |  |  |
| 136 | 49.1 | VAMOS Stage 2 |  | 126d? | 2008-11-21 A | 2009-05-15 | 50% | 63d? | 2008-11-21 | 2009-05-15 | 126d? | 215d | finish no earlier than 2009-05-15 | GP | 1008h | 504h | VAMOS | PCG-22 | Rel-9 | GP-40 | Paolo | Nokia Siemens Networks, China Mobile |  |  |  |
| 137 | 49.2 | VAMOS Stage 3 |  | 221d? | 2008-11-21 A | 2009-09-25 | 20% | 176.8d? | 2008-11-21 | 2009-09-25 | 221d? | 120d | finish no earlier than 2009-09-25 | GP | 1768h | 353.6h | VAMOS | PCG-22 | Rel-9 | GP-40 | Paolo | Nokia Siemens Networks, China Mobile |  |  |  |
| 138 | 49.3 | VAMOS Radio Performance Requirements |  | 261d? | 2008-11-21 | 2009-11-20 |  |  | 2008-11-21 | 2009-11-20 | 261d? | 80d | finish no earlier than 2009-11-20 | GP | 2088h |  | VAMOS | PCG-22 | Rel-9 | GP-40 | Paolo | Nokia Siemens Networks, China Mobile |  |  |  |
| 139 | 50 | Local Call Local Switch |  | 196d? | 2009-02-20 | 2009-11-20 |  |  | 2009-02-20 | 2009-11-20 | 196d? | 80d | finish no earlier than 2009-11-20 | GP | 1568h |  | LCLS | PCG-22 | Rel-9 | GP-41 | Paolo | Huawei |  |  |  |
| 140 | 51 | (Small) Technical Enhancements and Improvements for Rel-9 |  | 391d? | 2008-09-12 | 2010-03-12 |  |  | 2008-09-12 | 2010-03-12 | 391d? | 0d | finish no earlier than 2010-03-12 | All | 3128h |  | TEI9 | PCG-22 | Rel-9 | SP-42 |  | ALL |  |  |  |
| 141 | 52 | **Deleted - SAES Enhancements (non RAN aspects)** |  | 381d? | 2007-06-25 A | 2008-12-08 A | 100% |  | 2007-06-25 | 2008-12-08 | 381d? |  |  | S2 | 11664h | 11664h | SAES_Ph2 | PCG-21 | Rel-9 | SP-39 | Maurice | Nokia Siemens Networks | PCG-21 | SP-39 |  |
| 142 | 52.1 | Deleted - Functions and procedures for SAE to support LTE MBMS |  | 381d? | 2007-06-25 A | 2008-12-08 A | 100% |  | 2007-06-25 | 2008-12-08 | 381d? |  | finish no earlier than 2008-12-08 | S2 | 3048h | 3048h | SAES_Ph2 |  | Rel-9 | SP-35 | Maurice |  | PCG-21 | SP-39 |  |
| 143 | 52.2 | Deleted - CS over EPS |  | 194d? | 2008-03-12 A | 2008-12-08 A | 100% |  | 2008-03-12 | 2008-12-08 | 194d? |  | finish no earlier than 2008-12-08 | S2 | 1552h | 1552h | SAES_Ph2 | PCG-21 | Rel-9 | SP-39 | Maurice |  | PCG-21 | SP-39 |  |
| 144 | 52.3 | **Deleted - SAE for generic support for non-3GPP accesses** |  | 251d? | 2007-06-25 A | 2008-06-09 A | 100% |  | 2007-06-25 | 2008-06-09 | 251d? |  |  | S2 | 4016h | 4016h | SAES_Ph2 | PCG-21 | Rel-9 | SP-39 | Maurice |  | PCG-21 | SP-39 |  |
| 145 | 52.3.1 | Deleted - Single Radio Aspects of SAE for Optimized Handover with WiMAX |  | 251d? | 2007-06-25 A | 2008-06-09 A | 100% |  | 2007-06-25 | 2008-06-09 | 251d? |  | finish no earlier than 2008-06-09 | S2 | 2008h | 2008h | SAES_Ph2 | PCG-21 | Rel-9 | SP-39 | Maurice |  | PCG-21 | SP-39 |  |
| 146 | 53 | Deleted - Harmonization of Gq'/Rx for Common IMS |  | 304d? | 2008-01-14 A | 2009-03-12 A | 100% |  | 2008-01-14 | 2009-03-12 | 304d? |  | finish no earlier than 2009-03-12 | S2 | 2432h | 2432h | IMS_Comm_GqRx_Harm | PCG-21 | Rel-9 | SP-38 | Maurice | Alcatel-Lucent | PCG-22 | SP-43 |  |
| 147 | 54 | Deleted - Support of WiMAX - LTE Mobility |  | 406d? | 2008-06-06 A | 2009-12-25 A | 100% |  | 2008-06-06 | 2009-12-25 | 406d? |  | start no earlier than 2008-06-06 | R2 | 3248h | 3248h | WiMAX_LTE_Mobility | PCG-21 | Rel-9 | RP-38 | Joern | Samsung | PCG-21 | SP-39 |  |
| 148 | 55 | Deleted - Support of WiMAX - UMTS Mobility |  | 406d? | 2008-06-06 A | 2009-12-25 A | 100% |  | 2008-06-06 | 2009-12-25 | 406d? |  | start no earlier than 2008-06-06 | R2 | 3248h | 3248h | WiMAX_UMTS_Mobility | PCG-21 | Rel-9 | RP-38 | Joern | Intel | PCG-21 | SP-39 |  |
| 149 | 56 | Release 9 Feasibility Studies | milestone | 0d? | 2000-01-01 | 2000-01-01 |  |  | 2000-01-01 | 2000-01-01 | 0d? | 2660d |  | CP,GP,RP,SP |  |  |  |  | Rel-9 |  |  |  |  |  |  |
| 150 | 57 | **Study on enhanced voice service requirements for the EPS** |  | 459d? | 2007-09-03 A | 2009-06-04 | 57% | 199.26d? | 2007-09-03 | 2009-06-04 | 459d? | 201d |  | S1,S4 | 10016h | 5667.94h | FS_EV_EPS |  | Rel-9 | SP-37 | Alain | Orange |  |  |  |
| 151 | 57.1 | Use cases definition and service and system requirements |  | 334d? | 2007-09-03 A | 2008-12-11 A | 100% |  | 2007-09-03 | 2008-12-11 | 334d? |  | finish no earlier than 2008-12-11 | S1 | 2672h | 2672h | FS_EV_EPS-S1 |  | Rel-9 | SP-37 | Alain | Orange |  |  |  |
| 152 | 57.2 | Codec specific part of FSEV_EPS |  | 459d? | 2007-09-03 A | 2009-06-04 | 25% | 344.25d? | 2007-09-03 | 2009-06-04 | 459d? | 201d | finish no earlier than 2009-06-04 | S4 | 3672h | 918h | FS_EV_EPS-S4 |  | Rel-9 | SP-37 | Paolo | Orange |  |  |  |
| 153 | 58 | Study on advanced requirements for IP interconnect |  | 528d? | 2007-12-04 A | 2009-12-10 | 50% | 264d? | 2007-12-04 | 2009-12-10 | 528d? | 66d | finish no earlier than 2009-12-10 | S1 | 4224h | 2112h | FS_IPXS | PCG-21 | Rel-9 | SP-38 | Alain | Telefonica O2 |  |  |  |
| 154 | 59 | Study on Service Specific Access Control in EPS |  | 136d? | 2008-06-05 A | 2008-12-11 A | 100% |  | 2008-06-05 | 2008-12-11 | 136d? |  | start no earlier than 2008-06-05 | S1 | 1088h | 1088h | FS_SSAC | PCG-21 | Rel-9 | SP-40 | Alain | NTT DoCoMo |  |  |  |
| 155 | 60 | Study on Unauthenticated PS Emergency Calls |  | 396d? | 2008-06-05 A | 2009-12-10 | 20% | 316.8d? | 2008-06-05 | 2009-12-10 | 396d? | 66d | finish no earlier than 2009-12-10 | S1 | 3168h | 633.6h | FS_UAPSEC | PCG-21 | Rel-9 | SP-40 | Alain | Nokia Siemens Networks |  |  |  |
| 156 | 61 | Study on Personal Broadcast Service |  | 321d? | 2008-09-18 A | 2009-12-10 | 60% | 128.4d? | 2008-09-18 | 2009-12-10 | 321d? | 66d | finish no earlier than 2009-12-10 | S1 | 2568h | 1540.8h | FS_PBS | PCG-21 | Rel-9 | SP-41 | Alain | ETRI |  |  |  |
| 157 | 62 | Study on LCS support in SAE for non-3GPP accesses |  | 321d? | 2008-09-18 A | 2009-12-10 | 35% | 208.65d? | 2008-09-18 | 2009-12-10 | 321d? | 66d | finish no earlier than 2009-12-10 | S1 | 2568h | 898.8h | FS_LCS_n3GPP | PCG-21 | Rel-9 | SP-41 | Alain | SK Telecom |  |  |  |
| 158 | 63 | Study on CS Domain Services over EPS access |  | 492d? | 2007-04-25 A | 2009-03-12 A | 100% |  | 2007-04-25 | 2009-03-12 | 492d? |  | finish no earlier than 2009-03-12 | S2 | 3936h | 3936h | FS_CSoPS |  | Rel-9 | SP-35 | Maurice | T-Mobile |  |  |  |
| 159 | 64 | Study on Extended Support of IMS Emergency Calls |  | 319d? | 2007-09-24 A | 2008-12-11 A | 100% |  | 2007-09-24 | 2008-12-11 | 319d? |  | finish no earlier than 2009-06-18 | S2 | 2552h | 2552h | FS_IMS-eCall |  | Rel-9 | SP-37 | Maurice | Qualcomm |  |  |  |
| 160 | 65 | Study on System enhancements for the use of IMS services in local breakout and optimal routing of media |  | 510d? | 2007-10-01 A | 2009-09-11 | 60% | 202.8d? | 2007-10-01 | 2009-09-11 | 510d? | 130d | finish no earlier than 2009-09-11 | S2 | 4080h | 2457.6h | FS_IMS_LBO_ORM |  | Rel-9 | SP-37 | Maurice | Telecom Italia, BT |  |  |  |
| 161 | 66 | Study on Intra Domain Connection of RAN Nodes to Multiple CN Nodes |  | 322d? | 2008-03-12 A | 2009-06-04 | 50% | 161d? | 2008-03-12 | 2009-06-04 | 322d? | 201d | finish no earlier than 2009-06-04 | S2 | 2576h | 1288h | FS_IDC | PCG-21 | Rel-9 | SP-39 | Maurice | China Mobile |  |  |  |
| 162 | 67 | Study on IMS Evolution |  | 257d? | 2008-09-18 A | 2009-09-11 | 15% | 217.85d? | 2008-09-18 | 2009-09-11 | 257d? | 130d | finish no earlier than 2009-09-11 | S2 | 2056h | 313.2h | FS_eIMS | PCG-21 | Rel-9 | SP-41 | Maurice | China Mobile |  |  |  |
| 163 | 68 | Study on enhancements to IMS border functions for IMS Interconnection of services |  | 186d? | 2008-09-18 A | 2009-06-04 | 15% | 158.1d? | 2008-09-18 | 2009-06-04 | 186d? | 201d | finish no earlier than 2009-06-04 | S2 | 1488h | 223.2h | FS_eIMS_IBCF | PCG-21 | Rel-9 | SP-41 | Maurice | Starent Networks |  |  |  |
| 164 | 69 | Study on Multi Access PDN connectivity and IP flow Mobility |  | 186d? | 2008-09-18 A | 2009-06-04 | 60% | 74.4d? | 2008-09-18 | 2009-06-04 | 186d? | 201d | finish no earlier than 2009-06-04 | S2,S1 | 1488h | 892.8h | FS_MAPIM | PCG-21 | Rel-9 | SP-41 | Maurice | Qualcomm |  |  |  |
| 165 | 70 | Study on Service Continuity for Emergency Voice Calls |  | 721d? | 2006-06-08 A | 2009-03-12 A | 100% |  | 2006-06-08 | 2009-03-12 | 721d? |  | finish no earlier than 2009-03-12 | S2 | 5768h | 5768h | FS_VCCEm |  | Rel-9 | SP-32 | Maurice | Nortel |  |  |  |
| 166 | 71 | Study on Protection against SMS and MMS spam |  | 916d? | 2006-06-08 A | 2009-12-10 | 30% | 641.2d? | 2006-06-08 | 2009-12-10 | 916d? | 66d | finish no earlier than 2009-12-10 | S3 | 7328h | 2198.4h | FS_CPSMal |  | Rel-9 | SP-32 | Dionisio | Orange |  |  |  |
| 167 | 72 | Study on Remote management of USIM application on M2M Equipment |  | 518d? | 2005-07-20 A | 2009-09-11 | 60% | 207.2d? | 2005-07-20 | 2009-09-11 | 518d? | 130d | finish no earlier than 2009-09-11 | S3 | 4144h | 2486.4h | FS_UM2M |  | Rel-9 | SP-37 | Dionisio | Ericsson |  |  |  |
| 168 | 73 | Study on UTRAN key management enhancements |  | 381d? | 2007-12-20 A | 2009-06-04 | 20% | 304.8d? | 2007-12-20 | 2009-06-04 | 381d? | 201d | finish no earlier than 2009-06-04 | S3 | 3048h | 609.6h | FS_UKM | PCG-21 | Rel-9 | SP-38 | Dionisio | Ericsson |  |  |  |
| 169 | 74 | Study on Surround Sound codec extension for PSS and MBMS |  | 132d? | 2009-03-12 | 2009-09-11 |  |  | 2009-03-12 | 2009-09-11 | 132d? | 130d | finish no earlier than 2009-09-11 | S4 | 1056h |  | FS_SS_PSS_MBMS | PCG-22 | Rel-9 | SP-43 | Paolo | Fraunhofer Gesellschaft |  |  |  |
| 170 | 75 | Study on System Maintenance over Itf-N |  | 656d? | 2007-06-07 A | 2009-12-10 | 75% | 164d? | 2007-06-07 | 2009-12-10 | 656d? | 66d | finish no earlier than 2009-12-10 | S5 | 5248h | 3936h | FS_OAM-Maint-Itf-N |  | Rel-9 | SP-36 | Dionisio | ZTE |  |  |  |
| 171 | 76 | Study on Self-Organizing Networks (SON) related OAM interfaces for Home NodeB |  | 656d? | 2007-06-07 A | 2009-12-10 | 70% | 196.1d? | 2007-06-07 | 2009-12-10 | 656d? | 66d | finish no earlier than 2009-12-10 | S5 | 5248h | 3679.2h | FS_OAM-SON-HNB |  | Rel-9 | SP-36 | Dionisio | Huawei |  |  |  |
| 172 | 77 | Study on Self-healing of Self-Organizing Networks (SON) |  | 470d? | 2008-02-22 A | 2009-12-10 | 45% | 258.5d? | 2008-02-22 | 2009-12-10 | 470d? | 66d | finish no earlier than 2009-12-10 | S5 | 3760h | 1692h | FS_OAM-SON-SH | PCG-21 | Rel-9 | SP-39 | Dionisio | ZTE |  |  |  |
| 173 | 78 | Study on Service Oriented Architecture (SOA) for IRP |  | 396d? | 2008-06-05 A | 2009-12-10 | 85% | 59.4d? | 2008-06-05 | 2009-12-10 | 396d? | 66d | finish no earlier than 2009-12-10 | S5 | 3168h | 2692.8h | FS_OAM_SOA_IRP | PCG-21 | Rel-9 | SP-40 | Dionisio | Ericsson |  |  |  |
| 174 | 79 | Study on Rc Reference Point Functionalities and Message Flows |  | 321d? | 2008-09-18 A | 2009-12-10 | 30% | 224.7d? | 2008-09-18 | 2009-12-10 | 321d? | 66d | finish no earlier than 2009-12-10 | S5 | 2568h | 770.4h | FS_OAM_Rc | PCG-21 | Rel-9 | SP-41 | Dionisio | Huawei |  |  |  |
| 175 | 80 | Study on Telecommunication Management; Energy Savings Management (ESM) |  | 196d? | 2009-03-12 | 2009-12-10 |  |  | 2009-03-12 | 2009-12-10 | 196d? | 66d | finish no earlier than 2009-12-10 | S5 | 1568h |  | FS_OAM_ESM | PCG-22 | Rel-9 | SP-43 | Dionisio | Orange, Vodafone |  |  |  |
| 176 | 81 | Study on Evaluation of the inclusion of Path Loss Based Technology in the UTRAN |  | 380d? | 2007-12-17 A | 2009-05-29 | 75% | 95d? | 2007-12-17 | 2009-05-29 | 380d? | 205d | finish no earlier than 2009-05-29 | R4 | 3040h | 2280h | FS_RAN-Pathloss | PCG-21 | Rel-9 | RP-38 | Stefania | Polaris Wireless |  |  | RP-090164 |
| 177 | 82 | Study on LTE-Advanced |  | 326d? | 2008-06-13 A | 2009-09-11 | 40% | 195.6d? | 2008-06-13 | 2009-09-11 | 326d? | 130d | finish no earlier than 2009-09-11 | R1 | 2608h | 1043.2h | FS_RAN_LTEA | PCG-21 | Rel-9 | RP-39 | Patrick | NTT DoCoMo |  |  | RP-090067 |
| 178 | 83 | Study on 1.28 Mcps TDD Home NodeB |  | 251d? | 2008-02-20 A | 2009-05-29 | 40% | 150.6d? | 2008-02-20 | 2009-05-29 | 251d? | 205d | finish no earlier than 2009-05-29 | R4 | 2008h | 803.2h | FS_RAN-HNBLCRTDD | PCG-21 | Rel-9 | RP-41 | Stefania | TD Tech |  |  | RP-090068 |
| 179 | 84 | Study on E-UTRAN Mobility Evaluation and Enhancement |  | 126d? | 2008-12-05 A | 2009-05-29 | 30% | 88.2d? | 2008-12-05 | 2009-05-29 | 126d? | 205d | finish no earlier than 2009-05-29 | R1 | 1008h | 302.4h | FS_EUTRAN_mob | PCG-22 | Rel-9 | RP-42 | Patrick | Qualcomm |  |  | RP-090069 |
| 180 | 85 | Study on Measurement of Radiated Performance for MIMO and multi-antenna reception for HSPA and LTE terminals |  | 200d? | 2009-03-06 | 2009-12-10 |  |  | 2009-03-06 | 2009-12-10 | 200d? | 66d | start no earlier than 2009-03-06 | R4 | 1600h |  | FS_HSPA_LTE_measRP_MIMO_multi-antenna | PCG-22 | Rel-9 | RP-43 | Stefania | Vodafone |  |  |  |
| 181 | 86 | Study on Minimization of drive-tests in Next Generation Networks |  | 136d? | 2009-03-06 | 2009-09-11 |  |  | 2009-03-06 | 2009-09-11 | 136d? | 130d | finish no earlier than 2009-09-11 | R2 | 1088h |  | FS_NGN_min_drive-tests | PCG-22 | Rel-9 | RP-43 | Joern | Qualcomm |  |  |  |
| 182 | 87 | Study on Enhanced Interference Management for HNBs |  | 200d? | 2009-03-06 | 2009-12-10 |  |  | 2009-03-06 | 2009-12-10 | 200d? | 66d | start no earlier than 2009-03-06 | R4 | 1600h |  | FS_eInterfMgmt_HNB | PCG-22 | Rel-9 | RP-43 | Stefania | Qualcomm |  |  |  |
| 183 | 88 | Release 8 Features | milestone | 0d? | 2000-01-03 | 2000-01-03 |  |  | 2000-01-03 | 2000-01-03 | 0d? | 2659d | start no earlier than 2000-01-03 | CP,GP,RP,SP |  |  |  |  | Rel-8 |  |  |  |  |  |  |

Notes:
- 131: Text3: 36.8xy (RF requirements for LTE Pico NodeB), 36.104, 36.141 / Text5: Liyan Yin
- 132: Text3: 36.101, 36.104, 36.106, 36.133, 36.211, 36.212, 36.213, 36.321, 36.331 / Text5: xuxiaodong@chinamobile.com
- 133: Text5: Krzysztof Kordybach
- 134: Text3: TR 36.9xx (Self-Organized Networks (SON) – E-UTRAN aspects), 36.300, 36.423, 36.902 / Text5: Krzysztof Kordybach
- 135: GP#40 WID approved / Text5: juergen.hofmann@nsn.com, liuxiaoyu@chinamobile.com
- 136: GP#40 WID approved / Text3: 45.001 (Overview of VAMOS solution) / Text5: juergen.hofmann@nsn.com, liuxiaoyu@chinamobile.com
- 137: GP#40 WID approved / Text3: 24.008, 44.018, 45.002, 45.003, 45.004, 45.008, 48.008, 48.058 / Text5: juergen.hofmann@nsn.com, liuxiaoyu@chinamobile.com
- 138: GP#40 WID approved / Text3: 45.005 (Test Scenarios for VAMOS Performance requiremen) / Text5: juergen.hofmann@nsn.com, liuxiaoyu@chinamobile.com
- 139: GP#41 WID approved / Text3: 48.008 (MSC-BSS interface; Layer 3 specification) / Text5: Xing Zhu
- 141: SA#39 created to host Rel-9 Wis. BUT no agreed WID
- 142: SA#39 SAE functionality moved to Rel-9. WID returned to SA2 for re-consideration & remove MBMS for EPS from Rel 8
- 143: SA#39 SAE functionality moved to Rel-9. BUT no agreed WID
- 144: SA#39 SAE functionality moved to Rel-9. BUT no agreed WID
- 145: SA#39 SAE functionality moved to Rel-9. BUT no agreed WID
- 146: SA#43 stopped. LS_out to TISPAN informs about stopping this activity / Text3: 23.822, 23.203 / Text5: geoffrey.cristallo@alcatel-lucent.be
- 147: RP#39: No agreed WID / Text3: 36.306, 36.331, 36.413, 36.300, 36.214, 36.133, 36.304
- 148: RP#39: No agreed WID / Text3: 25.306, 25.331, 25.413
- 150: SA#42 SA1 part completed / Text5: tim.haysom@orange-ftgroup.com
- 151: SA#42 completed / Text3: 22.813 / Text5: tim.haysom@orange-ftgroup.com
- 152: Text5: tim.haysom@orange-ftgroup.com
- 153: Completion target 03/09=>12/09 / Text3: 22.893 / Text5: chris.friel@O2.com
- 154: SA#42 completed. Spinn-off Feature UID_420020 (SSAC) / Text3: 22.986 / Text5: Frederic Thepot (thepot@docomolab-euro.com)
- 155: Completion target 03/09=>12/09 / Text3: 22.984 / Text5: Juergen Merkel
- 156: Completion target 03/09=>12/09 / Text3: 22.947 / Text5: Jaihyung Cho
- 157: Completion target 03/09=>12/09 / Text3: 22.913 / Text5: Donghee Shim
- 158: SA#43 completed / Text3: 23.879 / Text5: sabine.demel@t-mobile.at
- 159: SA#42 completed / Text3: 23.868 / Text5: Stephen Edge
- 160: SA#43 TR 23.894 for Information / Text3: 23.894 / Text5: mario.madella@telecomitalia.it, victor.kueh@bt.com
- 161: Linked to 23.236 / Text3: 23.823 / Text5: LIU HONG (liuhongyfw@chinamobile.com)
- 162: Text3: 23.812 / Text5: Li Gang (ligangyf@chinamobile.com), Yu Qing (yuqing@chinamobile.com)
- 163: 01/09: TR# allocated. Changed Rapporteur / Text3: 23.848 / Text5: Rajat Ghai (rghai@starentnetworks.com)
- 164: SA#43 TR 23.861 for Information / Text3: 23.861 / Text5: Gerardo Giaretta (gerardog@qualcomm.com)
- 165: SA#43 completed / Text3: 23.826 / Text5: Ricky Kaura (rkaura@nortel.com)
- 166: SA#42 moved to Rel-9. 01/09 MCC shifted target completion 12/08 => 12/09. / Text3: 33.9xx / Text5: eric.gauthier@orange.ch
- 167: SA#43 TR 33.812 for Information. Completion target 03/09=>09/09. Triggered by SA1 Study UID_7027 (FS_M2M) TR 22.868 / Text3: 33.812 / Text5: vesa.lehtovirta@ericsson.com
- 168: SA#43: target 03/09=>06/09. / Text3: 33.8xy / Text5: Karl Norrman
- 169: Work to extend Rel-8 UID_34043 PSS_MBMS_OMTV (Extending PSS and MBMS User Services for optimized Mobile TV) / Text3: 26.9xx (Study on Surround Sound for PSS and MBMS) / Text5: jan.plogsties@iis.franhofer.de
- 170: SA#42 target completion 12/08=>12/09 / Text3: 32.822 / Text5: HUANG, Shuqiang
- 171: SA#42 target completion 03/09=>12/09. SA#41 SID updated SP-070308=>SP-080461. / Text3: 32.821 / Text5: Zou Lan (zlan@huawei.com)
- 172: SA#42 target completion 03/09=>12/09 / Text3: 32.823 / Text5: zhu.weihong@zte.com.cn
- 173: SA#42 target completion 03/09=>12/09 / Text3: 32.824 / Text5: edwin.tse@ericsson.com
- 174: SA#42 target completion 03/09=>12/09 / Text3: 32.825 / Text5: shan.mingjun@huawei.com
- 175: Study result might impact Feature UID_420011 Self Organising Networks (SON) / Text3: 32.8xy (Study on Energy Savings Management - Concepts and Requirements) / Text5: Orange, Vodafone
- 176: RP#43 completion target 03/09=>05/09 / Text3: 25.9xx / Text5: Norman Shaw (nshaw@polariswireless.com)
- 177: RP#43 TR 36.814 for Information. RP#40 TR 36.913 completed / Text3: 36.913, 36.814 / Text5: Takehiro Nakamura (takehiro@wsp.yrp.nttdocomo.co.jp)
- 178: Text3: 25.866 / Text5: Li Rong (lirong@td-tech.com)
- 179: Text3: TR (E-UTRAN handover procedure and performance) / Text5: Rajat Prakash (rprakash@qualcomm.com)
- 180: Text3: New TR (25/36) on Measurements of radiated performance for MIMO and multi-antenna reception for HSPA and LTE terminals / Text5: SoonLeh Ling
- 181: Text3: 36.805 / Text5: Masato Kitazoe
- 182: Text3: none identified in WID / Text5: Farhad Meshkati

| ID | WBS | Task | Duration | Start | Finish | Complete | Remaining | Baseline start | Baseline finish | Baseline duration | Total slack | Constraint | Resources | Work | Actual work | Text1 | Text4 | Text5 | Text6 | Text8 | Text7 | Text2 |
| --- | --- | --- | --- | --- | --- | --- | --- | --- | --- | --- | --- | --- | --- | --- | --- | --- | --- | --- | --- | --- | --- | --- |
| 184 | 89 | **3GPP System Architecture Evolution Specification - Evolved Packet System (non RAN aspects)** | 898d? | 2006-04-12 A | 2009-09-18 | 99% | 9.71d? | 2006-04-12 | 2009-09-18 | 898d? | 125d |  | SP,CP | 254708h | 245920h | SAES | T-Mobile | michael.kurz@t-mobile.at | Rel-8 | Alain |  |  |
| 185 | 89.1 | Requirements for evolution of the 3GPP system architecture | 395d? | 2006-06-08 A | 2007-12-12 A | 100% |  | 2006-06-08 | 2007-12-12 | 395d? |  | finish no earlier than 2007-11-30 | S1 | 3160h | 3160h | AIPN-SAE | T-Mobile | michael.kurz@t-mobile.at | Rel-8 | Alain |  |  |
| 186 | 89.2 | **High level and common (for all accesses) functions** | 629d? | 2007-01-02 A | 2009-05-29 | 99% | 6.49d? | 2007-01-02 | 2009-05-29 | 629d? | 205d |  | SP,CP | 42536h | 40076.8h | EPS-ComF | Nokia Siemens Networks | balazs.bertenyi@nsn.com | Rel-8 | Maurice | SP-37 |  |
| 187 | 89.2.1 | Stage 2 for High level functions | 370d? | 2007-01-02 A | 2008-06-02 A | 100% |  | 2007-01-02 | 2008-06-02 | 370d? |  | finish no earlier than 2008-06-02 | S2 | 2960h | 2960h | SAES-SA-HLF | Motorola | Irfan.Ali@motorola.com | Rel-8 | Maurice |  |  |
| 188 | 89.2.2 | Stage 2 Security Architecture | 197d? | 2008-03-12 A | 2008-12-11 A | 100% |  | 2008-03-12 | 2008-12-11 | 197d? |  | finish no earlier than 2008-12-11 | S3 | 1576h | 1576h | SAES | Nokia Siemens Networks | marc.blommaert.ext@nsn.com | Rel-8 | Dionisio | SP-39 | PCG-21 |
| 189 | 89.2.3 | Stage 3 (CT1) for SAE impact on services, network functions and capabilities | 545d? | 2007-02-05 A | 2009-03-06 A | 100% |  | 2007-02-05 | 2009-03-06 | 545d? |  | finish no earlier than 2009-03-06 | C1 | 4360h | 4360h | SAES | Nokia Siemens Networks | robert.zaus@nsn.com | Rel-8 | Frederic |  |  |
| 190 | 89.2.4 | Stage 3 SAE impact on existing capabilities | 480d? | 2007-02-05 A | 2008-12-05 A | 100% |  | 2007-02-05 | 2008-12-05 | 480d? |  | finish no earlier than 2008-12-12 | C3 | 3840h | 3840h | SAES | Huawei | Wei Weihua (weiwh@huawei.com) | Rel-8 | Gwiho |  |  |
| 191 | 89.2.5 | Stage 3 (CT4) of SAE impact on existing capabilities | 545d? | 2007-02-05 A | 2009-03-06 A | 100% |  | 2007-02-05 | 2009-03-06 | 545d? |  | finish no earlier than 2009-03-06 | C4 | 4360h | 4360h | SAES | Huawei | shahab.lavasani@huawei.com | Rel-8 | Kimmo |  |  |
| 192 | 89.2.6 | Stage 2/3 for Network selection procedures | 480d? | 2007-02-05 A | 2008-12-05 A | 100% |  | 2007-02-05 | 2008-12-05 | 480d? |  | finish no earlier than 2009-03-06 | C1 | 3840h | 3840h | SAES | Nokia Siemens Networks | robert.zaus@nsn.com | Rel-8 | Frederic |  |  |
| 193 | 89.2.7 | Stage 3 EPC interworking with external PDNs (SGi) | 605d? | 2007-02-05 A | 2009-05-29 | 98% | 12.1d? | 2007-02-05 | 2009-05-29 | 605d? | 205d | finish no earlier than 2009-05-29 | C3 | 4840h | 4743.2h | SAES-St3-intwk | Huawei | Wei Weihua (weiwh@huawei.com) | Rel-8 | Gwiho |  |  |
| 194 | 89.2.8 | Stage 3 PCC within SAE | 605d? | 2007-02-05 A | 2009-05-29 | 94% | 36.3d? | 2007-02-05 | 2009-05-29 | 605d? | 205d | finish no earlier than 2009-05-29 | C3 | 4840h | 4549.6h | SAES-St3-PCC | Ericsson | j.javier.pastor@ericsson.com | Rel-8 | Gwiho |  |  |
| 195 | 89.2.9 | Stage 3 for SAE / LTE identities | 545d? | 2007-02-05 A | 2009-03-06 A | 100% |  | 2007-02-05 | 2009-03-06 | 545d? |  | finish no earlier than 2009-03-06 | C4 | 4360h | 4360h | SAES | Huawei | shahab.lavasani@huawei.com | Rel-8 | Kimmo |  |  |
| 196 | 89.2.10 | Unified guidelines for Diameter usage within 3GPP | 316d? | 2007-09-21 A | 2008-12-05 A | 100% |  | 2007-09-21 | 2008-12-05 | 316d? |  | finish no earlier than 2008-12-05 | C3 | 2528h | 2528h | SAES-DIAM | Huawei | Javier Gonzalez Gallego | Rel-8 | Gwiho | CP-37 |  |
| 197 | 89.3 | **SAE for LTE access** | 569d? | 2007-01-02 A | 2009-03-06 A | 100% |  | 2007-01-02 | 2009-03-06 | 569d? |  |  | S2,C1,C3,C4 | 57824h | 57824h | SAES-LTE | Motorola | Irfan.Ali@motorola.com | Rel-8 | Maurice |  |  |
| 198 | 89.3.1 | CT4 Stage 3 for protocol between EPCs | 545d? | 2007-02-05 A | 2009-03-06 A | 100% |  | 2007-02-05 | 2009-03-06 | 545d? |  | finish no earlier than 2009-03-06 | C4 | 4360h | 4360h | SAES | Huawei | shahab.lavasani@huawei.com | Rel-8 | Kimmo |  |  |
| 199 | 7.2.2.1 | **SAES-SA-FP_LTE with GTP variant** | 569d? | 2007-01-02 A | 2009-03-06 A | 100% |  | 2007-01-02 | 2009-03-06 | 569d? |  |  | S2,C4 | 11896h | 11896h | SAES-SA-FP_LTE-GTP | Nokia Siemens Networks | balazs.bertenyi@nsn.com | Rel-8 | Maurice |  |  |
| 200 | 89.3.2.1 | Stage 2 for SAES-SA-FP_LTE with GTP variant | 373d? | 2007-01-02 A | 2008-06-05 A | 100% |  | 2007-01-02 | 2008-06-05 | 373d? |  | finish no earlier than 2008-06-02 | S2 | 2984h | 2984h | SAES-SA-FP_LTE-GTP-St2 | Nokia Siemens Networks | balazs.bertenyi@nsn.com | Rel-8 | Maurice |  |  |
| 201 | 89.3.2.2 | CT4 Stage 3 for GTP v2 protocol | 545d? | 2007-02-05 A | 2009-03-06 A | 100% |  | 2007-02-05 | 2009-03-06 | 545d? |  | finish no earlier than 2009-03-06 | C4 | 4360h | 4360h | SAES | Huawei | shahab.lavasani@huawei.com | Rel-8 | Kimmo |  |  |
| 202 | 7.2.2.2 | **SAES-SA-FP_LTE with PMIP variant** | 569d? | 2007-01-02 A | 2009-03-06 A | 100% |  | 2007-01-02 | 2009-03-06 | 569d? |  |  | S2,C4 | 15736h | 15736h | SAES-SA-FP_LTE-IETF | Nokia Siemens Networks | balazs.bertenyi@nsn.com | Rel-8 | Maurice |  |  |
| 203 | 89.3.3.1 | Stage 2 for SAES-SA-FP_LTE with PMIP variant | 373d? | 2007-01-02 A | 2008-06-05 A | 100% |  | 2007-01-02 | 2008-06-05 | 373d? |  | finish no earlier than 2008-06-02 | S2 | 2984h | 2984h | SAES-SA-FP_LTE-IETF-St2 | Nokia Siemens Networks | balazs.bertenyi@nsn.com | Rel-8 | Maurice |  |  |
| 204 | 89.3.3.2 | CT4 Stage 3 for PMIP protocol within EPC | 545d? | 2007-02-05 A | 2009-03-06 A | 100% |  | 2007-02-05 | 2009-03-06 | 545d? |  | finish no earlier than 2009-03-06 | C4 | 4360h | 4360h | SAES | Huawei | shahab.lavasani@huawei.com | Rel-8 | Kimmo |  |  |
| 205 | 89.3.3.3 | Mobile IPv4 (MIPv4) based Mobility protocols | 480d? | 2007-02-05 A | 2008-12-05 A | 100% |  | 2007-02-05 | 2008-12-05 | 480d? |  | finish no earlier than 2008-12-05 | C4 | 3840h | 3840h | SAES | Motorola | Lewis Milton | Rel-8 | Kimmo | CP-41 |  |
| 206 | 89.3.4 | Stage 3 for UE NAS mobility procedures in idle and active mode | 545d? | 2007-02-05 A | 2009-03-06 A | 100% |  | 2007-02-05 | 2009-03-06 | 545d? |  | finish no earlier than 2009-03-06 | C1 | 4360h | 4360h | SAES | Nokia Siemens Networks | robert.zaus@nsn.com | Rel-8 | Frederic |  |  |
| 207 | 89.3.5 | Stage 3 for Session management, bearer control and QoS aspects | 545d? | 2007-02-05 A | 2009-03-06 A | 100% |  | 2007-02-05 | 2009-03-06 | 545d? |  | finish no earlier than 2009-03-06 | C1 | 4360h | 4360h | SAES | Nokia Siemens Networks | robert.zaus@nsn.com | Rel-8 | Frederic |  |  |
| 208 | 89.3.6 | Stage 3 for security aspects of LTE Access | 545d? | 2007-02-05 A | 2009-03-06 A | 100% |  | 2007-02-05 | 2009-03-06 | 545d? |  | finish no earlier than 2009-03-06 | C1 | 4360h | 4360h | SAES | Nokia Siemens Networks | robert.zaus@nsn.com | Rel-8 | Frederic |  |  |
| 209 | 89.3.7 | Stage 3 for QoS mechanisms | 480d? | 2007-02-05 A | 2008-12-05 A | 100% |  | 2007-02-05 | 2008-12-05 | 480d? |  | finish no earlier than 2008-12-12 | C3 | 3840h | 3840h | SAES | Ericsson | j.javier.pastor@ericsson.com | Rel-8 | Gwiho |  |  |
| 210 | 89.3.8 | Stage 3 for EPC - HSS interface | 545d? | 2007-02-05 A | 2009-03-06 A | 100% |  | 2007-02-05 | 2009-03-06 | 545d? |  | finish no earlier than 2009-03-06 | C4 | 4360h | 4360h | SAES | Huawei | shahab.lavasani@huawei.com | Rel-8 | Kimmo |  |  |

Notes:
- 184: SA#39 WID updated SP-070933=>SP-080132.
- 185: SA#38 completed / Text3: 22.278, 22.011, 22.246
- 186: CT#43 extension 03/09=>05/09 (no extension sheet needed). SA#39 WID updated SP-070933=>SP-080132.
- 187: SA#40 completed / Text3: 23.402
- 188: SA#42 completed. SA#39 WID updated SP-070933=>SP-080132 / Text3: 33.401, 33.210, 33.310
- 189: CT#43 completed. CT#42 Rel-8 extension to 03/09 / Text3: 24.229, 24.305, 27.007
- 190: CT#42 completed. WID updated CP-080056=>CP-080772 / Text3: 29.061
- 191: CT#43 completed. WID updated CP-080724=>CP-090018. CT#42 Rel-8 extension to 03/09. Network sharing, etc, MBMS removed / Text3: 29.274, 29.275
- 192: CT#42 completed. CT#41 WID updated CP-080075=>CP-080493. / Text3: 23.122, 24.302
- 193: CT#43 extension 03/09=>05/09 (no extension sheet needed) / Text3: 29.061
- 194: CT#42 Rel-8 extension to 03/09. CT#43 Controversial issue on UE initiated resource modification still open. Extension 03/09=>05/09 (no extension sheet needed) / Text3: 29.212, 29.213, 29.214, 29.215
- 195: CT#43 completed. WID updated CP-080724=>CP-090018. CT#42 Rel-8 extension to 03/09 / Text3: 23.003
- 196: CT#42 completed / Text3: 29.909
- 197: CT#43 completed. SA#39 WID updated SP-070933=>SP-080132. / Text3: 23.401, 23.060, 23.002, 23.246, 23.203, 23.107, 23.234, 23.271
- 198: CT#43 completed. WID updated CP-080724=>CP-090018. CT#42 Rel-8 extension to 03/09. PMIP and GTP based S8 interface (EPC-EPC). / Text3: 29.274, 29.275
- 199: CT#43 completed. SA#39 WID updated SP-070933=>SP-080132.
- 200: SA#40 completed / Text3: 23.401, 23.060, 23.002, 23.246, 23.203, 23.107, 23.234, 23.271
- 201: CT#43 completed. WID updated CP-080724=>CP-090018. CT#42 Rel-8 extension to 03/09 / Text3: 29.274
- 202: CT#43 completed. SA#39 WID updated SP-070933=>SP-080132.
- 203: SA#40 completed. Multiple PDN related alignments, 23.060-derived changes.
- 204: CT#43 completed. WID updated CP-080724=>CP-090018. CT#42 Rel-8 extension to 03/09. PMIP based S5 interface. / Text3: 29.275, 29.282
- 205: CT#42 completd. CT#43 WID updated CP-080724=>CP-090018. / Text3: 29.279
- 206: CT#43 completed. CT#42 Rel-8 extension to 03/09 / Text3: 24.007, 24.301
- 207: CT#43 completed. CT#42 Rel-8 extension to 03/09 / Text3: 24.007, 24.301
- 208: CT#43 completed. CT#42 Rel-8 extension to 03/09 / Text3: 24.008, 24.301
- 209: CT#42 completed. CT#41 updated WID CP-080057=>CP-080576. / Text3: 29.213
- 210: CT#43 completed. WID updated CP-080724=>CP-090018. CT#42 Rel-8 extension to 03/09. S6a, S6d, S13, S13' interface / Text3: 29.272

| ID | WBS | Task | Type | Duration | Start | Finish | Complete | Baseline start | Baseline finish | Baseline duration | Constraint | Resources | Work | Actual work | Text1 | Text4 | Text5 | Text6 | Text8 | Text3 | Text7 | Text2 | Text12 |
| --- | --- | --- | --- | --- | --- | --- | --- | --- | --- | --- | --- | --- | --- | --- | --- | --- | --- | --- | --- | --- | --- | --- | --- |
| 211 | 89.4 | **SAE for Interoperation between LTE and legacy cellular PS accesses** |  | 545d? | 2007-02-05 A | 2009-03-06 A | 100% | 2007-02-05 | 2009-03-06 | 545d? |  | S2,C1,C4 | 40152h | 40152h | SAES-SA-FP_3GPP | Motorola | Irfan.Ali@motorola.com | Rel-8 | Maurice |  |  |  |  |
| 212 | 89.4.1 | Stage 2 for Interoperation between LTE and 2G/3G |  | 424d? | 2007-02-05 A | 2008-09-18 A | 100% | 2007-02-05 | 2008-09-18 | 424d? | finish no earlier than 2008-09-11 | S2 | 3392h | 3392h | EPSto2_3G | Motorola | Irfan.Ali@motorola.com | Rel-8 | Maurice | 23.401, 23.402 | SP-37 |  |  |
| 213 | 89.4.2 | Stage 3 for Inter-system mobility between E-UTRAN and 2G/3G |  | 545d? | 2007-02-05 A | 2009-03-06 A | 100% | 2007-02-05 | 2009-03-06 | 545d? | finish no earlier than 2009-03-06 | C1 | 4360h | 4360h | SAES | Nokia Siemens Networks | robert.zaus@nsn.com | Rel-8 | Frederic | 24.008, 24.301 | CP-38 | PCG-21 |  |
| 214 | 89.4.3 | Stage 2 GPRS enhancements for LTE access |  | 272d? | 2007-09-04 A | 2008-09-18 A | 100% | 2007-09-04 | 2008-09-18 | 272d? | start no earlier than 2007-09-04 | S2 | 2176h | 2176h | SAES-GPRS_LTE | Vodafone | chris.pudney@vodafone.com | Rel-8 | Maurice | 23.401 |  |  |  |
| 215 | 89.4.4 | Stage 2 GPRS for EPC (23.060, etc.) |  | 179d? | 2008-01-14 A | 2008-09-18 A | 100% | 2008-01-14 | 2008-09-18 | 179d? | finish no earlier than 2008-09-18 | S2 | 1432h | 1432h | SAES | Nokia Siemens Networks | balazs.bertenyi@nsn.com | Rel-8 | Maurice | 23.060 | SP-39 | PCG-21 |  |
| 216 | 89.4.5 | Stage 3 for EPC - GPRS |  | 545d? | 2007-02-05 A | 2009-03-06 A | 100% | 2007-02-05 | 2009-03-06 | 545d? | finish no earlier than 2009-03-06 | C4 | 4360h | 4360h | SAES | Huawei | shahab.lavasani@huawei.com | Rel-8 | Kimmo | 29.274, 29.275, 29.281 |  |  |  |
| 217 | 89.4.6 | Stage 3 for EPC to UTRAN |  | 545d? | 2007-02-05 A | 2009-03-06 A | 100% | 2007-02-05 | 2009-03-06 | 545d? | finish no earlier than 2009-03-06 | C4 | 4360h | 4360h | SAES | Huawei | shahab.lavasani@huawei.com | Rel-8 | Kimmo | 29.274, 29.275, 29.281 | CP-38 | PCG-21 |  |
| 218 | 89.4.7 | Stage 3 for EPC to 3GPP2 |  | 545d? | 2007-02-05 A | 2009-03-06 A | 100% | 2007-02-05 | 2009-03-06 | 545d? | finish no earlier than 2009-03-06 | C4 | 4360h | 4360h | SAES | Huawei | shahab.lavasani@huawei.com | Rel-8 | Kimmo | 29.277, 29.276 | CP-38 | PCG-21 |  |
| 219 | 89.4.8 | Stage 2 for Interoperation between LTE and CDMA2000 |  | 329d? | 2007-06-18 A | 2008-09-18 A | 100% | 2007-06-18 | 2008-09-18 | 329d? | finish no earlier than 2008-04-25 | S2 | 2632h | 2632h | EPStoC2k | Motorola, Vodafone | Irfan.Ali@motorola.com, chris.pudney@vodafone.com | Rel-8 | Maurice | 23.401, 23.402 | CP-37 |  |  |
| 220 | 89.4.9 | Stage 3 for Inter-system mobility between E-UTRAN and CDMA2000 |  | 545d? | 2007-02-05 A | 2009-03-06 A | 100% | 2007-02-05 | 2009-03-06 | 545d? | finish no earlier than 2009-03-06 | C1 | 4360h | 4360h | SAES | Nokia Siemens Networks | robert.zaus@nsn.com | Rel-8 | Frederic | 24.301, 24.302 |  |  |  |
| 221 | 89.4.10 | Stage 3 for MME - SGSN "signalling free" protocol |  | 545d? | 2007-02-05 A | 2009-03-06 A | 100% | 2007-02-05 | 2009-03-06 | 545d? | finish no earlier than 2009-03-06 | C4 | 4360h | 4360h | SAES | Huawei | shahab.lavasani@huawei.com | Rel-8 | Kimmo | 29.272, 29.274 |  |  |  |
| 222 | 89.5 | **SAE for support for non-3GPP accesses** |  | 569d? | 2007-01-02 A | 2009-03-06 A | 100% | 2007-01-02 | 2009-03-06 | 569d? |  | S2,S3,C1,C4 | 53872h | 53872h | SAES-SA-FP_n3GPP | Motorola | Irfan.Ali@motorola.com | Rel-8 | Maurice |  |  |  |  |
| 223 | 7.2.4.1 | Stage 2 for Host-based Mobility aspects |  | 373d? | 2007-01-02 A | 2008-06-05 A | 100% | 2007-01-02 | 2008-06-05 | 373d? | finish no earlier than 2008-04-11 | S2 | 2984h | 2984h | SAES-SA-FP_n3GPP-HBMob | Motorola | Irfan.Ali@motorola.com | Rel-8 | Maurice | 23.402 |  |  |  |
| 224 | 7.2.4.2 | Stage 2 for Network-based Mobility aspects |  | 448d? | 2007-01-02 A | 2008-09-18 A | 100% | 2007-01-02 | 2008-09-18 | 448d? | finish no earlier than 2008-09-18 | S2 | 3584h | 3584h | SAES-SA-FP_n3GPP-NBMob | Motorola | Irfan.Ali@motorola.com | Rel-8 | Maurice | 23.402 |  |  |  |
| 225 | 89.5.3 | Stage 3 for Mobility management based on DSMIP v6 |  | 480d? | 2007-02-05 A | 2008-12-05 A | 100% | 2007-02-05 | 2008-12-05 | 480d? | finish no earlier than 2008-12-05 | C1 | 3840h | 3840h | SAES | Nokia Siemens Networks | robert.zaus@nsn.com | Rel-8 | Frederic | 24.303 |  |  |  |
| 226 | 89.5.4 | Stage 3 for Mobility management based on MIP v4 |  | 480d? | 2007-02-05 A | 2008-12-05 A | 100% | 2007-02-05 | 2008-12-05 | 480d? | start no earlier than 2007-02-05 | C1 | 3840h | 3840h | SAES | Nokia Siemens Networks | robert.zaus@nsn.com | Rel-8 | Frederic | 24.304 | CP-39 | PCG-21 |  |
| 227 | 89.5.5 | Stage 3 for Inter-system mobility between E-UTRAN and non 3GPP accesses |  | 545d? | 2007-02-05 A | 2009-03-06 A | 100% | 2007-02-05 | 2009-03-06 | 545d? | finish no earlier than 2009-03-06 | C1 | 4360h | 4360h | SAES | Nokia Siemens Networks | robert.zaus@nsn.com | Rel-8 | Frederic | 24.008, 24.301 | CP-38 | PCG-21 |  |
| 228 | 89.5.6 | Stage 2 for Optimized Dual-Radio Handover with WiMAX |  | 249d? | 2007-06-25 A | 2008-06-05 A | 100% | 2007-06-25 | 2008-06-05 | 249d? | finish no earlier than 2008-06-09 | S2 | 1992h | 1992h | SAES-SA-FP_n3GPP-OptWIMAX | Motorola | Irfan.Ali@motorola.com | Rel-8 | Maurice | 23.402 |  |  |  |
| 229 | 89.5.7 | Stage 2 Security aspects for non-3GPP Access |  | 197d? | 2008-03-12 A | 2008-12-11 A | 100% | 2008-03-12 | 2008-12-11 | 197d? | finish no earlier than 2008-12-11 | S3 | 1576h | 1576h | SAES | Nokia Siemens Networks | marc.blommaert.ext@nsn.com | Rel-8 | Dionisio | 33.402, 33.210, 33.310 | SP-39 | PCG-21 |  |
| 230 | 89.5.8 | Stage 3 security aspects for DSMIP v6 Access |  | 480d? | 2007-02-05 A | 2008-12-05 A | 100% | 2007-02-05 | 2008-12-05 | 480d? | finish no earlier than 2008-12-05 | C1 | 3840h | 3840h | SAES | Nokia Siemens Networks | robert.zaus@nsn.com | Rel-8 | Frederic | 24.303 | CP-37 |  |  |
| 231 | 89.5.9 | Stage 3 security aspects for MIPv4 Access |  | 480d? | 2007-02-05 A | 2008-12-05 A | 100% | 2007-02-05 | 2008-12-05 | 480d? | finish no earlier than 2008-12-05 | C1 | 3840h | 3840h | SAES | Nokia Siemens Networks | robert.zaus@nsn.com | Rel-8 | Frederic | 24.304 | CP-39 | PCG-21 |  |
| 232 | 89.5.10 | Stage 3 for Access to the EPC via non-3GPP access networks |  | 545d? | 2007-02-05 A | 2009-03-06 A | 100% | 2007-02-05 | 2009-03-06 | 545d? | finish no earlier than 2009-03-06 | C1 | 4360h | 4360h | SAES | Nokia Siemens Networks | robert.zaus@nsn.com | Rel-8 | Frederic | 24.302, 24.312 |  |  |  |
| 233 | 89.5.11 | Stage 3 for interfaces within EPC |  | 383d? | 2007-09-19 A | 2009-03-06 A | 100% | 2007-09-19 | 2009-03-06 | 383d? | finish no earlier than 2009-03-06 | C4 | 3064h | 3064h | SAES | Huawei | shahab.lavasani@huawei.com | Rel-8 | Kimmo | 29.274, 29.281 | CP-37 |  |  |
| 234 | 89.5.12 | Stage 3 for Interfaces EPC - non-3GPP IP access |  | 545d? | 2007-02-05 A | 2009-03-06 A | 100% | 2007-02-05 | 2009-03-06 | 545d? | finish no earlier than 2009-03-06 | C4 | 4360h | 4360h | SAES | Huawei | shahab.lavasani@huawei.com | Rel-8 | Kimmo | 29.273, 29.275 |  |  |  |
| 235 | 89.5.13 | Stage 3 for AAA/HSS related |  | 480d? | 2007-02-05 A | 2008-12-05 A | 100% | 2007-02-05 | 2008-12-05 | 480d? | finish no earlier than 2008-12-05 | C4 | 3840h | 3840h | SAES | Huawei | shahab.lavasani@huawei.com | Rel-8 | Kimmo | 29.273 |  |  |  |
| 236 | 89.5.14 | Stage 3 for EPC - AAA interface |  | 480d? | 2007-02-05 A | 2008-12-05 A | 100% | 2007-02-05 | 2008-12-05 | 480d? | finish no earlier than 2008-12-05 | C4 | 3840h | 3840h | SAES | Huawei | shahab.lavasani@huawei.com | Rel-8 | Kimmo | 29.273 |  |  |  |
| 237 | 89.5.15 | Deleted (already covered) SAES-SA-FP_n3GPP Optimized Handover with CDMA | milestone | 0d? | 2007-06-25 A | 2007-06-25 A | 100% | 2007-06-25 | 2007-06-25 | 0d? | finish no earlier than 2007-06-25 | S2 |  |  | SAES-SA-FP_n3GPP-OptCDMA | Nokia Siemens Networks |  | Rel-8 | Maurice |  |  |  | SP-37 |

Notes:
- 211: CT#43 completed. SA#39 WID updated SP-070933=>SP-080132.
- 212: SA#41 completed. SA#40 extension to Sep 2008 (default bearer issue).
- 213: CT#43 completed. CT#42 Rel-8 extension to 03/09
- 214: SA#41 completed. 25/03/08 claimed as SA#34 stopped. Resurrected. WID updated SP-060926 => SP-080132
- 215: SA#41 completed. SA#40 extension to Sep 2008 (QoS mapping related changes, Interoperation between Gn/Gp and S4 SGSN).
- 216: CT#43 completed. WID updated CP-080724=>CP-090018. CT#42 Rel-8 extension to 03/09.S3, S4 Interface
- 217: CT#43 completed. WID updated CP-080724=>CP-090018. CT#42 Rel-8 extension to 03/09
- 218: CT#43 completed. WID updated CP-080724=>CP-090018. CT#42 Rel-8 extension to 03/09. S101, S103 Interface MME - HRPD access S102, Interface to CDMA2000 1x RTT
- 219: SA#40 extension to Sep 2008 (Handover of multiple PDNs, Handling of multiple BBERFs). SA#41 completed (except: Handover of multiple PDNs=>Rel-9)
- 220: CT#43 completed. CT#42 Rel-8 extension to 03/09
- 221: CT#43 completed. WID updated CP-080724=>CP-090018. CT#42 Rel-8 extension to 03/09
- 222: CT#43 completed. SA#39 retained in Rel-8 (in addition to the essential functionality defined in SP-070699). Replaces UID_340037
- 223: SA#40 completed
- 224: SA#40 extension to Sep 2008 (Multiple PDN connections to the same APN using PMIP). SA#41 completed
- 225: CT#41 WID updated CP-080075=>CP-080493. CT#42 completed
- 226: CT#41 WID updated CP-080075=>CP-080493. CT#42 completed
- 227: CT#43 completed. CT#42 Rel-8 extension to 03/09
- 228: SA#40 completed
- 229: SA#42 completed. SA#39 WID updated SP-070933=>SP-080132. WP record created. SA#41 extension granted to Stage 2 UE-ANDSF security (Access Network Discovery and Selection Function)
- 230: CT#42 completed. post-CT#39: split into DSMIP v6 and MIPv4 Access. CT#41 WID updated CP-080075=>CP-080493.
- 231: CT#42 completed. post-CT#39: split into DSMIP v6 and MIPv4 Access. UID_390072->390172. CT#41 WID updated CP-080075=>CP-080493.
- 232: CT#43 completed. CT#42 Rel-8 extension to 03/09
- 233: CT#43 completed. WID updated CP-080724=>CP-090018. CT#42 Rel-8 extension to 03/09. S10, S11. GTP based S5 Interface
- 234: CT#43 completed. WID updated CP-080724=>CP-090018. CT#42 Rel-8 extension to 03/09. S2a, S2b, SWa, STa, SWn (Untrusted IP access - ePDG) interface
- 235: CT#42 completd. CT#43 WID updated CP-080724=>CP-090018.
- 236: CT#42 completd. CT#43 WID updated CP-080724=>CP-090018.
- 237: SA#37 stopped

| ID | WBS | Task | Type | Duration | Start | Finish | Complete | Remaining | Baseline start | Baseline finish | Baseline duration | Total slack | Constraint | Resources | Work | Actual work | Text1 | Text4 | Text5 | Text6 | Text8 | Text2 | Text7 | Text9 | Text12 | Text11 |
| --- | --- | --- | --- | --- | --- | --- | --- | --- | --- | --- | --- | --- | --- | --- | --- | --- | --- | --- | --- | --- | --- | --- | --- | --- | --- | --- |
| 238 | 89.6 | **Single Radio Voice Call Continuity for 3GPP (SRVCC)** |  | 569d? | 2007-01-02 A | 2009-03-06 A | 100% |  | 2007-01-02 | 2009-03-06 | 569d? |  |  | S2,C1,C4 | 10752h | 10752h | SAES-SRVCC | Nokia Siemens Networks | curt.c.wong@nokia.com | Rel-8 | Maurice |  |  |  |  |  |
| 239 | 89.6.1 | Stage 2 for 2G/3G SRVCC |  | 448d? | 2007-01-02 A | 2008-09-18 A | 100% |  | 2007-01-02 | 2008-09-18 | 448d? |  | finish no earlier than 2008-09-15 | S2 | 3584h | 3584h | SAES-SRVCC | Nokia Siemens Networks | curt.c.wong@nokia.com | Rel-8 | Maurice |  |  |  |  |  |
| 240 | 89.6.2 | Stage 3 for SRVCC in EPS |  | 201d? | 2008-05-30 A | 2009-03-06 A | 100% |  | 2008-05-30 | 2009-03-06 | 201d? |  | finish no earlier than 2009-03-06 | C1 | 1608h | 1608h | SAES-SRVCC | Nokia Siemens Networks | robert.zaus@nsn.com | Rel-8 | Frederic | PCG-21 | CP-41 |  |  |  |
| 241 | 89.6.3 | MME to MSC interface for SRVCC |  | 126d? | 2008-09-12 A | 2009-03-06 A | 100% |  | 2008-09-12 | 2009-03-06 | 126d? |  | finish no earlier than 2009-03-06 | C4 | 1008h | 1008h | SAES-SRVCC | Nokia Siemens Networks | Giorgi Gulbani | Rel-8 | Kimmo | PCG-21 | CP-41 |  |  |  |
| 242 | 89.7 | Voice Call Continuity for CDMA2000 1X |  | 249d? | 2007-06-25 A | 2008-06-05 A | 100% |  | 2007-06-25 | 2008-06-05 | 249d? |  | finish no earlier than 2008-06-13 | S2 | 1992h | 1992h | SAES-VCC_1X | Nokia Siemens Networks | balazs.bertenyi@nsn.com | Rel-8 | Maurice |  |  |  |  |  |
| 243 | 89.8 | SAE impacts on IMS |  | 373d? | 2007-01-02 A | 2008-06-05 A | 100% |  | 2007-01-02 | 2008-06-05 | 373d? |  | finish no earlier than 2008-06-13 | S2 | 2984h | 2984h | SAES-SA_IMS | Nokia Siemens Networks | balazs.bertenyi@nsn.com | Rel-8 | Maurice |  |  |  |  |  |
| 244 | 89.9 | **CS Fallback in EPS** |  | 258d? | 2008-03-12 A | 2009-03-06 A | 100% |  | 2008-03-12 | 2009-03-06 | 258d? |  |  | S2,C1,C4 | 4800h | 4800h | SAES-CSFB | T-Mobile, Vodafone | sabine.demel@t-mobile.at, chris.pudney@vodafone.com | Rel-8 | Maurice | PCG-21 | SP-39 |  |  |  |
| 245 | 89.9.1 | Stage 2 for CS Fallback in EPS |  | 62d? | 2008-03-12 A | 2008-06-05 A | 100% |  | 2008-03-12 | 2008-06-05 | 62d? |  | finish no earlier than 2008-12-05 | S2 | 496h | 496h | SAES-CSFB | T-Mobile, Vodafone | sabine.demel@t-mobile.at, chris.pudney@vodafone.com | Rel-8 | Maurice | PCG-21 | SP-40 |  |  |  |
| 246 | 89.9.2 | Stage 3 for CS Fallback in EPS |  | 201d? | 2008-05-30 A | 2009-03-06 A | 100% |  | 2008-05-30 | 2009-03-06 | 201d? |  | finish no earlier than 2009-03-06 | C1 | 1608h | 1608h | SAES-CSFB | NEC | yannick.lair@nectech.fr | Rel-8 | Frederic | PCG-21 | CP-40 |  |  |  |
| 247 | 89.9.3 | Stage 3 for CS Fallback in EPS |  | 136d? | 2008-05-30 A | 2008-12-05 A | 100% |  | 2008-05-30 | 2008-12-05 | 136d? |  | finish no earlier than 2008-12-05 | C4 | 1088h | 1088h | SAES-CSFB | NEC | yannick.lair@nectech.fr | Rel-8 | Kimmo | PCG-21 | CP-40 |  |  |  |
| 248 | 89.10 | System enhancements for the use of IMS services in local breakout |  | 62d? | 2008-03-12 A | 2008-06-05 A | 100% |  | 2008-03-12 | 2008-06-05 | 62d? |  | finish no earlier than 2008-06-05 | S2 | 496h | 496h | SAES-IMS_LBO | Telecom Italia | mario.madella@telecomitalia.it | Rel-8 | Maurice | PCG-21 | SP-39 |  |  |  |
| 249 | 89.11 | **EPC Data Definitions** |  | 309d? | 2008-01-07 A | 2009-03-12 A | 100% |  | 2008-01-07 | 2009-03-12 | 309d? |  |  | S5 | 7144h | 7144h | EPC-OAM |  |  | Rel-8 | Dionisio | PCG-21 | SP-39 |  |  |  |
| 250 | 89.11.1 | EPC Network Resource Model (NRM) Integration Reference Point (IRP) |  | 309d? | 2008-01-07 A | 2009-03-12 A | 100% |  | 2008-01-07 | 2009-03-12 | 309d? |  | finish no earlier than 2009-03-12 | S5 | 2472h | 2472h | EPC-OAM | Huawei | WANG, Xuelong | Rel-8 | Dionisio | PCG-21 | SP-38 |  |  |  |
| 251 | 89.11.2 | Performance measurements for EPC |  | 275d? | 2008-02-22 A | 2009-03-12 A | 100% |  | 2008-02-22 | 2009-03-12 | 275d? |  | finish no earlier than 2009-03-12 | S5 | 2200h | 2200h | EPC-OAM | China Mobile | Li Jian, Liang Shuangchun | Rel-8 | Dionisio | PCG-21 | SP-39 |  |  |  |
| 252 | 89.12 | EPC Charging |  | 309d? | 2008-01-07 A | 2009-03-12 A | 100% |  | 2008-01-07 | 2009-03-12 | 309d? |  | finish no earlier than 2009-03-12 | S5 | 2472h | 2472h | EPC-CH | Nokia Siemens Networks | GÖRMER, Gerald | Rel-8 | Dionisio | PCG-21 | SP-38 |  |  |  |
| 253 | 89.13 | Issues for CT1 TR 24.801 |  | 420d? | 2007-01-04 A | 2008-12-05 A | 100% |  | 2007-01-04 | 2008-12-05 | 420d? |  | finish no earlier than 2008-12-05 | C1 | 3360h | 3360h | SAES | Nokia Siemens Networks | robert.zaus@nsn.com | Rel-8 | Frederic | PCG-21 | CP-39 |  |  |  |
| 254 | 89.14 | Issues for CT3 TR 29.804 |  | 420d? | 2007-02-05 A | 2008-09-12 A | 100% |  | 2007-02-05 | 2008-09-12 | 420d? |  | finish no earlier than 2008-12-12 | C3 | 3360h | 3360h | SAES | Ericsson | j.javier.pastor@ericsson.com | Rel-8 | Gwiho | PCG-21 | CP-39 |  |  |  |
| 255 | 89.15 | Deleted - Issues for CT4 TR 29.803 |  | 420d? | 2007-01-04 A | 2008-09-12 A | 100% |  | 2007-01-04 | 2008-09-12 | 420d? |  | finish no earlier than 2008-12-11 | C4 | 3360h | 3360h | SAES | Huawei |  | Rel-8 | Kimmo | PCG-21 | CP-39 | PCG-21 | CP-41 |  |
| 256 | 89.16 | Domain Name System Procedures for Evolved Packet System (DEPS) |  | 179.75d? | 2008-05-30 A | 2009-03-06 A | 100% |  | 2008-05-30 | 2009-03-06 | 179.75d? |  | finish no earlier than 2009-03-06 | C4 | 1438h | 1438h | SAES-DEPS | TeliaSonera | jouni.korhonen@teliasonera.com | Rel-8 | Kimmo | PCG-21 | CP-40 |  |  |  |
| 257 | 89.17 | InterWorking Function (IWF) between MAP based and Diameter based interfaces |  | 126d? | 2008-09-12 A | 2009-03-06 A | 100% |  | 2008-09-12 | 2009-03-06 | 126d? |  | finish no earlier than 2009-03-06 | C4 | 1008h | 1008h | SAES-MAP2Diam | Huawei | liming49985@huawei.com | Rel-8 | Kimmo | PCG-21 | CP-41 |  |  |  |
| 258 | 89.18 | **CT6 aspects of SAE** |  | 401d? | 2008-03-07 A | 2009-09-18 | 43% | 230.57d? | 2008-03-07 | 2009-09-18 | 401d? | 125d |  | C6 | 3608h | 1960h | SAES | Nokia | Rune Lindholm | Rel-8 | Xavier | PCG-21 | SP-39 |  |  |  |
| 259 | 89.18.1 | CT6 aspects of SAE |  | 206d? | 2008-03-07 A | 2009-05-29 | 85% | 30.9d? | 2008-03-07 | 2009-05-29 | 206d? | 205d | finish no earlier than 2009-05-29 | C6 | 312h | 312h | SAES | Nokia | Rune Lindholm | Rel-8 | Xavier | PCG-21 | SP-39 |  |  | CP-090186 |
| 260 | 89.18.2 | Test interworking of LTE Terminals with the USIM |  | 206d? | 2008-12-05 | 2009-09-18 |  |  | 2008-12-05 | 2009-09-18 | 206d? | 125d | finish no earlier than 2009-09-18 | C6 | 1648h |  | SAES-USIM_LTE-Test | Comprion | Udo Willenbrink | Rel-8 | Xavier | PCG-22 | CP-42 |  |  |  |
| 261 | 89.19 | Deleted (covered by 380068): Functions and procedures for SAE to support LCS | milestone | 0d? | 2008-03-03 A | 2008-03-03 A | 100% |  | 2008-03-03 | 2008-03-03 | 0d? |  | finish no earlier than 2008-03-03 | S2 |  |  | SAES-SA-FP_LCS | Nokia Siemens Networks |  | Rel-8 | Maurice |  |  |  | SP-37 |  |
| 262 | 89.20 | Deleted (covered by 380064): SAE aspects of Emergency Calls | milestone | 0d? | 2008-03-03 A | 2008-03-03 A | 100% |  | 2008-03-03 | 2008-03-03 | 0d? |  | start no earlier than 2008-03-03 | S2 |  |  | SAES-SA-EmCall | Nokia Siemens Networks |  | Rel-8 | Maurice |  |  |  | SP-37 |  |
| 263 | 89.21 | Deleted - CT1 aspects of SAES |  | 16.7d? | 2007-09-04 A | 2007-09-27 A | 100% |  | 2007-09-04 | 2007-09-27 | 16.7d? |  | start no earlier than 2007-09-04 | CP,C1 | 133.62h | 133.62h | SAES-St3 |  |  | Rel-8 | Frederic |  |  |  | SP-37 |  |
| 264 | 89.22 | Deleted - CT1 aspects of SAES | milestone | 0d? | 2007-09-04 A | 2007-09-04 A | 100% |  | 2007-09-04 | 2007-09-04 | 0d? |  | start no earlier than 2007-09-04 | C1 |  |  | SAES-St3 |  |  | Rel-8 | Frederic |  |  |  | SP-37 |  |
| 265 | 89.23 | Deleted - Interoperability | milestone | 0d? | 2008-03-14 A | 2008-03-14 A | 100% |  | 2008-03-14 | 2008-03-14 | 0d? |  | start no earlier than 2008-03-14 | C1 |  |  | SAES-St3-interop |  |  | Rel-8 | Frederic |  |  |  | SP-37 |  |
| 266 | 89.24 | Deleted - CT3 aspects of SAES | milestone | 0d? | 2007-09-04 A | 2007-09-04 A | 100% |  | 2007-09-04 | 2007-09-04 | 0d? |  | start no earlier than 2007-09-04 | C3 |  |  | SAES-St3 |  |  | Rel-8 | Gwiho |  |  |  | SP-37 |  |
| 267 | 89.25 | Deleted - CT4 aspects of SAES | milestone | 0d? | 2007-09-04 A | 2007-09-04 A | 100% |  | 2007-09-04 | 2007-09-04 | 0d? |  | start no earlier than 2007-09-04 | C4 |  |  | SAES-St3 |  |  | Rel-8 | Kimmo |  |  |  | SP-37 |  |
| 268 | 89.26 | Deleted - UE to EPC NAS signalling (incl. MBMS and QoS aspects) | milestone | 0d? | 2008-03-14 A | 2008-03-14 A | 100% |  | 2008-03-14 | 2008-03-14 | 0d? |  | start no earlier than 2008-03-14 | C1 |  |  | SAES-St3-sig |  |  | Rel-8 | Frederic |  |  |  | SP-37 |  |
| 269 | 89.27 | Deleted -User and Control plane protocols | milestone | 0d? | 2007-09-21 A | 2007-09-21 A | 100% |  | 2007-09-21 | 2007-09-21 | 0d? |  | start no earlier than 2007-09-21 | C4 |  |  | SAES-St3-prot |  |  | Rel-8 | Kimmo |  |  |  | SP-37 |  |
| 270 | 89.28 | Deleted - Architecture enhancements for non-3GPP accesses | milestone | 0d? | 2007-09-04 A | 2007-09-04 A | 100% |  | 2007-09-04 | 2007-09-04 | 0d? |  | start no earlier than 2007-09-04 | S2 |  |  | SAES-non_3GPP | Motorola | Irfan.Ali@motorola.com | Rel-8 | Maurice |  |  |  | SP-34 |  |
| 271 | 89.29 | Deleted: Stage 2 of architecture for the 3GPP System Architecture Evolution | milestone | 0d? | 2007-10-02 A | 2007-10-02 A | 100% |  | 2007-10-02 | 2007-10-02 | 0d? |  | start no earlier than 2007-10-02 | S2 |  |  | SAES-St2 | Vodafone | chris.pudney@vodafone.com | Rel-8 | Maurice |  |  |  | SP-34 |  |
| 272 | 89.30 | Deleted - SA aspects of System Architecture Evolution |  | 384d? | 2006-04-12 A | 2007-10-02 A | 100% |  | 2006-04-12 | 2007-10-02 | 384d? |  | finish no earlier than 2007-10-02 | S2 | 3072h | 3072h | SAES-SA |  |  | Rel-8 | Maurice |  |  |  | SP-34 |  |

Notes:
- 238: CT#43 completed. CT#42 Rel-8 extension to 03/09. SA#41 Stage 2 completed. SA#38 WID approved (extract from SAE WID SP-070817).
- 239: SA#41 completed. SA#38 WID approved. SA#40 extension to Sep 2008 for Single Radio VCC: incorporating of results of the RAN HSPA VoIP to CS alignment work. / Text3: 23.216
- 240: CT#43 completed. CT#42 Rel-8 extension to 03/09 / Text3: 23.009, 24.008, 24.301
- 241: CT#43 completed. CT#42 Rel-8 extension to 03/09 / Text3: 29.274, 29.277, 23.003, 23.008, 29.280
- 242: SA#40 completed
- 243: SA#40 completed
- 244: CT#43 completed. CT#42 Rel-8 extension to 03/09. SA#40 Stage 2 completed.
- 245: SA#40 completed / Text3: 23.272, 23.401
- 246: CT#43 completed. CT#42 Rel-8 extension to 03/09 / Text3: 24.301, 24.801, 24.007, 24.008, 24.011, 29.018, 29.118 [Mobility Management Entity (MME) – Visitor Location Register (VLR) SGs interface specification]
- 247: CT#42 completed. WID updated CP-080321=>CP-080495=>CP-080791 / Text3: 23.007, 23.008, 29.274, 29.277
- 248: SA#40 completed / Text3: 23.228, 23.221, 23.203
- 249: SA#43 completed
- 250: SA#43 completed. SA#42 Rel-8 extension to 03/09 / Text3: 32.751, 32.752, 32.753, 32.755
- 251: SA#43 completed. SA#42 Rel-8 extension to 03/09 / Text3: 32.426
- 252: SA#43 completed. SA#42 Rel-8 extension to 03/09 / Text3: 32.240/296/251/252/298/299
- 253: CT#43 completed / Text3: 24.801
- 254: CT#41 completed / Text3: 29.804
- 255: CT#41 Work stopped and continued in Normative specifications / Text3: 29.803
- 256: CT#43 completed. CT#42 Rel-8 extension to 03/09 / Text3: 23.003, 29.303
- 257: CT#43 completed. CT#42 Rel-8 extension to 03/09. Triggered by UID_ 380023 (FS_MAP2Diam) / Text3: 29.305
- 258: CT#43 Rel-8 further extension 03/09=>05/09 (CP-090186). CT#42 Rel-8 extension to 03/09.
- 259: CT#43 Rel-8 further extension 03/09=>05/09 (CP-090186) / Text3: 31.102, 31.111
- 260: Testing for UID_390021 (BB: Rel-8 CT6 aspects of SAE) / Text3: 31.xyz (USIM application interworking with E-UTRA/EPC test specification)
- 261: SA#37 stopped
- 262: SA#37 stopped
- 263: SA#37 stopped
- 264: SA#37 stopped
- 265: SA#37 stopped
- 266: SA#37 stopped
- 267: SA#37 stopped / Text3: 29.803
- 268: SA#37 stopped
- 269: SA#37 stopped
- 270: SA#34 stopped. Replaced by UID_350027 and its children / Text3: 23.402
- 271: SA#34 stopped. Replaced by UIDs 340018 and 340037. (SA#34 report discussion of SP-060917.) / Text3: 23.002, 23.060, 23.107, 23.203, 23.228, 23.234, 23.246, 23.271, 23.279
- 272: SA#34 stopped

| ID | WBS | Task | Duration | Start | Finish | Complete | Baseline start | Baseline finish | Baseline duration | Constraint | Resources | Work | Actual work | Text1 | Text4 | Text5 | Text6 | Text7 | Text8 | Text2 | Text9 | Text12 |
| --- | --- | --- | --- | --- | --- | --- | --- | --- | --- | --- | --- | --- | --- | --- | --- | --- | --- | --- | --- | --- | --- | --- |
| 273 | 90 | **IMS Centralized Service Control (ICSRA)** | 395d? | 2007-09-03 A | 2009-03-06 A | 100% | 2007-09-03 | 2009-03-06 | 395d? |  | S1,S2,C1,C3,C4 | 9072h | 9072h | ICSRA | AT&T | Randolph Wohlert (rwohlert@tri.sbc.com) | Rel-8 | SP-37 | Alain |  |  |  |
| 274 | 90.1 | Stage 1 for ICSRA | 138d? | 2007-09-03 A | 2008-03-12 A | 100% | 2007-09-03 | 2008-03-12 | 138d? | finish no earlier than 2007-12-14 | S1 | 1104h | 1104h | ICSRA | AT&T | Randolph Wohlert (rwohlert@tri.sbc.com) | Rel-8 | SP-38 | Alain | PCG-21 |  |  |
| 275 | 90.2 | Stage 2 for ICSRA | 125d? | 2007-12-14 A | 2008-06-05 A | 100% | 2007-12-14 | 2008-06-05 | 125d? | start no earlier than 2007-12-14 | S2 | 1000h | 1000h | ICSRA-St2 | Alcatel-Lucent |  | Rel-8 | SP-38 | Maurice | PCG-21 |  |  |
| 276 | 90.3 | Stage 3 for ICSRA – Protocol, Addressing, Subscriber Data | 201d? | 2008-05-30 A | 2009-03-06 A | 100% | 2008-05-30 | 2009-03-06 | 201d? | finish no earlier than 2009-03-06 | C1 | 1608h | 1608h | ICSRA | Ericsson | Sean Schneyer | Rel-8 | CP-40 | Frederic | PCG-21 |  |  |
| 277 | 90.4 | Deleted - Stage 3 for ICSRA – I1 interface | 76d? | 2008-05-30 A | 2008-09-12 A | 100% | 2008-05-30 | 2008-09-12 | 76d? | finish no earlier than 2008-09-12 | C1 | 608h | 608h | ICSRA | Huawei | xupeili@huawei.com | Rel-8 | CP-40 | Frederic | PCG-21 | PCG-21 | CP-41 |
| 278 | 90.5 | Stage 3 for ICSRA – Protocol, Addressing, Subscriber Data | 201d? | 2008-05-30 A | 2009-03-06 A | 100% | 2008-05-30 | 2009-03-06 | 201d? | finish no earlier than 2009-03-06 | C3 | 1608h | 1608h | ICSRA | Mavenir | Brett Wallis | Rel-8 | CP-40 | Gwiho | PCG-21 |  |  |
| 279 | 90.6 | Stage 3 for ICSRA – Protocol, Addressing, Subscriber Data | 136d? | 2008-05-30 A | 2008-12-05 A | 100% | 2008-05-30 | 2008-12-05 | 136d? | start no earlier than 2008-05-30 | C4 | 1088h | 1088h | ICSRA | Ericsson | Sean Schneyer | Rel-8 | CP-40 | Kimmo | PCG-21 |  |  |
| 280 | 91 | **IMS Multimedia Telephony and Supplementary Services** | 487d? | 2007-05-02 A | 2009-03-12 A | 100% | 2007-05-02 | 2009-03-12 | 487d? |  | S1,S5,C1,C3,C4 | 46006.4h | 46006.4h | IMSTSS |  |  | Rel-8 | SP-37 | Alain |  |  |  |
| 281 | 91.1 | **General aspects of IMS Sup Services** | 395d? | 2007-09-03 A | 2009-03-06 A | 100% | 2007-09-03 | 2009-03-06 | 395d? |  | S1,C1,C3,C4 | 9752h | 9752h | IMSSS-Gal | Ericsson | Susana Sabater | Rel-8 | SP-37 | Alain |  |  |  |
| 282 | 91.1.1 | Service and Capability for Core IMS - inclusion of TISPAN requirements | 75d? | 2007-09-03 A | 2007-12-14 A | 100% | 2007-09-03 | 2007-12-14 | 75d? | finish no earlier than 2007-12-14 | S1 | 600h | 600h | TISCAPR8 | Ericsson | Susana Sabater | Rel-8 | SP-37 | Alain |  |  |  |
| 283 | 91.1.2 | Documentation of TISPAN R1 and R2 in CT1 | 208d? | 2007-11-28 A | 2008-09-12 A | 100% | 2007-11-28 | 2008-09-12 | 208d? | finish no earlier than 2008-09-12 | C1 | 1664h | 1664h | REDOC_TIS-C1 | Nokia Siemens Networks | peter.leis@nsn.com | Rel-8 | SP-38 | Frederic | PCG-21 |  |  |
| 284 | 91.1.3 | Documentation of TISPAN R1 and R2 in CT3 | 333d? | 2007-11-28 A | 2009-03-06 A | 100% | 2007-11-28 | 2009-03-06 | 333d? | finish no earlier than 2009-03-06 | C3 | 2664h | 2664h | REDOC_TIS-C3 | Nokia Siemens Networks | peter.leis@nsn.com | Rel-8 | SP-38 | Gwiho | PCG-21 |  |  |
| 285 | 91.1.4 | Documentation of TISPAN R1 and R2 in CT4 | 208d? | 2007-11-28 A | 2008-09-12 A | 100% | 2007-11-28 | 2008-09-12 | 208d? | finish no earlier than 2008-09-12 | C4 | 1664h | 1664h | REDOC_TIS-C4 | Nokia Siemens Networks | peter.leis@nsn.com | Rel-8 | SP-38 | Kimmo | PCG-21 |  |  |
| 286 | 91.2 | **IMS Multimedia Telephony Service** | 394d? | 2007-09-10 A | 2009-03-12 A | 100% | 2007-09-10 | 2009-03-12 | 394d? |  | S1,S5 | 5096h | 5096h | IMS-MMTel |  |  | Rel-8 | SP-37 | Alain |  |  |  |
| 287 | 91.2.1 | Merging TISPAN MMTel [requirements] for Common IMS | 65d? | 2007-09-10 A | 2007-12-07 A | 100% | 2007-09-10 | 2007-12-07 | 65d? | finish no earlier than 2007-12-07 | S1 | 520h | 520h | TMMTEL | Nokia Siemens Networks |  | Rel-8 | SP-37 | Alain |  |  |  |
| 288 | 91.2.2 | Multimedia Telephony Service and Supplementary Services (MMTel) offline Charging | 309d? | 2008-01-07 A | 2009-03-12 A | 100% | 2008-01-07 | 2009-03-12 | 309d? | finish no earlier than 2009-03-12 | S5 | 2472h | 2472h | MMTel-CH | Alcatel-Lucent | GARDELLA, Maryse | Rel-8 | SP-38 | Dionisio | PCG-21 |  |  |
| 289 | 91.3 | **Call Completion on Busy Subscriber (CCBS)/Call Completion on Non-Reachable (CCNR) on IMS** | 483d? | 2007-05-02 A | 2009-03-06 A | 100% | 2007-05-02 | 2009-03-06 | 483d? |  | C1,C3 | 11072h | 11072h | CCBS_CCNR | Deutsche Telekom | martin.huelsemann@telekom.de | Rel-8 | SP-38 | Frederic | PCG-21 |  |  |
| 290 | 91.3.1 | Stage 3 CCBS_CCNR | 483d? | 2007-05-02 A | 2009-03-06 A | 100% | 2007-05-02 | 2009-03-06 | 483d? | finish no earlier than 2009-03-06 | C1 | 3864h | 3864h | CCBS_CCNR | Deutsche Telekom | martin.huelsemann@telekom.de | Rel-8 | SP-38 | Frederic | PCG-21 |  |  |
| 291 | 91.3.2 | Stage 3 CCBS_CCNR | 418d? | 2007-05-02 A | 2008-12-05 A | 100% | 2007-05-02 | 2008-12-05 | 418d? | finish no earlier than 2008-12-05 | C3 | 3344h | 3344h | CCBS_CCNR | Deutsche Telekom | martin.huelsemann@telekom.de | Rel-8 | SP-38 | Gwiho | PCG-21 |  |  |
| 292 | 91.4 | **Flexible Alerting** | 288d? | 2008-01-30 A | 2009-03-06 A | 100% | 2008-01-30 | 2009-03-06 | 288d? |  | S1,C1 | 5278.4h | 5278.4h | FA | Nortel | milanpa@nortel.com | Rel-8 | SP-39 | Alain | PCG-21 |  |  |
| 293 | 91.4.1 | Stage 1 FA | 92d? | 2008-01-30 A | 2008-06-05 A | 100% | 2008-01-30 | 2008-06-05 | 92d? |  | S1 | 670.4h | 670.4h | FA | Telecom Italia |  | Rel-8 | SP-39 | Alain | PCG-21 |  |  |
| 294 | 91.4.2 | Stage 3 FA | 288d? | 2008-01-30 A | 2009-03-06 A | 100% | 2008-01-30 | 2009-03-06 | 288d? | finish no earlier than 2009-03-06 | C1 | 2304h | 2304h | FA | Nortel | milanpa@nortel.com | Rel-8 | SP-39 | Frederic | PCG-21 |  |  |
| 295 | 91.5 | **Communication Wait on IMS** | 331d? | 2007-11-30 A | 2009-03-06 A | 100% | 2007-11-30 | 2009-03-06 | 331d? |  | C1,C3 | 7416h | 7416h | CW_IMS | Deutsche Telekom | martin.huelsemann@telekom.de | Rel-8 | SP-38 | Frederic | PCG-21 |  |  |
| 296 | 91.5.1 | Stage 3 CW-IMS | 331d? | 2007-11-30 A | 2009-03-06 A | 100% | 2007-11-30 | 2009-03-06 | 331d? | finish no earlier than 2009-03-06 | C1 | 2648h | 2648h | CW_IMS | Deutsche Telekom | martin.huelsemann@telekom.de | Rel-8 | SP-38 | Frederic | PCG-21 |  |  |
| 297 | 91.5.2 | Stage 3 CW-IMS | 265d? | 2007-11-30 A | 2008-12-05 A | 100% | 2007-11-30 | 2008-12-05 | 265d? | finish no earlier than 2008-12-05 | C3 | 2120h | 2120h | CW_IMS | Deutsche Telekom | martin.huelsemann@telekom.de | Rel-8 | SP-38 | Gwiho | PCG-21 |  |  |
| 298 | 91.6 | Advice of Charge (AoC) support in IMS Charging | 309d? | 2008-01-07 A | 2009-03-12 A | 100% | 2008-01-07 | 2009-03-12 | 309d? | finish no earlier than 2009-03-12 | S5 | 2472h | 2472h | IMSTSS | Nokia Siemens Networks | GÖRMER, Gerald | Rel-8 | SP-38 | Dionisio | PCG-21 |  |  |
| 299 | 91.7 | Add Interconnection Border Control Function (IBCF) to IMS Charging | 128d? | 2007-09-17 A | 2008-03-12 A | 100% | 2007-09-17 | 2008-03-12 | 128d? | finish no earlier than 2008-03-12 | S5 | 1024h | 1024h | IMSTSS | Alcatel-Lucent | GARDELLA, Maryse | Rel-8 | SP-37 | Dionisio |  |  |  |

Notes:
- 273: CT#43 completed. SA#40 SA1/2 completed. CT#40 WID approved.
- 274: SA#38 WID approved. SA#39 completed / Text3: 22.101
- 275: SA#38 WID approved. SA#40 completed / Text3: 23.292, 23.206
- 276: CT#43 completed. CT#42 Rel-8 extension to 03/09 / Text3: 24.292, 24.229
- 277: 23/07/08 Line created at CT1 Zagreb request. CT#41 WID updated CP-080319=>CP-080492. CT#41 work stopped / Text3: 24.293
- 278: CT#43 completed. CT#42 Rel-8 extension to 03/09 / Text3: 29.292
- 279: CT#42 completed. CT#41 WID updated CP-080319=>CP-080492. / Text3: 23.003, 29.232, 23.018, 29.002
- 280: SA#43 completed
- 281: CT#43 completed
- 282: SA#39 completed / Text3: 22.228, 22.115, 22.101
- 283: CT#41 completed / Text3: 24.141, 24.147, 24.173, 24.229, 24.247, 24.341, 24.604, 24.605, 24.606, 24.607, 24.608, 24.610, 24.611, 24.616, 24.623, 24.628, 24.629, 24.647, 24.654
- 284: CT#43 completed. CT#42 Rel-8 extension to 03/09 / Text3: 29.162, 29.163, 29.658
- 285: CT#41 completed / Text3: 29.228, 29.229
- 286: SA#43 completed
- 287: SA#38 completed / Text3: 22.173
- 288: SA#43 completed. SA#42 Rel-8 extension to 03/09 / Text3: 32.275, 32.298/299
- 289: CT#43 completed
- 290: CT#43 completed. CT#42 Rel-8 extension to 03/09 / Text3: 24.642, 24.229, 24.173
- 291: CT#42 completed / Text3: 29.163
- 292: CT#43 completed
- 293: SA#40 completed / Text3: 22.173
- 294: CT#43 completed. CT#42 Rel-8 extension to 03/09 / Text3: 24.239, 24.173
- 295: CT#43 completed
- 296: CT#43 completed. CT#42 Rel-8 extension to 03/09 / Text3: 24.615, 24.229, 24.173
- 297: CT#42 completed / Text3: 29.163
- 298: SA#43 completed. SA#42 Rel-8 extension to 03/09 / Text3: 32.280, 32.240/260/296/298/299
- 299: SA#39 completed / Text3: 32.260, 32.298

| ID | WBS | Task | Duration | Start | Finish | Complete | Remaining | Baseline start | Baseline finish | Baseline duration | Total slack | Constraint | Resources | Work | Actual work | Text1 | Text2 | Text4 | Text5 | Text6 | Text7 | Text8 |
| --- | --- | --- | --- | --- | --- | --- | --- | --- | --- | --- | --- | --- | --- | --- | --- | --- | --- | --- | --- | --- | --- | --- |
| 300 | 92 | **3GPP2 Input to Common IMS** | 200d? | 2008-03-07 A | 2008-12-11 A | 100% |  | 2008-03-07 | 2008-12-11 | 200d? |  |  | S1,S2,S3,C1,C3,C4 | 8653.2h | 8653.2h | CIMS_3GPP2 | PCG-21 | Nortel | Amar Deol (deola@nortelnetworks.com) | Rel-8 | SP-39 | Alain |
| 301 | 92.1 | Stage 1 CIMS_3GPP2 (SA1) | 30.65d? | 2008-03-12 A | 2008-06-05 A | 100% |  | 2008-03-12 | 2008-06-05 | 30.65d? |  | finish no earlier than 2008-06-12 | S1 | 245.2h | 245.2h | CIMS_3GPP2 | PCG-21 | Nortel | Amar Deol (deola@nortelnetworks.com) | Rel-8 | SP-39 | Alain |
| 302 | 92.2 | Stage 2 CIMS_3GPP2 (SA2) | 62d? | 2008-03-12 A | 2008-06-05 A | 100% |  | 2008-03-12 | 2008-06-05 | 62d? |  | finish no earlier than 2008-09-11 | S2 | 496h | 496h | IMS_Common | PCG-21 | Nortel | Amar Deol (deola@nortelnetworks.com) | Rel-8 | SP-39 | Maurice |
| 303 | 92.3 | Security CIMS_3GPP2 (SA3) | 197d? | 2008-03-12 A | 2008-12-11 A | 100% |  | 2008-03-12 | 2008-12-11 | 197d? |  | finish no earlier than 2008-12-11 | S3 | 1576h | 1576h | IMS_Common | PCG-21 | Nortel | Amar Deol (deola@nortelnetworks.com) | Rel-8 | SP-39 | Dionisio |
| 304 | 92.4 | Stage 3 CIMS_3GPP2 (CT1) | 196d? | 2008-03-07 A | 2008-12-05 A | 100% |  | 2008-03-07 | 2008-12-05 | 196d? |  | finish no earlier than 2008-12-11 | C1 | 1568h | 1568h | REDOC_3GPP2 | PCG-21 | Alcatel-Lucent | orsic@alcatel-lucent.com | Rel-8 | SP-39 | Frederic |
| 305 | 92.5 | Stage 3 CIMS_3GPP2 (CT3) | 196d? | 2008-03-07 A | 2008-12-05 A | 100% |  | 2008-03-07 | 2008-12-05 | 196d? |  | finish no earlier than 2008-12-05 | C3 | 1568h | 1568h | REDOC_3GPP2 | PCG-21 | Alcatel-Lucent | orsic@alcatel-lucent.com | Rel-8 | SP-39 | Gwiho |
| 306 | 92.6 | Stage 3 CIMS_3GPP2 (CT4) | 200d? | 2008-03-07 A | 2008-12-11 A | 100% |  | 2008-03-07 | 2008-12-11 | 200d? |  | finish no earlier than 2008-12-11 | C4 | 1600h | 1600h | REDOC_3GPP2 | PCG-21 | Alcatel-Lucent | orsic@alcatel-lucent.com | Rel-8 | SP-39 | Kimmo |
| 307 | 93 | **IMS Enhancements for support of Packet Cable access** | 388d? | 2006-12-06 A | 2008-05-30 A | 100% |  | 2006-12-06 | 2008-05-30 | 388d? |  |  | S2,S3,C1,C3,C4 | 27448h | 27448h | PktCbl |  | Cablelabs | Bernie McKibben | Rel-8 |  | Maurice |
| 308 | 93.1 | **IMS Enhancements for Cable Client Types and Deployment Models** | 345d? | 2007-02-05 A | 2008-05-30 A | 100% |  | 2007-02-05 | 2008-05-30 | 345d? |  |  | S2,C1 | 6992h | 6992h | PktCbl-Deploy |  | Cablelabs | Bernie McKibben | Rel-8 |  | Maurice |
| 309 | 93.1.1 | Architecture aspects of PktCbl-Deploy | 219d? | 2007-02-05 A | 2007-12-06 A | 100% |  | 2007-02-05 | 2007-12-06 | 219d? |  | finish no earlier than 2007-12-03 | S2 | 1752h | 1752h | PktCbl-Deploy |  | Cablelabs | Bernie McKibben | Rel-8 |  | Maurice |
| 310 | 93.1.2 | CT1 aspects of PktCbl-Deploy | 310d? | 2007-03-26 A | 2008-05-30 A | 100% |  | 2007-03-26 | 2008-05-30 | 310d? |  | finish no earlier than 2008-06-15 | C1 | 2480h | 2480h | PktCbl-Deploy |  | Cablelabs | D.Hancock@ CableLabs.com | Rel-8 |  | Frederic |
| 311 | 93.2 | **IMS Inter-working aspects in Support of Cable Regulatory requirements** | 290d? | 2007-02-05 A | 2008-03-15 A | 100% |  | 2007-02-05 | 2008-03-15 | 290d? |  |  | S2,C1,C3 | 5640h | 5640h | PktCbl-Intw |  | Cablelabs | B.McKibben@CableLabs.com | Rel-8 |  | Maurice |
| 312 | 93.2.1 | Architecture PktCbl-Interwork | 160d? | 2007-02-05 A | 2007-09-14 A | 100% |  | 2007-02-05 | 2007-09-14 | 160d? |  | start no earlier than 2007-02-05 | S2 | 1280h | 1280h | PktCbl-Intw |  | Cablelabs | B.McKibben@CableLabs.com | Rel-8 |  | Maurice |
| 313 | 93.2.2 | CT1,CT3 PktCbl-Interwork | 255d? | 2007-03-26 A | 2008-03-15 A | 100% |  | 2007-03-26 | 2008-03-15 | 255d? |  | finish no earlier than 2008-03-15 | C1,C3 | 2040h | 2040h | PktCbl-Intw |  | Cablelabs | D.Hancock@ CableLabs.com | Rel-8 |  | Frederic |
| 314 | 93.3 | **IMS Enhancements for Security Requirements in Support of Cable Deployments** | 388d? | 2006-12-06 A | 2008-05-30 A | 100% |  | 2006-12-06 | 2008-05-30 | 388d? |  |  | S3,C1,C3,C4 | 11712h | 11712h | PktCbl-Sec |  | Cablelabs | s.dotson@cablelabs.com | Rel-8 |  | Dionisio |
| 315 | 93.3.1 | SA3 Aspects of PktCbl-Sec | 331d? | 2006-12-06 A | 2008-03-12 A | 100% |  | 2006-12-06 | 2008-03-12 | 331d? |  | finish no earlier than 2007-12-20 | S3 | 2648h | 2648h | PktCbl-Sec |  | Cablelabs | s.dotson@cablelabs.com | Rel-8 |  | Dionisio |
| 316 | 93.3.2 | CT1 Aspects of PktCbl-Sec | 310d? | 2007-03-26 A | 2008-05-30 A | 100% |  | 2007-03-26 | 2008-05-30 | 310d? |  | finish no earlier than 2008-06-06 | C1 | 2480h | 2480h | PktCbl-Sec |  | Cablelabs | D.Hancock@ CableLabs.com | Rel-8 |  | Frederic |
| 317 | 93.3.3 | CT3 Aspects of PktCbl-Sec | 180d? | 2007-03-26 A | 2007-11-30 A | 100% |  | 2007-03-26 | 2007-11-30 | 180d? |  | finish no earlier than 2008-03-15 | C3 | 1440h | 1440h | PktCbl-Intw | PCG-21 | Cablelabs | D.Hancock@ CableLabs.com | Rel-8 | SP-38 | Gwiho |
| 318 | 93.3.4 | CT4 Aspects of PktCbl-Sec | 255d? | 2007-03-26 A | 2008-03-14 A | 100% |  | 2007-03-26 | 2008-03-14 | 255d? |  | finish no earlier than 2008-03-14 | C4 | 2040h | 2040h | PktCbl-Sec |  | Cablelabs | D.Hancock@ CableLabs.com | Rel-8 |  | Kimmo |
| 319 | 94 | **IMS System enhancements for corporate network access** | 506d? | 2007-06-22 A | 2009-05-29 | 93% | 37.53d? | 2007-06-22 | 2009-05-29 | 506d? | 205d |  | S2,S1,C1,C4 | 10972.8h | 6885.2h | IMS_Corp |  | Orange | Delphin Barankanira | Rel-8 |  | Maurice |
| 320 | 94.1 | SA1 aspects of IMS_Corp | 23.6d? | 2008-03-12 A | 2008-06-05 A | 100% |  | 2008-03-12 | 2008-06-05 | 23.6d? |  | finish no earlier than 2008-06-05 | S1 | 188.8h | 188.8h | IMS_Corp | PCG-21 | Telecom Italia |  | Rel-8 | SP-39 | Alain |
| 321 | 94.2 | SA2 aspects of IMS_Corp | 325d? | 2007-06-22 A | 2008-09-18 A | 100% |  | 2007-06-22 | 2008-09-18 | 325d? |  | finish no earlier than 2008-12-25 | S2 | 2600h | 2600h | IMS_Corp |  | Orange | Delphin Barankanira | Rel-8 |  | Maurice |
| 322 | 94.3 | CT1 aspects of IMS_Corp | 321d? | 2008-03-07 A | 2009-05-29 | 80% | 64.2d? | 2008-03-07 | 2009-05-29 | 321d? | 205d | finish no earlier than 2009-05-29 | C1 | 2568h | 2054.4h | IMS_Corp | PCG-21 | Alcatel-Lucent | Keith Drage (drage@alcatel-lucent.com) | Rel-8 | SP-39 | Frederic |
| 323 | 94.4 | CT4 aspects of IMS_Corp | 196d? | 2008-02-26 A | 2008-12-05 A | 100% |  | 2008-02-26 | 2008-12-05 | 196d? |  | finish no earlier than 2008-12-11 | C4 | 1568h | 1568h | IMS_Corp | PCG-21 | Alcatel-Lucent | Keith Drage (drage@alcatel-lucent.com) | Rel-8 | SP-39 | Kimmo |

Notes:
- 300: TSG#42 completed
- 301: SA#40 completed / Text3: 22.228, 22.173, 22.101, 22.153
- 302: SA#40 completed / Text3: 23.002, 23.141, 23.203, 23.167, 23.228
- 303: SA#42 completed [issues addressed under UID_370078 (IMS-Sec)] / Text3: 33.141, 33.203, 33.210
- 304: CT#42 completed. WID updated CP-080218=>CP-080494=>CP-080795 / Text3: 23.218, 24.141, 24.147, 24.173, 24.229, 24.238, 24.247, 24.604, 24.605, 24.606, 24.607, 24.608, 24.610, 24.611, 24.629, 24.930
- 305: CT#42 completed. WID updated CP-080218=>CP-080494=>CP-080795 / Text3: 29.163, 29.212, 29.213, 29.214
- 306: CT#42 completed. WID updated CP-080218=>CP-080494=>CP-080795 / Text3: 29.228, 29.229, 29.328, 29.329
- 307: CT#40 completed
- 308: CT#40 completed
- 309: SA#38 completed / Text3: 23.228
- 310: CT#40 completed
- 311: CT#39 completed
- 312: SA#37 completed / Text3: 23.228
- 313: CT#39 completed / Text3: 24.229
- 314: CT#40 completed
- 315: SA#39 completed / Text3: 33.203, 33.210, 33.220
- 316: CT#40 completed / Text3: 24.229
- 317: CT#38 completed / Text3: 29.163
- 318: CT#39 completed / Text3: 29.228, 29.229, 23.008
- 319: CT#43 Rel-8 further extension 03/09=>05/09 (no extension sheet needed). SA#41 work completed (No Stage 2 impacts identified by Joint Workshop)
- 320: SA#40 completed
- 321: SA#41 completed / Text3: 23.228
- 322: CT#43 Rel-8 further extension 03/09=>05/09 (no extension sheet needed) / Text3: 24.229, 24.503
- 323: CT#42 completed / Text3: 29.228, 29.229, 23.003, 23.008, 29.433

| ID | WBS | Task | Duration | Start | Finish | Complete | Remaining | Baseline start | Baseline finish | Baseline duration | Total slack | Constraint | Resources | Work | Actual work | Text1 | Text2 | Text7 | Text8 | Text4 | Text5 | Text6 |
| --- | --- | --- | --- | --- | --- | --- | --- | --- | --- | --- | --- | --- | --- | --- | --- | --- | --- | --- | --- | --- | --- | --- |
| 324 | 95 | **Maintenance of TISPAN documentation** | 244d? | 2007-07-02 A | 2008-06-05 A | 100% |  | 2007-07-02 | 2008-06-05 | 244d? |  |  | S2,C1,C3,C4 | 5984h | 5984h | MAINTISP | PCG-21 | SP-38 | Maurice |  |  |  |
| 325 | 95.1 | Maintenance of TISPAN R1 | 86d? | 2007-11-09 A | 2008-03-07 A | 100% |  | 2007-11-09 | 2008-03-07 | 86d? |  | start no earlier than 2007-11-09 | C1,C3,C4 | 688h | 688h | MAINT_R1 | PCG-21 | SP-38 | Frederic | Alcatel-Lucent | Keith Drage (drage@alcatel-lucent.com) | Rel-7 |
| 326 | 95.2 | Maintenance of TISPAN R2 | 86d? | 2007-11-09 A | 2008-03-07 A | 100% |  | 2007-11-09 | 2008-03-07 | 86d? |  | start no earlier than 2007-11-09 | C1,C3,C4 | 688h | 688h | MAINT_R2 | PCG-21 | SP-38 | Frederic | Alcatel-Lucent | Keith Drage (drage@alcatel-lucent.com) | Rel-8 |
| 327 | 95.3 | Documentation of TISPAN NGN R1 and R2 in 3GPP SA2 | 104d? | 2008-01-14 A | 2008-06-05 A | 100% |  | 2008-01-14 | 2008-06-05 | 104d? |  | finish no earlier than 2008-06-20 | S2 | 832h | 832h | IMS_Comm_Doc | PCG-21 | SP-38 | Maurice | Nokia Siemens Networks | jozsef.varga@nsn.com | Rel-8 |
| 328 | 95.4 | Maintenance of TISPAN release 1 common IMS | 114d? | 2007-07-02 A | 2007-12-06 A | 100% |  | 2007-07-02 | 2007-12-06 | 114d? |  | finish no earlier than 2007-12-06 | S2,S1 | 912h | 912h | IMS_Comm_Mtce7 | PCG-21 | SP-38 | Maurice | BT, Ericsson | Dick Knight, Raymond Forbes | Rel-7 |
| 329 | 95.5 | Maintenance of TISPAN release 2 common IMS | 114d? | 2007-07-02 A | 2007-12-06 A | 100% |  | 2007-07-02 | 2007-12-06 | 114d? |  | finish no earlier than 2007-12-06 | S2 | 912h | 912h | IMS_Comm_Mtce8 | PCG-21 | SP-38 | Maurice | Telecom Italia | antonio.ascolese@telecomitalia.it | Rel-8 |
| 330 | 96 | **IMS Service Continuity** | 318d? | 2008-03-12 A | 2009-05-29 | 99% | 4.31d? | 2008-03-12 | 2009-05-29 | 318d? | 205d |  | S2,S1,C1 | 5624h | 5547.76h | IMS-Cont | PCG-21 | SP-39 | Maurice | LG Electronics | JaeSeung SONG (anthonys@lge.com) | Rel-8 |
| 331 | 96.1 | Stage 1 IMS Service Continuity | 62d? | 2008-03-12 A | 2008-06-05 A | 100% |  | 2008-03-12 | 2008-06-05 | 62d? |  | start no earlier than 2008-03-12 | S1 | 496h | 496h | IMS-Cont | PCG-21 | SP-39 | Alain | LG Electronics | JaeSeung SONG (anthonys@lge.com) | Rel-8 |
| 332 | 96.2 | Stage 2 IMS Service Continuity | 62d? | 2008-03-12 A | 2008-06-05 A | 100% |  | 2008-03-12 | 2008-06-05 | 62d? |  | finish no earlier than 2008-06-05 | S2 | 496h | 496h | IMS-Cont | PCG-21 | SP-39 | Maurice | LG Electronics | JaeSeung SONG (anthonys@lge.com) | Rel-8 |
| 333 | 96.3 | Stage 3 IMS Service Continuity | 261d? | 2008-05-30 A | 2009-05-29 | 98% | 5.22d? | 2008-05-30 | 2009-05-29 | 261d? | 205d | finish no earlier than 2009-05-29 | C1 | 2088h | 2046.24h | IMS-Cont | PCG-21 | SP-40 | Frederic | Huawei | Lili Yang (kadyyang@huawei.com) | Rel-8 |
| 334 | 97 | **Security Enhancements for IMS** | 643.3d? | 2006-09-19 A | 2009-03-06 A | 100% |  | 2006-09-19 | 2009-03-06 | 643.3d? |  |  | S3,C1,C4 | 18624h | 18624h | IMS-Sec |  | SP-37 | Dionisio | Ericsson | Bengt.Sahlin@ericsson.com | Rel-8 |
| 335 | 97.1 | Stage 2 for IMS-Sec | 466d? | 2007-03-01 A | 2008-12-11 A | 100% |  | 2007-03-01 | 2008-12-11 | 466d? |  | finish no earlier than 2008-12-11 | S3 | 3728h | 3728h | IMS-Sec |  |  | Dionisio | Ericsson | Bengt.Sahlin@ericsson.com | Rel-8 |
| 336 | 97.2 | CT1 part of Stage 3 for IMS-Sec | 392d? | 2006-09-19 A | 2008-12-05 A | 100% |  | 2006-09-19 | 2008-12-05 | 392d? |  | finish no earlier than 2008-12-05 | C1 | 3136h | 3136h | IMS-Sec | PCG-21 | SP-39 | Frederic | Ericsson |  | Rel-8 |
| 337 | 97.3 | CT4 part of Stage 3 for IMS-Sec | 457d? | 2007-06-07 A | 2009-03-06 A | 100% |  | 2007-06-07 | 2009-03-06 | 457d? |  | finish no earlier than 2009-03-06 | C4 | 3656h | 3656h | IMS-Sec | PCG-21 | SP-39 | Kimmo | Ericsson |  | Rel-8 |
| 338 | 97.4 | CT1 part of NASS Bundled Authentication | 343d? | 2007-11-14 A | 2009-03-06 A | 100% |  | 2007-11-14 | 2009-03-06 | 343d? |  | finish no earlier than 2009-03-06 | C1 | 2744h | 2744h | NBA | PCG-21 | SP-38 | Frederic | Alcatel-Lucent | Keith Drage (drage@alcatel-lucent.com) | Rel-8 |
| 339 | 97.5 | CT4 part of NASS Bundled Authentication | 143d? | 2007-11-14 A | 2008-05-30 A | 100% |  | 2007-11-14 | 2008-05-30 | 143d? |  | start no earlier than 2007-11-14 | C4 | 1144h | 1144h | NBA-CT4 | PCG-21 | SP-38 | Kimmo | Alcatel-Lucent |  | Rel-8 |
| 340 | 98 | IMS initiated and controlled PSS and MBMS User Service | 262d? | 2008-03-12 A | 2009-03-12 A | 100% |  | 2008-03-12 | 2009-03-12 | 262d? |  | finish no earlier than 2009-03-12 | S4,S3 | 1003.2h | 1003.2h | IMS_PSS_MBMS_US |  |  | Paolo | FT, Ericsson | olle.franceschi@ericsson.com | Rel-8 |
| 341 | 99 | **Multimedia interworking between IMS and CS networks** | 836d? | 2005-09-23 A | 2008-12-05 A | 100% |  | 2005-09-23 | 2008-12-05 | 836d? |  |  | C3,C4 | 16112h | 16112h | MIW-IMS |  |  | Gwiho | Vodafone | nico.gabriele@vodafone.com | Rel-8 |
| 342 | 99.1 | Note: Stages 1 and 2 defined in earlier Release | 49d? | 2005-09-23 A | 2005-11-30 A | 100% |  | 2005-09-23 | 2005-11-30 | 49d? |  | start no earlier than 2005-09-23 | S2 | 392h | 392h | MIW-IMS |  |  | Maurice | Vodafone | nico.gabriele@vodafone.com | Rel-8 |
| 343 | 99.2 | Stage 3 of MW-IMS | 571d? | 2005-09-23 A | 2007-11-30 A | 100% |  | 2005-09-23 | 2007-11-30 | 571d? |  | finish no earlier than 2007-09-14 | C3 | 4568h | 4568h | MIW-IMS-St3 |  |  | Gwiho | Vodafone | nico.gabriele@vodafone.com | Rel-8 |
| 344 | 99.3 | Stage 3 for MW-IMS, MONA extension | 285d? | 2007-11-05 A | 2008-12-05 A | 100% |  | 2007-11-05 | 2008-12-05 | 285d? |  | finish no earlier than 2008-12-05 | C3 | 2280h | 2280h | MIW-IMS | PCG-21 | SP-38 | Gwiho | Vodafone | Christer.Holmberg@ericsson.com | Rel-8 |
| 345 | 99.4 | Mn interface (MGCF – IM MGW) | 273d? | 2007-11-21 A | 2008-12-05 A | 100% |  | 2007-11-21 | 2008-12-05 | 273d? |  | finish no earlier than 2008-12-19 | C4 | 2184h | 2184h | MIW-IMS | PCG-21 | SP-38 | Kimmo | Vodafone | Christer.Holmberg@ericsson.com | Rel-8 |
| 346 | 100 | IMS Stage 3 IETF Protocol Alignment | 446d? | 2007-06-22 A | 2009-03-06 A | 100% |  | 2007-06-22 | 2009-03-06 | 446d? |  | finish no earlier than 2009-03-06 | C1 | 3568h | 3568h | IMSProtoc2 |  |  | Frederic | Alcatel-Lucent | Keith Drage (drage@alcatel-lucent.com) | Rel-8 |
| 347 | 101 | **Interworking between User-to-User Signalling (UUS) and SIP** | 335d? | 2007-11-30 A | 2009-03-12 A | 100% |  | 2007-11-30 | 2009-03-12 | 335d? |  |  | C1,C3 | 7488h | 7488h | UUSIW | PCG-21 | SP-38 | Kimmo | Huawei | Lili Yang (kadyyang@huawei.com) | Rel-8 |
| 348 | 101.1 | Stage 3 MGCF UUSIW | 266d? | 2007-11-30 A | 2008-12-05 A | 100% |  | 2007-11-30 | 2008-12-05 | 266d? |  | finish no earlier than 2008-12-05 | C1 | 2128h | 2128h | UUSIW | PCG-21 | SP-38 | Frederic | Huawei | Lili Yang (kadyyang@huawei.com) | Rel-8 |
| 349 | 101.2 | Stage 3 MGCF UUSIW | 335d? | 2007-11-30 A | 2009-03-12 A | 100% |  | 2007-11-30 | 2009-03-12 | 335d? |  | finish no earlier than 2009-03-12 | C3 | 2680h | 2680h | UUSIW | PCG-21 | SP-38 | Gwiho | Huawei | Lili Yang (kadyyang@huawei.com) | Rel-8 |

Notes:
- 324: SA#40 completed
- 325: CT#39 completed / Text3: 24.404, 24.405, 24.406, 24.407, 24.408, 24.410, 24.411, 24.416, 29.421, 24.423, 24.428, 24.429, 29.433, 24.441, 24.403, 29.427, 24.430, 29.412
- 326: CT#39 completed / Text3: 24.406, 24.407, 24.410, 24.411, 24.423, 24.430, 24.447, 24.451, 24.454, 24.503, 24.505, 24.508, 24.516, 24.528, 24.529, 29.412, 29.421, 29.433, 29.458, 29.527
- 327: WID approved SA#38. per OPs & ETSI GA 39. This is a joint effort of SA WG2 and TISPAN WG2. SA#40 completed / Text3: 23.228, 23.204, 23.167
- 328: SA#38 WID and TSs approved. SA#40 WID updated SP-070915=>SP-080315. SA#41 WID updated SP-080315=>SP-080501 / Text3: 22.273, 22.401, 23.406, 23.417, 23.508, 23.509, 23.511, 22.401, 22.173
- 329: SA#38 approved WID and TSs / Text3: 23.506, 23.507,23.517, 23.521
- 330: CT#43 Rel-8 further extension 03/09=>05/09 (no extension sheet needed). SA#40 Stage 1/2 completed
- 331: SA#40 completed
- 332: SA#40 completed / Text3: 23.237, 23.292
- 333: CT#43 Rel-8 further extension 03/09=>05/09 (no extension sheet needed) / Text3: 24.237, 24.229, 24.216
- 334: CT#43 completed. SA#36 WID approved
- 335: SA#42 completed. SA#39 SA3 to remove Stage 3 from 33.178-100 for CTx work. SA#40 withdrawn 33.178-100. / Text3: 33.203, 33.141, 33.978, 33.828, 33.803
- 336: CT#42 completed. SA#39 SA3 to remove Stage 3 from 33.178-100 for CT1 work
- 337: CT#43 completed. CT#42 Rel-8 extension to 03/09
- 338: CT#43 completed. CT#42 Rel-8 extension to 03/09 / Text3: 24.229
- 339: CT#40 completed / Text3: 29.229, 29.228, 23.008
- 340: SA#43 completed. SA#42 Rel-8 extension to 03/09. SA#39 WID approved. / Text3: 26.237, 26.234, 26.346, 33.246
- 341: CT#42 completed
- 342: SA#31 Moved from FS section Feb 2006
- 343: Moved from R7 WP because it is part of Feature UID_713024. This feature was extended to R8 by the inclusion (at Nov 2007 CT3 meeting) of Stage 3 extension covering MONA (WI 380021) / Text3: 29.863, 29.163
- 344: CT#42 completed / Text3: 29.863, 29.163
- 345: CT#42 completed / Text3: 29.332
- 346: CT#43 completed. CT#42 Rel-8 extension to 03/09 / Text3: 23.218, 24.229, 24.930
- 347: CT#43 completed
- 348: CT#42 completed / Text3: 24.279, 24.229
- 349: Depending on IETF draft. CT#43 completed / Text3: 29.163

| ID | WBS | Task | Type | Duration | Start | Finish | Complete | Remaining | Baseline start | Baseline finish | Baseline duration | Total slack | Constraint | Resources | Work | Actual work | Text1 | Text2 | Text4 | Text5 | Text6 | Text7 | Text8 | Text3 |
| --- | --- | --- | --- | --- | --- | --- | --- | --- | --- | --- | --- | --- | --- | --- | --- | --- | --- | --- | --- | --- | --- | --- | --- | --- |
| 350 | 102 | **Support of Overlap signalling** |  | 331d? | 2007-11-30 A | 2009-03-06 A | 100% |  | 2007-11-30 | 2009-03-06 | 331d? |  |  | C3,C1,C4 | 10008.2h | 10008.2h | Overlap | PCG-21 | Deutsche Telekom | r.jesske@telekom.de | Rel-8 | SP-38 | Gwiho |  |
| 351 | 102.1 | Stage 3 Overlap (CT1) |  | 331d? | 2007-11-30 A | 2009-03-06 A | 100% |  | 2007-11-30 | 2009-03-06 | 331d? |  | finish no earlier than 2009-03-06 | C1 | 2648h | 2648h | Overlap | PCG-21 | Deutsche Telekom | r.jesske@telekom.de | Rel-8 | SP-38 | Frederic | 24.229 |
| 352 | 102.2 | Stage 3 Overlap (CT3) |  | 331d? | 2007-11-30 A | 2009-03-06 A | 100% |  | 2007-11-30 | 2009-03-06 | 331d? |  | finish no earlier than 2009-03-06 | C3 | 2648h | 2648h | Overlap | PCG-21 | Deutsche Telekom | r.jesske@telekom.de | Rel-8 | SP-38 | Gwiho | 29.163 |
| 353 | 102.3 | Stage 3 Overlap (CT4) |  | 258.02d? | 2007-11-30 A | 2008-12-05 A | 100% |  | 2007-11-30 | 2008-12-05 | 258.02d? |  | start no earlier than 2007-11-30 | C4 | 2064.16h | 2064.16h | Overlap | PCG-21 | Deutsche Telekom | r.jesske@telekom.de | Rel-8 | SP-38 | Kimmo | 29.228, 29.229 |
| 354 | 103 | AS/MRFC Stage 2 and 3 |  | 278d? | 2007-11-14 A | 2008-12-05 A | 100% |  | 2007-11-14 | 2008-12-05 | 278d? |  | finish no earlier than 2008-12-05 | C1 | 2224h | 2224h | MRFC_TS | PCG-21 | HP | mark.syrett@hp.com | Rel-8 | SP-38 | Frederic | 23.218, 24.229, 24.147, 24.247 |
| 355 | 104 | **IMS Restoration Procedures** |  | 201d? | 2008-05-30 A | 2009-03-06 A | 100% |  | 2008-05-30 | 2009-03-06 | 201d? |  |  | C4,C1 | 4824h | 4824h | IMS_RP | PCG-21 | Ericsson | german.blanco@ericsson.com | Rel-8 | SP-40 | Kimmo |  |
| 356 | 104.1 | IMS Restoration Procedures |  | 201d? | 2008-05-30 A | 2009-03-06 A | 100% |  | 2008-05-30 | 2009-03-06 | 201d? |  | finish no earlier than 2009-03-06 | C4 | 1608h | 1608h | IMS_RP | PCG-21 | Ericsson | german.blanco@ericsson.com | Rel-8 | SP-40 | Kimmo | 23.380, 29.228, 29.229, 29.230, 23.008 |
| 357 | 104.2 | IMS Restoration Procedures |  | 201d? | 2008-05-30 A | 2009-03-06 A | 100% |  | 2008-05-30 | 2009-03-06 | 201d? |  | finish no earlier than 2009-03-06 | C1 | 1608h | 1608h | IMS_RP | PCG-21 | Ericsson | german.blanco@ericsson.com | Rel-8 | SP-40 | Frederic | 24.229 |
| 358 | 105 | IMS Application Server Service Data Descriptions for AS interoperability |  | 125d? | 2008-09-12 A | 2009-03-06 A | 100% |  | 2008-09-12 | 2009-03-06 | 125d? |  | finish no earlier than 2009-03-06 | C4 | 1000h | 1000h | IMS_ASIO | PCG-21 | Alcatel-Lucent | nhberry@alcatel-lucent.com | Rel-8 | CP-41 | Kimmo | 29.328, 29.329, 29.364 |
| 359 | 106 | **I-WLAN Network Selection Principle (NSP)** |  | 431d? | 2007-06-14 A | 2009-02-06 A | 100% |  | 2007-06-14 | 2009-02-06 | 431d? |  |  | S1,C1,C6 | 6323.2h | 6323.2h | IWLANNSP |  | Telefonica O2 | chris.friel@o2.com | Rel-8 |  | Alain |  |
| 360 | 106.1 | Stage 1 for I-WLAN NSP | milestone | 0d? | 2007-06-14 A | 2007-06-14 A | 100% |  | 2007-06-14 | 2007-06-14 | 0d? |  |  | S1 |  |  | IWLANNSP | PCG-21 | Telefonica O2 | chris.friel@o2.com | Rel-8 | SP-39 | Alain | 22.234 |
| 361 | 106.2 | Stage 3 for I-WLAN NSP |  | 241d? | 2008-03-07 A | 2009-02-06 A | 100% |  | 2008-03-07 | 2009-02-06 | 241d? |  | finish no earlier than 2008-12-05 | C1 | 1928h | 1928h | IWLANNSP | PCG-21 | RIM | Adrian Buckley (abuckley@rim.com) | Rel-8 | CP-39 | Frederic | 24.234 |
| 362 | 106.3 | Stage 3 for I-WLAN NSP |  | 118.4d? | 2008-03-07 A | 2008-12-11 A | 100% |  | 2008-03-07 | 2008-12-11 | 118.4d? |  | finish no earlier than 2008-12-11 | C6 | 947.2h | 947.2h | IWLANNSP | PCG-21 | RIM | Adrian Buckley (abuckley@rim.com) | Rel-8 | CP-39 | Xavier | 31.102, 31.111 |
| 363 | 107 | **Mobility between 3GPP-WLAN Interworking and 3GPP Systems** |  | 386d? | 2007-09-14 A | 2009-03-06 A | 100% |  | 2007-09-14 | 2009-03-06 | 386d? |  |  | S2,C1 | 6216h | 6216h | IWLAN_Mob |  | Orange | xiaobao.chen@orange-ftgroup.com | Rel-8 | SP-37 | Maurice |  |
| 364 | 107.1 | Stage 2: I-WLAN Mobility |  | 190d? | 2007-09-14 A | 2008-06-05 A | 100% |  | 2007-09-14 | 2008-06-05 | 190d? |  | finish no earlier than 2008-09-08 | S2 | 1520h | 1520h | IWLAN_Mob | PCG-21 | Orange | xiaobao.chen@orange-ftgroup.com | Rel-8 | SP-38 | Maurice | 23.327 |
| 365 | 107.2 | CT1 aspects of I-WLAN Mobility |  | 201d? | 2008-05-30 A | 2009-03-06 A | 100% |  | 2008-05-30 | 2009-03-06 | 201d? |  | finish no earlier than 2009-03-06 | C1 | 1608h | 1608h | IWLAN_Mob | PCG-21 | Orange | reina.nader@orange-ftgroup.com | Rel-8 | CP-40 | Frederic | 24.327, 24.303 |
| 366 | 108 | **Enhancements for VGCS Applications (EVA)** |  | 838d? | 2006-03-15 A | 2009-05-29 | 98% | 16.88d? | 2006-03-15 | 2009-05-29 | 838d? | 205d |  | S1,C1,C4,G2 | 22216h | 16727.6h | EVA |  | Nortel | Amar Deol (deola@nortelnetworks.com) | Rel-8 |  | Alain |  |
| 367 | 108.1 | SA1 aspects of EVA |  | 191d? | 2006-03-15 A | 2006-12-06 A | 100% |  | 2006-03-15 | 2006-12-06 | 191d? |  | finish no earlier than 2006-12-06 | S1 | 1528h | 1528h | EVA-s1 |  | Nortel | Amar Deol (deola@nortelnetworks.com) | Rel-8 |  | Alain | 42.068 |
| 368 | 108.2 | VGCS/VBS and GPRS Interactions |  | 145d? | 2007-09-03 A | 2008-03-21 A | 100% |  | 2007-09-03 | 2008-03-21 | 145d? |  | finish no earlier than 2008-03-21 | S1 | 1160h | 1160h | EVA |  | Huawei | Ling Liu | Rel-8 | SP-37 | Alain | 42.068, 42.069 |
| 369 | 108.3 | CT1 aspects of EVA |  | 781d? | 2006-06-02 A | 2009-05-29 | 95% | 39.05d? | 2006-06-02 | 2009-05-29 | 781d? | 205d | finish no earlier than 2009-05-29 | C1 | 6248h | 5935.6h | EVA |  | Nortel | milanpa@nortel.com | Rel-8 |  | Frederic | 43.068, 44.068 |
| 370 | 108.4 | CT4 aspects of EVA |  | 391d? | 2006-06-02 A | 2007-11-30 A | 100% |  | 2006-06-02 | 2007-11-30 | 391d? |  | finish no earlier than 2007-06-01 | C4 | 3128h | 3128h | EVA |  | Nortel |  | Rel-8 |  | Kimmo | 29.002 |
| 371 | 108.5 | GERAN2 aspects of EVA |  | 431d? | 2006-06-30 A | 2008-02-22 A | 100% |  | 2006-06-30 | 2008-02-22 | 431d? |  | finish no earlier than 2008-02-22 | G2 | 3448h | 3448h | EVA-EVGCSA |  | Nortel | frank.billenkamp@nortel.com | Rel-8 |  | Juha | 44.018, 48.008 |
| 372 | 109 | **Personal Network Management** |  | 955d? | 2005-07-11 A | 2009-03-06 A | 100% |  | 2005-07-11 | 2009-03-06 | 955d? |  |  | S1,C1,C4,S3 | 24800h | 24800h | PNM |  | Vodafone | armin.toepfer@vodafone.com | Rel-8 |  | Alain |  |
| 373 | 109.1 | Stage 1 for PNM |  | 276d? | 2005-07-11 A | 2006-07-31 A | 100% |  | 2005-07-11 | 2006-07-31 | 276d? |  | start no earlier than 2005-07-11 | S1 | 2208h | 2208h | PNM |  | Vodafone | armin.toepfer@vodafone.com | Rel-8 |  | Alain | 22.259 |
| 374 | 109.2 | Stage 2 for PNM |  | 445d? | 2007-03-26 A | 2008-12-05 A | 100% |  | 2007-03-26 | 2008-12-05 | 445d? |  | finish no earlier than 2008-12-05 | C1 | 3560h | 3560h | PNM |  | Vodafone | yang.lu@vodafone.com | Rel-8 |  | Frederic | 23.259 |

Notes:
- 350: CT#43 completed. CT#42 Rel-8 extension to 03/09
- 351: CT#43 completed. CT#42 Rel-8 extension to 03/09
- 352: CT#43 completed. CT#42 Rel-8 extension to 03/09
- 353: CT#42 completed
- 354: CT#42 completed. Triggered by Study UID_7048 (MRFC)
- 355: CT#43 completed. CT#42 Rel-8 extension to 03/09. CT#41 WID updated CP-080281=>CP-080447. Triggered by Study TR 23.820 (FS_IMS_RP) UID_350018
- 356: CT#43 completed. CT#42 Rel-8 extension to 03/09
- 357: CT#43 completed. CT#42 Rel-8 extension to 03/09
- 358: CT#43 completed. CT#42 Rel-8 extension to 03/09. Triggered by UID_360030 (FS_IMS_ASIO)
- 359: CT#43 completed. SA#36 Stage 1 completed
- 360: SA#36 completed
- 361: CT#43 completed
- 362: CT#42 completed
- 363: CT#43 completed. SA#40 Stage 2 completed
- 364: SA#40 completed
- 365: CT#43 completed
- 366: Stage 1/2 completed
- 367: SA#38 completed
- 368: SA#39 completed
- 369: CT#43 Rel-8 extension 05/09 (no written extension was requested at CT#42/43)
- 370: CT#38 completed
- 371: GP#37 completed
- 372: CT#43 completed. Feb 06 moved FS=>Feature. SA#31 Stage 1 completed. SA#40 WID updated with reduced scope SP-060574=>SP-080327
- 373: SA#31 completed. SA#40 WID updated SP-060574=>SP-080327
- 374: CT#42 completed

| ID | WBS | Task | Type | Duration | Start | Finish | Complete | Remaining | Baseline start | Baseline finish | Baseline duration | Total slack | Constraint | Resources | Work | Actual work | Text1 | Text4 | Text5 | Text6 | Text8 | Text3 | Text12 | Text7 | Text2 |
| --- | --- | --- | --- | --- | --- | --- | --- | --- | --- | --- | --- | --- | --- | --- | --- | --- | --- | --- | --- | --- | --- | --- | --- | --- | --- |
| 375 | 109.3 | **Stage 3 for PNM** |  | 510d? | 2007-03-26 A | 2009-03-06 A | 100% |  | 2007-03-26 | 2009-03-06 | 510d? |  |  | C1,C4 | 11720h | 11720h | PNM | Vodafone | yang.lu@vodafone.com | Rel-8 | Frederic |  |  |  |  |
| 376 | 109.3.1 | CT1 aspects of Stage 3 PNM |  | 510d? | 2007-03-26 A | 2009-03-06 A | 100% |  | 2007-03-26 | 2009-03-06 | 510d? |  | finish no earlier than 2008-12-05 | C1 | 4080h | 4080h | PNM | Vodafone | yang.lu@vodafone.com | Rel-8 | Frederic | 24.259, 24.229 |  |  |  |
| 377 | 109.3.2 | CT4 aspects of Stage 3 PNM |  | 445d? | 2007-03-26 A | 2008-12-05 A | 100% |  | 2007-03-26 | 2008-12-05 | 445d? |  | finish no earlier than 2008-12-11 | C4 | 3560h | 3560h | PNM | Vodafone | yang.lu@vodafone.com | Rel-8 | Kimmo | 23.008, 23.018, 29.002, 29.328, 29.329 |  |  |  |
| 378 | 109.4 | Key establishment between a UICC hosting device and a remote device |  | 235d? | 2006-12-06 A | 2007-10-30 A | 100% |  | 2006-12-06 | 2007-10-30 | 235d? |  | finish no earlier than 2007-10-30 | S3 | 1880h | 1880h | PNM | Ericsson | Vesa.Lehtovirta@ericsson.com | Rel-7 | Dionisio | 33.259 |  |  |  |
| 379 | 109.5 | Deleted - Actual Requirements of PNM | milestone | 0d? | 2007-03-26 A | 2007-03-26 A | 100% |  | 2007-03-26 | 2007-03-26 | 0d? |  | finish no earlier than 2007-03-26 | C1 |  |  | PNM | Ericsson |  | Rel-8 | Frederic |  | SP-37 |  |  |
| 380 | 110 | **eCall Data Transfer** |  | 637d? | 2006-09-28 A | 2009-03-06 A | 100% |  | 2006-09-28 | 2009-03-06 | 637d? |  |  | S1,C1 | 9744h | 9744h | Edata | Airbiquity | rrobinson@airbiquity.com | Rel-8 | Alain |  |  |  |  |
| 381 | 110.1 | eData Requirements |  | 380d? | 2006-09-28 A | 2008-03-12 A | 100% |  | 2006-09-28 | 2008-03-12 | 380d? |  | finish no earlier than 2006-12-07 | S1 | 3040h | 3040h | EData | Airbiquity | rrobinson@airbiquity.com | Rel-8 | Alain | 22.101, 22.105 |  | SP-37 |  |
| 382 | 110.2 | Transfer of data during an emergency call |  | 201d? | 2008-05-30 A | 2009-03-06 A | 100% |  | 2008-05-30 | 2009-03-06 | 201d? |  | finish no earlier than 2009-03-06 | C1 | 1608h | 1608h | Edata | T-Mobile | Dieter Jacobsohn | Rel-8 | Frederic | 24.008 |  | SP-40 | PCG-21 |
| 383 | 111 | eCall data transfer Phase 2: Comparison of alternative in-band modem solutions and standardization of one in-band modem solution |  | 396d? | 2007-12-06 A | 2009-06-11 | 90% | 39.6d? | 2007-12-06 | 2009-06-11 | 396d? | 196d | finish no earlier than 2009-06-11 | S4 | 3168h | 2851.2h | eCall_Phase2 | Airbiquity | lhong@airbiquity.com & rrobinson@airbiquity.com | Rel-8 | Paolo | 26.967, 26.267, 26.268, 26.269 |  |  |  |
| 384 | 112 | **IP Interconnection of Services** |  | 668d? | 2006-08-16 A | 2009-03-06 A | 100% |  | 2006-08-16 | 2009-03-06 | 668d? |  |  | S1,S2,S5,C3 | 17520h | 17520h | IPinterc | Telefonica O2 | chris.friel@O2.com | Rel-8 | Alain |  |  | SP-38 | PCG-21 |
| 385 | 112.1 | Stage 1 for IPinterc |  | 70d? | 2007-12-06 A | 2008-03-12 A | 100% |  | 2007-12-06 | 2008-03-12 | 70d? |  | start no earlier than 2007-12-06 | S1 | 560h | 560h | IPinterc | Telefonica O2 | chris.friel@O2.com | Rel-8 | Alain | 22.101, 22.228 |  | SP-38 | PCG-21 |
| 386 | 112.2 | **System enhancements for interconnection interfaces between two IMSs** |  | 668d? | 2006-08-16 A | 2009-03-06 A | 100% |  | 2006-08-16 | 2009-03-06 | 668d? |  |  | S2,S5,C3 | 11616h | 11616h | IMS_NNI | Telecom Italia | Mario Madella (mario.madella@telecomitalia.it) | Rel-8 | Maurice |  |  |  |  |
| 387 | 112.2.1 | Stage 2 for IMS_NNI |  | 120d? | 2007-06-22 A | 2007-12-06 A | 100% |  | 2007-06-22 | 2007-12-06 | 120d? |  | finish no earlier than 2007-12-21 | S2 | 960h | 960h | IMS_NNI | Telecom Italia | Mario Madella (mario.madella@telecomitalia.it) | Rel-8 | Maurice | 23.002, 23.228 |  |  |  |
| 388 | 112.2.2 | IMS inter-operator service interconnection interface |  | 461d? | 2007-06-01 A | 2009-03-06 A | 100% |  | 2007-06-01 | 2009-03-06 | 461d? |  | finish no earlier than 2009-03-06 | C3 | 3688h | 3688h | FBI2-IOPSI | Telecom Italia | antonio.ascolese@telecomitalia.it | Rel-8 | Gwiho | 29.865, 29.165 |  |  |  |
| 389 | 112.2.3 | Charging harmonization for NGN between 3GPP and ATIS-TMOC |  | 51d? | 2006-09-28 A | 2006-12-07 A | 100% |  | 2006-09-28 | 2006-12-07 | 51d? |  | finish no earlier than 2006-12-07 | S5 | 408h | 408h | FBI2-TISP2-CH | Amdocs | Brown, Yishai | Rel-8 | Dionisio | 32.297 |  |  |  |
| 390 | 112.2.4 | Deleted - Protocol impact of FBI for TISPAN R2 |  | 152d? | 2006-08-16 A | 2007-03-15 A | 100% |  | 2006-08-16 | 2007-03-15 | 152d? |  | finish no earlier than 2007-03-15 | C1 | 1216h | 1216h | FBI2-TISP2-c1 | Ericsson |  | Rel-8 | Frederic |  | SP-38 |  |  |
| 391 | 112.2.5 | Deleted (never approved) - Stage 2 of FBI for TISPAN R2 - Rel 8 | milestone | 0d? | 2007-11-30 A | 2007-11-30 A | 100% |  | 2007-11-30 | 2007-11-30 | 0d? |  | finish no earlier than 2007-11-30 | S2 |  |  | FBI2-TISP2-s2 | Nokia Siemens Networks |  | Rel-8 | Maurice |  | SP-36 |  |  |
| 392 | 113 | **Support of (G)MSC-S – (G)MSC-S Nc Interface based on the SIP-I protocol** |  | 386d? | 2007-09-14 A | 2009-03-06 A | 100% |  | 2007-09-14 | 2009-03-06 | 386d? |  |  | C4,C3 | 11872h | 11872h | SIP_Nc | Vodafone | David.Hutton@vodafone.com | Rel-8 | Kimmo |  |  |  |  |
| 393 | 113.1 | Stage 1 for SIP_Nc (covered by Feature IPinterc) |  | 70d? | 2007-12-06 A | 2008-03-12 A | 100% |  | 2007-12-06 | 2008-03-12 | 70d? |  | start no earlier than 2007-12-06 | S1 | 560h | 560h | IPinterc | Telefonica O2 | chris.friel@O2.com | Rel-8 | Alain | 22.101, 22.228 |  | CP-41 | PCG-21 |
| 394 | 113.2 | SIP-I based circuit-switched core network; Stage 2 |  | 321d? | 2007-09-14 A | 2008-12-05 A | 100% |  | 2007-09-14 | 2008-12-05 | 321d? |  | finish no earlier than 2008-12-11 | C4 | 2568h | 2568h | SIP_Nc-St2 | Vodafone | David.Hutton@vodafone.com | Rel-8 | Kimmo | 23.231, 23.153, 23.205 |  |  |  |
| 395 | 113.3 | Application of SIP-I Protocols to Circuit Switched (CS) core network architecture; Stage 3 |  | 321d? | 2007-09-14 A | 2008-12-05 A | 100% |  | 2007-09-14 | 2008-12-05 | 321d? |  | finish no earlier than 2008-12-11 | C4 | 2568h | 2568h | SIP_Nc-St3 | Vodafone | David.Hutton@vodafone.com | Rel-8 | Kimmo | 29.231, 29.232, 29.332 |  |  |  |
| 396 | 113.4 | Interworking between the 3GPP CS domain with SIP-I as signalling protocol and other networks |  | 386d? | 2007-09-14 A | 2009-03-06 A | 100% |  | 2007-09-14 | 2009-03-06 | 386d? |  | finish no earlier than 2009-03-06 | C3 | 3088h | 3088h | SIP_Nc | Nokia Siemens Networks | Thomas.Belling@nsn.com | Rel-8 | Gwiho | 29.235, 23.172, 23.202, 29.007, 29.163, 29.414 |  |  |  |
| 397 | 114 | **Earthquake and Tsunami Warning System** |  | 440d? | 2007-09-10 A | 2009-05-15 | 90% | 44.96d? | 2007-09-10 | 2009-05-15 | 440d? | 215d |  | S1,S2,CP,G2 | 6136h | 3304h | ETWS | NTT DoCoMo | kitaharar@nttdocomo.co.jp | Rel-8 | Alain |  |  | SP-37 |  |
| 398 | 114.1 | Stage 1 for ETWS |  | 133d? | 2007-09-10 A | 2008-03-12 A | 100% |  | 2007-09-10 | 2008-03-12 | 133d? |  | finish no earlier than 2008-03-12 | S1 | 1064h | 1064h | ETWS | NTT DoCoMo | kitaharar@nttdocomo.co.jp | Rel-8 | Alain | 22.168 |  | SP-37 |  |
| 399 | 114.2 | SA2 aspects of ETWS |  | 179d? | 2008-01-14 A | 2008-09-18 A | 100% |  | 2008-01-14 | 2008-09-18 | 179d? |  | finish no earlier than 2008-09-08 | S2 | 1432h | 1432h | ETWS | NTT DoCoMo | tanakai@nttdocomo.co.jp | Rel-8 | Maurice | 23.828, 23.401 |  | SP-38 | PCG-21 |
| 400 | 114.3 | CT1 aspects of ETWS |  | 50.5d? | 2008-05-30 A | 2008-12-05 A | 100% |  | 2008-05-30 | 2008-12-05 | 50.5d? |  | finish no earlier than 2008-12-05 | C1 | 404h | 404h | ETWS | NTT DoCoMo | yamashitahi@s1.nttdocomo.co.jp | Rel-8 | Frederic | 23.041 |  | CP-40 | PCG-21 |
| 401 | 114.4 | CT4 aspects of ETWS |  | 50.5d? | 2008-09-26 A | 2008-12-05 A | 100% |  | 2008-09-26 | 2008-12-05 | 50.5d? |  | finish no earlier than 2008-12-05 | C4 | 404h | 404h | ETWS | NTT DoCoMo | yamashitahi@s1.nttdocomo.co.jp | Rel-8 | Kimmo | 29.168 |  | CP-40 | PCG-21 |
| 402 | 114.5 | ETWS primary notification message definition in GERAN |  | 47d? | 2009-03-12 | 2009-05-15 |  |  | 2009-03-12 | 2009-05-15 | 47d? | 215d | finish no earlier than 2009-05-15 | G2 | 376h |  | ETWS | Ericsson | claes-goran.persson@ericsson.com | Rel-8 | Juha | 44.018, 44.060 |  | SP-43 | PCG-22 |

Notes:
- 375: CT#43 completed. Moved from FS section Feb 06: SP-33: Create new section to capture the PNM stage 2 aspects and identify any impacts to existing stage 2 specifications.
- 376: CT#43 completed
- 377: CT#42 No impact to CT4 specifications
- 378: 07/08: Moved from Rel-7 to Rel-8 WP; Feature=>BB as per SA3/SA WID in SP-060839, keeping the same UID
- 379: SA#37 stopped
- 380: SA#39 completed. Linked to SA4 Feature UID_34042 (eCall_Phase2). CT#40 approved Stage 3 WID.
- 381: SA4 to select a suitable in-band modem. SA#39 completed
- 382: CT#43 completed. CT#42 Rel-8 extension to 03/09
- 383: SA#43 Rel-8 extension 03/09=>06/09 (exception sheet in SP-090011). SA#42 Rel-8 extension to 03/09. Triggered by Study UID_360015 (eCALLIBMS). Linked to SA1 Feature UID_330005 (EData).
- 384: SA#43 completed. CT#42 Rel-8 extension to 03/09. Covers Stage 1 for IMS_NNI (UID_360024),SIP_Nc (UID_360026),CS-IBCF (UID_400008). SA#41 WID updated SP-070871=>SP-080565 [Moved under it as BBs 3 existing Features: CS-IBCF, IMS_NNI, SIP_Nc]
- 385: SA#39 completed.
- 386: CT#43 completed. CT#42 Rel-8 extension to 03/09. SA#36 Name changed from "System enhancements for TISPAN Rel2". Stage 1 in Feature UID_380060 (IPinterc). CT#41 updated WID CP-080054=>CP-080578 (Feature IMS_NNI=>BB under Ipinterc)
- 387: SA#38 completed. SA#41 WID updated SP-070490=>SP-080554
- 388: CT#43 completed. CT#42 Rel-8 extension to 03/09
- 389: SA#34 completed
- 390: SA#38 stopped
- 391: SA#36 stopped
- 392: CT#43 completed. Stage 1 in Feature UID_380060 (IPinterc). CT#40 updated WID CP-070517=>CP-080282
- 393: 22/07/08 Created. Stage 1 for SIP_Nc (covered by SA1 Feature UID_380060 Ipinterc)
- 394: CT#42 completed
- 395: CT#42 completed
- 396: CT#43 completed. CT#42 target 12/08=>03/09
- 397: CT#42 completed. SA#38 WID approved. Larger scope Feature UID_380057 (PWS) moved to Rel-9. No SA2 impact.
- 398: SA#39 completed
- 399: SA#41 completed . SA#40 extension to Sep 2008 on impacts of adding the CBC to MME interface.
- 400: CT#42 completed. WID updated CP-080318=>CP-080659=>CP-080951
- 401: CT#42 completed. WID updated CP-080318=>CP-080659=>CP-080951
- 402: SA#43 extesion to 05/09 (GERAN2 LS_in SP-090154)

| ID | WBS | Task | Type | Duration | Start | Finish | Complete | Remaining | Baseline start | Baseline finish | Baseline duration | Total slack | Constraint | Resources | Work | Actual work | Text1 | Text2 | Text4 | Text5 | Text6 | Text7 | Text8 | Text3 |
| --- | --- | --- | --- | --- | --- | --- | --- | --- | --- | --- | --- | --- | --- | --- | --- | --- | --- | --- | --- | --- | --- | --- | --- | --- |
| 403 | 115 | **In Case of Emergency numbers storage and easy access on UICC** |  | 519d? | 2007-03-13 A | 2009-03-06 A | 100% |  | 2007-03-13 | 2009-03-06 | 519d? |  |  | S1,C6 | 8864h | 8864h | ICE | PCG-21 | Vodafone | armin.toepfer@vodafone.com | Rel-8 | SP-38 | Alain |  |
| 404 | 115.1 | Stage 1 for ICE |  | 262d? | 2007-03-13 A | 2008-03-12 A | 100% |  | 2007-03-13 | 2008-03-12 | 262d? |  | finish no earlier than 2008-03-12 | S1 | 2096h | 2096h | ICE | PCG-21 | Vodafone | armin.toepfer@vodafone.com | Rel-8 | SP-38 | Alain | 22.030, 22.101 |
| 405 | 115.2 | CT6 aspects of ICE |  | 519d? | 2007-03-13 A | 2009-03-06 A | 100% |  | 2007-03-13 | 2009-03-06 | 519d? |  | finish no earlier than 2009-03-06 | C6 | 4152h | 4152h | ICE | PCG-21 | Vodafone | armin.toepfer@vodafone.com | Rel-8 | SP-38 | Xavier | 31.102 |
| 406 | 116 | Local Charging Zone Requirements |  | 380d? | 2006-09-28 A | 2008-03-12 A | 100% |  | 2006-09-28 | 2008-03-12 | 380d? |  | finish no earlier than 2006-12-07 | S1 | 3040h | 3040h | LCZR |  | China Mobile | liuhongyfw@chinamobile.com | Rel-8 |  | Alain | 22.115 |
| 407 | 117 | **Customized Alerting Tone (CAT) Service** |  | 648d? | 2006-12-06 A | 2009-05-29 | 70% | 193.08d? | 2006-12-06 | 2009-05-29 | 648d? | 205d |  | S1,C1,C3,C4 | 11014h | 5255.44h | CAT |  | China Mobile | fenglingjuan@chinamobile.com | Rel-8 |  | Alain |  |
| 408 | 117.1 | Stage 1 for CAT |  | 207d? | 2006-12-06 A | 2007-09-20 A | 100% |  | 2006-12-06 | 2007-09-20 | 207d? |  | start no earlier than 2006-12-06 | S1 | 1656h | 1656h | CAT |  | China Mobile | fenglingjuan@chinamobile.com | Rel-8 | SP-37 | Alain | 22.182 |
| 409 | 117.2 | TISPAN requirements for customized multimedia information services |  | 71d? | 2007-09-03 A | 2007-12-10 A | 100% |  | 2007-09-03 | 2007-12-10 | 71d? |  | finish no earlier than 2007-12-10 | S1 | 568h | 568h | TISCMI |  | China Mobile | fenglingjuan@chinamobile.com | Rel-8 | SP-37 | Alain | 22.182 |
| 410 | 117.3 | IMS CAT Supplementary Service |  | 164d? | 2008-04-21 A | 2008-12-05 A | 100% |  | 2008-04-21 | 2008-12-05 | 164d? |  | finish no earlier than 2008-12-05 | C1 | 1312h | 1312h | CAT-SS | PCG-21 | Nortel | milanpa@nortel.com | Rel-8 | CP-39 | Frederic | 24.182 |
| 411 | 117.4 | CAT solution for voice and video call in CS domain |  | 309.8d? | 2008-03-12 A | 2009-05-29 | 10% | 278.82d? | 2008-03-12 | 2009-05-29 | 309.8d? | 205d | finish no earlier than 2009-05-29 | C3 | 2478.4h | 247.84h | CAT-SS | PCG-21 | Nortel | milanpa@nortel.com | Rel-8 | CP-39 | Gwiho | 29.163 |
| 412 | 117.5 | CAT Service in 3GPP CS domain |  | 126d? | 2008-09-12 A | 2009-03-06 A | 100% |  | 2008-09-12 | 2009-03-06 | 126d? |  | finish no earlier than 2009-03-06 | C4 | 1008h | 1008h | CAT-3G_CS | PCG-21 | China Mobile | zhaoyuyi@chinamobile.com | Rel-8 | CP-41 | Kimmo | 23.205, 23.231, 29.002 |
| 413 | 117.6 | CAT Service in 3GPP CS domain |  | 57.95d? | 2008-09-12 A | 2008-12-05 A | 100% |  | 2008-09-12 | 2008-12-05 | 57.95d? |  | start no earlier than 2008-09-12 | C1 | 463.6h | 463.6h | CAT-3G_CS | PCG-21 | China Mobile | zhaoyuyi@chinamobile.com | Rel-8 | CP-41 | Frederic | 24.008, 23.014 |
| 414 | 118 | **Service-Level Interworking for Messaging Services** |  | 509d? | 2007-03-26 A | 2009-03-06 A | 100% |  | 2007-03-26 | 2009-03-06 | 509d? |  |  | S1,S2,C3,C1 | 8584h | 8584h | MESSIW |  | Huawei | ling.liu@huawei.com; duanxiaoqin@huawei.com | Rel-8 |  | Alain |  |
| 415 | 118.1 | Stage 1 for MESSIW | milestone | 0d? | 2007-03-26 A | 2007-03-26 A | 100% |  | 2007-03-26 | 2007-03-26 | 0d? |  | finish no earlier than 2007-12-01 | S1 |  |  | MESSIW |  | Huawei | ling.liu@huawei.com | Rel-8 |  | Alain | 22.105, 22.340 |
| 416 | 118.2 | Stage 2 for MESSIW |  | 227d? | 2007-04-26 A | 2008-03-07 A | 100% |  | 2007-04-26 | 2008-03-07 | 227d? |  | finish no earlier than 2008-03-07 | S2 | 1816h | 1816h | MESSIW |  | Huawei | patrice.hede@huawei.com | Rel-8 |  | Maurice | 23.811, 23.204 |
| 417 | 118.3 | Stage 3 for MESSIW |  | 201d? | 2008-05-30 A | 2009-03-06 A | 100% |  | 2008-05-30 | 2009-03-06 | 201d? |  | finish no earlier than 2008-12-05 | C3 | 1608h | 1608h | MESSIW | PCG-21 | Huawei | xupeili@huawei.com | Rel-8 | CP-40 | Gwiho | 29.311 |
| 418 | 118.4 | Stage 3 for MESSIW |  | 136d? | 2008-05-30 A | 2008-12-05 A | 100% |  | 2008-05-30 | 2008-12-05 | 136d? |  | finish no earlier than 2008-12-12 | C1 | 1088h | 1088h | MESSIW | PCG-21 | Huawei | xupeili@huawei.com | Rel-8 | CP-40 | Frederic | 24.229 |
| 419 | 119 | **Multimedia Priority Service** |  | 777d? | 2006-06-08 A | 2009-05-29 | 59% | 319.51d? | 2006-06-08 | 2009-05-29 | 777d? | 205d |  | S1,C1,C3,C4 | 21128h | 12439.9h | PRIOR |  | Telcordia | jgarraha@telcordia.com | Rel-8 | SP-34 | Alain |  |
| 420 | 119.1 | Service Requirements for PRIOR |  | 391d? | 2006-06-08 A | 2007-12-06 A | 100% |  | 2006-06-08 | 2007-12-06 | 391d? |  | finish no earlier than 2007-11-30 | S1 | 3128h | 3128h | PRIOR-EMR |  | Telcordia | jgarraha@telcordia.com | Rel-8 | SP-32 | Alain | 22.153 |
| 421 | 119.2 | Stage 3 for PRIOR |  | 651d? | 2006-12-01 A | 2009-05-29 | 50% | 325.5d? | 2006-12-01 | 2009-05-29 | 651d? | 205d | finish no earlier than 2009-05-29 | C1 | 5208h | 2604h | PRIOR |  | Alcatel-Lucent | Keith Drage (drage@alcatel-lucent.com) | Rel-8 | SP-34 | Frederic | 24.229 |
| 422 | 119.3 | Stage 3 for PRIOR |  | 441d? | 2007-09-21 | 2009-05-29 |  |  | 2007-09-21 | 2009-05-29 | 441d? | 205d | finish no earlier than 2009-05-29 | C3 | 3528h |  | PRIOR |  | Alcatel-Lucent | Keith Drage (drage@alcatel-lucent.com) | Rel-8 | SP-37 | Gwiho | 29.212, 29.213, 29.214, 29.163 |
| 423 | 119.4 | Stage 3 for PRIOR |  | 381d? | 2007-09-21 A | 2009-03-06 A | 100% |  | 2007-09-21 | 2009-03-06 | 381d? |  | finish no earlier than 2009-03-06 | C4 | 3048h | 3048h | PRIOR |  | Alcatel-Lucent | Keith Drage (drage@alcatel-lucent.com) | Rel-8 | SP-37 | Kimmo | 23.008, 29.228, 29.229 |
| 424 | 120 | **OSA Rel-8** |  | 202d? | 2007-08-23 A | 2008-05-30 A | 100% |  | 2007-08-23 | 2008-05-30 | 202d? |  |  | S1,C5 | 23552h | 23552h | OSA8 |  | Orange | Song Dong | Rel-8 |  | Alain |  |
| 425 | 120.1 | OSA Stage 1 - Service Requirements |  | 145d? | 2007-08-23 A | 2008-03-12 A | 100% |  | 2007-08-23 | 2008-03-12 | 145d? |  | finish no earlier than 2007-12-04 | S1 | 1160h | 1160h | OSA8 |  | Orange, AePONA | Song Dong | Rel-8 |  | Alain | 22.127 |
| 426 | 120.2 | OSA Stage 1 - NGN Service Requirement |  | 140d? | 2007-09-03 A | 2008-03-14 A | 100% |  | 2007-09-03 | 2008-03-14 | 140d? |  | finish no earlier than 2008-03-14 | S1 | 1120h | 1120h | OSA8-IMS |  | Orange | Song Dong | Rel-8 | SP-37 | Alain | 22.127 |

Notes:
- 403: CT#43 completed (ICE Graphics not included in Rel-8)
- 404: SA#39 Stage 1 completed
- 405: CT#43 completed (ICE Graphics not in Rel-8 / not explicitly in SA1 WID either). CT#42 Rel-8 extension to 03/09 (add ICE Graphics as per SA1 request)
- 406: SA#39 Stage 1 completed
- 407: Conflict 3GPP vs. 3GPP2 IMS CAT. SA#40 extension to Sep 2008 for SA2 (Forking, Early session model)
- 409: SA#38 completed
- 410: CT#42 completed. CT#41 WID updated CP-080074=>CP-080496.
- 411: CT#41 WID updated CP-080074=>CP-080496. Triggered by Study UID_360031 (FS_CAT_VVC_CS) TR 29.882.
- 412: CT#43 completed. CT#42 Rel-8 extension to 03/09. Triggered by Study UID_360031 (FS_CAT_VVC_CS) TR 29.882.
- 413: Triggered by Study UID_360031 (FS_CAT_VVC_CS) TR 29.882. CT#42 completed
- 414: CT#43 completed. SA#39 Stage 2 completed
- 415: SA#35 completed
- 416: SA#39 completed
- 417: CT#43 completed
- 418: CT#42 completed. WID updated CP-080391=>CP-080575=>CP-080773
- 419: SA#38 Stage 1 completed. No Stage 2 identified
- 420: SA#38 completed
- 421: CT#43 Rel-8 further extension 03/09=>05/09 (no extension sheet needed)
- 422: CT#43 Rel-8 further extension 03/09=>05/09 (no extension sheet needed)
- 423: CT#43 completed
- 424: TSG#40 completed. New OSA work in OMA. SA1 need to remove unfulfilled Requirements to align with CT5 Stage 2/3 reality.
- 425: TSG#40 New OSA work in OMA. SA1 to remove non-fulfilled Requirements.
- 426: TSG#40 New OSA work in OMA. SA1 to remove non-fulfilled Requirements.

| ID | WBS | Task | Duration | Start | Finish | Complete | Baseline start | Baseline finish | Baseline duration | Constraint | Resources | Work | Actual work | Text1 | Text3 | Text4 | Text5 | Text6 | Text8 | Text2 | Text7 | Text9 | Text12 |
| --- | --- | --- | --- | --- | --- | --- | --- | --- | --- | --- | --- | --- | --- | --- | --- | --- | --- | --- | --- | --- | --- | --- | --- |
| 427 | 120.3 | **OSA Stage 2/3 enhancements** | 157d? | 2007-10-25 A | 2008-05-30 A | 100% | 2007-10-25 | 2008-05-30 | 157d? |  | C5 | 20016h | 20016h | OSA8 | 23.198, 29.198, 29.199 | Alcatel-Lucent | unmehopa@alcatel-lucent.com | Rel-8 | Kimmo |  |  |  |  |
| 428 | 120.3.1 | Delete - Ensure Parlay-X composable with identity management frameworks, in particular Liberty Alliance | 157d? | 2007-10-25 A | 2008-05-30 A | 100% | 2007-10-25 | 2008-05-30 | 157d? | finish no earlier than 2008-12-25 | C5 | 1256h | 1256h | OSA8 | existing 29.199-xy | Ericsson, FT/Orange, Sprint, Telecom Italia | catherine.mulligan@ericsson.com | Rel-8 | Kimmo | PCG-21 | CP-37 | PCG-21 | CP-40 |
| 429 | 120.3.2 | Parlay-X Content Management web service (store/manage meta-data) | 157d? | 2007-10-25 A | 2008-05-30 A | 100% | 2007-10-25 | 2008-05-30 | 157d? | finish no earlier than 2008-12-04 | C5 | 1256h | 1256h | OSA8 | 29.199-21 | Alcatel-Lucent | unmehopa@alcatel-lucent.com | Rel-8 | Kimmo |  | CP-37 |  |  |
| 430 | 120.3.3 | Parlay-X Policy web service | 157d? | 2007-10-25 A | 2008-05-30 A | 100% | 2007-10-25 | 2008-05-30 | 157d? | finish no earlier than 2008-12-04 | C5 | 1256h | 1256h | OSA8 | 29.199-22 | Alcatel-Lucent | unmehopa@alcatel-lucent.com | Rel-8 | Kimmo |  | CP-37 |  |  |
| 431 | 120.3.4 | Parlay-X Terminal status web service | 157d? | 2007-10-25 A | 2008-05-30 A | 100% | 2007-10-25 | 2008-05-30 | 157d? | finish no earlier than 2008-05-30 | C5 | 1256h | 1256h | OSA8 | 29.199-08 | Alcatel-Lucent | unmehopa@alcatel-lucent.com | Rel-8 | Kimmo |  | CP-37 |  |  |
| 432 | 120.3.5 | Delete - Identify communication format used by a particular application | 157d? | 2007-10-25 A | 2008-05-30 A | 100% | 2007-10-25 | 2008-05-30 | 157d? | finish no earlier than 2008-05-30 | C5 | 1256h | 1256h | OSA8 | existing 29.199-xy | Ericsson | catherine.mulligan@ericsson.com | Rel-8 | Kimmo | PCG-21 | CP-37 | PCG-21 | CP-40 |
| 433 | 120.3.6 | Delete - Security on User Profile Management - reuse GUP API (22.127 CR 0084 S1-071794) | 128d? | 2007-12-05 A | 2008-05-30 A | 100% | 2007-12-05 | 2008-05-30 | 128d? | finish no earlier than 2008-12-25 | C5 | 1024h | 1024h | OSA8 | PXWS Framework | Telecom Italia | vincenzo.amorino@telecomitalia.it | Rel-8 | Kimmo | PCG-21 | CP-38 | PCG-21 | CP-40 |
| 434 | 120.3.7 | Delete - Privacy on Subscriber Identity (Liberty Alliance, OASIS) (22.127 CR 0085 S1-071835) | 128d? | 2007-12-05 A | 2008-05-30 A | 100% | 2007-12-05 | 2008-05-30 | 128d? | finish no earlier than 2008-12-25 | C5 | 1024h | 1024h | OSA8 | PXWS Framework | Telecom Italia | vincenzo.amorino@telecomitalia.it | Rel-8 | Kimmo | PCG-21 | CP-38 | PCG-21 | CP-40 |
| 435 | 120.3.8 | Delete - Topology Hiding (22.127 CR 0086 S1-071838) | 128d? | 2007-12-05 A | 2008-05-30 A | 100% | 2007-12-05 | 2008-05-30 | 128d? | finish no earlier than 2008-12-25 | C5 | 1024h | 1024h | OSA8 | PXWS Framework | Telecom Italia | vincenzo.amorino@telecomitalia.it | Rel-8 | Kimmo | PCG-21 | CP-38 | PCG-21 | CP-40 |
| 436 | 120.3.9 | Delete - Subscriber event notification (22.127 CR 0087 S1-071836) | 128d? | 2007-12-05 A | 2008-05-30 A | 100% | 2007-12-05 | 2008-05-30 | 128d? | finish no earlier than 2008-12-25 | C5 | 1024h | 1024h | OSA8 | PXWS Framework | Telecom Italia | vincenzo.amorino@telecomitalia.it | Rel-8 | Kimmo | PCG-21 | CP-38 | PCG-21 | CP-40 |
| 437 | 120.3.10 | Delete - Event notification (22.127 CR 0088 S1-071762) | 128d? | 2007-12-05 A | 2008-05-30 A | 100% | 2007-12-05 | 2008-05-30 | 128d? | finish no earlier than 2008-12-25 | C5 | 1024h | 1024h | OSA8 | PXWS Framework | Telecom Italia | vincenzo.amorino@telecomitalia.it | Rel-8 | Kimmo | PCG-21 | CP-38 | PCG-21 | CP-40 |
| 438 | 120.3.11 | Delete - Access policy (22.127 CR 0089 S1-071763) | 128d? | 2007-12-05 A | 2008-05-30 A | 100% | 2007-12-05 | 2008-05-30 | 128d? | finish no earlier than 2008-12-25 | C5 | 1024h | 1024h | OSA8 | PXWS Framework | Telecom Italia | vincenzo.amorino@telecomitalia.it | Rel-8 | Kimmo | PCG-21 | CP-38 | PCG-21 | CP-40 |
| 439 | 120.3.12 | Delete - API usage accounting (22.127 CR 0090 S1-071792) | 128d? | 2007-12-05 A | 2008-05-30 A | 100% | 2007-12-05 | 2008-05-30 | 128d? | finish no earlier than 2008-12-25 | C5 | 1024h | 1024h | OSA8 | PXWS Framework | Telecom Italia | vincenzo.amorino@telecomitalia.it | Rel-8 | Kimmo | PCG-21 | CP-38 | PCG-21 | CP-40 |
| 440 | 120.3.13 | Presence alignment with OMA and IETF (22.127 CR 0092 S1-071764) | 128d? | 2007-12-05 A | 2008-05-30 A | 100% | 2007-12-05 | 2008-05-30 | 128d? | finish no earlier than 2008-05-30 | C5 | 1024h | 1024h | OSA8 | 29.199-14/13 | Alcatel-Lucent | unmehopa@alcatel-lucent.com | Rel-8 | Kimmo | PCG-21 | CP-38 |  |  |
| 441 | 120.3.14 | Delete - Service identification (22.127 CR 0095 S1-071837) | 128d? | 2007-12-05 A | 2008-05-30 A | 100% | 2007-12-05 | 2008-05-30 | 128d? | finish no earlier than 2008-05-30 | C5 | 1024h | 1024h | OSA8 | existing 29.199-xy | Ericsson | catherine.mulligan@ericsson.com | Rel-8 | Kimmo | PCG-21 | CP-38 | PCG-21 | CP-40 |
| 442 | 120.3.15 | Framework Enterprise Operator (Service Subscription function) | 102d? | 2008-01-10 A | 2008-05-30 A | 100% | 2008-01-10 | 2008-05-30 | 102d? | finish no earlier than 2008-05-30 | C5 | 816h | 816h | OSA8 | 29.198-03 | Alcatel-Lucent | unmehopa@alcatel-lucent.com | Rel-8 | Kimmo | PCG-21 | CP-39 |  |  |
| 443 | 120.3.16 | Mobility Emergency Location | 102d? | 2008-01-10 A | 2008-05-30 A | 100% | 2008-01-10 | 2008-05-30 | 102d? | finish no earlier than 2008-05-30 | C5 | 816h | 816h | OSA8 | 29.198-06 | Alcatel-Lucent | unmehopa@alcatel-lucent.com | Rel-8 | Kimmo | PCG-21 | CP-39 |  |  |
| 444 | 120.3.17 | Connectivity Manager SCF | 102d? | 2008-01-10 A | 2008-05-30 A | 100% | 2008-01-10 | 2008-05-30 | 102d? |  | C5 | 816h | 816h | OSA8 | 29.198-10 | Alcatel-Lucent | unmehopa@alcatel-lucent.com | Rel-8 | Kimmo | PCG-21 | CP-39 |  |  |
| 445 | 120.3.18 | PAM Presence Agent | 102d? | 2008-01-10 A | 2008-05-30 A | 100% | 2008-01-10 | 2008-05-30 | 102d? | finish no earlier than 2008-05-30 | C5 | 816h | 816h | OSA8 | 29.198-14 | Alcatel-Lucent | unmehopa@alcatel-lucent.com | Rel-8 | Kimmo | PCG-21 | CP-39 |  |  |
| 446 | 121 | **Paging Permission with Access Control (PPACR)** | 389d? | 2007-06-12 A | 2008-12-05 A | 100% | 2007-06-12 | 2008-12-05 | 389d? |  | S1,C1 | 5888h | 5888h | PPACR |  | NTT DoCoMo | Morita Takashi | Rel-8 | Alain |  |  |  |  |
| 447 | 121.1 | Stage 1 for PPACR | 69d? | 2007-06-12 A | 2007-09-14 A | 100% | 2007-06-12 | 2007-09-14 | 69d? | finish no earlier than 2007-09-14 | S1 | 552h | 552h | PPACR-S1 | 22.011 | NTT DoCoMo | Morita Takashi | Rel-8 | Alain |  | SP-37 |  |  |
| 448 | 121.2 | Stage 3 for PPACR (CT1) | 278d? | 2007-11-14 A | 2008-12-05 A | 100% | 2007-11-14 | 2008-12-05 | 278d? | finish no earlier than 2008-12-05 | C1 | 2224h | 2224h | PPACR-CT1 | 24.008, 23.122, 24.301 | NTT DoCoMo |  | Rel-8 | Frederic | PCG-21 | CP-38 |  |  |
| 449 | 122 | **Charging for multi-phases services** | 70d? | 2007-12-06 A | 2008-03-12 A | 100% | 2007-12-06 | 2008-03-12 | 70d? |  | S1 | 560h | 560h | CHRGMPH | 22.115 | Telecom Italia | Marco.DeLuca1@telecomitalia.it | Rel-8 | Alain | PCG-21 | SP-38 |  |  |
| 450 | 122.1 | Stage 1 for CHRGMPH | 70d? | 2007-12-06 A | 2008-03-12 A | 100% | 2007-12-06 | 2008-03-12 | 70d? | start no earlier than 2007-12-06 | S1 | 560h | 560h | CHRGMPH-s1 | 22.115 | Telecom Italia | Marco.DeLuca1@telecomitalia.it | Rel-8 | Alain | PCG-21 | SP-38 |  |  |

Notes:
- 427: CT#40 WID updated CP-070349=>CP-080252. Started work completed. Unfulfilled Rel-8 Stage 1 and New OSA work to be done in OMA. SA1 needs to remove non-fulfilled requirements in 22.127
- 428: CT#40: Work moved to OMA
- 429: CT#40 completed
- 430: CT#40 completed
- 431: CT#40 completed
- 432: CT#40: Work moved to OMA
- 433: SA#38 SP-070853 R8 CRs 22.127 OSA Stage 1. CT#40: Work moved to OMA
- 434: SA#38 SP-070853 R8 CRs 22.127 OSA Stage 1. CT#40: Work moved to OMA
- 435: SA#38 SP-070853 R8 CRs 22.127 OSA Stage 1. CT#40: Work moved to OMA
- 436: SA#38 SP-070853 R8 CRs 22.127 OSA Stage 1. CT#40: Work moved to OMA
- 437: SA#38 SP-070853 R8 CRs 22.127 OSA Stage 1. CT#40: Work moved to OMA
- 438: SA#38 SP-070853 R8 CRs 22.127 OSA Stage 1. CT#40: Work moved to OMA
- 439: SA#38 SP-070853 R8 CRs 22.127 OSA Stage 1. CT#40: Work moved to OMA
- 440: CT#40 completed
- 441: SA#38 SP-070853 R8 CRs 22.127 OSA Stage 1. CT#40: Work moved to OMA
- 442: CT#40 completed
- 443: CT#40 completed
- 444: CT#40 completed
- 445: CT#40 completed
- 446: CT#42 completed. Triggered by Study UID_330016 (PPAC).
- 447: SA#37 completed
- 448: CT#42 completed
- 449: SA#39 Stage 1 completed
- 450: SA#39 completed

| ID | WBS | Task | Duration | Start | Finish | Complete | Remaining | Baseline start | Baseline finish | Baseline duration | Total slack | Constraint | Resources | Work | Actual work | Text1 | Text2 | Text4 | Text6 | Text7 | Text8 | Text11 |
| --- | --- | --- | --- | --- | --- | --- | --- | --- | --- | --- | --- | --- | --- | --- | --- | --- | --- | --- | --- | --- | --- | --- |
| 451 | 123 | **Home NodeB / eNodeB** | 327d? | 2007-12-06 A | 2009-03-06 A | 100% |  | 2007-12-06 | 2009-03-06 | 327d? |  |  | S1,C1,C4 | 5720h | 5720h | HomeNB | PCG-21 | Vodafone | Rel-8 | SP-38 | Alain |  |
| 452 | 123.1 | Stage 1 for HNB_eHNB | 70d? | 2007-12-06 A | 2008-03-12 A | 100% |  | 2007-12-06 | 2008-03-12 | 70d? |  | start no earlier than 2007-12-06 | S1 | 560h | 560h | HomeNB-S1 | PCG-21 | Vodafone | Rel-8 | SP-38 | Alain |  |
| 453 | 123.2 | CSG and Idle Mode Mobility for LTE Home eNodeB | 126d? | 2008-09-12 A | 2009-03-06 A | 100% |  | 2008-09-12 | 2009-03-06 | 126d? |  | finish no earlier than 2009-03-06 | C1 | 1008h | 1008h | HomeNB-LTE | PCG-21 | Huawei | Rel-8 | CP-41 | Frederic |  |
| 454 | 123.3 | CSG and Idle Mode Mobility for 3G Home NodeB | 126d? | 2008-09-12 A | 2009-03-06 A | 100% |  | 2008-09-12 | 2009-03-06 | 126d? |  | finish no earlier than 2009-03-06 | C1 | 1008h | 1008h | HomeNB-3G | PCG-21 | Qualcomm | Rel-8 | CP-41 | Frederic |  |
| 455 | 123.4 | Support of Closed Subscriber Group (CSG) | 66d? | 2008-12-05 A | 2009-03-06 A | 100% |  | 2008-12-05 | 2009-03-06 | 66d? |  | finish no earlier than 2009-03-06 | C4 | 528h | 528h | HomeNB | PCG-22 | CT#42 | Rel-8 | CP-42 | Kimmo | CT#42 report |
| 456 | 124 | **UTRA HNB** | 325d? | 2008-03-07 A | 2009-06-04 | 98% | 5.66d? | 2008-03-07 | 2009-06-04 | 325d? | 201d |  | RP,S5 | 6824h | 5691.2h | HNB | PCG-21 |  | Rel-8 | SP-39 | Stefania |  |
| 457 | 124.1 | Support of UTRA HNB | 201d? | 2008-05-30 A | 2009-03-06 A | 100% |  | 2008-05-30 | 2009-03-06 | 201d? |  | finish no earlier than 2009-03-06 | R2 | 1608h | 1608h | HNB-supp | PCG-21 | Huawei | Rel-8 | SP-40 | Joern | RP-090040 |
| 458 | 124.2 | FDD Home NodeB RF requirements | 261d? | 2008-03-07 A | 2009-03-06 A | 100% |  | 2008-03-07 | 2009-03-06 | 261d? |  | finish no earlier than 2009-03-06 | R4 | 2088h | 2088h | HNB-RF | PCG-21 | Motorola | Rel-8 | SP-39 | Stefania | RP-090041 |
| 459 | 124.3 | UTRAN Architecture for 3G HNB | 136d? | 2008-05-30 A | 2008-12-05 A | 100% |  | 2008-05-30 | 2008-12-05 | 136d? |  | finish no earlier than 2008-12-05 | R3 | 1088h | 1088h | HNB-arch | PCG-21 | Alcatel-Lucent | Rel-8 | SP-40 | Gert | RP-090042 |
| 460 | 124.4 | 3G Home NodeB OAM&P (Interface Type 1 Management) | 126d? | 2008-12-11 A | 2009-06-04 | 90% | 12.6d? | 2008-12-11 | 2009-06-04 | 126d? | 201d | finish no earlier than 2009-06-04 | S5 | 1008h | 907.2h | HNB-3G_OAM | PCG-22 | Huawei | Rel-8 | SP-42 | Dionisio |  |
| 461 | 125 | **UTRA HNB – UE Conformance Testing** | 196d? | 2009-03-06 | 2009-12-04 |  |  | 2009-03-06 | 2009-12-04 | 196d? | 70d |  | R5 | 3136h |  | HNB-UEConTest | PCG-22 |  | Rel-8 | RP-43 | Ingbert |  |
| 462 | 125.1 | Conformance Test Aspects – UTRA HNB (FDD) | 196d? | 2009-03-06 | 2009-12-04 |  |  | 2009-03-06 | 2009-12-04 | 196d? | 70d | finish no earlier than 2009-12-04 | R5 | 1568h |  | HNB-UEConTestFDD | PCG-22 | Huawei | Rel-8 | RP-43 | Ingbert |  |
| 463 | 126 | Lawful Interception in the 3GPP Rel-8 | 524d? | 2007-03-12 A | 2009-03-12 A | 100% |  | 2007-03-12 | 2009-03-12 | 524d? |  | finish no earlier than 2009-03-12 | S3 | 4192h | 4192h | LI8 |  | BMWi, Verizon | Rel-8 |  | Dionisio |  |
| 464 | 127 | **Generic Bootstrapping Architecture Push Function** | 258d? | 2008-03-12 A | 2009-03-06 A | 100% |  | 2008-03-12 | 2009-03-06 | 258d? |  |  | S3,C1,C4 | 6468.8h | 6468.8h | GBAPush | PCG-21 | Ericsson | Rel-8 | SP-39 | Dionisio |  |
| 465 | 127.1 | SA3 part of GBAPush (33.223) | 193d? | 2008-03-12 A | 2008-12-05 A | 100% |  | 2008-03-12 | 2008-12-05 | 193d? |  | finish no earlier than 2008-12-05 | S3 | 1544h | 1544h | GBAPush | PCG-21 | Ericsson | Rel-8 | SP-39 | Dionisio |  |
| 466 | 127.2 | CT1 part of GBAPush | 178.8d? | 2008-03-12 A | 2009-03-06 A | 100% |  | 2008-03-12 | 2009-03-06 | 178.8d? |  | finish no earlier than 2009-03-06 | C1 | 1430.4h | 1430.4h | GBAPush | PCG-21 | Ericsson | Rel-8 | SP-39 | Frederic |  |
| 467 | 127.3 | CT4 part of GBAPush | 178.8d? | 2008-03-12 A | 2009-03-06 A | 100% |  | 2008-03-12 | 2009-03-06 | 178.8d? |  | finish no earlier than 2009-03-06 | C4 | 1430.4h | 1430.4h | GBAPush | PCG-21 | Ericsson | Rel-8 | SP-39 | Kimmo |  |
| 468 | 128 | Requirements and Test methods for Wideband Terminals | 197d? | 2008-03-12 A | 2008-12-11 A | 100% |  | 2008-03-12 | 2008-12-11 | 197d? |  | start no earlier than 2008-03-12 | S4 | 1576h | 1576h | RETEM_WB_T |  | FT, Ericsson | Rel-8 |  | Paolo |  |
| 469 | 129 | Extending PSS and MBMS User Services for optimized Mobile TV | 266d? | 2007-12-06 A | 2008-12-11 A | 100% |  | 2007-12-06 | 2008-12-11 | 266d? |  | finish no earlier than 2008-12-11 | S4 | 2128h | 2128h | PSS_MBMS_OMTV |  | Ericsson | Rel-8 |  | Paolo |  |
| 470 | 130 | **Encoding formats, transport formats and media description signalling for interworking, QoE, and other enhancements to MTSI-MHI** | 331d? | 2007-12-06 A | 2009-03-12 A | 100% |  | 2007-12-06 | 2009-03-12 | 331d? |  |  | S4,C3,C1,C4 | 9640h | 9640h | MTSI_eMHI | PCG-21 | Ericsson, Qualcomm | Rel-8 | SP-40 | Paolo |  |
| 471 | 130.1 | MTSI Video - Dynamic Rate Adaptation/Signalling of Image Size | 331d? | 2007-12-06 A | 2009-03-12 A | 100% |  | 2007-12-06 | 2009-03-12 | 331d? |  | finish no earlier than 2009-03-12 | S4 | 2648h | 2648h | MTSI_eMHI-DRASIS |  | Qualcomm, Samsung | Rel-8 |  | Paolo |  |
| 472 | 130.2 | CT3 part of Enhancement of interworking between MTSI and CS networks | 201d? | 2008-05-30 A | 2009-03-06 A | 100% |  | 2008-05-30 | 2009-03-06 | 201d? |  | finish no earlier than 2009-03-06 | C3 | 1608h | 1608h | MTSI_eMHI | PCG-21 | Huawei | Rel-8 | CP-40 | Gwiho |  |
| 473 | 130.3 | CT1 part of Enhancement of interworking between MTSI and CS networks | 141d? | 2008-05-30 A | 2008-12-12 A | 100% |  | 2008-05-30 | 2008-12-12 | 141d? |  | start no earlier than 2008-05-30 | C1 | 1128h | 1128h | MTSI_eMHI | PCG-21 | Huawei | Rel-8 | CP-40 | Frederic |  |
| 474 | 130.4 | CT4 part of Enhancement of interworking between MTSI and CS networks | 201d? | 2008-05-30 A | 2009-03-06 A | 100% |  | 2008-05-30 | 2009-03-06 | 201d? |  | finish no earlier than 2009-03-06 | C4 | 1608h | 1608h | MTSI_eMHI | PCG-21 | Huawei | Rel-8 | CP-40 | Kimmo |  |

Notes:
- 451: CT#43 completed. SA#39 Stage 1 completed / Text5: John Watson
- 452: SA#39 completed / Text3: 22.011, 22.115 / Text5: John Watson
- 453: CT#43 completed. CT#42 Rel-8 extension to 03/09 / Text3: 23.122, 24.301, 24.801, 24.285 / Text5: zhang.peng@huawei.com
- 454: CT#43 completed. CT#42 Rel-8 extension to 03/09 / Text3: 23.122, 24.008, 24.285 / Text5: Osok Song
- 455: CT#43 completed. CT#42 Rel-8 extension to 03/09. SA#42 SP-080874 22.011CR0141 confirmed Requirement to support roaming subscribers with CSG home network subscription but did NOT confirmed requirement for home network independent support of roamers in CSG / Text3: 29.002, 29.272, 23.008, 23.003 / Text5: Hannu Hietalahti
- 456: RP#43 completed. SA#43 Rel-8 further extension SA5 to 06/09.
- 457: RP#43 completed. RP#42 Rel-8 extension to 03/09. RP#41 WID updated RP-080483=>RP-080752. / Text3: 25.304, 25.306, 25.331, 25.367 / Text5: Yang Xudong (yangxudong@huawei.com)
- 458: RP#43 completed. RP#42 Rel-8 extension to 03/09 / Text3: 25.104, 25.141, 25.967 / Text5: Ying Cai (yingcai@motorola.com)
- 459: RP#42 completed / Text3: 25.401, 25.410, 25.412, 25.413, 25.414, 25.415, 25.467, 25.468, 25.469 / Text5: Martin Warner (mw15@alcatel-lucent.com)
- 460: SA#43 Rel-8 further extension to 06/09 (SP-090047). SA#42 Rel-8 extension to 03/09. Complements work in the Broadband Forum. / Text3: 32.581, 32.582, 32.583, 32.584 / Text5: Zou Lan (zlan@huawei.com)
- 461: testing for Feature UID_390033 UTRA HNB
- 462: Text3: 34.108, 34.123-1, 34.123-2, 34.123-3 / Text5: Trica Li (trica_li@huawei.com)
- 463: SA#43 completed. SA#42 extension 12/08=>03/09. SA#40/41 each 3-months extensions granted / Text3: 33.106, 33.107, 33.108 / Text5: berthold.wilhelm@bnetza.de, ron_ryan@verizon.net
- 464: CT#43 completed / Text5: Rolf Blom
- 465: SA#42 completed 33.223 as Rel-8. TS 33.224 moved to Rel-9 under new UID_420039 / Text3: 33.223 / Text5: Rolf Blom
- 466: CT#43 completed. WID updated SP-080133=>CP-090112. CT#42 Rel-8 extension to 03/09 / Text3: 24.109 / Text5: Rolf Blom
- 467: CT#43 completed. WID updated SP-080133=>CP-090112. CT#42 Rel-8 extension to 03/09 / Text3: 29.109 / Text5: Rolf Blom
- 468: SA#42 completed. SA#39 WID approved. / Text3: 26.131, 26.132 / Text5: stephane.ragot@orange-ftgroup.com, wanqing.shi@sonyericsson.com
- 469: SA#42 completed. SA#38 WID approved. / Text3: 26.234, 26.346, 26.946 / Text5: thorsten.lohmar@ericsson.com
- 470: TSG#43 completed. TSG#42 Rel-8 extension to 03/09 / Text5: olle.franceschi@ericsson.com, nleung@qualcomm.com
- 471: SA#43 completed. SA#42 Rel-8 extension to 03/09. SA#40 WID updated SP-070755=>SP-080246. [Feature=>BB under new Feature UID_400028 (MTSI)] / Text3: 26.114 / Text5: nleung@qualcomm.com & kyunghun.jung@samsung.com
- 472: CT#43 completed. CT#42 Rel-8 extension to 03/09 / Text3: 29.163 / Text5: Tingfang Tang (tagna_online@huawei.com)
- 473: CT#42 completed (No CT1-impact). WID updated CP-080422=>CP-080774 / Text5: Tingfang Tang (tagna_online@huawei.com)
- 474: CT#43 completed. CT#42 Rel-8 extension to 03/09 / Text3: 29.332 / Text5: Tingfang Tang (tagna_online@huawei.com)

| ID | WBS | Task | Duration | Start | Finish | Complete | Baseline start | Baseline finish | Baseline duration | Constraint | Resources | Work | Actual work | Text1 | Text6 | Text8 | Text4 | Text5 | Text7 | Text9 | Text12 | Text2 |
| --- | --- | --- | --- | --- | --- | --- | --- | --- | --- | --- | --- | --- | --- | --- | --- | --- | --- | --- | --- | --- | --- | --- |
| 475 | 131 | **OAM&P 8** | 461d? | 2007-06-07 A | 2009-03-12 A | 100% | 2007-06-07 | 2009-03-12 | 461d? |  | S5,C1 | 39739.2h | 39739.2h | OAM8 | Rel-8 | Dionisio |  |  |  |  |  |  |
| 476 | 131.1 | **Network Infrastructure Management** | 461d? | 2007-06-07 A | 2009-03-12 A | 100% | 2007-06-07 | 2009-03-12 | 461d? |  | S5 | 17512h | 17512h | OAM8-NIM | Rel-8 | Dionisio |  |  |  |  |  |  |
| 477 | 131.1.1 | Telecom Management Methodology | 461d? | 2007-06-07 A | 2009-03-12 A | 100% | 2007-06-07 | 2009-03-12 | 461d? | finish no earlier than 2009-03-12 | S5 | 3688h | 3688h | OAM8 | Rel-8 | Dionisio | Ericsson | thomas.tovinger@ericsson.com |  |  |  |  |
| 478 | 131.1.2 | Advanced Alarming on Itf-N | 266d? | 2007-06-07 A | 2008-06-12 A | 100% | 2007-06-07 | 2008-06-12 | 266d? | finish no earlier than 2008-12-11 | S5 | 2128h | 2128h | OAM8 | Rel-8 | Dionisio | Nokia Siemens Networks | SUERBAUM, Clemens |  |  |  |  |
| 479 | 131.1.3 | CN CS Bearer Transport Network (BTN) relative NRM | 266d? | 2007-06-07 A | 2008-06-12 A | 100% | 2007-06-07 | 2008-06-12 | 266d? | finish no earlier than 2008-12-11 | S5 | 2128h | 2128h | OAM8 | Rel-8 | Dionisio | China Mobile | LI, Jian |  |  |  |  |
| 480 | 131.1.4 | Deleted - End point modelling for reference point | 324d? | 2007-09-17 A | 2008-12-11 A | 100% | 2007-09-17 | 2008-12-11 | 324d? | finish no earlier than 2008-12-11 | S5 | 2592h | 2592h | OAM8 | Rel-8 | Dionisio | Motorola | YAO, Yizhi | SP-37 | PCG-21 | SP-41 |  |
| 481 | 131.1.5 | Alignment with eTOM and M.3060 architectural concepts | 210d? | 2008-02-22 A | 2008-12-11 A | 100% | 2008-02-22 | 2008-12-11 | 210d? | start no earlier than 2008-02-22 | S5 | 1680h | 1680h | OAM8 | Rel-8 | Dionisio | TeliaSonera | Berggren, Tommy | SP-39 |  |  | PCG-21 |
| 482 | 131.1.6 | IRP SOAP Solution Sets | 201d? | 2008-06-05 A | 2009-03-12 A | 100% | 2008-06-05 | 2009-03-12 | 201d? | finish no earlier than 2009-03-12 | S5 | 1608h | 1608h | OAM8 | Rel-8 | Dionisio | Ericsson | edwin.tse@ericsson.com | SP-40 |  |  | PCG-21 |
| 483 | 131.2 | **Performance Management** | 461d? | 2007-06-07 A | 2009-03-12 A | 100% | 2007-06-07 | 2009-03-12 | 461d? |  | S5 | 13712h | 13712h | OAM8-PM | Rel-8 | Dionisio |  |  |  |  |  |  |
| 484 | 131.2.1 | IP bearer network Performance measurement definitions | 396d? | 2007-06-07 A | 2008-12-11 A | 100% | 2007-06-07 | 2008-12-11 | 396d? | finish no earlier than 2008-12-11 | S5 | 3168h | 3168h | OAM8 | Rel-8 | Dionisio | China Mobile | lilianyuan@chinamobile.com |  |  |  |  |
| 485 | 131.2.2 | HSUPA performance measurements | 396d? | 2007-06-07 A | 2008-12-11 A | 100% | 2007-06-07 | 2008-12-11 | 396d? | finish no earlier than 2008-12-11 | S5 | 3168h | 3168h | OAM8 | Rel-8 | Dionisio | China Mobile | LI, Jian |  |  |  |  |
| 486 | 131.2.3 | Key Performance Indicators (KPIs) for UMTS and GSM | 461d? | 2007-06-07 A | 2009-03-12 A | 100% | 2007-06-07 | 2009-03-12 | 461d? | finish no earlier than 2009-03-12 | S5 | 3688h | 3688h | OAM8 | Rel-8 | Dionisio | China Mobile | Liang Shuangchun |  |  |  |  |
| 487 | 131.3 | **Trace Management** | 196d? | 2008-03-07 A | 2008-12-05 A | 100% | 2008-03-07 | 2008-12-05 | 196d? |  | S5,C1,C3,C4 | 5777.6h | 5777.6h | OAM8-Trace | Rel-8 | Dionisio |  |  |  |  |  |  |
| 488 | 131.3.1 | Service Level Tracing in IMS | 196d? | 2008-03-07 A | 2008-12-05 A | 100% | 2008-03-07 | 2008-12-05 | 196d? | finish no earlier than 2008-12-05 | C1 | 1568h | 1568h | OAM8-Trace | Rel-8 | Frederic | Vodafone | peter.dawes@vodafone.com |  |  |  |  |
| 489 | 131.3.2 | Service Level Tracing in IMS | 175.4d? | 2008-03-07 A | 2008-12-05 A | 100% | 2008-03-07 | 2008-12-05 | 175.4d? | finish no earlier than 2008-12-05 | C3 | 1403.2h | 1403.2h | OAM8-Trace | Rel-8 | Gwiho | Vodafone | peter.dawes@vodafone.com | CP-40 |  |  | PCG-21 |
| 490 | 131.3.3 | Service Level Tracing in IMS | 175.4d? | 2008-03-07 A | 2008-12-05 A | 100% | 2008-03-07 | 2008-12-05 | 175.4d? | finish no earlier than 2008-12-05 | C4 | 1403.2h | 1403.2h | OAM8-Trace | Rel-8 | Frederic | Vodafone | peter.dawes@vodafone.com | CP-40 |  |  | PCG-21 |
| 491 | 132 | **Charging Management small Enhancements** | 716d? | 2006-03-16 A | 2008-12-11 A | 100% | 2006-03-16 | 2008-12-11 | 716d? |  | S5 | 12544h | 12544h | CH8 | Rel-8 | Dionisio |  |  |  |  |  |  |
| 492 | 132.1 | Online charging correlation | 457d? | 2006-03-16 A | 2007-12-14 A | 100% | 2006-03-16 | 2007-12-14 | 457d? | start no earlier than 2006-03-16 | S5 | 3656h | 3656h | CH8 | Rel-8 | Dionisio | Orange | Chahine, Rony |  |  |  |  |
| 493 | 132.2 | SMS online charging | 137d? | 2007-06-07 A | 2007-12-14 A | 100% | 2007-06-07 | 2007-12-14 | 137d? | finish no earlier than 2007-12-14 | S5 | 1096h | 1096h | CH8 | Rel-8 | Dionisio | Vodafone | WONG, Gavin |  |  |  |  |
| 494 | 132.3 | Introduce Online Charging from SMS-SC into the SMS Charging Specifications | 61d? | 2008-09-18 A | 2008-12-11 A | 100% | 2008-09-18 | 2008-12-11 | 61d? | finish no earlier than 2008-12-11 | S5 | 488h | 488h | CH8 | Rel-8 | Dionisio | Acision | Gebler, Erik - Acision [erik.gebler (at) acision.com] | SP-41 |  |  | PCG-21 |
| 495 | 132.4 | Deleted - WLAN Offline Charging | 244d? | 2008-01-07 A | 2008-12-11 A | 100% | 2008-01-07 | 2008-12-11 | 244d? | finish no earlier than 2008-12-11 | S5 | 1952h | 1952h | CH8 | Rel-8 | Dionisio | Alcatel-Lucent | GARDELLA, Maryse | SP-38 | PCG-22 | SP-42 | PCG-21 |
| 496 | 133 | **Conferencing enhancements for Mp interface** | 266d? | 2007-11-30 A | 2008-12-05 A | 100% | 2007-11-30 | 2008-12-05 | 266d? |  | C4 | 6384h | 6384h | eMp | Rel-8 | Kimmo | Huawei | Chencheng@huawei.com |  |  |  | PCG-21 |
| 497 | 133.1 | Stage 2 for eMp | 266d? | 2007-11-30 A | 2008-12-05 A | 100% | 2007-11-30 | 2008-12-05 | 266d? | finish no earlier than 2008-12-11 | C4 | 2128h | 2128h | eMp | Rel-8 | Kimmo | Huawei | Chencheng@huawei.com | CP-38 |  |  | PCG-21 |
| 498 | 133.2 | Stage 3 for eMp | 266d? | 2007-11-30 A | 2008-12-05 A | 100% | 2007-11-30 | 2008-12-05 | 266d? | finish no earlier than 2008-12-05 | C4 | 2128h | 2128h | eMp | Rel-8 | Kimmo | Huawei | Chencheng@huawei.com | CP-38 |  |  | PCG-21 |

Notes:
- 477: SA#43 completed. SA#42 Rel-8 extension to 03/09 / Text3: 32.155, 32.153
- 478: SA#40 completed / Text3: 32.121, 32.122, 32.123
- 479: SA#40 completed / Text3: 32.632/3/5
- 480: SA#41 Work stopped. Contributions related to E-UTRAN/EPC to be submitted to UID_380036 E-UTRAN NRM IRP/ UID_380037 EPC NRM IRP / Text3: 32.152, 32.62/3/4x, 32.73x
- 481: SA#42 completed / Text3: 32.101/2, 32-series
- 482: SA#43 completed. WID updated SP-080276=>SP-090148. SA#42 Rel-8 extension to 03/09 / Text3: 32.111-7, 32.617, 32.417, 32.367, 32.347, 32.111-1, 32.111-2, 32.111-3, 32.111-5, 32.307, 32.317, 32.341, 32.342, 32.343, 32.345, 32.361, 32.362, 32.363, 32.365, 32.411, 32.412, 32.413, 32.415, 32.611, 32.612, 32.613, 32.615, 32.625
- 484: SA#42 completed. SA#36 WID updated SP-050319=>SP-070301 / Text3: 32.321/2/3/5
- 485: SA#42 completed / Text3: 32.405
- 486: SA#43 completed. SA#42 Rel-8 extension to 03/09 / Text3: 32.410
- 488: CT#42 completed. CT#40 WID updated CP-060521=>CP-080315. / Text3: 24.323, 24.229
- 489: CT#42 completed (No CT3-impact). CT#40 WID updated CP-060521=>CP-080315
- 490: CT#42 completed. CT#40 WID updated CP-060521=>CP-080315. / Text3: 29.228, 29.229
- 491: SA#42 completed.
- 492: SA#38 completed / Text3: 32.296
- 493: SA#38 completed / Text3: 32.274, 32.240/299
- 494: SA#42 completed. Linked to SA2 UID 32081 (Support of SMS over IP networks) and CT4 UID 340016 (Routeing of MT-SMS via the HPLMN). / Text3: 32.274, 32.299
- 495: SA#42 stopped / Text3: 32.252, 32.298, 32.299
- 496: CT#42 completed. WID updated CP-070868=>CP-080725
- 497: CT#42 completed. WID updated CP-070868=>CP-080725 / Text3: 23.333
- 498: CT#42 completed. WID updated CP-070868=>CP-080725 / Text3: 29.333

| ID | WBS | Task | Type | Duration | Start | Finish | Complete | Remaining | Baseline start | Baseline finish | Baseline duration | Total slack | Constraint | Resources | Work | Actual work | Text1 | Text4 | Text5 | Text6 | Text8 | Text7 | Text12 | Text2 | Text11 |
| --- | --- | --- | --- | --- | --- | --- | --- | --- | --- | --- | --- | --- | --- | --- | --- | --- | --- | --- | --- | --- | --- | --- | --- | --- | --- |
| 499 | 134 | **Contact Manager for 3GPP UICC applications** |  | 642d? | 2006-06-22 A | 2008-12-05 A | 100% |  | 2006-06-22 | 2008-12-05 | 642d? |  |  | C6 | 13352h | 13352h | eUPHBOOK | Gemalto | Jacques.seif@gemalto.com | Rel-8 | Xavier |  |  |  |  |
| 500 | 134.1 | Requirements for Contact Manager |  | 392d? | 2006-06-22 A | 2007-12-21 A | 100% |  | 2006-06-22 | 2007-12-21 | 392d? |  | finish no earlier than 2007-12-21 | C6 | 3136h | 3136h | eUPHBOOK-St1 | Gemalto | Jacques.seif@gemalto.com | Rel-8 | Xavier |  |  |  |  |
| 501 | 134.2 | External interface for eUPHBOOK |  | 220d? | 2007-05-07 A | 2008-03-07 A | 100% |  | 2007-05-07 | 2008-03-07 | 220d? |  | finish no earlier than 2008-03-07 | C6 | 1760h | 1760h | eUPHBOOK-Ext_Spec | Gemalto | Jacques.seif@gemalto.com | Rel-8 | Xavier |  |  |  |  |
| 502 | 134.3 | Internal interface for eUPHBOOK |  | 415d? | 2007-05-07 A | 2008-12-05 A | 100% |  | 2007-05-07 | 2008-12-05 | 415d? |  | finish no earlier than 2008-12-05 | C6 | 3320h | 3320h | eUPHBOOK-Int_Spec | Gemalto | Jacques.seif@gemalto.com | Rel-8 | Xavier | CP-37 |  |  |  |
| 503 | 134.4 | Deleted - Implementation of eUPHBOOK | milestone | 0d? | 2007-06-21 A | 2007-06-21 A | 100% |  | 2007-06-21 | 2007-06-21 | 0d? |  | start no earlier than 2007-06-21 | C6 |  |  | eUPHBOOK-St23 | Giesecke & Devrient | Claus Dietze | Rel-8 | Xavier |  | SP-33 |  |  |
| 504 | 135 | **Contact Manager Conformance Test specifications** |  | 396d? | 2008-05-30 | 2009-12-04 |  |  | 2008-05-30 | 2009-12-04 | 396d? | 70d |  | C6 | 9504h |  | eUPHBOOK-Test | Comprion, Gemalto | Udo Willenbrink, Jacques Seif | Rel-8 | Xavier | CP-40 |  | PCG-21 |  |
| 505 | 135.1 | Contact Manager for 3GPP UICC applications test specifications |  | 396d? | 2008-05-30 | 2009-12-04 |  |  | 2008-05-30 | 2009-12-04 | 396d? | 70d | finish no earlier than 2009-12-04 | C6 | 3168h |  | eUPHBOOK-Test | Comprion | Udo Willenbrink | Rel-8 | Xavier | CP-40 |  |  |  |
| 506 | 135.2 | Contact Manager API for Java™ Card test specification |  | 396d? | 2008-05-30 | 2009-12-04 |  |  | 2008-05-30 | 2009-12-04 | 396d? | 70d | finish no earlier than 2009-12-04 | C6 | 3168h |  | eUPHBOOK-Test | Gemalto | jacques.seif@gemalto.com | Rel-8 | Xavier | CP-40 |  |  |  |
| 507 | 136 | **Rel-8 LTE – 3G Long Term Evolution - Evolved Packet System RAN part** |  | 644d? | 2006-09-25 A | 2009-03-12 A | 100% |  | 2006-09-25 | 2009-03-12 | 644d? |  |  | RP,S5 | 44896h | 44896h | LTE | NTT DoCoMo | Takehiro Nakamura (takehiro@wsp.yrp.nttdocomo.co.jp) | Rel-8 | Stefania |  |  |  | RP-080741 |
| 508 | 136.1 | LTE – Physical Layer |  | 380d? | 2006-09-25 A | 2008-03-07 A | 100% |  | 2006-09-25 | 2008-03-07 | 380d? |  | finish no earlier than 2007-09-14 | R1 | 3040h | 3040h | LTE-Phys | NTT DoCoMo | Sadayuki Abeta | Rel-8 | Patrick |  |  |  | RP-080741 |
| 509 | 136.2 | LTE – Radio Interface Layer 2 and 3 Protocol Aspect |  | 575d? | 2006-09-25 A | 2008-12-05 A | 100% |  | 2006-09-25 | 2008-12-05 | 575d? |  | finish no earlier than 2008-12-11 | R2 | 4600h | 4600h | LTE-L23 | Nokia Siemens Networks | Benoist Sébire | Rel-8 | Joern |  |  |  | RP-080741 |
| 510 | 136.3 | LTE – eUTRAN Interfaces |  | 575d? | 2006-09-25 A | 2008-12-05 A | 100% |  | 2006-09-25 | 2008-12-05 | 575d? |  | finish no earlier than 2008-12-11 | R3 | 4600h | 4600h | LTE-interfaces | Ericsson | Martin Israelsson | Rel-8 | Gert |  |  |  | RP-080741 |
| 511 | 136.4 | LTE – Evolved UTRA and UTRAN RF Radio Transmission/Reception, System Performance Requirements and Conformance Testing |  | 575d? | 2006-09-25 A | 2008-12-05 A | 100% |  | 2006-09-25 | 2008-12-05 | 575d? |  | finish no earlier than 2008-12-11 | R4 | 4600h | 4600h | LTE-RF | Nokia Siemens Networks | Tuomo Saynajakangas | Rel-8 | Stefania |  |  |  | RP-080741 |
| 512 | 136.5 | LTE – FDD repeaters |  | 386d? | 2007-09-14 A | 2009-03-06 A | 100% |  | 2007-09-14 | 2009-03-06 | 386d? |  | finish no earlier than 2009-03-06 | R4 | 3088h | 3088h | LTE-Repeaters | Powerwave Technologies, Andrew Wireless | ralf.michanikl@andrew.com, Alf.Ahlstrom@pwav.com | Rel-8 | Stefania | RP-37 |  |  | RP-090037 |
| 513 | 136.6 | **E-UTRAN Data Definitions** |  | 389d? | 2007-09-17 A | 2009-03-12 A | 100% |  | 2007-09-17 | 2009-03-12 | 389d? |  |  | S5 | 13096h | 13096h | E-UTRAN-OAM |  |  | Rel-8 | Dionisio | SP-39 |  | PCG-21 |  |
| 514 | 136.6.1 | Subscriber and Equipment Trace for E-UTRAN and EPC |  | 389d? | 2007-09-17 A | 2009-03-12 A | 100% |  | 2007-09-17 | 2009-03-12 | 389d? |  | finish no earlier than 2009-03-12 | S5 | 3112h | 3112h | E-UTRAN-OAM | Ericsson | PETERSEN, Robert | Rel-8 | Dionisio | SP-37 |  |  |  |
| 515 | 136.6.2 | E-UTRAN Network Resource Model (NRM) Integration Reference Point (IRP) |  | 309d? | 2008-01-07 A | 2009-03-12 A | 100% |  | 2008-01-07 | 2009-03-12 | 309d? |  | finish no earlier than 2009-03-12 | S5 | 2472h | 2472h | E-UTRAN-OAM | Ericsson | ELMDAHL, Per | Rel-8 | Dionisio | SP-38 |  | PCG-21 |  |
| 516 | 136.6.3 | Performance measurements for E-UTRAN |  | 275d? | 2008-02-22 A | 2009-03-12 A | 100% |  | 2008-02-22 | 2009-03-12 | 275d? |  | finish no earlier than 2009-03-12 | S5 | 2200h | 2200h | E-UTRAN-OAM | Motorola, Huawei | YAO, Yizhi | Rel-8 | Dionisio | SP-39 |  | PCG-21 |  |
| 517 | 136.6.4 | Key Performance Indicators (KPIs) for E-UTRAN |  | 275d? | 2008-02-22 A | 2009-03-12 A | 100% |  | 2008-02-22 | 2009-03-12 | 275d? |  | finish no earlier than 2009-03-12 | S5 | 2200h | 2200h | E-UTRAN-OAM | Ericsson | HÜBINETTE, Ulf | Rel-8 | Dionisio | SP-39 |  | PCG-21 |  |
| 518 | 136.7 | **Self-Organizing Networks (SON)** |  | 210d? | 2008-02-22 A | 2008-12-11 A | 100% |  | 2008-02-22 | 2008-12-11 | 210d? |  |  | S5 | 6720h | 6720h | LTE_SON-OAM | Vodafone | GOMPAKIS, Panagiotis | Rel-8 | Dionisio | SP-39 |  | PCG-21 |  |
| 519 | 136.7.1 | SON Concepts and requirements |  | 210d? | 2008-02-22 A | 2008-12-11 A | 100% |  | 2008-02-22 | 2008-12-11 | 210d? |  |  | S5 | 1680h | 1680h | LTE_SON-OAM | Vodafone | GOMPAKIS, Panagiotis | Rel-8 | Dionisio | SP-39 |  | PCG-21 |  |
| 520 | 136.7.2 | Self-Establishment of eNBs, including automated Software Management |  | 210d? | 2008-02-22 A | 2008-12-11 A | 100% |  | 2008-02-22 | 2008-12-11 | 210d? |  | start no earlier than 2008-02-22 | S5 | 1680h | 1680h | LTE_SON-OAM | Nokia Siemens Networks | SUERBAUM, Clemens | Rel-8 | Dionisio | SP-39 |  | PCG-21 |  |
| 521 | 136.7.3 | SON Automatic Neighbour Relations (ANR) List Management |  | 210d? | 2008-02-22 A | 2008-12-11 A | 100% |  | 2008-02-22 | 2008-12-11 | 210d? |  | finish no earlier than 2008-12-11 | S5 | 1680h | 1680h | LTE_SON-OAM | Ericsson | edwin.tse@ericsson.com | Rel-8 | Dionisio | SP-39 |  | PCG-21 |  |
| 522 | 137 | **Rel-8 LTE – Terminal Conformance Test Specification** |  | 656d? | 2007-06-01 A | 2009-12-04 | 55% | 293.94d? | 2007-06-01 | 2009-12-04 | 656d? | 70d |  | R5 | 20328h | 11219.3h | LTE-UEConTest |  |  | Rel-8 | Ingbert |  |  |  |  |
| 523 | 137.1 | 3G LTE – Terminal Protocol Conformance Test Specifications |  | 601d? | 2007-06-01 A | 2009-09-18 | 55% | 273.2d? | 2007-06-01 | 2009-09-18 | 601d? | 125d | finish no earlier than 2009-09-18 | R5 | 4808h | 2622.4h | LTE-UEConTest_SIG | NEC, Motorola | david.lecompte@nectech.fr, Jacob.John@motorola.com | Rel-8 | Ingbert |  |  |  | RP-090038 |
| 524 | 137.2 | LTE – Terminal Radio Transmission and Reception Conformance Test Specifications (FDD) |  | 601d? | 2007-06-01 A | 2009-09-18 | 70% | 180.3d? | 2007-06-01 | 2009-09-18 | 601d? | 125d | finish no earlier than 2009-09-18 | R5 | 4808h | 3365.6h | LTE-UEConTest_RF_FDD | Agilent | andrea_leonardi@agilent.com | Rel-8 | Ingbert |  |  |  | RP-090039 |
| 525 | 137.3 | LTE – Terminal Radio Transmission and Reception Conformance Test Specifications (TDD) |  | 601d? | 2007-06-01 A | 2009-09-18 | 65% | 210.35d? | 2007-06-01 | 2009-09-18 | 601d? | 125d | finish no earlier than 2009-09-18 | R5 | 4808h | 3125.2h | LTE-UEConTest_RF_TDD | Agilent | andrea_leonardi@agilent.com | Rel-8 | Ingbert | RP-41 |  | PCG-21 | RP-090039 |
| 526 | 137.4 | LTE 3500 – Conformance Test Aspects |  | 261d? | 2008-12-05 | 2009-12-04 |  |  | 2008-12-05 | 2009-12-04 | 261d? | 70d | finish no earlier than 2009-12-04 | R5 | 2088h |  | LTE-UEConTest_LTE3500 | Ericsson | fredrik.sundstrom@ericsson.com |  | Ingbert | RP-42 |  | PCG-22 | RP-090063 |

Notes:
- 499: CT#42 completed. CT#40: WID updated CP-070622=>CP-080382. aka Enhanced USIM phonebook
- 500: CT#38 completed / Text3: 21.111
- 501: CT#39 completed / Text3: 31.220
- 502: CT#42 completed / Text3: 31.221
- 503: SA#33 stopped / Text3: 31.102
- 504: CT#42 work not started
- 505: CT#42 work not started / Text3: 31.320 (external interface for communication with the ME)
- 506: CT#42 work not started / Text3: 31.321 (internal interface (API))
- 507: RP#43 completed. RP#42 Rel-8 extension for UID_370046 (LTE FDD repeaters) to 03/09. / Text3: 36.300, 36.938
- 508: RP#39 completed. / Text3: 36.201, 36.211, 36.212, 36.213, 36.214, 25.215, 25.225
- 509: RP#42 completed. ASN.1 freezing target 03/09 / Text3: 36.302, 36.304, 36.306, 36.314, 36.321, 36.322, 36.323, 36.331, 25.302, 25.304, 25.331
- 510: RP#42 completed / Text3: 36.401, 36.410, 36.411, 36.412, 36.413, 36.414, 36.420, 36.421, 36.422, 36.423, 36.424, 36.902, 25.413
- 511: RP#42 completed (closed at 95%) / Text3: 36.101, 36.104, 36.113, 36.124, 36.133, 36.141, 36.942, 25.123, 25.133
- 512: RP#43 completed. RP#42 Rel-8 extension to 03/09 / Text3: 36.106, 36.143, 25.113
- 513: SA#43 completed
- 514: SA#43 completed. SA#42 Rel-8 extension to 03/09 / Text3: 32.42x, 32.44x
- 515: SA#43 completed. SA#42 Rel-8 extension to 03/09 / Text3: 32.761/2/3/5
- 516: SA#43 completed. SA#42 Rel-8 extension to 03/09 / Text3: 32.425
- 517: SA#43 completed. SA#42 Rel-8 extension to 03/09 / Text3: 32.450, 32.451
- 518: SA#42 completed (WT UID_390007 moved to Rel-9). SA#40 updated WID SP-080064=>SP-080275.
- 519: SA#42 completed. SA#40 updated WID SP-080064=>SP-080275. SA#41 UID_390004 split to monitor 32.500 progress. / Text3: 32.500
- 520: SA#42 completed. WID updated SP-080065=>SP-080849 / Text3: 32.501, 32.502, 32.531, 32.532, 32.533, 32.537
- 521: SA#42 completed / Text3: 32.511, 32.761/2/3/5
- 522: Testing for Feature UID_20068 (LTE)
- 523: RP#43 Completion target 03/09=>09/09 / Text3: 36.521-1, 36.521-2, 36.508, 36.509, 36.523-1, 36.523-2
- 524: RP#43 Completion target 03/09=>09/09 / Text3: 36.521-1, 36.521-2, 36.521-3, 36.508, 36.509, 36.903
- 525: RP#43 Completion target 03/09=>09/09 / Text3: 36.521-1, 36.521-2, 36.521-3, 36.508, 36.509, 36.903
- 526: RP#42 WID approved. Testing for UID_380073 / Text3: 36.508, 36.521-1, 36.521-2, 36.521-3

| ID | WBS | Task | Duration | Start | Finish | Complete | Remaining | Baseline start | Baseline finish | Baseline duration | Total slack | Constraint | Resources | Work | Actual work | Text1 | Text6 | Text8 | Text4 | Text5 | Text11 | Text2 | Text7 | Text9 | Text12 |
| --- | --- | --- | --- | --- | --- | --- | --- | --- | --- | --- | --- | --- | --- | --- | --- | --- | --- | --- | --- | --- | --- | --- | --- | --- | --- |
| 527 | 138 | **Rel-8 Improvements of the Radio Interface** | 585d? | 2007-03-05 A | 2009-05-29 | 88% | 68.03d? | 2007-03-05 | 2009-05-29 | 585d? | 205d |  | RP | 21672h | 15656h | RInImp8 | Rel-8 | Stefania |  |  |  |  |  |  |  |
| 528 | 138.1 | UMTS 1500 MHz | 140d? | 2007-03-05 A | 2007-09-14 A | 100% |  | 2007-03-05 | 2007-09-14 | 140d? |  | finish no earlier than 2007-09-14 | R4 | 1120h | 1120h | RInImp8-UMTS1500 | Rel-8 | Stefania | NTT DoCoMo | Takehiro Nakamura (takehiro@wsp.yrp.nttdocomo.co.jp) | RP-070526 |  |  |  |  |
| 529 | 138.2 | UMTS 700 MHz FDD | 325d? | 2007-03-05 A | 2008-05-30 A | 100% |  | 2007-03-05 | 2008-05-30 | 325d? |  | finish no earlier than 2008-06-12 | R4 | 2600h | 2600h | RInImp8-UMTS700 | Rel-8 | Stefania | Nokia | Tuomo Saynajakangas | RP-080260 |  |  |  |  |
| 530 | 138.3 | UMTS 2300 MHz TDD LCR | 195d? | 2007-12-17 A | 2008-09-12 A | 100% |  | 2007-12-17 | 2008-09-12 | 195d? |  | finish no earlier than 2008-09-12 | R4 | 1560h | 1560h | RInImp8-UMTS2300TDD | Rel-8 | Stefania | CATT | songyuexia@datangmobile.cn | RP-080517 | PCG-21 | RP-38 |  |  |
| 531 | 138.4 | UMTS/LTE 3500 MHz | 380d? | 2007-12-17 A | 2009-05-29 | 35% | 247d? | 2007-12-17 | 2009-05-29 | 380d? | 205d | finish no earlier than 2009-05-29 | R4 | 3040h | 1064h | RInImp8-UMTSLTE3500 |  | Stefania | Ericsson | Johan Sköld (johan.skold@ericsson.com) | RP-090043 | PCG-21 | RP-38 |  |  |
| 532 | 138.5 | Further Improved Minimum Performance Requirements for HSDPA UE (FDD) - Two-Branch Interference Cancellation | 265d? | 2007-03-05 A | 2008-03-07 A | 100% |  | 2007-03-05 | 2008-03-07 | 265d? |  | finish no earlier than 2008-03-12 | R4 | 2120h | 2120h | RInImp8-2BIC | Rel-8 | Stefania | AT&T | Marc Grant | RP-080041 |  |  |  |  |
| 533 | 138.6 | CS Voice Service over HSPA | 167d? | 2007-07-19 A | 2008-03-07 A | 100% |  | 2007-07-19 | 2008-03-07 | 167d? |  |  | R2 | 1336h | 1336h | RInImp8-CsHspa | Rel-8 | Joern | Nokia Siemens Networks | woonhee.hwang@nsn.com | RP-080042 |  | RP-37 |  |  |
| 534 | 138.7 | Performance requirements for 15 code reception with 16QAM/QPSK | 126d? | 2007-06-11 A | 2008-03-07 A | 100% |  | 2007-06-11 | 2008-03-07 | 126d? |  | finish no earlier than 2008-06-12 | R4 | 1008h | 1008h | RInImp8-Hsdpa15codes | Rel-8 | Stefania | Vodafone | tim.frost@vodafone.com | RP-080043 |  | RP-37 |  |  |
| 535 | 138.8 | UMTS 1880 MHz TDD | 126d? | 2008-09-12 A | 2009-03-06 A | 100% |  | 2008-09-12 | 2009-03-06 | 126d? |  | finish no earlier than 2009-03-09 | R4 | 1008h | 1008h | RInImp9-UMTS1880TDD | Rel-8 | Stefania | CATT | Yuexia Song (songyuexia@datangmobile.cn) | RP-090044 | PCG-21 | RP-41 |  |  |
| 536 | 138.9 | Deleted - UMTS 2300 MHz FDD/TDD | 400d? | 2007-03-05 A | 2008-09-12 A | 100% |  | 2007-03-05 | 2008-09-12 | 400d? |  | finish no earlier than 2008-12-11 | R4 | 3200h | 3200h | RInImp8-UMTS2300 | Rel-8 | Stefania | AT&T | Marc Grant | RP-080515 |  |  | PCG-21 | RP-41 |
| 537 | 139 | **Rel-8 Improvements of the Radio Interface - UE Conformance Testing** | 656d? | 2007-06-01 A | 2009-12-04 | 67% | 216.18d? | 2007-06-01 | 2009-12-04 | 656d? | 70d |  | R5 | 10424h | 6988.82h | RInImp-UEConTest | Rel-8 | Ingbert |  |  |  |  |  |  |  |
| 538 | 139.1 | Conformance Test Aspects – CS Voice Service over HSPA | 336d? | 2007-06-01 A | 2008-09-12 A | 100% |  | 2007-06-01 | 2008-09-12 | 336d? |  | finish no earlier than 2008-09-12 | R5 | 2688h | 2688h | RInImp8-CsHspa_UEConTest | Rel-8 | Ingbert | Huawei | baoyi@huawei.com | RP-080542 |  |  |  |  |
| 539 | 139.2 | Conformance Test Aspects – Performance requirements for 15 code reception with 16QAM/QPSK (FDD) | 195d? | 2008-03-07 A | 2008-12-05 A | 100% |  | 2008-03-07 | 2008-12-05 | 195d? |  | finish no earlier than 2008-12-05 | R5 | 1560h | 1560h | RInImp8-UEConTest_ Hsdpa15codes | Rel-8 | Ingbert | Ericsson | Mikael.Ziren@Ericsson.com | RP-080818 | PCG-21 | RP-40 |  |  |
| 540 | 139.3 | UMTS 3500 – Conformance Test Aspects | 261d? | 2008-12-05 | 2009-12-04 |  |  | 2008-12-05 | 2009-12-04 | 261d? | 70d | finish no earlier than 2009-12-04 | R5 | 2088h |  | RInImp-UEConTest_UMTS3500 |  | Ingbert | Nokia | jukka.vikstedt@nokia.com | RP-090064 | PCG-22 | RP-42 |  |  |
| 541 | 140 | **Rel-8 RAN improvements** | 655d? | 2007-06-04 A | 2009-12-04 | 91% | 59.08d? | 2007-06-04 | 2009-12-04 | 655d? | 70d |  | RP | 35528h | 32323.3h | RANimp | Rel-8 | Stefania |  |  |  |  |  |  |  |
| 542 | 140.1 | Combination of 64QAM and MIMO for HSDPA (FDD) | 205d? | 2007-06-04 A | 2008-09-12 A | 100% |  | 2007-06-04 | 2008-09-12 | 205d? |  | finish no earlier than 2008-09-12 | R1 | 1640h | 1640h | RANimp-64QamMimoHsdpa | Rel-8 | Patrick | Ericsson | Johan.Bergman@ericsson.com | RP-080518 |  |  |  |  |
| 543 | 140.2 | Improved L2 for uplink | 186d? | 2007-09-14 A | 2008-05-30 A | 100% |  | 2007-09-14 | 2008-05-30 | 186d? |  | finish no earlier than 2008-05-30 | R2 | 1488h | 1488h | RANimp-UplinkL2dataRates | Rel-8 | Joern | Ericsson | Janne.Peisa@ericsson.com | RP-080265 |  | RP-37 |  |  |
| 544 | 140.3 | Enhanced Uplink for CELL_FACH State in FDD | 321d? | 2007-09-14 A | 2008-12-05 A | 100% |  | 2007-09-14 | 2008-12-05 | 321d? |  | finish no earlier than 2008-12-12 | R2 | 2568h | 2568h | RANimp-UplinkEnhState | Rel-8 | Joern | Nokia Siemens Networks | markus.wimmer@nsn.com | RP-080804 |  | RP-37 |  |  |
| 545 | 140.4 | Enhanced UE DRX for FDD | 261d? | 2007-09-14 A | 2008-09-12 A | 100% |  | 2007-09-14 | 2008-09-12 | 261d? |  | finish no earlier than 2008-09-12 | R2 | 2088h | 2088h | RANimp-DRX | Rel-8 | Joern | Nokia | luis.barreto@nokia.com | RP-080520 |  | RP-37 |  |  |
| 546 | 140.5 | Enhancements for SRNS Relocation Procedure | 261d? | 2007-09-14 A | 2008-09-12 A | 100% |  | 2007-09-14 | 2008-09-12 | 261d? |  | finish no earlier than 2008-09-12 | R3 | 2088h | 2088h | RANimp-SrnsReloc | Rel-8 | Gert | Nokia Siemens Networks | masatoshi.nakamata@nsn.com | RP-080521 |  | RP-37 |  |  |
| 547 | 140.6 | Enhancements for FDD HSPA Evolution | 321d? | 2007-09-14 A | 2008-12-05 A | 100% |  | 2007-09-14 | 2008-12-05 | 321d? |  | finish no earlier than 2008-12-05 | R3,R2 | 2568h | 2568h | RANimp-HSPAEvo | Rel-8 | Gert | Nokia Siemens Networks | masatoshi.nakamata@nsn.com | RP-080805 |  | RP-37 |  |  |
| 548 | 140.7 | 64QAM for 1.28 Mcps TDD HSDPA | 264d? | 2007-12-04 A | 2008-12-05 A | 100% |  | 2007-12-04 | 2008-12-05 | 264d? |  | finish no earlier than 2008-12-05 | R1 | 2112h | 2112h | RANimp-64Qam1.28TDD | Rel-8 | Patrick | ZTE | zfmail@zte.com.cn | RP-080806 | PCG-21 | RP-38 |  |  |
| 549 | 140.8 | Enhanced CELL_FACH state in 1.28 Mcps TDD | 264d? | 2007-12-04 A | 2008-12-05 A | 100% |  | 2007-12-04 | 2008-12-05 | 264d? |  | finish no earlier than 2008-12-12 | R2 | 2112h | 2112h | RANimp-EnhState1.28TDD | Rel-8 | Joern | ZTE | zhang.yincheng@zte.com.cn | RP-080807 | PCG-21 | RP-38 |  |  |
| 550 | 140.9 | 1.28 Mcps TDD Repeater | 524d? | 2007-12-04 A | 2009-12-04 | 40% | 312.4d? | 2007-12-04 | 2009-12-04 | 524d? | 70d | finish no earlier than 2009-12-04 | R4 | 4192h | 1692.8h | RANimp-Repeaters1.28TDD |  | Stefania | RITT | qinyan@chinattl.com | RP-090048 | PCG-21 | RP-38 |  |  |
| 551 | 140.10 | Continuous Connectivity for packet data users for 1.28 Mcps TDD | 321d? | 2008-03-07 A | 2009-05-29 | 95% | 16.05d? | 2008-03-07 | 2009-05-29 | 321d? | 205d | finish no earlier than 2009-05-29 | R1 | 2568h | 2439.6h | RANimp-LCRCPC | Rel-8 | Patrick | TD Tech | chenying@td-tech.com | RP-090262 | PCG-21 | RP-39 |  |  |
| 552 | 140.11 | HSPA VoIP to WCDMA/GSM CS continuity | 261d? | 2008-03-07 A | 2009-03-06 A | 100% |  | 2008-03-07 | 2009-03-06 | 261d? |  | finish no earlier than 2009-03-06 | R2 | 2088h | 2088h | RANimp-HSPAVoIP | Rel-8 | Joern | Nokia | Simone.Provvedi@nokia.com | RP-090050 | PCG-21 | RP-39 |  |  |
| 553 | 140.12 | HS-DSCH Serving Cell Change Enhancements | 196d? | 2008-03-07 A | 2008-12-05 A | 100% |  | 2008-03-07 | 2008-12-05 | 196d? |  | finish no earlier than 2008-12-12 | R2 | 1568h | 1568h | RANimp-HSDSCH | Rel-8 | Joern | Ericsson | henrik.enbuske@ericsson.com | RP-080811 | PCG-21 | RP-39 |  |  |
| 554 | 140.13 | MIMO for 1.28 Mcps TDD | 261d? | 2007-11-01 A | 2009-05-29 | 95% | 13.05d? | 2007-11-01 | 2009-05-29 | 261d? | 205d | finish no earlier than 2009-05-29 | R1,R4 | 2088h | 1983.6h | RANimp-MIMOLCR | Rel-8 | Patrick | CATT | wangke@datangmobile.cn | RP-090313 | PCG-21 | RP-40 |  |  |
| 555 | 140.14 | Dual-Cell HSDPA operation on adjacent carriers | 140d? | 2008-05-30 A | 2008-12-11 A | 100% |  | 2008-05-30 | 2008-12-11 | 140d? |  | finish no earlier than 2009-05-29 | R1,R4 | 1120h | 1120h | RANimp-DCHSDPA | Rel-8 | Patrick | Ericsson | johan.bergman@ericsson.com | RP-080814 | PCG-21 | RP-40 |  |  |

Notes:
- 528: SR in RP-070526 / Text3: 25.101, 25.104, 25.133, 25.141, 25.331, 25.942, 25.306, 25.307, 34.121
- 529: SR in RP-080260 / Text3: 25.101, 25.104, 25.133, 25.141, 25.331, 25.942, 25.306, 25.307, 34.121
- 530: SR in RP-080517. RP#41 completed / Text3: 25.102, 25.105, 25.113, 25.123, 25.142, 34.124, 25.306, 25.331, 34.122
- 531: RP#42 WID updated RP-071012=>RP-081096. Testing in UID_420013 & UID_420014 / Text3: 25.101, 25.104, 25.113, 25.133, 25.141, 34.124, 25.307, 25.331, 25.461, 25.463, 36.101, 36.104, 36.141, 25.307, 36.331
- 532: SR in RP-080041.
- 533: SR in RP-080042. / Text3: 25.323, 25.331, 25.322
- 534: SR in RP-080043. / Text3: 25.101
- 535: RP#43 completed as Rel-8 / Text3: 25.102, 25.105, 25.113, 25.123, 25.142, 34.124, 25.307
- 536: SR in RP-080515. RP#41 stopped / Text3: 25.101, 25.104, 25.133, 25.141, 25.331, 25.942, 25.306, 25.307, 34.121
- 537: 05/08: Linked to Feature UID_20028 (RInImp)
- 538: SR in RP-080542. RP#41 completed. / Text3: 34.108, 34.123-1, 34.123-2, 34.123-3
- 539: RP#42 completed. SR in RP-080818. Linked to UID_370033. / Text3: 34.121-1, 34.121-2
- 540: Testing for UID_380073 / Text3: 34.108, 34.121-1, 34.121-2
- 542: SR in RP-080518. RP#41 completed / Text3: 25.308, 25.211, 25.212, 25.213, 25.306, 25.331, 25.433, 25.435, 25.423, 25.425, 25.101, 25.104, 25.141
- 543: SR in RP-080265. RP#40 completed / Text3: 25.319, 25.301, 25.306, 25.321, 25.331, 25.433, 25.435, 25.423, 25.425, 25.427
- 544: SR in RP-080804. RP#42 completed / Text3: 25.309, 25.211, 25.214, 25.321, 25.331, 25.423, 25.433
- 545: SR in RP-080520. RP#41 completed / Text3: 25.306, 25.308, 25.321, 25.331, 25.423
- 546: SR in RP-080521. RP#41 completed / Text3: 25.306, 25.308, 25.321, 25.331, 25.423, 25.433, 25.214, 25.133
- 547: SR in RP-080805. RP#42 completed. WID updated RP-070760=>RP-080830 / Text3: 25.401, 25.413, 25.420, 25.423, 25.427, 25.433, 25.446, 25.301, 25.346
- 548: SR in RP-080806. RP#42 completed / Text3: 25.102, 25.105, 25.123, 25.142, 25.201, 25.221, 25.222, 25.223, 25.224, 25.306, 25.308, 25.321, 25.331, 25.423, 25.433
- 549: SR in RP-080807. RP#42 completed / Text3: 25.123, 25.221, 25.222, 25.224, 25.301, 25.302, 25.304, 25.306, 25.308, 25.319, 25.321, 25.331, 25.401, 25.423, 25.425, 25.433, 25.435
- 550: RP#43 Completion target 09/09=>12/09 / Text3: 25.113
- 551: RP#43 completed except R4 Rel-8 extension sheet in RP-090336. RP#42 Rel-8 extension to 03/09 (condition: ASN.1 available Jan 09 to RAN2/3. If not, shifted to Rel-9) / Text3: 25.929, 25.308, 25.319
- 552: RP#43 completed. RP#42 Rel-8 extension to 03/09. (condition: ASN.1 available Jan 09 to RAN2/3. If not, shifted to Rel-9) / Text3: 25.331, 25.413
- 553: SR in RP-080811. RP#42 completed / Text3: 25.101, 25.104, 25.133, 25.212, 25.214, 25.308, 25.321, 25.331, 25.423, 25.433
- 554: RP#43 completed (R1 part). RP#42 Rel-8 extension to 05/09 (the only part missing is R4 performance part) / Text3: 25.201, 25.221, 25.222, 25.223, 25.224, 25.306, 25.308, 25.321, 25.331, 25.423, 25.433, 25.102, 25.105, 25.142
- 555: RP#42 completed except R4 performance part 05/09. Triggered by FS_RAN-DCHS UID_390032 / Text3: 25.101, 25.104, 25.133, 25.141, 25.211, 25.212, 25.213, 25.214, 25.215, 25.306, 25.308, 25.321, 25.331, 25.423, 25.433

| ID | WBS | Task | Type | Duration | Start | Finish | Complete | Remaining | Baseline start | Baseline finish | Baseline duration | Total slack | Constraint | Resources | Work | Actual work | Text1 | Text6 | Text8 | Text2 | Text4 | Text7 | Text11 |
| --- | --- | --- | --- | --- | --- | --- | --- | --- | --- | --- | --- | --- | --- | --- | --- | --- | --- | --- | --- | --- | --- | --- | --- |
| 556 | 141 | **Rel-8 RAN improvements - UE Conformance Testing** |  | 466d? | 2008-05-30 A | 2010-03-12 | 32% | 315.44d? | 2008-05-30 | 2010-03-12 | 466d? | 0d |  | R5 | 15807.2h | 3970h | RANimp-UEConTest | Rel-8 | Ingbert |  |  |  |  |
| 557 | 141.1 | Conformance Test Aspects – Combination of 64QAM and MIMO for HSDPA (FDD) |  | 266d? | 2008-09-12 A | 2009-09-18 | 50% | 133d? | 2008-09-12 | 2009-09-18 | 266d? | 125d | finish no earlier than 2009-09-18 | R5 | 2128h | 1064h | RANimp-UEConTest_64QamMimoHsdpa | Rel-8 | Ingbert | PCG-21 | Ericsson | RP-41 | RP-090059 |
| 558 | 141.2 | Conformance Test Aspects – Improved L2 for uplink |  | 341d? | 2008-05-30 A | 2009-09-18 | 50% | 170.5d? | 2008-05-30 | 2009-09-18 | 341d? | 125d | finish no earlier than 2009-09-18 | R5 | 2728h | 1364h | RANimp-UEConTest_UplinkL2dataRates | Rel-8 | Ingbert | PCG-21 | Ericsson | RP-40 | RP-090057 |
| 559 | 141.3 | Conformance Test Aspects – 64QAM for 1.28 Mcps TDD HSDPA |  | 261d? | 2008-05-30 A | 2009-05-29 | 70% | 78.3d? | 2008-05-30 | 2009-05-29 | 261d? | 205d | finish no earlier than 2009-05-29 | R5 | 2088h | 1461.6h | RANimp-UEConTest_64Qam1.28TDD | Rel-8 | Ingbert | PCG-21 | ZTE | RP-40 | RP-090060 |
| 560 | 141.4 | Conformance Test Aspects – Dual-Cell HSDPA operation on adjacent carriers |  | 206d? | 2008-12-05 A | 2009-09-18 | 5% | 195.95d? | 2008-12-05 | 2009-09-18 | 206d? | 125d | finish no earlier than 2009-09-18 | R5 | 1648h | 80.4h | RANimp-UEConTest_DCHSDPA | Rel-8 | Ingbert | PCG-22 | Qualcomm | RP-42 | RP-090011 |
| 561 | 141.5 | Conformance Test Aspects – Enhanced Uplink for CELL_FACH State in FDD |  | 266d? | 2009-03-06 | 2010-03-12 |  |  | 2009-03-06 | 2010-03-12 | 266d? | 0d | finish no earlier than 2010-03-12 | R5 | 2128h |  | RANimp-UEConTest_EnhancedRACHCellFACHState | Rel-8 | Ingbert | PCG-22 | Nokia | RP-43 |  |
| 562 | 141.6 | Conformance Test Aspects – Receiver Type3i |  | 196d? | 2009-03-06 | 2009-12-04 |  |  | 2009-03-06 | 2009-12-04 | 196d? | 70d | finish no earlier than 2009-12-04 | R5 | 1568h |  | RANimp_UEConTest_ReceiverType3i | Rel-8 | Ingbert | PCG-22 | Qualcomm | RP-43 |  |
| 563 | 142 | 3.84 Mcps TDD MBSFN Integrated Mobile Broadcast |  | 395d? | 2007-06-04 A | 2008-12-05 A | 100% |  | 2007-06-04 | 2008-12-05 | 395d? |  | finish no earlier than 2008-12-05 | R1 | 3160h | 3160h | MBSFN-DOB | Rel-8 | Patrick |  | Ericsson |  | RP-080218 |
| 564 | 143 | **MBMS - UE Conformance Testing** |  | 601d? | 2007-06-01 A | 2009-09-18 | 56% | 262.01d? | 2007-06-01 | 2009-09-18 | 601d? | 125d |  | R5 | 12952h | 7305.54h | MBMSE_UEConTest | Rel-8 | Ingbert | PCG-21 |  | SP-40 |  |
| 565 | 143.1 | Conformance Test Aspects – MBMS TDD Physical layer Enhancements – MBSFN for HCR and VHCR TDD |  | 336d? | 2007-06-01 A | 2008-09-12 A | 100% |  | 2007-06-01 | 2008-09-12 | 336d? |  | start no earlier than 2007-06-01 | R5 | 2688h | 2688h | MBMSE-RANPhysTDD_UEConTest | Rel-7 | Ingbert |  | IPWireless |  | RP-080541 |
| 566 | 143.2 | Conformance Test Aspects – MBMS LCR TDD Physical Layer Enhancement |  | 341d? | 2008-05-30 A | 2009-09-18 | 60% | 136.4d? | 2008-05-30 | 2009-09-18 | 341d? | 125d | finish no earlier than 2009-09-18 | R5 | 2728h | 1636.8h | MBMSE-RANPhysLCRTDD_UEConTest | Rel-8 | Ingbert | PCG-21 | CATT | RP-40 | RP-090061 |
| 567 | 143.3 | Conformance Test Aspects – MBSFN for FDD |  | 341d? | 2008-05-30 A | 2009-09-18 | 10% | 307.4d? | 2008-05-30 | 2009-09-18 | 341d? | 125d | finish no earlier than 2009-09-18 | R5 | 2728h | 268.8h | MBMSE-UEConTest_RANPhysFDD | Rel-8 | Ingbert | PCG-21 | Huawei | RP-40 | RP-090058 |
| 568 | 144 | GERAN support for GERAN - 3G Long Term Evolution interworking |  | 641d? | 2006-09-08 A | 2009-02-20 A | 100% |  | 2006-09-08 | 2009-02-20 | 641d? |  | finish no earlier than 2009-02-20 | GP | 5128h | 5128h | GELTE | Rel-8 | Paolo |  | Nokia, Nokia Siemens Networks |  |  |
| 569 | 145 | U-TDOA Enhancement | milestone | 0d? | 2007-05-18 A | 2007-05-18 A | 100% |  | 2007-05-18 | 2007-05-18 | 0d? |  | finish no earlier than 2007-05-18 | GP |  |  | GUTEN | Rel-8 | Paolo |  | TruePosition |  |  |
| 570 | 146 | **GAN Enhancements** |  | 533.2d? | 2007-05-15 A | 2009-05-29 | 84% | 83.55d? | 2007-05-15 | 2009-05-29 | 533.2d? | 205d |  | GP | 8304h | 7002.75h | GANENH | Rel-8 | Paolo |  | T-Mobile |  |  |
| 571 | 146.1 | Update to GAN specifications |  | 126d? | 2007-08-31 A | 2008-02-22 A | 100% |  | 2007-08-31 | 2008-02-22 | 126d? |  | finish no earlier than 2008-02-22 | GP | 1008h | 1008h | GANENH-SPEC | Rel-8 | Paolo |  | T-Mobile |  |  |
| 572 | 146.2 | Update TS 51.010 Mobile Station (MS) Conformance Specification for GAN Enhancements |  | 456d? | 2007-05-15 A | 2009-05-29 | 80% | 91.2d? | 2007-05-15 | 2009-05-29 | 456d? | 205d | finish no earlier than 2009-05-29 | G3new | 3648h | 2918.4h | GANENH-MStest | Rel-8 | Ingbert |  | T-Mobile |  |  |
| 573 | 147 | **AoIP (A-interface over IP)** |  | 2334d? | 2000-01-03 A | 2008-12-11 A | 100% |  | 2000-01-03 | 2008-12-11 | 2334d? |  |  | GP,S4,C4,C1,C3 | 41404.1h | 41404.1h | AoIP | Rel-8 | Paolo | PCG-21 | China Mobile, Ericsson |  |  |
| 574 | 147.1 | GERAN aspects of AoIP |  | 2320d? | 2000-01-03 A | 2008-11-21 A | 100% |  | 2000-01-03 | 2008-11-21 | 2320d? |  | finish no earlier than 2008-11-21 | GP | 18560h | 18560h | AoIP | Rel-8 | Paolo | PCG-21 | China Mobile, Ericsson | SP-40 |  |
| 575 | 147.2 | Media Requirements for CS over IP based User Plane |  | 267d? | 2007-12-05 A | 2008-12-11 A | 100% |  | 2007-12-05 | 2008-12-11 | 267d? |  | finish no earlier than 2008-12-11 | S4 | 1996.09h | 1996.09h | AoIP-CSoIP | Rel-8 | Paolo | PCG-21 | China Mobile, Ericsson | SP-40 |  |
| 576 | 147.3 | Core Network Impacts for A-Interface User Plane over IP |  | 136d? | 2008-05-30 A | 2008-12-05 A | 100% |  | 2008-05-30 | 2008-12-05 | 136d? |  | start no earlier than 2008-05-30 | C4 | 1088h | 1088h | AoIP-CN | Rel-8 | Kimmo | PCG-21 | Ericsson | CP-40 |  |
| 577 | 147.4 | Core Network Impacts for A-Interface User Plane over IP |  | 68d? | 2008-05-30 A | 2008-12-05 A | 100% |  | 2008-05-30 | 2008-12-05 | 68d? |  | finish no earlier than 2008-12-05 | C1 | 544h | 544h | AoIP-CN | Rel-8 | Frederic | PCG-21 | Ericsson | CP-40 |  |
| 578 | 147.5 | Core Network Impacts for A-Interface User Plane over IP |  | 68d? | 2008-05-30 A | 2008-12-05 A | 100% |  | 2008-05-30 | 2008-12-05 | 68d? |  | finish no earlier than 2008-12-05 | C3 | 544h | 544h | AoIP-CN | Rel-8 | Gwiho | PCG-21 | Ericsson | CP-40 |  |
| 579 | 148 | New multicarrier BTS class |  | 261d? | 2007-08-31 A | 2008-08-29 A | 100% |  | 2007-08-31 | 2008-08-29 | 261d? |  | finish no earlier than 2008-08-29 | G1 | 2088h | 2088h | MCBTS | Rel-8 | Paolo |  | Alcatel-Lucent |  |  |

Notes:
- 556: 05/08: Linked to Feature UID_20029 (RANimp)
- 557: RP#43 Completion target 03/09=>09/09 / Text3: 34.108, 34.121-1, 34.121-2, 34.123-1, 34.123-2, 34.123-3 / Text5: leif.mattisson@ericsson.com
- 558: RP#43 Completion target 03/09=>09/09. Linked UID_370036 / Text3: 34.108, 34.123-1, 34.123-2, 34.123-3 / Text5: leif.mattisson@ericsson.com
- 559: RP#43 Completion target 12/08=>05/09. Linked UID_380075 / Text3: 34.108, 34.122, 34.123-1, 34.123-2, 34.123-3 / Text5: ma.zijiang@zte.com.cn
- 560: Testing for UID_400052 / Text3: 34.108, 34.121-1, 34.121-2, 34.123-1, 34.123-2, 34.123-3 / Text5: Shubhang Vora (svora@qualcomm.com)
- 561: Testing for UID_370037 / Text3: 34.108, 34.121-1, 34.121-2, 34.123-1, 34.123-2, 34.123-3 / Text5: jarkko.hellsten@nokia.com
- 562: Text3: 34.108, 34.121-1, 34.121-2 / Text5: Ashokkumar Narayanaswamy (anarayan@qualcomm.com)
- 563: RP#42 completed. WID updated RP-070493=>RP-081124 (changed WI title "MBSFN Downlink Optimized Broadcast (DOB) 3.84 Mcps TDD" => "3.84Mcps TDD MBSFN Integrated Mobile Broadcast"). RP#39 SR in RP-080218. / Text3: 25.102, 25.105, 25.123, 25.201, 25.221, 25.222, 25.223, 25.224, 25.304, 25.306, 25.331, 25.346, 25.402, 25.433 / Text5: Lars.Lindbom@ericsson.com
- 564: Linked to Feature UID_31084 (MBMSE)
- 565: SR in RP-080541. RP#41 completed. Linked to Feature UID_31084 (MBMSE), BB UID_340043 (MBMSE-RANPhysTDD) / Text3: 34.108, 34.122, 34.123-1/2/3 / Text5: tspeight@ipwireless.com
- 566: Text3: 34.108, 34.123-1 / Text5: chenxiaozhong@datangmobile.cn
- 567: RP#43 Completion target 03/09=>09/09 / Text5: Xiang Li (trica_li@huawei.com)
- 568: GP#41 completed (MS conformance testing open). GP#40 Rel-8 extension to 02/09 / Text3: 24.008, 43.055, 43.129, 43.246, 44.018, 44.060, 45.002, 45.008, 45.010, 48.008, 48.018, 51.010 / Text5: sergio.parolari@nsn.com, vlora.rexhepi@nokia.com
- 569: GP#36 completed U-TDOA (Uplink Time Difference of Arrival) / Text3: 43.059, 45.008, 48.071 / Text5: terri.brooks@trueposition.com
- 570: GP#37 completed. Testing open / Text5: mohammed.versi@t-mobile.com
- 571: GP#37 completed / Text3: 43.318, 44.318 / Text5: mohammed.versi@t-mobile.com
- 572: GP#41 completion 02/09=>05/09. GP#39 completion 08/08=>11/08=>02/09 / Text3: 51.010 / Text5: mohammed.versi@t-mobile.com
- 573: GP#40/TSG#42 completed . Triggered by TR 43.903 Study on A-interface over IP (AINTIP) UID_50589. / Text5: wangshuaiyu@chinamobile.com, paul.schliwa-bertling@ericsson.com
- 574: GP#40 completed. GP#39 updated WID GP-080901=>GP-081362. / Text3: 48.001, 48.002, 48.008, 48.020, 49.008, 48.103 / Text5: wangshuaiyu@chinamobile.com, paul.schliwa-bertling@ericsson.com
- 575: SA#42 completed / Text3: 26.102, 26.103, 26.202 / Text5: Karl.Hellwig@Ericsson.com
- 576: CT#42 completed. Updated WID CP-080278=>CP-080722 / Text3: 23.205, 23.153, 23.231, 29.232 / Text5: philip.hodges@ericsson.com
- 577: CT#42 completed. Updated WID CP-080278=>CP-080722 / Text3: 23.009 / Text5: philip.hodges@ericsson.com
- 578: CT#42 completed. Updated WID CP-080278=>CP-080722 / Text3: 29.007 / Text5: philip.hodges@ericsson.com
- 579: GP#39 completed / Text3: 45.005, 45.050, 51.021 / Text5: thomas.bitzer@alcatel-lucent.de

| ID | WBS | Task | Type | Duration | Start | Finish | Complete | Remaining | Baseline start | Baseline finish | Baseline duration | Total slack | Constraint | Resources | Work | Actual work | Text1 | Text4 | Text6 | Text8 | Text11 | Text2 | Text3 | Text7 | Text12 |
| --- | --- | --- | --- | --- | --- | --- | --- | --- | --- | --- | --- | --- | --- | --- | --- | --- | --- | --- | --- | --- | --- | --- | --- | --- | --- |
| 580 | 149 | **Support for Additional Navigation Satellite Systems (ANSS) for LCS** |  | 150d? | 2008-05-16 A | 2008-12-11 A | 100% |  | 2008-05-16 | 2008-12-11 | 150d? |  |  | S1,G2 | 3384h | 3384h | ANSS | Qualcomm | Rel-8 | Paolo | RP-080813 |  |  |  |  |
| 581 | 149.1 | Stage 1 for ANSS for LCS |  | 1d? | 2008-12-11 A | 2008-12-11 A | 100% |  | 2008-12-11 | 2008-12-11 | 1d? |  | start no earlier than 2008-12-11 | S1 | 8h | 8h | ANSS |  | Rel-8 | Alain |  | PCG-22 | 22.071 | SP-42 |  |
| 582 | 149.2 | Support for Additional Navigation Satellite Systems (ANSS) for LCS |  | 136d? | 2008-05-16 A | 2008-11-21 A | 100% |  | 2008-05-16 | 2008-11-21 | 136d? |  | start no earlier than 2008-05-16 | G2 | 1088h | 1088h | ANSS | Qualcomm | Rel-8 | Paolo |  |  | 43.059, 44.031, 49.031, 44.071, 48.031, 51.010 |  |  |
| 583 | 149.3 | Support for Additional Navigation Satellite Systems (ANSS) for LCS |  | 136d? | 2008-05-30 A | 2008-12-05 A | 100% |  | 2008-05-30 | 2008-12-05 | 136d? |  | finish no earlier than 2008-12-08 | R2 | 1088h | 1088h | RANimp-ANSS | Qualcomm | Rel-8 | Joern | RP-080813 | PCG-21 | 25.305, 25.306, 25.331, 25.413, 25.423, 25.433, 25.453 | RP-40 |  |
| 584 | 150 | **A-GNSS Performances and Testing Procedures** |  | 341d? | 2008-05-16 A | 2009-09-04 | 15% | 289.26d? | 2008-05-16 | 2009-09-04 | 341d? | 135d |  | GP | 7544h | 1144.76h | AGNSSPTP | Thales | Rel-8 | Paolo |  |  |  |  |  |
| 585 | 150.1 | A-GNSS Minimum Performances |  | 261d? | 2008-05-16 A | 2009-05-15 | 35% | 169.65d? | 2008-05-16 | 2009-05-15 | 261d? | 215d | start no earlier than 2008-05-16 | G1 | 2088h | 730.8h | AGNSSPTP- Perfreq | Thales | Rel-8 | Paolo |  |  | 45.005 |  |  |
| 586 | 150.2 | A-GNSS Testing Procedures |  | 341d? | 2008-05-16 | 2009-09-04 |  |  | 2008-05-16 | 2009-09-04 | 341d? | 135d | start no earlier than 2008-05-16 | G3new | 2728h |  | AGNSSPTP-MStest | Thales | Rel-8 | Ingbert |  |  | 51.010-1 |  |  |
| 587 | 151 | **Conformance testing for the Latency Reductions feature** |  | 456d? | 2008-02-22 A | 2009-11-20 | 75% | 116d? | 2008-02-22 | 2009-11-20 | 456d? | 80d |  | G1, G3new | 9384h | 6996.77h | CTLATRED | Ericsson | Rel-8 | Paolo |  | PCG-21 |  |  |  |
| 588 | 151.1 | MS conformance testing for the Latency Reductions feature |  | 456d? | 2008-02-22 A | 2009-11-20 | 60% | 182.4d? | 2008-02-22 | 2009-11-20 | 456d? | 80d | finish no earlier than 2009-11-20 | G3new | 3648h | 2188.8h | CTLATRED-MStest | Ericsson | Rel-8 | Ingbert |  | PCG-21 | 51.010 |  |  |
| 589 | 151.2 | BTS conformance testing for the Latency Reductions feature |  | 261d? | 2008-02-22 A | 2009-02-20 A | 100% |  | 2008-02-22 | 2009-02-20 | 261d? |  | finish no earlier than 2009-02-20 | G1 | 2088h | 2088h | CTLATRED-BTStest | Ericsson | Rel-8 | Paolo |  | PCG-21 | 51.021 |  |  |
| 590 | 152 | MS conformance testing of changes introduced by WI “Support of Packet-switched Handover for GERAN A/Gb mode” |  | 196d? | 2008-02-22 A | 2008-11-21 A | 100% |  | 2008-02-22 | 2008-11-21 | 196d? |  | finish no earlier than 2008-11-21 | G3new | 1568h | 1568h | PSHCT-MStest | Rohde & Schwarz | Rel-8 | Ingbert |  | PCG-21 | 51.010 |  |  |
| 591 | 153 | MS conformance testing of Support of Conversational Services in A/Gb mode via the PS domain |  | 321d? | 2008-02-22 | 2009-05-15 |  |  | 2008-02-22 | 2009-05-15 | 321d? | 215d | finish no earlier than 2009-05-15 | G3new | 2568h |  | SCSAGBCT-MStest | Nokia | Rel-8 | Ingbert |  | PCG-21 | 51.010 |  |  |
| 592 | 154 | (Small) Technical Enhancements and Improvements for Rel-8 |  | 509d? | 2007-01-01 A | 2008-12-11 A | 100% |  | 2007-01-01 | 2008-12-11 | 509d? |  | finish no earlier than 2008-12-11 | All | 4072h | 4072h | TEI8 | ALL | Rel-8 |  |  |  |  |  |  |
| 593 | 155 | Test - (Small) Technical Enhancements and Improvements for Rel-8 |  | 281d? | 2008-05-30 A | 2009-06-26 | 80% | 56.2d? | 2008-05-30 | 2009-06-26 | 281d? | 185d | finish no earlier than 2009-06-26 | R5 | 2248h | 1798.4h | TEI8_Test | ALL | Rel-8 | Ingbert |  | PCG-21 |  | RP-40 |  |
| 594 | 156 | **Deleted - All-IP Network** |  | 448d? | 2004-06-28 A | 2006-03-15 A | 100% |  | 2004-06-28 | 2006-03-15 | 448d? |  |  | S1 | 7168h | 7168h | AIPN | NTT DoCoMo | Rel-8 | Alain |  |  |  |  | SP-38 |
| 595 | 156.1 | Deleted - Stage 1 |  | 448d? | 2004-06-28 A | 2006-03-15 A | 100% |  | 2004-06-28 | 2006-03-15 | 448d? |  | finish no earlier than 2006-03-15 | S1 | 3584h | 3584h | AIPN | NTT DoCoMo | Rel-8 | Alain |  |  | 22.258 |  | SP-38 |
| 596 | 157 | Deleted - was Rel7 - LCS for 3GPP Interworking WLAN | milestone | 0d? | 2007-09-28 A | 2007-09-28 A | 100% |  | 2007-09-28 | 2007-09-28 | 0d? |  | start no earlier than 2007-09-28 | S2 |  |  | LCS4_IWLAN | LG Electronics | Rel-8 | Maurice |  |  | 23.234, 23.271, 23.167 |  | SP-35 |
| 597 | 158 | Deleted - never approved- FBI Phase 2 | milestone | 0d | 2007-09-28 A | 2007-09-28 A | 100% |  | 2007-09-28 | 2007-09-28 | 0d |  | start no earlier than 2007-09-28 | S2 |  |  | FBI2 | Nokia Siemens Networks | Rel-8 | Maurice |  |  |  |  | SP-38 |
| 598 | 159 | Deleted -Enhancements to BS30 Bearer service for Videotelephony | milestone | 0d? | 2007-03-15 A | 2007-03-15 A | 100% |  | 2007-03-15 | 2007-03-15 | 0d? |  | finish no earlier than 2007-03-15 | S1 |  |  | BS30 |  | Rel-8 | Alain |  |  | 22.002, 22.004, 22.101, 22.105, 24.008 |  | SP-38 |
| 599 | 160 | Deleted - IMS Enhancements Rel-8 |  | 75d? | 2007-09-03 A | 2007-12-14 A | 100% |  | 2007-09-03 | 2007-12-14 | 75d? |  |  | S1 | 600h | 600h | IMS8 | Telecom Italia | Rel-8 | Alain |  |  |  | SP-37 | SP-38 |
| 600 | 161 | Release 8 Feasibility Studies | milestone | 0d? | 2008-03-20 | 2008-03-20 |  |  | 2008-03-20 | 2008-03-20 | 0d? | 516d | finish no earlier than 2008-03-20 | CP,GP,RP,SP |  |  |  |  | Rel-8 |  |  |  |  |  |  |
| 601 | 162 | Study on Customised Alerting Tone (CAT) Requirements |  | 245d? | 2005-10-07 A | 2006-09-14 A | 100% |  | 2005-10-07 | 2006-09-14 | 245d? |  | start no earlier than 2005-10-07 | S1 | 1960h | 1960h | FS_CAT | China Mobile | Rel-8 | Alain |  |  | 22.982 |  |  |
| 602 | 163 | Study on Facilitating Machine to Machine Communication in GSM and UMTS (M2M) |  | 350d? | 2005-11-04 A | 2007-03-08 A | 100% |  | 2005-11-04 | 2007-03-08 | 350d? |  | finish no earlier than 2006-06-16 | S1 | 2800h | 2800h | FS_M2M | Siemens | Rel-8 | Alain |  |  | 22.868 |  |  |
| 603 | 164 | Study on Network Composition |  | 526d? | 2005-12-07 A | 2007-12-12 A | 100% |  | 2005-12-07 | 2007-12-12 | 526d? |  | finish no earlier than 2006-09-27 | S1 | 4208h | 4208h | FS_NetComp | Nokia Siemens Networks | Rel-8 | Alain |  |  | 22.980 |  |  |
| 604 | 165 | Study on Requirements of IMS Multimedia Conferencing |  | 330d? | 2006-06-08 A | 2007-09-12 A | 100% |  | 2006-06-08 | 2007-09-12 | 330d? |  | finish no earlier than 2007-03-21 | S1 | 2640h | 2640h | FS_IMSconf | China Mobile | Rel-8 | Alain |  |  | 22.948 |  |  |
| 605 | 166 | Study on support of a Public Warning System |  | 140d? | 2007-09-03 A | 2008-03-14 A | 100% |  | 2007-09-03 | 2008-03-14 | 140d? |  |  | S1 | 1120h | 1120h | FS_PWS | T-Mobile | Rel-8 | Alain |  |  | 22.968 |  |  |
| 606 | 167 | Study on Paging Permission with Access Control |  | 256d? | 2006-09-28 A | 2007-09-20 A | 100% |  | 2006-09-28 | 2007-09-20 | 256d? |  | finish no earlier than 2007-09-20 | S1 | 2048h | 2048h | FS_PPAC | NTT DoCoMo | Rel-8 | Alain |  |  | 22.908 |  |  |
| 607 | 168 | Study on Non 3GPP access NSP |  | 392d? | 2006-12-06 A | 2008-06-05 A | 100% |  | 2006-12-06 | 2008-06-05 | 392d? |  | finish no earlier than 2007-11-19 | S1 | 3136h | 3136h | FS_N3GtoNSP | Telefonica O2 | Rel-8 | Alain |  |  | 22.912 |  |  |
| 608 | 169 | Study on Value Added Services for Short Message Service |  | 263d? | 2006-12-06 A | 2007-12-07 A | 100% |  | 2006-12-06 | 2007-12-07 | 263d? |  | finish no earlier than 2007-12-07 | S1 | 2104h | 2104h | FS_VAS4SMS | China Mobile | Rel-8 | Alain |  |  | 22.942 |  |  |
| 609 | 170 | Study on Service continuity between mobile and WLAN networks |  | 262d? | 2006-12-06 A | 2007-12-06 A | 100% |  | 2006-12-06 | 2007-12-06 | 262d? |  | finish no earlier than 2008-12-25 | S1 | 2096h | 2096h | FS_SMLSWLAN | BT | Rel-8 | Alain |  |  | 22.937 |  |  |
| 610 | 171 | Study on Services Alignment and Migration |  | 331d? | 2006-12-06 A | 2008-03-12 A | 100% |  | 2006-12-06 | 2008-03-12 | 331d? |  | finish no earlier than 2007-09-20 | S1 | 2648h | 2648h | FS_ServAl | China Mobile | Rel-8 | Alain |  |  | 22.983 | SP-37 |  |

Notes:
- 580: GP#40 completed. Align with RANimp-ANSS ongoing work item. GP#40 WID updated GP-080776=>GP-081784 (Conformance testing moved to A-GNSS WID) / Text5: Mungal Dhanda
- 581: SA#42 completed by 22.071 CR0077
- 582: GP#40 completed. Align with RANimp-ANSS ongoing work item. GP#40 WID updated GP-080776=>GP-081784 (Conformance testing moved to A-GNSS WID) / Text5: Mungal Dhanda
- 583: SR in RP-080813. RP#42 WI closed at 95%. GERAN leading the work / considers performance requirements for Rel-9 / Text5: Etienne Chaponniere (echaponn@qualcomm.com)
- 584: GP#40 Completion target 08/09=>09/09. WID updated GP-080790=>GP-081785. / Text5: Michel.monnerat@thalesaleniaspace.com
- 585: GP#40 WID updated GP-080791=>GP-081786 / Text5: Michel.monnerat@thalesaleniaspace.com
- 586: GP#41 stagnates at 0%. GP#40 WID updated GP-080792=>GP-081787. / Text5: Michel.monnerat@thalesaleniaspace.com
- 587: GP#41 completion 09/09=>11/09 / Text5: mats.y.samuelsson@ericsson.com, hakan.e.grunditz@ericsson.com
- 588: GP#41 completion 09/09=>11/09. GP#40 completion 11/08=>09/09 / Text5: hakan.e.grunditz@ericsson.com
- 589: GP#41 completed / Text5: mats.y.samuelsson@ericsson.com
- 590: GP#40 completed / Text5: Franz.Segerer@ROHDE-SCHWARZ.COM
- 591: GP#41 stagnates at 0% / Text5: arsi.heino@nokia.com
- 594: SA#38 stopped. 25/07/08 Moved UID_31059 Study on All-IP Network (FS_AIPN/was AIPFS ) to Rel-7 out of the stopped Rel-8 Feature UID_31067 Deleted - All-IP Network (AIPN) / Text5: c.masyu@nttdocomo.co.jp
- 595: 22.258 withdrawn, superseded by 22.278 (UID 320022). SA#38 stopped / Text5: c.masyu@nttdocomo.co.jp
- 596: SP-35 stopped / Text5: dhshim@lge.com
- 597: SA#38 stopped
- 598: SA#38 stopped (no support) / Text5: andre.jarvis@three.co.uk
- 599: SA#38 stopped
- 601: Spin-off WID UID_370028 under Feature CAT UID_340029 / Text5: fenglingjuan@chinamobile.com
- 602: SA#35 completed. Spin-off SA3 SID UID_370053. SA#40 Spin-off new Feature UID_400033 (NIMTC) / Text5: Juergen Merkel
- 603: SA#38 completed / Text5: Joerg Swetina (joerg.swetina@nw.neclab.eu)
- 604: SA#37 completed. Spin-off New Feature UID_370026 (VAS4SM) / Text5: zhengjianping@chinamobile.com
- 605: SA#39 completed. Spin-off Rel-9 Feature UID_380057 (PWS) / Text5: mark.younge@t-mobile.com
- 606: SA#37 completed. Spin-off new Feature UID_370084 (PPACR) / Text5: noguchi@nttdocomo.co.jp
- 607: SA#38 completed. Spin-off New Feature UID_380062 (N3GTONSP). SA#40 WID updated SP-060930=>SP-080318. TR re-approved with new # 22.812=>22.912 / Text5: chris.friel@o2.com
- 608: SA#38 completed. Spin-off New Feature UID_370026 (VAS4SM) / Text5: wubin@chinamobile.com
- 609: SA#38 completed / Text5: mike.meyerstein@bt.com
- 610: SA#39 completed. Spin-off Feature UID_330017 (ServAl) / Text5: fenglingjuan@chinamobile.com

| ID | WBS | Task | Duration | Start | Finish | Complete | Remaining | Baseline start | Baseline finish | Baseline duration | Total slack | Constraint | Resources | Work | Actual work | Text1 | Text4 | Text5 | Text6 | Text8 | Text3 | Text2 | Text7 | Text11 | Text9 | Text12 |
| --- | --- | --- | --- | --- | --- | --- | --- | --- | --- | --- | --- | --- | --- | --- | --- | --- | --- | --- | --- | --- | --- | --- | --- | --- | --- | --- |
| 611 | 172 | **Study on 3GPP System Architecture Evolution** | 1115d? | 2004-12-03 A | 2009-03-12 A | 100% |  | 2004-12-03 | 2009-03-12 | 1115d? |  |  | S2,S3 | 23456h | 23456h | FS_SAE | Vodafone | Chris Pudney | Rel-8 | Maurice |  |  |  |  |  |  |
| 612 | 172.1 | Stage 2 Interim conclusion for RAN Work to start | 990d? | 2004-12-03 A | 2008-09-18 A | 100% |  | 2004-12-03 | 2008-09-18 | 990d? |  | finish no earlier than 2005-09-23 | S2 | 7920h | 7920h | FS_SAE | Vodafone | Chris Pudney | Rel-8 | Maurice | 23.882 |  |  |  |  |  |
| 613 | 172.2 | Stage 2 study on 3GPP architectural development | 704d? | 2006-01-09 A | 2008-09-18 A | 100% |  | 2006-01-09 | 2008-09-18 | 704d? |  | finish no earlier than 2007-09-28 | S2 | 5632h | 5632h | FS_SAE | Vodafone | Chris Pudney | Rel-8 | Maurice | 23.882 |  |  |  |  |  |
| 614 | 172.3 | Security study for Inter-access mobility between non-3GPP and 3GPP system | 334d? | 2007-09-03 A | 2009-03-12 A | 100% |  | 2007-09-03 | 2009-03-12 | 334d? |  | finish no earlier than 2009-03-12 | S3 | 2672h | 2672h | FS_SAE | Nokia | dajiang.zhang@nokia.com | Rel-8 | Dionisio | 33.821, 33.822 |  |  |  |  |  |
| 615 | 173 | Study on Stage 2 aspects of IMS Service Brokering | 589d? | 2006-06-19 A | 2008-09-18 A | 100% |  | 2006-06-19 | 2008-09-18 | 589d? |  | finish no earlier than 2008-09-18 | S2 | 4712h | 4712h | FS_ISB_ST2 | Telcordia | raquel@research.telcordia.com | Rel-8 | Maurice | 23.810 |  |  |  |  |  |
| 616 | 174 | Study on IMS utilizing multicast bearer services | 447d? | 2006-03-22 A | 2007-12-06 A | 100% |  | 2006-03-22 | 2007-12-06 | 447d? |  | finish no earlier than 2007-12-03 | S2 | 3576h | 3576h | FS_MLTICAST-IMS | Nokia Siemens Networks |  | Rel-8 | Maurice | 23.847 |  |  |  |  |  |
| 617 | 175 | Study on Mobility between 3GPP-WLAN Interworking and 3GPP Systems | 393d? | 2007-03-20 A | 2008-09-18 A | 100% |  | 2007-03-20 | 2008-09-18 | 393d? |  | finish no earlier than 2008-09-18 | S2 | 3144h | 3144h | FS_SM3GWLAN | Orange |  | Rel-8 | Maurice | 23.827 withdrawn |  |  |  |  |  |
| 618 | 176 | Study on Multimedia Session Continuity | 291d? | 2007-04-26 A | 2008-06-05 A | 100% |  | 2007-04-26 | 2008-06-05 | 291d? |  | finish no earlier than 2008-06-05 | S2 | 2328h | 2328h | FS_MMSC | LG Electronics |  | Rel-8 | Maurice | 23.893 |  |  |  |  |  |
| 619 | 177 | **Study on centralized IMS service control** | 363d? | 2006-10-23 A | 2008-03-12 A | 100% |  | 2006-10-23 | 2008-03-12 | 363d? |  |  | S2,S1 | 7952h | 7952h | FS_ICS | Ericsson | peter.bleckert@ericsson.com | Rel-8 | Alain |  | PCG-21 | SP-38 |  |  |  |
| 620 | 177.1 | Study on centralized IMS services requirements | 268d? | 2007-03-05 A | 2008-03-12 A | 100% |  | 2007-03-05 | 2008-03-12 | 268d? |  | start no earlier than 2007-03-05 | S1 | 2144h | 2144h | FS_ICS-S1 | Ericsson | peter.bleckert@ericsson.com | Rel-8 | Alain | 22.892 |  | SP-37 |  |  |  |
| 621 | 177.2 | Study on centralized IMS services control | 363d? | 2006-10-23 A | 2008-03-12 A | 100% |  | 2006-10-23 | 2008-03-12 | 363d? |  | finish no earlier than 2008-02-21 | S2 | 2904h | 2904h | FS_IMS_CSC | Alcatel-Lucent | Andy Bennett (andybennett@alcatel-lucent.com) | Rel-8 | Maurice | 23.892 |  |  |  |  |  |
| 622 | 178 | Study on Architecture of IMS based Customized Alerting Tone (CAT) | 208d? | 2007-12-04 A | 2008-09-18 A | 100% |  | 2007-12-04 | 2008-09-18 | 208d? |  | finish no earlier than 2008-09-08 | S2 | 1664h | 1664h | FS_CAT-St2 | China Mobile | WANG, Jing (wangjing@chinamobilecom) | Rel-8 | Maurice | 23.872 | PCG-21 | SP-38 |  |  |  |
| 623 | 179 | Study on Home (e)NodeB Security | 321d? | 2007-12-20 A | 2009-03-12 A | 100% |  | 2007-12-20 | 2009-03-12 | 321d? |  | finish no earlier than 2009-03-10 | S3 | 2568h | 2568h | FS_HNB_Sec | Huawei | yangyanmei@huawei.com | Rel-8 | Dionisio | 33.820 | PCG-21 | SP-38 |  |  |  |
| 624 | 180 | Study on Transferring of emergency call data – in-band modem solution | 265d? | 2006-12-07 A | 2007-12-12 A | 100% |  | 2006-12-07 | 2007-12-12 | 265d? |  | finish no earlier than 2008-09-18 | S4 | 2120h | 2120h | eCALLIBMS | Airbiquity | lhong@airbiquity.com | Rel-8 | Paolo | 26.967 |  |  |  |  |  |
| 625 | 181 | Study on Element Operations Systems Function (EOSF) definition | 266d? | 2007-06-07 A | 2008-06-12 A | 100% |  | 2007-06-07 | 2008-06-12 | 266d? |  | finish no earlier than 2008-12-11 | S5 | 2128h | 2128h | OAM7-NIM- EOSF | China Mobile | LI, Jian | Rel-8 | Dionisio | 32.819 |  |  |  |  |  |
| 626 | 182 | Study on SA5 MTOSI XML Harmonization | 351d? | 2006-05-10 A | 2007-09-12 A | 100% |  | 2006-05-10 | 2007-09-12 | 351d? |  | finish no earlier than 2007-12-14 | S5 | 2808h | 2808h | OAM7-NIM-XML | Nortel | jduguay@nortel.com | Rel-8 | Dionisio | 32.818 |  |  |  |  |  |
| 627 | 183 | Study on Common Profile Storage (CPS) Framework of User Data for network services and management | 244d? | 2006-07-03 A | 2007-06-07 A | 100% |  | 2006-07-03 | 2007-06-07 | 244d? |  | finish no earlier than 2007-06-07 | S5 | 1952h | 1952h | OAM7-CPS | T-Mobile | istvan.aba@t-mobile.at | Rel-8 | Dionisio | 32.808 |  |  |  |  |  |
| 628 | 184 | Study on Management for LTE and SAE | 526d? | 2006-12-07 A | 2008-12-11 A | 100% |  | 2006-12-07 | 2008-12-11 | 526d? |  | finish no earlier than 2008-12-11 | S5 | 4208h | 4208h | FS_OAM_LTE_SAE | Ericsson | PETERSEN, Robert | Rel-8 | Dionisio | 32.816 |  |  |  |  |  |
| 629 | 185 | Study on Charging Aspects of 3GPP System Evolution | 179d? | 2007-04-02 A | 2007-12-06 A | 100% |  | 2007-04-02 | 2007-12-06 | 179d? |  | finish no earlier than 2007-12-06 | S5 | 1432h | 1432h | FS_SAEcharg | Nokia Siemens Networks | GÖRMER, Gerald | Rel-8 | Dionisio | 32.820 |  |  |  |  |  |
| 630 | 186 | Study on AS-MRFC media server control protocol | 583d? | 2006-03-22 A | 2008-06-13 A | 100% |  | 2006-03-22 | 2008-06-13 | 583d? |  | finish no earlier than 2008-06-13 | C1 | 4664h | 4664h | MRFC | HP | mark.syrett@hp.com | Rel-8 | Frederic | 24.880 |  |  |  |  |  |
| 631 | 187 | Study on IMS Restoration Procedures | 310d? | 2007-03-26 A | 2008-05-30 A | 100% |  | 2007-03-26 | 2008-05-30 | 310d? |  | finish no earlier than 2008-05-30 | C4 | 2480h | 2480h | FS_IMS_RP | Ericsson | german.blanco@ericsson.com | Rel-8 | Kimmo | 23.820 |  |  |  |  |  |
| 632 | 188 | Study on IMS Application Server Service Data Descriptions for AS interoperability | 261d? | 2007-09-14 A | 2008-09-12 A | 100% |  | 2007-09-14 | 2008-09-12 | 261d? |  | finish no earlier than 2008-09-12 | C4 | 2088h | 2088h | FS_IMS_ASIO | Alcatel-Lucent | Jean-Jacques Trottin | Rel-8 | Kimmo | 29.864 |  |  |  |  |  |
| 633 | 189 | Study on Customized Alerting Tone (CAT) solution for voice and video call in CS domain | 261d? | 2007-09-14 A | 2008-09-12 A | 100% |  | 2007-09-14 | 2008-09-12 | 261d? |  |  | C4 | 626.4h | 626.4h | FS_CAT_VVC_CS | China Mobile | zhanghao@chinamobile.com | Rel-8 | Kimmo | 29.882 |  |  |  |  |  |
| 634 | 190 | Study on InterWorking Function between MAP based and Diameter based interfaces | 266d? | 2007-11-30 A | 2008-12-05 A | 100% |  | 2007-11-30 | 2008-12-05 | 266d? |  | finish no earlier than 2008-12-05 | C4 | 2128h | 2128h | FS_MAP2Diam | Huawei | liming49985@huawei.com | Rel-8 | Kimmo | 29.805 | PCG-21 | CP-38 |  |  |  |
| 635 | 191 | Study on Scope of future HSPA Evolution for 1.28Mcps TDD | 186d? | 2007-09-14 A | 2008-05-30 A | 100% |  | 2007-09-14 | 2008-05-30 | 186d? |  | finish no earlier than 2008-05-30 | R1 | 1488h | 1488h | FS_RAN-LCRTDDHSPAEvo | RITT | Xu Fei | Rel-8 | Patrick | 25.824 |  | RP-37 | RP-080290 |  |  |
| 636 | 192 | Study on Synchronized E-DCH for UTRA FDD | 126d? | 2007-09-14 A | 2008-03-07 A | 100% |  | 2007-09-14 | 2008-03-07 | 126d? |  | finish no earlier than 2008-03-14 | R1 | 1008h | 1008h | FS_RAN-UplinkSync | Nokia Siemens Networks | Karri.Ranta-aho@nsn.com | Rel-8 | Patrick | 25.823 |  | RP-37 | RP-080068 |  |  |
| 637 | 193 | Study on Improved network controlled mobility between LTE and 3GPP2/mobile WiMAX radio technologies | 131d? | 2007-06-04 A | 2007-12-03 A | 100% |  | 2007-06-04 | 2007-12-03 | 131d? |  | finish no earlier than 2007-12-03 | R4 | 1048h | 1048h | FS_RAN-LTEmob | Motorola | hao.bi@Motorola.com | Rel-8 | Stefania | 36.938 |  |  | RP-070827 |  |  |
| 638 | 194 | Study on 3G Home NodeB/eNodeB | 325d? | 2007-03-05 A | 2008-05-30 A | 100% |  | 2007-03-05 | 2008-05-30 | 325d? |  | finish no earlier than 2008-05-30 | R4 | 2600h | 2600h | FS_RAN-HNBeNB | Motorola | howard.thomas@motorola.com | Rel-8 | Stefania | 25.820 |  |  | RP-080289 |  |  |
| 639 | 195 | Study on HS-PDSCH serving cell change enhancements | 60d? | 2007-12-17 A | 2008-03-07 A | 100% |  | 2007-12-17 | 2008-03-07 | 60d? |  | finish no earlier than 2008-06-12 | R4 | 480h | 480h | FS_RAN-HSPDSCH | Qualcomm |  | Rel-8 | Stefania | none | PCG-21 | RP-38 | RP-080070 |  |  |
| 640 | 196 | Study on Dual-Cell HSDPA operation | 261d? | 2007-08-15 A | 2009-03-06 A | 100% |  | 2007-08-15 | 2009-03-06 | 261d? |  | finish no earlier than 2009-03-06 | R1 | 2088h | 2088h | FS_RAN-DCHS | Qualcomm | Josef Blanz | Rel-8 | Patrick | withdrawn 25.825 v100 | PCG-21 | RP-39 | RP-090066 |  |  |
| 641 | 197 | Study on A-interface over IP | 126d? | 2007-08-31 A | 2008-02-22 A | 100% |  | 2007-08-31 | 2008-02-22 | 126d? |  | finish no earlier than 2008-02-22 | GP | 1008h | 1008h | AINTIP | China Mobile, Ericsson | paul.schliwa-bertling@ericsson.com | Rel-8 | Paolo | 43.903 |  |  |  |  |  |
| 642 | 198 | Study on Multi-User Reusing-One-Slot | 391d? | 2007-11-16 A | 2009-05-15 | 95% | 19.55d? | 2007-11-16 | 2009-05-15 | 391d? | 215d | finish no earlier than 2009-05-15 | GP | 3128h | 2971.6h | MUROS | Nokia Siemens Networks | juergen.hofmann@nsn.com | Rel-8 | Paolo | 45.914 |  |  |  |  |  |
| 643 | 199 | Study on Optimized Transmit Pulse Shape for Downlink EGPRS2-B | 391d? | 2007-11-16 A | 2009-05-15 | 90% | 39.1d? | 2007-11-16 | 2009-05-15 | 391d? | 215d | finish no earlier than 2009-05-15 | G1 | 3128h | 2815.2h | WIDER | RIM, Nokia Siemens Networks | jdwyer@RIM.COM and eddie.riddington@nsn.com | Rel-8 | Paolo | 45.913 |  |  |  |  |  |
| 644 | 200 | Deleted - equals 340035 -FS on Service continuity between mobile and WLAN networks | 75d? | 2007-09-03 A | 2007-12-14 A | 100% |  | 2007-09-03 | 2007-12-14 | 75d? |  | finish no earlier than 2007-12-14 | S1 | 600h | 600h | FSSCMobToW | BT | mike.meyerstein@bt.com | Rel-8 | Alain | 22.937 |  | SP-37 |  | PCG-21 | SP-39 |
| 645 | 201 | Deleted - Study on Evaluation of LCS Control Plane Solution for EPS | 100d? | 2008-01-14 A | 2008-05-30 A | 100% |  | 2008-01-14 | 2008-05-30 | 100d? |  | finish no earlier than 2009-03-20 | S2 | 800h | 800h | FS_LCS_EPS | SiRF |  | Rel-8 | Maurice | 23.891 |  | SP-38 |  | PCG-21 | SP-40 |
| 646 | 202 | Release 7 Features | 1d? | 2000-01-03 | 2000-01-03 |  |  | 2000-01-03 | 2000-01-03 | 1d? | 2659d | start no earlier than 2000-01-01 | CP,GP, RP,SP | 8h |  |  |  |  | Rel-7 |  |  |  |  |  |  |  |

Notes:
- 611: SA#43 completed
- 612: SA#41 completed
- 613: SA#41 completed
- 614: SA#43 completed
- 615: SA#41 completed. No spin-off activity proposed. [Note: IMS Service Brokering enhancements UID_31088 moved back from R8 to R7 to give a home to 22228CR0036_(Rel-7)_S1-051232. Hence, Rel-7 ISB has Stage 1 only (and is misaligned with Rel-7 Stages 2/3.]
- 616: SA#38 completed
- 617: 08/08/08 TR 23.827 v 0.4.0 no progress for 1 year. MCC recommended FS be completed and 23.827 brought under CR. SA#41 completed (draft TR 23.827 not SA approved/published; TR content implemented in TSs)
- 618: SA#40 completed
- 619: SA#39 completed
- 620: SA#39 completed
- 621: SA#39 completed
- 622: SA#41 completed as Rel-8
- 623: SA#43 completed as Rel-8
- 624: SA#38 completed. Spin-off WID UID_34042 (eCall_Phase2)
- 625: SA#40 completed. SID updated SP-050608=>SP-070307
- 626: SA#37 completed. SID updated SP-050295=>SP-070305
- 627: SA#36 completed. Spin-off New Feature UID_400034 (UDC)
- 628: SA#42 completed
- 629: SA#38 completed
- 630: CT#40 completed. Spin-off New Feature UID_380035 (MRFC_TS)
- 631: CT#40 completed. Spin-off WID UID_400012 (IMS_RP)
- 632: CT#41 completed. Linked to SA5 Study on Common Profile Storage framework UID_320006. Spin-off WID UID_410003 (IMS_ASIO)
- 633: CT#41 completed. Spin-off WID under Feature CAT UID_340029
- 634: CT#41 Spin-off WID UID_410007 (MAP2Diam). CP#42 completed
- 635: SID in RP-070748. RP#40 completed. SR in RP-080290
- 636: SID in RP-070678. RP#39 completed. SR in RP-080068
- 637: SR in RP-070827. RP#38 completed
- 638: SID in RP-070257. RP#40 completed. SR in RP-080289
- 639: SID in RP-071044. SR in RP-080070. The study produced no TR. RP#39 completed. Spin-off New implementation WID in RP-080227
- 640: RP#43 closed. TR 25.825 v100 withdrawn. Conclusions in RP-090318 RAN1 findings of the UTRA Multi-Carrier Evolution study). RP#42 New WID RP-080490 (RANimp-DCHSDPA) UID_400052 aproved.
- 641: GP#37 completed. Spin-off implementation Feature AoIP (A-interface over IP) UID_50591
- 642: GP#41 completion 02/09=>05/09. GP#40 completion 11/08=>02/09
- 643: GP#41 completion 02/09=>05/09. GP#40 completion 11/08=>02/09
- 644: SA#39 stopped
- 645: SA#40 spin-off Feature UID_400038 (LCS_CPS_EPS). SA#40 FS stopped

| ID | WBS | Task | Type | Duration | Start | Finish | Complete | Baseline start | Baseline finish | Baseline duration | Constraint | Resources | Work | Actual work | Text1 | Text4 | Text5 | Text6 | Text8 | Text12 | Text11 | Text7 | Text2 |
| --- | --- | --- | --- | --- | --- | --- | --- | --- | --- | --- | --- | --- | --- | --- | --- | --- | --- | --- | --- | --- | --- | --- | --- |
| 647 | 203 | **Identification of Communication Services in IMS** |  | 620d? | 2005-05-02 A | 2007-09-14 A | 100% | 2005-05-02 | 2007-09-14 | 620d? |  | S2,S1,C1,S5 | 13016h | 13016h | ServID | Ericsson | stephen.terrill@ericsson.com | Rel-7 | Maurice |  |  |  |  |
| 648 | 203.1 | TR on ServID |  | 232d? | 2005-05-02 A | 2006-03-21 A | 100% | 2005-05-02 | 2006-03-21 | 232d? | finish no earlier than 2006-03-20 | S2 | 1856h | 1856h | ServID | Ericsson | stephen.terrill@ericsson.com | Rel-7 | Maurice |  |  |  |  |
| 649 | 203.2 | Stage 1,2 of ServID |  | 144d? | 2005-11-11 A | 2006-05-31 A | 100% | 2005-11-11 | 2006-05-31 | 144d? | start no earlier than 2005-11-11 | S1,S2 | 1152h | 1152h | ServID | Ericsson | stephen.terrill@ericsson.com | Rel-7 | Maurice |  |  |  |  |
| 650 | 203.3 | Stage 3 of ServID |  | 250d? | 2006-03-31 A | 2007-03-15 A | 100% | 2006-03-31 | 2007-03-15 | 250d? | finish no earlier than 2007-03-15 | C1 | 2000h | 2000h | ServID | Ericsson | christer.holmberg@ericsson.com | Rel-7 | Frederic |  |  |  |  |
| 651 | 203.4 | Charging of ServID |  | 381d? | 2006-03-31 A | 2007-09-14 A | 100% | 2006-03-31 | 2007-09-14 | 381d? | finish no earlier than 2007-09-14 | S5 | 3048h | 3048h | ServID | Orange | alain.bibas@orange-ft.com | Rel-7 | Dionisio |  |  |  |  |
| 652 | 204 | **Supporting Globally Routable User Agent URIs in IMS** |  | 415d? | 2005-11-14 A | 2007-06-15 A | 100% | 2005-11-14 | 2007-06-15 | 415d? |  | S2,S1,C1 | 7760h | 7760h | GRUU | RIM | Adrian Buckley (abuckley@rim.com) | Rel-7 | Maurice |  |  |  |  |
| 653 | 204.1 | Deleted - TR on GRUU |  | 219d? | 2005-11-14 A | 2006-09-14 A | 100% | 2005-11-14 | 2006-09-14 | 219d? | finish no earlier than 2006-09-14 | S2 | 1752h | 1752h | GRUU | RIM | Adrian Buckley (abuckley@rim.com) | Rel-7 | Maurice | SP-32 |  |  |  |
| 654 | 204.2 | Stage 1,2 of GRUU |  | 65d? | 2006-07-03 A | 2006-09-29 A | 100% | 2006-07-03 | 2006-09-29 | 65d? | start no earlier than 2006-07-03 | S1,S2 | 520h | 520h | GRUU | RIM | Adrian Buckley (abuckley@rim.com) | Rel-7 | Maurice |  |  |  |  |
| 655 | 204.3 | Stage 3 of GRUU |  | 271d? | 2006-06-02 A | 2007-06-15 A | 100% | 2006-06-02 | 2007-06-15 | 271d? | finish no earlier than 2007-06-15 | C1 | 2168h | 2168h | GRUU | CableLabs | Bernie McKibben | Rel-7 | Frederic |  |  |  |  |
| 656 | 205 | **Multimedia Telephony Service for IMS** |  | 357d? | 2006-02-01 A | 2007-06-15 A | 100% | 2006-02-01 | 2007-06-15 | 357d? |  | S1,C1,S4 | 8976h | 8976h | MTSI | Ericsson | peter.bleckert@ericsson.com | Rel-7 | Alain |  |  |  |  |
| 657 | 205.1 | Stage 1 of MTSI |  | 173d? | 2006-02-01 A | 2006-09-29 A | 100% | 2006-02-01 | 2006-09-29 | 173d? | start no earlier than 2006-02-01 | S1 | 1384h | 1384h | MTSI-REQ | Ericsson | peter.bleckert@ericsson.com | Rel-7 | Alain |  |  |  |  |
| 658 | 205.2 | Stage 3 of MTSI |  | 330d? | 2006-03-10 A | 2007-06-15 A | 100% | 2006-03-10 | 2007-06-15 | 330d? | finish no earlier than 2007-06-15 | C1 | 2640h | 2640h | MTSI | Ericsson | christer.holmberg@ericsson.com | Rel-7 | Frederic |  |  |  |  |
| 659 | 205.3 | Media handling and interaction in MTSI |  | 262d? | 2006-03-15 A | 2007-03-15 A | 100% | 2006-03-15 | 2007-03-15 | 262d? | finish no earlier than 2007-03-15 | S4 | 2096h | 2096h | MTSI-MHI | Ericsson | olle.franceschi@ericsson.com | Rel-7 | Paolo |  |  |  |  |
| 660 | 205.4 | Deleted - duplicates UID7039 - IMS Multimedia Telephony Service | milestone | 0d? | 2007-06-15 A | 2007-06-15 A | 100% | 2007-06-15 | 2007-06-15 | 0d? | start no earlier than 2007-06-15 | S1 |  |  | MMTEL | Ericsson | peter.bleckert@ericsson.com | Rel-7 | Alain | SP-32 |  |  |  |
| 661 | 206 | Multimedia Telephony Service for IMS (MTSI) - UE Conformance Testing |  | 387d | 2007-09-19 A | 2009-03-12 A | 100% | 2007-09-19 | 2009-03-12 | 387d | finish no earlier than 2009-03-13 | R5 | 1664h | 1664h | MTSI-UEConfTest | Ericsson, Motorola | Leif.Mattisson@ericsson.com, Jacob.John@motorola.com | Rel-7 | Ingbert |  | RP-090056 |  |  |
| 662 | 207 | TISPAN requirements for Multimedia Telephony with PSTN/ISDN simulation services |  | 58d? | 2007-09-18 A | 2007-12-06 A | 100% | 2007-09-18 | 2007-12-06 | 58d? | start no earlier than 2007-09-18 | S1 | 464h | 464h | TMMTEL7 |  |  | Rel-7 | Alain |  |  | SP-37 |  |
| 663 | 208 | **Maintenance of TISPAN release 1 common IMS** |  | 58d? | 2007-09-18 A | 2007-12-06 A | 100% | 2007-09-18 | 2007-12-06 | 58d? |  | S2 | 1392h | 1392h | MCIMSTR1 | Ericsson | Raymond Forbes | Rel-7 | Maurice |  |  | SP-38 | PCG-21 |
| 664 | 208.1 | SA1 aspects of MCIMSTR1 |  | 58d? | 2007-09-18 A | 2007-12-06 A | 100% | 2007-09-18 | 2007-12-06 | 58d? | finish no earlier than 2007-12-06 | S1 | 464h | 464h | MCIMSTR1-S1 | Telecom Italia | Marco.DeLuca1@telecomitalia.it | Rel-7 | Alain |  |  | SP-38 | PCG-21 |
| 665 | 208.2 | SA2 aspects of MCIMSTR1 |  | 58d? | 2007-09-18 A | 2007-12-06 A | 100% | 2007-09-18 | 2007-12-06 | 58d? | finish no earlier than 2007-12-06 | S2 | 464h | 464h | MCIMSTR1-S2 | Ericsson | Raymond Forbes | Rel-7 | Maurice |  |  | SP-38 | PCG-21 |
| 666 | 209 | **PS domain and IMS impacts for supporting IMS Emergency calls** |  | 1760d? | 2000-09-18 A | 2007-06-15 A | 100% | 2000-09-18 | 2007-06-15 | 1760d? |  | S2,S1 | 44157h | 44157h | EMC1 | Siemens | Rainer Liebhart | Rel-7 | Maurice |  |  |  |  |
| 667 | 10.1.1 | Service Requirements for IP-based emergency calls |  | 985d | 2000-09-18 A | 2004-06-25 A | 100% | 2000-09-18 | 2004-06-25 | 985d | finish no earlier than 2004-06-25 | S1 | 7880h | 7880h | EMC1 | Siemens | Rainer Liebhart | Rel-7 | Alain |  |  |  |  |
| 668 | 209.2 | Study on Stage 2 for IMS-level solution |  | 668d? | 2003-02-26 A | 2005-09-16 A | 100% | 2003-02-26 | 2005-09-16 | 668d? | finish no earlier than 2005-09-16 | S2 | 5344h | 5344h | EMC1 | Siemens | Rainer Liebhart | Rel-7 | Maurice |  |  |  |  |
| 669 | 209.3 | Study on Stage 2 for GPRS-level solution |  | 301d? | 2004-10-14 A | 2005-12-08 A | 100% | 2004-10-14 | 2005-12-08 | 301d? | finish no earlier than 2005-12-08 | S2 | 2408h | 2408h | EMC1 | Siemens | Rainer Liebhart | Rel-7 | Maurice |  |  |  |  |
| 670 | 209.4 | Stage 2 Specification Phase - IMS-level |  | 200d? | 2005-09-05 A | 2006-06-09 A | 100% | 2005-09-05 | 2006-06-09 | 200d? | finish no earlier than 2006-06-09 | S2 | 1600h | 1600h | EMC1 | Siemens | Rainer Liebhart | Rel-7 | Maurice |  |  |  |  |
| 671 | 209.5 | Deleted - Stage 2 Specification Phase - GPRS-level | milestone | 0d? | 2007-03-02 A | 2007-03-02 A | 100% | 2007-03-02 | 2007-03-02 | 0d? | start no earlier than 2007-03-02 | S2 |  |  | EMC1 | Siemens | Rainer Liebhart | Rel-7 | Maurice | SP-32 |  |  |  |

Notes:
- 647: WID approved SA#28. WID updated SA#32
- 648: Text3: 23.816
- 649: Text3: 22.228, 23.228, 23.203
- 650: CT#32 approved WID / Text3: 23.218, 24.229
- 651: Text3: 32.260, 32.298, 32.299
- 652: SA#29 approved WID
- 653: Abandoned
- 654: SA#29 approved WID / Text3: 22.228, 23.228, 23.218, 24.229
- 655: CT#32 approved WID / Text3: 24.229
- 657: Text3: 22.173
- 658: Text3: 24.173
- 659: Text3: 26.114
- 660: Text3: 22.173
- 661: RP#43 completed. Linked UID_7038 (MTSI) / Text3: 34.123-1, 34.123-2, 34.123-3, 34.229-1, 34.229-2
- 662: Text3: 22.273 (EI 181 002 maintenance)
- 663: Text3: http://www.3gpp.org/specs/TISPAN-IMS-ansfer.htm
- 664: Text3: 22.173, 22.273
- 665: Text3: 23.406, 23.417, 23.508,23.509, 23.511
- 667: Text3: 22.976 (DB shows 04/2003 withdrawn Study on PS domain services and capabilities (az: belongs this really here ?!)
- 668: Text3: 23.867
- 669: Text3: 23.867
- 670: Text3: 23.167, 23.228, 23.060, 23.002, 23.271

| ID | WBS | Task | Type | Duration | Start | Finish | Complete | Baseline start | Baseline finish | Baseline duration | Constraint | Resources | Work | Actual work | Text1 | Text4 | Text5 | Text6 | Text8 | Text3 | Text12 | Text10 | Text11 |
| --- | --- | --- | --- | --- | --- | --- | --- | --- | --- | --- | --- | --- | --- | --- | --- | --- | --- | --- | --- | --- | --- | --- | --- |
| 672 | 10.1 | **Emergency Call Enhancements for IP& PS Based Calls – stage 3** |  | 375d | 2006-01-09 A | 2007-06-15 A | 100% | 2006-01-09 | 2007-06-15 | 375d |  | C1 | 12845h | 12845h | EMC1 | Ericsson | alf.heidermark@ericsson.com | Rel-7 | Frederic |  |  |  |  |
| 673 | 10.1.2 | CT1 IMS aspects to support IMS Emergency sessions |  | 350.82d | 2006-01-09 A | 2007-06-15 A | 100% | 2006-01-09 | 2007-06-15 | 350.82d | finish no earlier than 2007-06-15 | C1 | 2806.57h | 2806.57h | EMC1 | Ericsson | alf.heidermark@ericsson.com | Rel-7 | Frederic | 24.229 |  |  |  |
| 674 | 10.1.2 | Deleted - CT3 IMS aspects to support IMS Emergency sessions |  | 95d | 2006-05-08 A | 2006-09-15 A | 100% | 2006-05-08 | 2006-09-15 | 95d | finish no earlier than 2006-09-15 | C3 | 760h | 760h | EMC1 | Ericsson | alf.heidermark@ericsson.com | Rel-7 | Gwiho | 29.163 | CP-33 |  |  |
| 675 | 10.1.5 | Deleted - CT3 PS domain aspects to support IMS Emergency sessions |  | 95d | 2006-05-08 A | 2006-09-15 A | 100% | 2006-05-08 | 2006-09-15 | 95d | start no earlier than 2006-05-08 | C3 | 760h | 760h | EMC1 | Ericsson | alf.heidermark@ericsson.com | Rel-7 | Gwiho | 29.061 | CP-33 |  |  |
| 676 | 10.1.5 | CT1 PS domain aspects to support IMS Emergency sessions |  | 349.9d | 2006-01-09 A | 2007-06-15 A | 100% | 2006-01-09 | 2007-06-15 | 349.9d | finish no earlier than 2007-06-15 | C1 | 2799.2h | 2799.2h | EMC1 | Ericsson | alf.heidermark@ericsson.com | Rel-7 | Frederic | 24.008, 24.234 |  |  |  |
| 677 | 10.1.5 | CT4 PS domain aspects to support IMS Emergency sessions |  | 365d | 2006-01-09 A | 2007-06-01 A | 100% | 2006-01-09 | 2007-06-01 | 365d | finish no earlier than 2007-06-01 | C4 | 2920h | 2920h | EMC1-GPRSc4 | Ericsson | alf.heidermark@ericsson.com | Rel-7 | Kimmo | 29.060 |  |  |  |
| 678 | 210 | IMS Support of Conferencing |  | 355d? | 2005-11-04 A | 2007-03-15 A | 100% | 2005-11-04 | 2007-03-15 | 355d? | finish no earlier than 2007-03-15 | C1 | 2840h | 2840h | IMSconf | Alcatel-Lucent | Keith Drage (drage@alcatel-lucent.com) | Rel-7 | Frederic | 24.147, 24.229 |  |  |  |
| 679 | 211 | Performance Characterization of VoIMS over HSDPA\EUL channels |  | 713d? | 2005-03-15 A | 2007-12-06 A | 100% | 2005-03-15 | 2007-12-06 | 713d? | finish no earlier than 2007-12-06 | S4 | 5704h | 5704h | VoIMS-PCVoIMS | Alcatel-Lucent | mcgowan@alcatel-lucent.com | Rel-7 | Paolo | 26.935 |  |  |  |
| 680 | 212 | **WLAN-UMTS Interworking Phase 2** |  | 371d? | 2004-01-05 A | 2005-06-07 A | 100% | 2004-01-05 | 2005-06-07 | 371d? |  | S1 | 3888h | 3888h | WLAN2 | Telenor | frederic.paint@telenor.com | Rel-7 | Alain | 33.234 (SP-36 SA3 CRs approved) |  |  |  |
| 681 | 212.1 | Stage 1 on Session Continuity |  | 115d? | 2004-01-05 A | 2004-06-11 A | 100% | 2004-01-05 | 2004-06-11 | 115d? | start no earlier than 2004-01-05 | S1 | 920h | 920h | WLAN-SC |  |  | Rel-7 | Alain | 22.234 |  | SP-24 |  |
| 682 | 212.2 | Stage 2 on Session Continuity: covered by SAE | milestone | 0d? | 2005-06-07 A | 2005-06-07 A | 100% | 2005-06-07 | 2005-06-07 | 0d? | finish no earlier than 2005-06-07 | S2 |  |  | WLAN-SC |  |  | Rel-7 | Maurice |  |  |  |  |
| 683 | 213 | **WLAN Interworking – Private Network access from WLAN 3GPP IP Access** |  | 252d? | 2005-10-10 A | 2006-09-26 A | 100% | 2005-10-10 | 2006-09-26 | 252d? |  | S2,C1,C3,C4 | 8936h | 8936h | WLANPNA | NEC | Toshiyuki Tamura (tamurato@aj.jp.nec.com) | Rel-7 | Maurice |  |  |  |  |
| 684 | 213.1 | WLAN-PNA - Stage 2 |  | 185d? | 2005-10-10 A | 2006-06-23 A | 100% | 2005-10-10 | 2006-06-23 | 185d? | start no earlier than 2005-10-10 | S2 | 1480h | 1480h | WLANPNA-st2 | NEC | Toshiyuki Tamura (tamurato@aj.jp.nec.com) | Rel-7 | Maurice | 23.234, 33.234 |  |  |  |
| 685 | 213.2 | **WLAN-PNA - Stage 3** |  | 170d? | 2006-02-01 A | 2006-09-26 A | 100% | 2006-02-01 | 2006-09-26 | 170d? |  | C1,C3,C4 | 5440h | 5440h | WLANPNA-st3 | NEC |  | Rel-7 | Frederic |  |  |  |  |
| 686 | 213.2.1 | CT1 aspets for WLAN-PNA |  | 170d? | 2006-02-01 A | 2006-09-26 A | 100% | 2006-02-01 | 2006-09-26 | 170d? | start no earlier than 2006-02-01 | C1 | 1360h | 1360h | WLANPNA-st3 | NEC |  | Rel-7 | Frederic | 24.234 |  |  |  |
| 687 | 213.2.2 | CT3 aspets for WLAN-PNA |  | 170d? | 2006-02-01 A | 2006-09-26 A | 100% | 2006-02-01 | 2006-09-26 | 170d? | start no earlier than 2006-02-01 | C3 | 1360h | 1360h | WLANPNA-st3 | NEC |  | Rel-7 | Gwiho | 29.161 |  |  |  |
| 688 | 213.2.3 | Deleted - CT4 aspets for WLAN-PNA |  | 170d? | 2006-02-01 A | 2006-09-26 A | 100% | 2006-02-01 | 2006-09-26 | 170d? | start no earlier than 2006-02-01 | C4 | 1360h | 1360h | WLANPNA-st3 | NEC |  | Rel-7 | Kimmo | 29.234 | CP-32 |  |  |
| 689 | 214 | **Enhancements to support QoS provisioning over 3GPP/WLAN Interworking** |  | 520d? | 2005-03-14 A | 2007-03-09 A | 100% | 2005-03-14 | 2007-03-09 | 520d? |  | S2,C4,C1 | 8360h | 8360h | WLANQOS | Samsung |  | Rel-7 | Maurice |  |  |  |  |
| 690 | 214.1 | Deleted - TR on support of QoS on WLAN |  | 232d? | 2005-03-14 A | 2006-01-31 A | 100% | 2005-03-14 | 2006-01-31 | 232d? | start no earlier than 2005-03-14 | S2 | 1856h | 1856h | WLANQOS | Samsung |  | Rel-7 | Maurice | 23.836 | SP-32 |  |  |
| 691 | 214.2 | Stage 2 on support of QoS over 3GPP/WLAN interworking |  | 108d? | 2006-02-01 A | 2006-06-30 A | 100% | 2006-02-01 | 2006-06-30 | 108d? | start no earlier than 2006-02-01 | S2 | 864h | 864h | WLANQOS | Samsung |  | Rel-7 | Maurice | 23.234 |  |  |  |
| 692 | 214.3 | Stage 3 CT4 on support of QoS over 3GPP/WLAN Interworking |  | 121d? | 2006-09-22 A | 2007-03-09 A | 100% | 2006-09-22 | 2007-03-09 | 121d? | finish no earlier than 2007-03-09 | C4 | 968h | 968h | WLANQOS | Huawei | zhang.peng@huawei.com | Rel-7 | Kimmo | 29.234, 23.008 |  |  |  |
| 693 | 214.4 | Stage 3 CT1 on support of QoS over 3GPP/WLAN Interworking |  | 64d? | 2006-09-04 A | 2006-11-30 A | 100% | 2006-09-04 | 2006-11-30 | 64d? | finish no earlier than 2006-11-30 | C1 | 512h | 512h | WLANQOS | Huawei | zhang.peng@huawei.com | Rel-7 | Frederic | 24.234 |  |  |  |
| 694 | 215 | **Location Services enhancements** |  | 906d? | 2004-06-28 A | 2007-12-17 A | 100% | 2004-06-28 | 2007-12-17 | 906d? |  | S1,S2,GP,C4,R2 | 46933.6h | 46933.6h | LCS3 |  |  | Rel-7 | Alain |  |  |  |  |
| 695 | 215.1 | Stage 2 for LCS3 (including IMS emergency location aspects) |  | 446d? | 2004-12-31 A | 2006-09-15 A | 100% | 2004-12-31 | 2006-09-15 | 446d? | finish no earlier than 2006-09-15 | S2 | 3568h | 3568h | LCS3 | SiRF | brodilitz@sirf.com | Rel-7 | Maurice | 23.271 |  |  |  |
| 696 | 215.2 | LCS Enhancements related to Location-Based Services |  | 695d? | 2005-01-03 A | 2007-08-31 A | 100% | 2005-01-03 | 2007-08-31 | 695d? | finish no earlier than 2007-08-31 | GP | 5560h | 5560h | LCS3-LBS | SiRF | kjudge@sirf.com | Rel-7 | Paolo | 43.059, 44.031, 48.008, 49.031 |  |  |  |
| 697 | 215.3 | CT4 aspects for LCS UEPos-LBS |  | 240d? | 2006-01-02 A | 2006-12-01 A | 100% | 2006-01-02 | 2006-12-01 | 240d? | finish no earlier than 2006-12-01 | C4 | 1920h | 1920h | LCS3-UEPos-LBS | SiRF | brodilitz@sirf.com | Rel-7 | Kimmo | 24.030, 24.080, 29.002 |  |  |  |
| 698 | 215.4 | UE positioning - Velocity |  | 394d? | 2005-03-15 A | 2006-09-15 A | 100% | 2005-03-15 | 2006-09-15 | 394d? | finish no earlier than 2006-09-15 | R2 | 3152h | 3152h | LCS3-UEPos-Velocity | SiRF | BRodilitz@SiRF.com | Rel-7 | Joern | 25.305, 25.331, 25.410, 25.413, 25.453 |  |  | RP-060459 |
| 699 | 215.5 | Inclusion of Uplink TDOA UE positioning method in the UTRAN specifications |  | 849d? | 2004-09-15 A | 2007-12-17 A | 100% | 2004-09-15 | 2007-12-17 | 849d? | finish no earlier than 2007-12-17 | R2 | 6792h | 6792h | LCS3-UEPos-UTDOA | TruePosition | Robert Gross | Rel-7 | Joern | 25.305, 25.453 |  |  | RP-070797 |

Notes:
- 674: Cancelled for Rel-7 and there is now corresponding Rel-8 WI
- 675: Cancelled for Rel-7 and there is now corresponding Rel-8 WI
- 678: CT#35 revised WID
- 680: Created at TSG#27 by A. Sultan because of WLAN items belonging to Rel-7. az: This WI is an extension of the WLAN-UMTS Interworking Rel-6 (No new WID)
- 684: Approved at SA#29
- 685: Approved at CT#29
- 686: Approved at CT#29
- 687: Approved at CT#29
- 688: CT4#31; no impacts identified, therefore completed. CP-32 stopped
- 689: Moved from FS section Feb 06. SP-30 updated WID
- 690: SP-32 stopped
- 691: SP-30 updated WID
- 692: CP-32 approved WID
- 693: CP-32 approved WID
- 695: SA#27 approved WID.
- 698: Completed Sept 2006; SR in RP-060459
- 699: Completed Nov 2007; SR in RP-070797

| ID | WBS | Task | Type | Duration | Start | Finish | Complete | Baseline start | Baseline finish | Baseline duration | Constraint | Resources | Work | Actual work | Text1 | Text4 | Text5 | Text6 | Text8 | Text12 | Text11 |
| --- | --- | --- | --- | --- | --- | --- | --- | --- | --- | --- | --- | --- | --- | --- | --- | --- | --- | --- | --- | --- | --- |
| 700 | 215.6 | **LCS for 3GPP Interworking WLAN** |  | 700d? | 2004-06-28 A | 2007-03-02 A | 100% | 2004-06-28 | 2007-03-02 | 700d? |  | S1 | 11901.6h | 11901.6h | LCS3-IWLAN | Telcordia | Mike Loushine | Rel-7 | Alain |  |  |
| 701 | 215.6.1 | FS on 3GPP system to WLAN Interworking with LCS |  | 512.7d? | 2004-06-28 A | 2006-06-30 A | 100% | 2004-06-28 | 2006-06-30 | 512.7d? | finish no earlier than 2005-09-29 | S1 | 4101.6h | 4101.6h | LCS3-IWLAN-FSs1 | Telcordia | Mike Loushine, Vijay Varma | Rel-7 | Alain |  |  |
| 702 | 215.6.2 | Delete - Study of work on an LCS architecture for I-WLAN. |  | 180d? | 2006-06-26 A | 2007-03-02 A | 100% | 2006-06-26 | 2007-03-02 | 180d? | finish no earlier than 2007-03-02 | S2 | 1440h | 1440h | LCS3-IWLAN-FSs2 | LG Electronics | dhshim@lge.com ; phede@lge.com | Rel-7 | Maurice | SP-35 |  |
| 703 | 215.6.3 | Stage 2 for LCS architecture for I-WLAN |  | 95d? | 2006-10-23 A | 2007-03-02 A | 100% | 2006-10-23 | 2007-03-02 | 95d? | finish no earlier than 2007-03-02 | S2 | 760h | 760h | LCS3-IWLAN | LG Electronics | dhshim@lge.com ; phede@lge.com | Rel-7 | Maurice |  |  |
| 704 | 215.7 | Deleted - UE positioning Rel-7 |  | 849d? | 2004-09-15 A | 2007-12-17 A | 100% | 2004-09-15 | 2007-12-17 | 849d? |  | RP | 6792h | 6792h | LCS3-UEpos |  |  | Rel-7 |  | RP-38 |  |
| 705 | 215.8 | Deleted - RAN2 aspects for LBS | milestone | 0d? | 2005-06-15 A | 2005-06-15 A | 100% | 2005-06-15 | 2005-06-15 | 0d? | start no earlier than 2005-06-15 | R2 |  |  | LCS3-UEPos-LBS | SiRF | BRodilitz@SiRF.com | Rel-7 | Joern | RP-31 |  |
| 706 | 216 | **MBMS Enhancements** |  | 625d? | 2005-07-11 A | 2007-11-30 A | 100% | 2005-07-11 | 2007-11-30 | 625d? |  | S1 | 10844.6h | 10844.6h | MBMSE | China Mobile | liuhongyfw@chinamobile.com | Rel-7 | Alain |  |  |
| 707 | 216.1 | Stage 1 of MBMSE |  | 109d? | 2005-07-11 A | 2005-12-08 A | 100% | 2005-07-11 | 2005-12-08 | 109d? | finish no earlier than 2005-12-08 | S1,R1,C3 | 872h | 872h | MBMSE | China Mobile | liuhongyfw@chinamobile.com | Rel-7 | Alain |  |  |
| 708 | 216.2 | MBMS FDD Physical layer Enhancements |  | 117.29d? | 2006-12-15 A | 2007-06-04 A | 100% | 2006-12-15 | 2007-06-04 | 117.29d? | finish no earlier than 2007-06-04 | R1 | 938.32h | 938.32h | MBMSE-RANPhysFDD | Ericsson | Lars.Lindbom@ericsson.com | Rel-7 | Patrick |  | RP-070290 |
| 709 | 216.3 | MBMS TDD Physical layer Enhancements |  | 117.29d? | 2006-12-15 A | 2007-06-04 A | 100% | 2006-12-15 | 2007-06-04 | 117.29d? | finish no earlier than 2007-06-04 | R1 | 938.32h | 938.32h | MBMSE-RANPhysTDD | IPWireless | Nicholas Anderson | Rel-7 | Patrick |  | RP-070291 |
| 710 | 216.4 | MBMS Low Chip Rate TDD Physical Layer Enhancement |  | 127d? | 2007-03-16 A | 2007-09-10 A | 100% | 2007-03-16 | 2007-09-10 | 127d? | finish no earlier than 2007-09-10 | R1 | 1016h | 1016h | MBMSE-RANPhysLCRTDD | RITT | Lin Hui | Rel-7 | Patrick |  | RP-070292 |
| 711 | 216.5 | MBMS Mz interface |  | 260d? | 2006-12-04 A | 2007-11-30 A | 100% | 2006-12-04 | 2007-11-30 | 260d? | finish no earlier than 2007-05-11 | C3 | 2080h | 2080h | MBMSMz | Huawei | Deng Tingting (ttdeng@huawei.com) | Rel-7 | Gwiho |  |  |
| 712 | 217 | MBMS User Service Extensions |  | 392d? | 2005-12-07 A | 2007-06-07 A | 100% | 2005-12-07 | 2007-06-07 | 392d? | finish no earlier than 2007-06-07 | S4 | 3136h | 3136h | MBMSUSE | Ericsson | Thorsten.Lohmar@ericsson.com | Rel-7 | Paolo |  |  |
| 713 | 218 | **Advanced Global Navigation Satellite System (A-GNSS) concept** |  | 830d? | 2004-06-28 A | 2007-08-31 A | 100% | 2004-06-28 | 2007-08-31 | 830d? |  | S1,GP,R2 | 9553.6h | 9553.6h | LCS3-AGNSS | Alcatel | Michel.monnerat@thalesaleniaspace.com | Rel-7 | Alain |  |  |
| 714 | 218.1 | Towards A-GNSS Concept |  | 811.2d? | 2004-06-28 A | 2007-08-31 A | 100% | 2004-06-28 | 2007-08-31 | 811.2d? | finish no earlier than 2007-08-31 | GP | 6489.6h | 6489.6h | AGNSS-GP | Alcatel | richard.couty@space.alcatel.fr | Rel-7 | Paolo |  |  |
| 715 | 218.2 | Global Navigation Satellite System (GNSS) in UTRAN |  | 383d? | 2005-12-15 A | 2007-06-04 A | 100% | 2005-12-15 | 2007-06-04 | 383d? | finish no earlier than 2007-06-04 | R2 | 3064h | 3064h | LCS3-GNSS-UTRAN | France Telecom | alain.abinakhoul@francetelecom.com | Rel-7 | Joern |  | RP-070482 |
| 716 | 218.3 | Deleted - Towards A-GNSS Concept | milestone | 0d? | 2007-02-16 A | 2007-02-16 A | 100% | 2007-02-16 | 2007-02-16 | 0d? | start no earlier than 2007-02-16 | S1 |  |  | GNSS | Alcatel | richard.couty@space.alcatel.fr | Rel-7 | Alain | SP-34 |  |
| 717 | 219 | A-GPS Minimum Performance |  | 351d? | 2006-04-28 A | 2007-08-31 A | 100% | 2006-04-28 | 2007-08-31 | 351d? | finish no earlier than 2007-08-31 | GP | 2808h | 2808h | GAGR | Spirent | richard.catmur@spirentcom.com | Rel-7 | Paolo |  |  |
| 718 | 220 | **USSD message delivery and transfer to USIM** |  | 376d? | 2004-03-05 A | 2005-08-12 A | 100% | 2004-03-05 | 2005-08-12 | 376d? |  | S1,C6 | 2762.4h | 2762.4h | USSD-USIM | Axalto | Christophe Dubois (cdubois@axalto.com) | Rel-7 | Alain |  |  |
| 719 | 220.1 | Stage 1 |  | 152d? | 2004-03-18 A | 2004-10-15 A | 100% | 2004-03-18 | 2004-10-15 | 152d? | start no earlier than 2004-03-18 | S1 | 1216h | 1216h | USSD-USIM | Axalto | Christophe Dubois (cdubois@axalto.com) | Rel-7 | Alain |  |  |
| 720 | 220.2 | Alignment with requirements regarding USSD usage |  | 193.3d? | 2004-03-05 A | 2005-08-12 A | 100% | 2004-03-05 | 2005-08-12 | 193.3d? | finish no earlier than 2005-08-12 | C6 | 1546.4h | 1546.4h | USSD-USIM | Axalto | Christophe Dubois (cdubois@axalto.com) | Rel-7 | Xavier |  |  |
| 721 | 221 | **Combinational Services** |  | 296d? | 2005-01-17 A | 2006-03-06 A | 100% | 2005-01-17 | 2006-03-06 | 296d? |  | S1,S2,C1,S4 | 5176h | 5176h | CSICS | TeliaSonera | Robert.Frank@teliasonera.com | Rel-7 | Alain |  |  |
| 722 | 221.1 | Stage 1 for CSICS |  | 104d? | 2005-01-17 A | 2005-06-09 A | 100% | 2005-01-17 | 2005-06-09 | 104d? | start no earlier than 2005-01-17 | S1 | 832h | 832h | CSICS | TeliaSonera | Robert.Frank@teliasonera.com | Rel-7 | Alain |  |  |
| 723 | 221.2 | Stage 2 for CSICS |  | 130d? | 2005-01-17 A | 2005-07-15 A | 100% | 2005-01-17 | 2005-07-15 | 130d? | start no earlier than 2005-01-17 | S2 | 1040h | 1040h | CSICS | TeliaSonera | Robert.Frank@teliasonera.com | Rel-7 | Maurice |  |  |
| 724 | 221.3 | Stage 3 for CSICS CN aspects |  | 221d? | 2005-05-02 A | 2006-03-06 A | 100% | 2005-05-02 | 2006-03-06 | 221d? | finish no earlier than 2006-03-06 | C1 | 1768h | 1768h | CSICS | Vodafone | Peter Dawes | Rel-7 | Frederic |  |  |
| 725 | 221.4 | Stage 3 for codec aspects |  | 192d? | 2005-03-15 A | 2005-12-07 A | 100% | 2005-03-15 | 2005-12-07 | 192d? | finish no earlier than 2005-12-07 | S4 | 1536h | 1536h | CSICS-Codec | Ericsson | Per.Frojdh@ericsson.com | Rel-7 | Paolo |  |  |

Notes:
- 700: Text3: 22.935
- 701: Text3: 22.935
- 702: Updated WID at SA#32 to change "stage 2" to "study" , duplicated UID 320017 deleted. SA#33 TR for Information. extension Granted for Rel-7 until 03/07. Last mention SP-35 Mar 2007 (abandoned ?) / Text3: 23.837
- 703: WID at SA#55 / Text3: 23.234, 23.271, 23.167
- 705: Text3: 25.305, 25.331, 25.410, 25.413, 25.453
- 707: Structure created by MCC to include RAN aspects under SA1 Feature / Text3: 22.146, 22.246, 22.228
- 708: Completed May 2007; SR in RP-070290 / Text3: 25.211, 25.212, 25.213, 25.101, 25.104, 25.331, 25.433, 25.346, 25.306
- 709: Completed May 2007; SR in RP-070291 / Text3: 25.346, 25.221, 25.222, 25.223, 25.224, 25.306, 25.331, 25.402, 25.433, 25.102, 25.105, 25.123
- 710: Completed May 2007; SR in RP-070292 / Text3: 25.346, 25.221, 25.222, 25.223, 25.224, 25.306, 25.331, 25.402, 25.433, 25.102, 25.105, 25.123
- 711: Text3: 29.061
- 712: Text3: 26.346, 26.946
- 714: GP#36 completed
- 715: Completed Sept 2006; SR in RP-070482 / Text3: 25.305, 25.331, 25.306, 25.413, 25.423, 25.433, 25.453, 25.302, 25.215, 25.401, 25.402, 25.450, 25.452
- 717: Text3: 45.005, 51.010
- 719: Text3: 22.090
- 722: Text3: 22.279
- 723: Text3: 23.279
- 724: Text3: 24.879, 24.279, 24.229, 24.008
- 725: Text3: 26.141, 26.235

| ID | WBS | Task | Type | Duration | Start | Finish | Complete | Baseline start | Baseline finish | Baseline duration | Constraint | Resources | Work | Actual work | Text1 | Text4 | Text5 | Text6 | Text8 | Text3 | Text12 |
| --- | --- | --- | --- | --- | --- | --- | --- | --- | --- | --- | --- | --- | --- | --- | --- | --- | --- | --- | --- | --- | --- |
| 726 | 222 | **CAMEL Trunk Triggers** |  | 251d? | 2004-12-17 A | 2005-12-05 A | 100% | 2004-12-17 | 2005-12-05 | 251d? |  | S1,C4 | 6024h | 6024h | TTCAMEL | Nortel | Amar Deol (deola@nortelnetworks.com) | Rel-7 | Alain |  |  |
| 727 | 222.1 | Stage 1 for CAMEL Trunk Triggers |  | 251d? | 2004-12-17 A | 2005-12-05 A | 100% | 2004-12-17 | 2005-12-05 | 251d? |  | S1 | 2008h | 2008h | TTCAMEL | Nortel | Amar Deol (deola@nortelnetworks.com) | Rel-7 | Alain | 22.078 |  |
| 728 | 222.2 | CAMEL Trunk Originated Trigger Detection Points |  | 251d? | 2004-12-17 A | 2005-12-05 A | 100% | 2004-12-17 | 2005-12-05 | 251d? | start no earlier than 2004-12-17 | C4 | 2008h | 2008h | CamelR7 | Nortel | David Hutton (dhutton@nortel.com) | Rel-7 | Kimmo |  |  |
| 729 | 223 | **IMS Service Brokering enhancements** |  | 69d? | 2005-12-07 A | 2006-03-13 A | 100% | 2005-12-07 | 2006-03-13 | 69d? |  | S1 | 1104h | 1104h | ISB | Telcordia | jbakker@telcordia.com | Rel-7 | Alain | 22.228 |  |
| 730 | 223.1 | Stage 1 for ISB |  | 69d? | 2005-12-07 A | 2006-03-13 A | 100% | 2005-12-07 | 2006-03-13 | 69d? | finish no earlier than 2006-03-13 | S1 | 552h | 552h | ISB-s1 | Telcordia | jbakker@telcordia.com | Rel-7 | Alain | 22.228 |  |
| 731 | 224 | **Enhancements of VGCS for public authority officials** |  | 731d? | 2004-08-27 A | 2007-06-15 A | 100% | 2004-08-27 | 2007-06-15 | 731d? |  | S1 | 25920h | 25920h | EVGCS |  |  | Rel-7 | Alain | 43.068, 44.068, 24.008, 29.002 |  |
| 732 | 224.1 | Stage 1 | milestone | 0d? | 2004-08-27 A | 2004-08-27 A | 100% | 2004-08-27 | 2004-08-27 | 0d? | finish no earlier than 2004-08-27 | S1 |  |  | EVGCS | Siemens | Joerg Swetina (joerg.swetina@nw.neclab.eu) | Rel-7 | Alain | 42.068, 43.068 |  |
| 733 | 224.2 | **Architecture and protocol aspects** |  | 731d? | 2004-08-27 A | 2007-06-15 A | 100% | 2004-08-27 | 2007-06-15 | 731d? |  | C1 | 14904h | 14904h | EVGCS | Siemens | robert.zaus@nsn.com | Rel-7 | Frederic | 43.068, 44.068 |  |
| 734 | 224.2.1 | CT1 aspects of EVGCS |  | 731d? | 2004-08-27 A | 2007-06-15 A | 100% | 2004-08-27 | 2007-06-15 | 731d? | finish no earlier than 2006-09-15 | C1 | 5848h | 5848h | EVGCS | Siemens |  | Rel-7 | Frederic | 43.068, 44.068, 24.008 |  |
| 735 | 224.2.2 | CT4 aspects of EVGCS |  | 401d? | 2004-08-27 A | 2006-03-10 A | 100% | 2004-08-27 | 2006-03-10 | 401d? | finish no earlier than 2006-03-10 | C4 | 3208h | 3208h | EVGCS-St23-c4 | Siemens |  | Rel-7 | Kimmo | 29.002 |  |
| 736 | 224.3 | GERAN2 aspects |  | 646d? | 2004-08-27 A | 2007-02-16 A | 100% | 2004-08-27 | 2007-02-16 | 646d? | finish no earlier than 2007-02-16 | G2 | 5168h | 5168h | EVGCS | Siemens | kenneth.isaacs@roke.co.uk | Rel-7 | Juha |  |  |
| 737 | 225 | **Improvements of VGCS for parallel use of services** |  | 523d? | 2005-03-15 A | 2007-03-15 A | 100% | 2005-03-15 | 2007-03-15 | 523d? |  | S1 | 12230.2h | 12230.2h | IVGCS |  |  | Rel-7 | Alain |  |  |
| 738 | 225.1 | Service Requirements for VGCS improvements |  | 62d? | 2005-03-15 A | 2005-06-08 A | 100% | 2005-03-15 | 2005-06-08 | 62d? | finish no earlier than 2005-06-08 | S1 | 496h | 496h | IVGCS | T-Mobile | kurt.bischinger@t-mobile.at | Rel-7 | Alain | 42.068 |  |
| 739 | 225.2 | Stage 2 modifications for VGCS improvements |  | 335d? | 2005-12-01 A | 2007-03-14 A | 100% | 2005-12-01 | 2007-03-14 | 335d? | start no earlier than 2005-12-01 | C1 | 2680h | 2680h | IVGCS | T-Mobile | kurt.bischinger@t-mobile.at | Rel-7 | Frederic | 43.068 |  |
| 740 | 225.3 | **Protocol aspects** |  | 336d? | 2005-12-01 A | 2007-03-15 A | 100% | 2005-12-01 | 2007-03-15 | 336d? |  | C1 | 5376h | 5376h | IVGCS | T-Mobile | Dieter Jacobsohn | Rel-7 | Frederic | 44.068 |  |
| 741 | 225.3.1 | CT1 aspects of IVGCS |  | 336d? | 2005-12-01 A | 2007-03-15 A | 100% | 2005-12-01 | 2007-03-15 | 336d? | finish no earlier than 2007-03-15 | C1 | 2688h | 2688h | IVGCS | T-Mobile |  | Rel-7 | Frederic | 43.068, 44.068 |  |
| 742 | 225.3.2 | Deleted - CT4 aspects of IVGCS | milestone | 0d? | 2007-03-09 A | 2007-03-09 A | 100% | 2007-03-09 | 2007-03-09 | 0d? | finish no earlier than 2007-03-09 | C4 |  |  | IVGCS-St3-c4 | T-mobile |  | Rel-7 | Kimmo | 29.002 | CP-35 |
| 743 | 226 | **OSA Rel-7** |  | 584d? | 2005-03-15 A | 2007-06-08 A | 100% | 2005-03-15 | 2007-06-08 | 584d? |  | S1,C5 | 17920h | 17920h | OSA7 | AePONA | eamonn.murray@aepona.com | Rel-7 | Alain |  |  |
| 744 | 226.1 | Service Requirements for OSA Service Broker |  | 62d? | 2005-03-15 A | 2005-06-08 A | 100% | 2005-03-15 | 2005-06-08 | 62d? | finish no earlier than 2005-06-08 | S1 | 496h | 496h | OSA7-SB | AePONA | eamonn.murray@aepona.com | Rel-7 | Alain | 22.127 |  |
| 745 | 226.2 | Stage 2 OSA API Service Brokering |  | 156d? | 2006-04-28 A | 2006-12-01 A | 100% | 2006-04-28 | 2006-12-01 | 156d? |  | C5 | 1248h | 1248h | OSA7-SB | AePONA | damian.oneill@aepona.com | Rel-7 | Kimmo | 23.198 |  |
| 746 | 226.3 | Stage 3 OSA API Service Brokering |  | 156d? | 2006-04-28 A | 2006-12-01 A | 100% | 2006-04-28 | 2006-12-01 | 156d? | finish no earlier than 2006-12-01 | C5 | 1248h | 1248h | OSA7-SB | AePONA | damian.oneill@aepona.com | Rel-7 | Kimmo | 29.198-16 |  |
| 747 | 226.4 | **OSA Stage 2/3 enhancements** |  | 291d? | 2006-04-28 A | 2007-06-08 A | 100% | 2006-04-28 | 2007-06-08 | 291d? |  | C5 | 10256h | 10256h | OSA7 | AePONA | damian.oneill@aepona.com | Rel-7 | Kimmo | 29.198/9, 23.198 |  |
| 748 | 226.4.1 | Parlay X Message Broadcast Web Service |  | 156d? | 2006-04-28 A | 2006-12-01 A | 100% | 2006-04-28 | 2006-12-01 | 156d? | finish no earlier than 2006-12-01 | C5 | 1248h | 1248h | OSA7 | ETRI |  | Rel-7 | Kimmo | 29.199-15, 23.198 |  |
| 749 | 226.4.2 | Parlay X Geocoding Web Service |  | 156d? | 2006-04-28 A | 2006-12-01 A | 100% | 2006-04-28 | 2006-12-01 | 156d? | finish no earlier than 2006-12-01 | C5 | 1248h | 1248h | OSA7 | ETRI |  | Rel-7 | Kimmo | 29.199-16, 23.198 |  |
| 750 | 226.4.3 | Parlay X Application driven QoS Web Service |  | 226d? | 2006-04-28 A | 2007-03-09 A | 100% | 2006-04-28 | 2007-03-09 | 226d? | finish no earlier than 2007-03-09 | C5 | 1808h | 1808h | OSA7 | BT |  | Rel-7 | Kimmo | 29.199-17, 23.198 |  |
| 751 | 226.4.4 | Parlay-X Device Capabilities and Configuration |  | 162d? | 2006-10-26 A | 2007-06-08 A | 100% | 2006-10-26 | 2007-06-08 | 162d? | finish no earlier than 2007-06-09 | C5 | 1296h | 1296h | OSA7 | Telenor |  | Rel-7 | Kimmo | 29.199-18, 23.198 |  |
| 752 | 226.4.5 | Parlay-X Multimedia Streaming Session Management Web Service |  | 97d? | 2006-10-26 A | 2007-03-09 A | 100% | 2006-10-26 | 2007-03-09 | 97d? | start no earlier than 2006-10-26 | C5 | 776h | 776h | OSA7 | Telenor |  | Rel-7 | Kimmo | 29.199-19, 23.198 |  |
| 753 | 226.4.6 | Parlay-X Multimedia Multicast Control Web Service |  | 97d? | 2006-10-26 A | 2007-03-09 A | 100% | 2006-10-26 | 2007-03-09 | 97d? | start no earlier than 2006-10-26 | C5 | 776h | 776h | OSA7 | ETRI |  | Rel-7 | Kimmo | 29.199-20, 23.198 |  |
| 754 | 226.4.7 | OSA API Conference Call Control SCF |  | 97d? | 2006-10-26 A | 2007-03-09 A | 100% | 2006-10-26 | 2007-03-09 | 97d? | start no earlier than 2006-10-26 | C5 | 776h | 776h | OSA7 | Ericsson |  | Rel-7 | Kimmo | 29.198-04-5, 23.198 |  |

Notes:
- 729: No CR submitted in rel-8 (according to CR database).
- 730: No Rel-8 changes
- 738: "completeed" as from Chris S' e-mail
- 739: Updated by CT1 chair
- 740: Previous name (before CT32) was Architecture and protocol aspects
- 741: end date updated by CT1-chairman after CT#33
- 742: CT4#33 stage 2 solution is still open. ...
- 744: az: WID URL corrected
- 747: CT#34: WID updated. Completion 12/06 =>03/07

| ID | WBS | Task | Type | Duration | Start | Finish | Complete | Baseline start | Baseline finish | Baseline duration | Constraint | Resources | Work | Actual work | Text1 | Text4 | Text6 | Text8 | Text3 | Text5 | Text12 | Text11 |
| --- | --- | --- | --- | --- | --- | --- | --- | --- | --- | --- | --- | --- | --- | --- | --- | --- | --- | --- | --- | --- | --- | --- |
| 755 | 227 | **Selective Disabling of UE Capabilities** |  | 624.36d? | 2005-01-24 A | 2007-06-15 A | 100% | 2005-01-24 | 2007-06-15 | 624.36d? |  | S1,S2,C1 | 12351.7h | 12351.7h | SDoUE | Motorola | Rel-7 | Alain |  |  |  |  |
| 756 | 227.1 | Stage 1 of SDoUE |  | 393.6d? | 2005-01-24 A | 2006-12-08 A | 100% | 2005-01-24 | 2006-12-08 | 393.6d? | finish no earlier than 2006-12-08 | S1 | 3148.8h | 3148.8h | SDoUE-CR | Motorola | Rel-7 | Alain | 22.011 |  |  |  |
| 757 | 227.2 | Deleted - TR on different possible architectures |  | 195d? | 2005-03-21 A | 2005-12-16 A | 100% | 2005-03-21 | 2005-12-16 | 195d? | finish no earlier than 2005-12-16 | S2 | 1560h | 1560h | SDoUE-FS | Vodafone | Rel-7 | Maurice | 23.805 abandonned at SP-30; descendant C1 24.305 | Gavin.Wong@vodafone.com | SP-30 |  |
| 758 | 227.3 | Stage 3 of SDoUE |  | 331d? | 2006-03-10 A | 2007-06-15 A | 100% | 2006-03-10 | 2007-06-15 | 331d? | finish no earlier than 2007-06-15 | C1 | 2648h | 2648h | SDoUE | Ericsson | Rel-7 | Frederic | 24.305 | christian.herrero@ericsson.com |  |  |
| 759 | 228 | **Network selection enhancements (NSP)** |  | 328d? | 2006-03-15 A | 2007-06-15 A | 100% | 2006-03-15 | 2007-06-15 | 328d? |  | S1 | 6320h | 6320h | NSP-CR | O2 | Rel-7 | Alain | 22.101, 22.011, 23.122, 24.008, 25.304, 31.102, 45.008 | chris.friel@o2.com |  |  |
| 760 | 228.1 | Stage 1 of NSP |  | 191d? | 2006-03-15 A | 2006-12-06 A | 100% | 2006-03-15 | 2006-12-06 | 191d? | start no earlier than 2006-03-15 | S1 | 1528h | 1528h | NSP-TS | O2 | Rel-7 | Alain | 22.101, 22.011, 23.122, 24.008, 25.304, 31.102, 45.008 | chris.friel@o2.com |  |  |
| 761 | 228.2 | Procedural aspects of NSP |  | 271d? | 2006-06-02 A | 2007-06-15 A | 100% | 2006-06-02 | 2007-06-15 | 271d? | finish no earlier than 2007-06-15 | C1 | 2168h | 2168h | NSP-CR | Motorola | Rel-7 | Frederic | 23.122, 24.008, 31.102 | Andrew Howell |  |  |
| 762 | 229 | Network Selection enhancements (NSP) - UE Conformance Testing |  | 396d? | 2007-06-01 A | 2008-12-05 A | 100% | 2007-06-01 | 2008-12-05 | 396d? | finish no earlier than 2008-12-05 | R5 | 3168h | 3168h | NSP-CR_UEConTest | Nokia | Rel-7 | Ingbert | 34.108, 34.123-1, 34.123-2, 34.123-3 | jarkko.hellsten@nokia.com |  | RP-080819 |
| 763 | 230 | **Access Class Barring and Overload Protection** |  | 650d? | 2004-03-15 A | 2006-09-08 A | 100% | 2004-03-15 | 2006-09-08 | 650d? |  | S2,C1 | 3568h | 3568h | ACBOP | Vodafone | Rel-7 | Maurice | 23.898 | Chris Pudney |  |  |
| 764 | 230.1 | TR on Stage 2 |  | 274d? | 2004-03-15 A | 2005-03-31 A | 100% | 2004-03-15 | 2005-03-31 | 274d? | finish no earlier than 2005-03-31 | S2 | 2192h | 2192h | ACBOP | NTT DoCoMo | Rel-7 | Maurice | 23.898 | Jean-Jacques Davidian (davidian@docomo.fr) |  |  |
| 765 | 230.2 | Stage 3 CN aspects of ACBOP |  | 172d? | 2005-06-06 A | 2006-01-31 A | 100% | 2005-06-06 | 2006-01-31 | 172d? | start no earlier than 2005-06-06 | C1 | 1376h | 1376h | ACBOP |  | Rel-7 | Frederic | 24.008 |  |  |  |
| 766 | 230.3 | Deleted - Potential impact on Iu interface Overload functionality | milestone | 0d? | 2004-03-15 A | 2004-03-15 A | 100% | 2004-03-15 | 2004-03-15 | 0d? | finish no earlier than 2004-03-15 | RP |  |  | ACBOP |  | Rel-7 | Stefania | 25.413 |  | RP-25 |  |
| 767 | 230.4 | Deleted - Extra ACBOP information in RAN | milestone | 0d? | 2004-03-15 A | 2004-03-15 A | 100% | 2004-03-15 | 2004-03-15 | 0d? | finish no earlier than 2004-03-15 | RP |  |  | ACBOP |  | Rel-7 | Stefania | 25.331 |  | RP-25 |  |
| 768 | 230.5 | Deleted - Extra ACBOP information in GERAN | milestone | 0d? | 2006-09-08 A | 2006-09-08 A | 100% | 2006-09-08 | 2006-09-08 | 0d? | start no earlier than 2006-09-08 | GP |  |  | ACBOP |  | Rel-7 | Paolo | 44.018 |  | RP-33 |  |
| 769 | 231 | **System enhancements for fixed broadband access to IMS** |  | 876d? | 2003-11-05 A | 2007-03-15 A | 100% | 2003-11-05 | 2007-03-15 | 876d? |  | S2,S3,S5,C1,C3,C4 | 36656h | 36656h | FBI |  | Rel-7 | Maurice |  |  |  |  |
| 770 | 231.1 | **TISPAN Rel 1 related aspects** |  | 873d? | 2003-11-05 A | 2007-03-09 A | 100% | 2003-11-05 | 2007-03-09 | 873d? |  | S2 | 31568h | 31568h | FBI-TIS1 |  | Rel-7 | Maurice |  |  |  |  |
| 771 | 231.1.1 | Stage 2 of FBI for TISPAN R1 |  | 365d? | 2004-10-14 A | 2006-03-08 A | 100% | 2004-10-14 | 2006-03-08 | 365d? | start no earlier than 2004-10-14 | S2 | 2920h | 2920h | FBI-TIS1 |  | Rel-7 | Maurice |  |  |  |  |
| 772 | 231.1.2 | **Protocol impact of FBI for TISPAN R1** |  | 873d? | 2003-11-05 A | 2007-03-09 A | 100% | 2003-11-05 | 2007-03-09 | 873d? |  | C1 | 20720h | 20720h | FBI-TIS1 | Siemens | Rel-7 | Frederic |  | peter.leis@nsn.com |  |  |
| 773 | 231.1.2.1 | CT1 aspects of FBI for TISPAN R1 |  | 802d? | 2003-11-05 A | 2006-11-30 A | 100% | 2003-11-05 | 2006-11-30 | 802d? | finish no earlier than 2006-11-30 | C1 | 6416h | 6416h | FBI-TIS1 | Siemens | Rel-7 | Frederic | 24.819, 24.229 | peter.leis@nsn.com |  |  |
| 774 | 231.1.2.2 | CT3 aspects of FBI for TISPAN R1 |  | 808d? | 2003-11-05 A | 2006-12-08 A | 100% | 2003-11-05 | 2006-12-08 | 808d? | finish no earlier than 2006-12-08 | C3 | 6464h | 6464h | FBI-TIS1 | Siemens | Rel-7 | Gwiho | 29.163, 29.209 | peter.leis@nsn.com |  |  |
| 775 | 231.1.2.3 | CT4 aspects of FBI for TISPAN R1 |  | 301d? | 2006-01-13 A | 2007-03-09 A | 100% | 2006-01-13 | 2007-03-09 | 301d? | finish no earlier than 2007-03-09 | C4 | 2408h | 2408h | FBI-TIS1-st3-c4 | Siemens | Rel-7 | Kimmo | 29.229 | peter.leis@nsn.com |  |  |
| 776 | 231.1.3 | Security Enhancements for FBI |  | 118d? | 2005-06-28 A | 2005-12-08 A | 100% | 2005-06-28 | 2005-12-08 | 118d? | start no earlier than 2005-06-28 | S3 | 944h | 944h | FBI-ISE | Ericsson | Rel-7 | Dionisio | 33.203 | Bengt.Sahlin@ericsson.com |  |  |
| 777 | 231.2 | **PacketCable Related aspects** |  | 291d? | 2006-02-01 A | 2007-03-15 A | 100% | 2006-02-01 | 2007-03-15 | 291d? |  | S2,S5,C1 | 5088h | 5088h | FBI-PCBL | CableLabs | Rel-7 | Maurice |  | Bernie McKibben |  |  |
| 778 | 231.2.1 | Stage 1,2 of FBI for PacketCable |  | 228d? | 2006-02-01 A | 2006-12-15 A | 100% | 2006-02-01 | 2006-12-15 | 228d? | finish no earlier than 2006-12-15 | S2 | 1824h | 1824h | FBI-PCBL | CableLabs | Rel-7 | Maurice | 22.228, 23.228 | Bernie McKibben |  |  |
| 779 | 231.2.2 | Protocol impact of FBI for PacketCable |  | 228d? | 2006-05-01 A | 2007-03-15 A | 100% | 2006-05-01 | 2007-03-15 | 228d? | finish no earlier than 2007-03-15 | C1 | 1824h | 1824h | FBI-PCBL |  | Rel-7 | Frederic |  |  |  |  |
| 780 | 231.2.3 | SA5 Charging aspects of FBI for PacketCable |  | 180d? | 2006-03-31 A | 2006-12-07 A | 100% | 2006-03-31 | 2006-12-07 | 180d? | finish no earlier than 2006-12-07 | S5 | 1440h | 1440h | FBI-PCBL-CH | CableLabs | Rel-7 | Dionisio | 32.240, 32.260, 32.298, 32.299 | Bernie McKibben |  |  |

Notes:
- 755: Moved from FS section Feb 06
- 756: Moved from FS section Feb 06
- 757: Moved from FS section Feb 06. Abandoned at SP-30
- 762: RP#42 completed. SR in RP-080819. Linked to UID_7041 (NSP-CR).
- 765: NEW - inserted on 2/9/2004
- 773: end date updated by CT1-chairman after CT#33
- 775: CT4#32: a set of CRs on FBI for cable labs
- 776: Duplicated entry ("ACCSEC2", "Access Security Enhancements", SP-040865) deleted by A.Sultan
- 780: 03/2006 SA#31 WID approved

| ID | WBS | Task | Type | Duration | Start | Finish | Complete | Baseline start | Baseline finish | Baseline duration | Constraint | Resources | Work | Actual work | Text1 | Text4 | Text5 | Text6 | Text8 | Text3 | Text12 |
| --- | --- | --- | --- | --- | --- | --- | --- | --- | --- | --- | --- | --- | --- | --- | --- | --- | --- | --- | --- | --- | --- |
| 781 | 232 | **Support of SMS over generic 3GPP IP access** |  | 696d? | 2004-10-14 A | 2007-06-15 A | 100% | 2004-10-14 | 2007-06-15 | 696d? |  | S2,C4,C1 | 12408h | 12408h | SMSIP | Huawei | zhangwenlin@huawei.com | Rel-7 | Maurice |  |  |
| 782 | 232.1 | FS on SMSIP |  | 173d? | 2004-10-14 A | 2005-06-13 A | 100% | 2004-10-14 | 2005-06-13 | 173d? | start no earlier than 2004-10-14 | S2 | 1384h | 1384h | SMSIP | Huawei | zhangwenlin@huawei.com | Rel-7 | Maurice | 23.804 |  |
| 783 | 232.2 | Stage 2 for SMSIP |  | 333d? | 2005-06-08 A | 2006-09-15 A | 100% | 2005-06-08 | 2006-09-15 | 333d? | finish no earlier than 2006-09-15 | S2 | 2664h | 2664h | SMSIP | Huawei | zhangwenlin@huawei.com | Rel-7 | Maurice | 23.204 |  |
| 784 | 232.3 | **Stage 3 for SMSIP** |  | 527d? | 2005-06-08 A | 2007-06-15 A | 100% | 2005-06-08 | 2007-06-15 | 527d? |  | C4,C1 | 8360h | 8360h | SMSIP-St3 | Nokia | jari.jansson@nokia.com | Rel-7 | Kimmo |  |  |
| 785 | 232.3.1 | CT1 aspects for SMSIP |  | 527d? | 2005-06-08 A | 2007-06-15 A | 100% | 2005-06-08 | 2007-06-15 | 527d? | finish no earlier than 2007-06-15 | C1 | 4216h | 4216h | SMSIP | Nokia | jari.jansson@nokia.com | Rel-7 | Frederic | 23.040, 24.229 |  |
| 786 | 232.3.2 | CT4 aspects for SMSIP |  | 518d? | 2005-06-08 A | 2007-06-01 A | 100% | 2005-06-08 | 2007-06-01 | 518d? | finish no earlier than 2007-06-01 | C4 | 4144h | 4144h | SMSIP-St3-c4 | Nokia | jari.jansson@nokia.com | Rel-7 | Kimmo | 23.008, 29.002 |  |
| 787 | 233 | **Evolution of Policy Control and Charging** |  | 817d? | 2004-10-14 A | 2007-11-30 A | 100% | 2004-10-14 | 2007-11-30 | 817d? |  | S2,S5,C3,C1 | 30336h | 30336h | PCC | Nokia | balazs.bertenyi@nsn.com | Rel-7 | Maurice |  |  |
| 788 | 233.1 | Deleted - TR for PCC |  | 315d? | 2004-10-14 A | 2005-12-29 A | 100% | 2004-10-14 | 2005-12-29 | 315d? | finish no earlier than 2005-12-28 | S2 | 2520h | 2520h | PCC | Nokia | balazs.bertenyi@nsn.com | Rel-7 | Maurice | 23.803 | SP-33 |
| 789 | 233.2 | Stage 2 for PCC |  | 315d? | 2005-07-04 A | 2006-09-15 A | 100% | 2005-07-04 | 2006-09-15 | 315d? | finish no earlier than 2006-09-15 | S2 | 2520h | 2520h | PCC | Nokia | balazs.bertenyi@nsn.com | Rel-7 | Maurice | 23.203 |  |
| 790 | 233.3 | Evolution of policy control and flow based bearer level charging |  | 109d? | 2006-08-01 A | 2006-12-29 A | 100% | 2006-08-01 | 2006-12-29 | 109d? | start no earlier than 2006-08-01 | S2 | 872h | 872h | PCC | Nokia | balazs.bertenyi@nsn.com | Rel-7 | Maurice | 23.207, 23.002, 23.228 |  |
| 791 | 233.4 | SA5 Charging aspects of PCC |  | 316d? | 2006-03-31 A | 2007-06-15 A | 100% | 2006-03-31 | 2007-06-15 | 316d? | finish no earlier than 2007-06-15 | S5 | 2528h | 2528h | PCC-CH | Orange | alain.bibas@orange-ft.com | Rel-7 | Dionisio | 32.250, 32.251, 32.298, 32.299 |  |
| 792 | 233.5 | Gx reference point for Policy and Charging Control |  | 521d? | 2005-12-02 A | 2007-11-30 A | 100% | 2005-12-02 | 2007-11-30 | 521d? | finish no earlier than 2007-09-14 | C3 | 4168h | 4168h | PCC-Gx | Siemens | Thomas.Belling@nsn.com | Rel-7 | Gwiho | 29.212 (not progressed to Rel-7: 29.210, 29.207, 29.208) |  |
| 793 | 233.6 | **Rx reference point for PCC CT3 aspects** |  | 521d? | 2005-12-02 A | 2007-11-30 A | 100% | 2005-12-02 | 2007-11-30 | 521d? |  | C3,C1 | 11192h | 11192h | PCC-Rx | Ericsson | j.javier.pastor@ericsson.com | Rel-7 | Gwiho |  |  |
| 794 | 233.6.1 | PCC-Rx CT3 aspects |  | 521d? | 2005-12-02 A | 2007-11-30 A | 100% | 2005-12-02 | 2007-11-30 | 521d? | finish no earlier than 2007-09-14 | C3 | 4168h | 4168h | PCC-Rx-c3 | Ericsson | j.javier.pastor@ericsson.com | Rel-7 | Gwiho | 29.213, 29.214 (not progressed to Rel-7: 29.209, 29.211) |  |
| 795 | 233.6.2 | PCC-Rx CT1 aspects |  | 357d? | 2005-12-02 A | 2007-06-15 A | 100% | 2005-12-02 | 2007-06-15 | 357d? | finish no earlier than 2007-06-15 | C1 | 2856h | 2856h | PCC-Rx-Gx-c1 | Ericsson | j.javier.pastor@ericsson.com | Rel-7 | Frederic | 24.229 |  |
| 796 | 234 | **Voice call continuity between CS and IMS (incl. I-WLAN)** |  | 641d? | 2004-12-31 A | 2007-06-15 A | 100% | 2004-12-31 | 2007-06-15 | 641d? |  | S2,S1,S5,C1,C4 | 12224h | 12224h | VCC | Alcatel-Lucent | Keith Drage (drage@alcatel-lucent.com) | Rel-7 | Maurice |  |  |
| 797 | 234.1 | TR for VCC |  | 245d? | 2004-12-31 A | 2005-12-08 A | 100% | 2004-12-31 | 2005-12-08 | 245d? | finish no earlier than 2005-12-08 | S2 | 1960h | 1960h | VCC | Alcatel-Lucent | Andy Bennett (andybennett@alcatel-lucent.com) | Rel-7 | Maurice | 23.806 |  |
| 798 | 234.2 | Stage 1 for VCC |  | 140d? | 2005-03-17 A | 2005-09-28 A | 100% | 2005-03-17 | 2005-09-28 | 140d? | finish no earlier than 2005-09-28 | S1 | 1120h | 1120h | VCC | Alcatel-Lucent | Andy Bennett (andybennett@alcatel-lucent.com) | Rel-7 | Alain | 22.101 |  |
| 799 | 234.3 | Stage 2 for VCC |  | 264d? | 2005-09-06 A | 2006-09-08 A | 100% | 2005-09-06 | 2006-09-08 | 264d? | finish no earlier than 2006-09-08 | S2 | 2112h | 2112h | VCC | Alcatel-Lucent | Andy Bennett (andybennett@alcatel-lucent.com) | Rel-7 | Maurice | 23.206 |  |
| 800 | 234.4 | SA5 Charging aspects of VCC |  | 325d? | 2006-03-17 A | 2007-06-14 A | 100% | 2006-03-17 | 2007-06-14 | 325d? | finish no earlier than 2007-06-14 | S5 | 2600h | 2600h | VCC-CH | Orange | alain.bibas@orange-ft.com | Rel-7 | Dionisio | 32.250, 32.260 |  |
| 801 | 234.5 | **Stage 3 for VCC** |  | 358d? | 2006-02-01 A | 2007-06-15 A | 100% | 2006-02-01 | 2007-06-15 | 358d? |  | C1,C4 | 4432h | 4432h | VCC | Alcatel-Lucent | Keith Drage (drage@alcatel-lucent.com) | Rel-7 | Frederic |  |  |
| 802 | 234.5.1 | CT1 aspects of VCC |  | 358d? | 2006-02-01 A | 2007-06-15 A | 100% | 2006-02-01 | 2007-06-15 | 358d? | finish no earlier than 2007-06-15 | C1 | 2864h | 2864h | VCC | Alcatel-Lucent | Keith Drage (drage@alcatel-lucent.com) | Rel-7 | Frederic | 24.206, 24.216 |  |
| 803 | 234.5.2 | CT4 aspects of VCC |  | 196d? | 2006-06-09 A | 2007-03-09 A | 100% | 2006-06-09 | 2007-03-09 | 196d? | start no earlier than 2006-06-09 | C4 | 1568h | 1568h | VCC-St3-c4 | Alcatel-Lucent | Keith Drage (drage@alcatel-lucent.com) | Rel-7 | Kimmo | 23.003 |  |
| 804 | 234.5.3 | Deleted - CT3 aspects of VCC | milestone | 0d? | 2006-11-02 A | 2006-11-02 A | 100% | 2006-11-02 | 2006-11-02 | 0d? | finish no earlier than 2006-11-02 | C3 |  |  | VCC | Alcatel-Lucent | Keith Drage (drage@alcatel-lucent.com) | Rel-7 | Gwiho | 29.163 | CP-33 |

Notes:
- 781: SA#33 updated WID (removed MMS)
- 782: SA#33 updated WID
- 783: SA#33 updated WID
- 784: CT#34 updated WID
- 785: CT#34 updated WID
- 786: CT#34 updated WID
- 787: SP-29 approved WID. SP-31 updated WID adding SA5 charging. 23.125 will be discontinued from Rel-7.
- 788: SP-30: S2 has no intention for TR completion
- 789: SP-29 approved WID. SP-31 updated WID. 23.125 will be discontinued from Rel-7.
- 790: SP-29 approved WID. SP-31 updated WID. 23.125 will be discontinued from Rel-7.
- 791: SP-31 updated WID with SA5 charging.
- 793: WID approved at CT#30, Revised at CT#31, Revised at CT#33
- 796: WID approved SA#27; updated SA#28; updated SA#32
- 800: 03/2006 SA#31 WID approved

| ID | WBS | Task | Type | Duration | Start | Finish | Complete | Baseline start | Baseline finish | Baseline duration | Constraint | Resources | Work | Actual work | Text1 | Text4 | Text5 | Text6 | Text8 | Text3 | Text12 |
| --- | --- | --- | --- | --- | --- | --- | --- | --- | --- | --- | --- | --- | --- | --- | --- | --- | --- | --- | --- | --- | --- |
| 805 | 235 | **One Tunnel solution for Optimisation of Packet Data Traffic** |  | 418d? | 2006-03-27 A | 2007-10-31 A | 100% | 2006-03-27 | 2007-10-31 | 418d? |  | S2 | 7048h | 7048h | OPTUNEL | Nokia | antti.j.pasanen@nokia.com | Rel-7 | Maurice |  |  |
| 806 | 235.1 | Deleted - Study on Stage 2 for One Tunnel solution |  | 125d? | 2006-03-27 A | 2006-09-15 A | 100% | 2006-03-27 | 2006-09-15 | 125d? | finish no earlier than 2005-09-12 | S2 | 1000h | 1000h | OPTUNEL-Study | Nokia | antti.j.pasanen@nokia.com | Rel-7 | Maurice | 23.809 | SP-34 |
| 807 | 235.2 | One Tunnel Deployment Guideline |  | 268d? | 2006-10-23 A | 2007-10-31 A | 100% | 2006-10-23 | 2007-10-31 | 268d? | finish no earlier than 2007-10-31 | S2 | 2144h | 2144h | OPTUNEL-Guide | Huawei | lan.liu@huawei.com | Rel-7 | Maurice | 23.919 |  |
| 808 | 235.3 | Stage 2 specification for One Tunnel solution |  | 70d? | 2006-09-11 A | 2006-12-15 A | 100% | 2006-09-11 | 2006-12-15 | 70d? | finish no earlier than 2006-12-15 | S2 | 560h | 560h | OPTUNEL-Stage2 | Nokia | antti.j.pasanen@nokia.com | Rel-7 | Maurice | 23.060 |  |
| 809 | 236 | **CSI Terminating Session handling** |  | 267d? | 2006-06-08 A | 2007-06-15 A | 100% | 2006-06-08 | 2007-06-15 | 267d? |  | S2,C1 | 4728h | 4728h | CSItermS | Samsung | Osok Song | Rel-7 | Maurice |  |  |
| 810 | 236.1 | Stage 2 of CStermS |  | 192d? | 2006-06-08 A | 2007-03-02 A | 100% | 2006-06-08 | 2007-03-02 | 192d? | start no earlier than 2006-06-08 | S2 | 1536h | 1536h | CSItermS | Samsung | Osok Song | Rel-7 | Maurice | 23.279 |  |
| 811 | 236.2 | Stage 3 of CStermS |  | 132d? | 2006-12-14 A | 2007-06-15 A | 100% | 2006-12-14 | 2007-06-15 | 132d? | finish no earlier than 2007-06-15 | C1 | 1056h | 1056h | CSItermS | Samsung | chenho.chin@samsung.com | Rel-7 | Frederic | 24.229, 24.279 |  |
| 812 | 236.3 | Deleted - duplicated with UID 340015 -Stage 3 CSI Terminating Session handling | milestone | 0d? | 2007-03-09 A | 2007-03-09 A | 100% | 2007-03-09 | 2007-03-09 | 0d? | start no earlier than 2007-03-09 | C1 |  |  | CSItermS | Samsung | chenho.chin@samsung.com | Rel-7 | Frederic | 24.229, 24.179, 24.279 | CP-34 |
| 813 | 237 | Liberty Alliance and 3GPP Security Interworking |  | 451d? | 2005-03-10 A | 2006-11-30 A | 100% | 2005-03-10 | 2006-11-30 | 451d? | finish no earlier than 2006-11-30 | S3 | 3608h | 3608h | LibSec | Nokia | Silke.Holtmanns@NOKIA.COM | Rel-7 | Dionisio | 33.980 |  |
| 814 | 238 | Trust Requirements for Open Platforms in 3GPP |  | 499d? | 2005-01-03 A | 2006-11-30 A | 100% | 2005-01-03 | 2006-11-30 | 499d? | finish no earlier than 2006-11-30 | S3 | 3992h | 3992h | TrustOP | Nokia | Silke.Holtmanns@NOKIA.COM | Rel-7 | Dionisio | 33.905 |  |
| 815 | 239 | Development of UEA2 and UIA2 |  | 268d? | 2004-12-01 A | 2005-12-09 A | 100% | 2004-12-01 | 2005-12-09 | 268d? | finish no earlier than 2005-12-09 | S3 | 2144h | 2144h | AlgUEA2 | TeliaSonera | per.christoffersson@teliasonera.com | Rel-7 | Dionisio | 35.919, 35.215, 35.216, 35.217, 35.218 |  |
| 816 | 240 | Lawful Interception in the 3GPP Rel-7 architecture |  | 118d? | 2005-06-28 A | 2005-12-08 A | 100% | 2005-06-28 | 2005-12-08 | 118d? | start no earlier than 2005-06-28 | S3 | 944h | 944h | LI-7A | BMWI | berthold.wilhelm@regtp.de | Rel-7 | Dionisio | 33.106, 33.107, 33.108 |  |
| 817 | 241 | Key establishment between a UICC and a terminal |  | 201.45d? | 2005-12-07 A | 2006-09-28 A | 100% | 2005-12-07 | 2006-09-28 | 201.45d? | finish no earlier than 2006-09-28 | S3 | 1611.6h | 1611.6h | KeyEstUTerm | Gemalto | mireille.pauliac@gemplus.com | Rel-7 | Dionisio | 33.110 |  |
| 818 | 242 | NDS Authentication Framework Extension for Transport Layer Security |  | 50d? | 2006-09-28 A | 2006-12-06 A | 100% | 2006-09-28 | 2006-12-06 | 50d? | finish no earlier than 2006-09-28 | S3 | 400h | 400h | NDSAFTLS | Nokia | tiina.s.koskinen@nokia.com | Rel-7 | Dionisio | 33.310 |  |
| 819 | 243 | **Security enhancements** |  | 319d? | 2005-09-12 A | 2006-11-30 A | 100% | 2005-09-12 | 2006-11-30 | 319d? |  | S3,C1,C4 | 4856h | 4856h | SEC7 |  |  | Rel-7 | Dionisio |  |  |
| 820 | 243.1 | HTTPS connection between a UICC and a NAF |  | 1d? | 2005-09-12 A | 2005-09-12 A | 100% | 2005-09-12 | 2005-09-12 | 1d? | start no earlier than 2005-09-12 | S3,C1 | 8h | 8h | SEC7-HSUN | Gemalto | JSeif@axalto.com, mireille.pauliac@gemplus.com | Rel-7 | Dionisio | 33.918, 33.222, 24.109 |  |
| 821 | 243.2 | 2G GBA: 2G SIM usage in 3GPP GAA framework |  | 61d? | 2005-09-12 A | 2005-12-05 A | 100% | 2005-09-12 | 2005-12-05 | 61d? | finish no earlier than 2005-12-05 | S3 | 488h | 488h | SEC7-2GGBA | Nokia | Silke.Holtmanns@nokia.com | Rel-7 | Dionisio | 33.920, 33.220 |  |
| 822 | 243.3 | Generic Authentication Architecture usage extensions and optimisations |  | 319d? | 2005-09-12 A | 2006-11-30 A | 100% | 2005-09-12 | 2006-11-30 | 319d? | finish no earlier than 2006-11-30 | S3 | 2552h | 2552h | SEC7-GAA2 | Nokia | Silke.Holtmanns@nokia.com | Rel-7 | Dionisio | 33.220, 29.109, 24.109, (33.223 goes to R8) |  |
| 823 | 243.4 | **SS7 TCAP security Gateway** |  | 241d? | 2005-09-12 A | 2006-08-14 A | 100% | 2005-09-12 | 2006-08-14 | 241d? |  | S3,C4 | 1808h | 1808h | SEC7-NDS-TCAPsec | Siemens | marc.blommaert.ext@nsn.com | Rel-7 | Dionisio |  |  |
| 824 | 243.4.1 | SA3 aspects of SEC7-NDS-TCAPsec |  | 130d? | 2005-09-12 A | 2006-03-10 A | 100% | 2005-09-12 | 2006-03-10 | 130d? | finish no earlier than 2006-03-10 | S3 | 1040h | 1040h | SEC7-NDS-TCAPsec-SA3 | Siemens | marc.blommaert.ext@nsn.com | Rel-7 | Dionisio | 33.204 |  |
| 825 | 243.4.2 | TCAPsec Gateway |  | 96d? | 2006-04-03 A | 2006-08-14 A | 100% | 2006-04-03 | 2006-08-14 | 96d? | start no earlier than 2006-04-01 | C4 | 768h | 768h | SEC7-TCAP | Siemens | Ulrich.wiehe@gksag.de | Rel-7 | Kimmo | 29.204, 29.002 |  |
| 826 | 244 | IMS Stage 3 IETF Protocol alignment |  | 589d? | 2004-12-10 A | 2007-03-15 A | 100% | 2004-12-10 | 2007-03-15 | 589d? | finish no earlier than 2007-03-15 | C1 | 4712h | 4712h | IMSProtoc |  |  | Rel-7 | Frederic | 24.930 |  |
| 827 | 245 | **Interoperability between VGCS/VBS and A/Gb flexibility** |  | 253d? | 2006-03-22 A | 2007-03-09 A | 100% | 2006-03-22 | 2007-03-09 | 253d? |  | C1,C4 | 3296h | 3296h | VGCSFlex | Siemens | robert.zaus@nsn.com | Rel-7 | Frederic |  |  |
| 828 | 245.1 | CT1 aspects of VGCSFlex |  | 159d? | 2006-03-22 A | 2006-10-30 A | 100% | 2006-03-22 | 2006-10-30 | 159d? | finish no earlier than 2006-10-30 | C1 | 1272h | 1272h | VGCSFlex | Siemens | robert.zaus@nsn.com | Rel-7 | Frederic | 43.068, 43.069 |  |
| 829 | 245.2 | CT4 aspects of VGCSFlex |  | 253d? | 2006-03-22 A | 2007-03-09 A | 100% | 2006-03-22 | 2007-03-09 | 253d? | finish no earlier than 2007-03-09 | C4 | 2024h | 2024h | VGCSFlex-c4 | Siemens | robert.zaus@nsn.com | Rel-7 | Kimmo | 29.002 |  |
| 830 | 246 | DIAMETER on the GGSN Gi interface |  | 586d? | 2004-09-10 A | 2006-12-08 A | 100% | 2004-09-10 | 2006-12-08 | 586d? | finish no earlier than 2006-12-08 | C3 | 4688h | 4688h | DIAMGi | Vodafone | Nico.Gabriele@vodafone.com | Rel-7 | Gwiho | 29.061 |  |
| 831 | 247 | DIAMETER on the PDG Wi interface |  | 586d? | 2004-09-10 A | 2006-12-08 A | 100% | 2004-09-10 | 2006-12-08 | 586d? | finish no earlier than 2006-12-08 | C3 | 4688h | 4688h | DIAMWi | Vodafone | Nico.Gabriele@vodafone.com | Rel-7 | Gwiho | 29.161 |  |
| 832 | 248 | Interworking between the 3GPP CS domain with BICC or ISUP as signalling protocol and external SIP-I networks |  | 478d? | 2006-09-22 A | 2008-07-22 A | 100% | 2006-09-22 | 2008-07-22 | 478d? | finish no earlier than 2007-09-14 | C3 | 3824h | 3824h | ExtSIPI | Siemens | Thomas.Belling@nsn.com | Rel-7 | Gwiho | 29.164 |  |
| 833 | 249 | PDU multiplexing at Nb Interface with IP transport |  | 427d? | 2006-12-04 A | 2008-07-22 A | 100% | 2006-12-04 | 2008-07-22 | 427d? | start no earlier than 2006-12-04 | C3 | 3416h | 3416h | NbIPMux | Alcatel-Lucent | Jean.Rzeznik@alcatel-lucent.fr | Rel-7 | Gwiho | 29.414 |  |

Notes:
- 806: S2#52 CREATED. TR for Info SP-33. SP-34: S2 Report intention to discontinue TR
- 807: S2#55 CREATED: SP-34 Approved and extension request granted until 03/07
- 808: S2#52 CREATED
- 809: Triggered by the abandoned Study UID_32117
- 811: CP-34 approved WID. CP-35 updated WID
- 812: CP-34 approved WID
- 813: WID approved SA#27.
- 814: WID approved SA#26.
- 815: WID approved SA#26, Dependant on Funding Availability.
- 818: TLS profile is moved to Rel-8
- 822: 33.223 goes to R8
- 826: TR 24.930: Signalling flows for the session setup in the IM CN subsystem based on Session Initiation Protocol (SIP)
- 833: 08/03/2007 08:00

| ID | WBS | Task | Type | Duration | Start | Finish | Complete | Baseline start | Baseline finish | Baseline duration | Constraint | Resources | Work | Actual work | Text1 | Text4 | Text5 | Text6 | Text8 | Text12 |
| --- | --- | --- | --- | --- | --- | --- | --- | --- | --- | --- | --- | --- | --- | --- | --- | --- | --- | --- | --- | --- |
| 834 | 250 | **Mp (MRFC - MRFP) interface** |  | 345d? | 2006-02-13 A | 2007-06-08 A | 100% | 2006-02-13 | 2007-06-08 | 345d? |  | C4,C1 | 4384h | 4384h | Mp | Ericsson | philip.hodges@ericsson.com | Rel-7 | Kimmo |  |
| 835 | 250.1 | CT1 aspects of Mp |  | 1d | 2006-02-13 A | 2006-02-13 A | 100% | 2006-02-13 | 2006-02-13 | 1d | finish no earlier than 2006-02-13 | C1 | 8h | 8h | Mp | Ericsson | philip.hodges@ericsson.com | Rel-7 | Frederic |  |
| 836 | 250.2 | Deleted - CT3 aspects of Mp |  | 1d | 2006-09-22 A | 2006-09-22 A | 100% | 2006-09-22 | 2006-09-22 | 1d | start no earlier than 2006-09-22 | C3 | 8h | 8h | Mp | Ericsson | philip.hodges@ericsson.com | Rel-7 | Gwiho | CP-33 |
| 837 | 250.3 | Procedures description |  | 201d? | 2006-06-02 A | 2007-03-09 A | 100% | 2006-06-02 | 2007-03-09 | 201d? | finish no earlier than 2007-03-09 | C4 | 1608h | 1608h | Mp-PROCc4 | Huawei | Chencheng@huawei.com | Rel-7 | Kimmo |  |
| 838 | 250.4 | Stage 3 |  | 345d | 2006-02-13 A | 2007-06-08 A | 100% | 2006-02-13 | 2007-06-08 | 345d | finish no earlier than 2007-06-08 | C4 | 2760h | 2760h | Mp-St3c4 | Ericsson | philip.hodges@ericsson.com | Rel-7 | Kimmo |  |
| 839 | 251 | Routeing of MT-SMs via the HPLMN |  | 71d? | 2006-12-01 A | 2007-03-09 A | 100% | 2006-12-01 | 2007-03-09 | 71d? | finish no earlier than 2007-03-09 | C4,C1 | 568h | 568h | SMSviaH | Vodafone | Nick.Russell@vodafone.com | Rel-7 | Kimmo |  |
| 840 | 252 | Mobile Termination whilst the MS is moving to another MSC |  | 60d? | 2007-03-09 A | 2007-05-31 A | 100% | 2007-03-09 | 2007-05-31 | 60d? | start no earlier than 2007-03-09 | C4 | 480h | 480h | MTmovMS | Alcatel-Lucent | bruno.landais@alcatel-lucent.fr | Rel-7 | Kimmo |  |
| 841 | 253 | ISIM API for Java Card |  | 620d? | 2005-03-14 A | 2007-07-27 A | 100% | 2005-03-14 | 2007-07-27 | 620d? | finish no earlier than 2007-07-27 | C6 | 4960h | 4960h | APIJAVA | Sun | Sebastian Hans | Rel-7 | Xavier |  |
| 842 | 254 | High speed interface between the UICC and the ME |  | 311d? | 2006-09-22 A | 2007-11-30 A | 100% | 2006-09-22 | 2007-11-30 | 311d? | finish no earlier than 2007-11-30 | C6 | 2488h | 2488h | HSI | Gemalto | jacques.seif@GEMALTO.COM | Rel-7 | Xavier |  |
| 843 | 255 | Video Codec Performance Requirements |  | 634d? | 2005-01-03 A | 2007-06-07 A | 100% | 2005-01-03 | 2007-06-07 | 634d? | finish no earlier than 2007-06-07 | S4 | 5072h | 5072h | VICPer | Siemens | juergen.pandel@siemens.com | Rel-7 | Paolo |  |
| 844 | 256 | Dynamic and Interactive Multimedia Scenes |  | 583d? | 2005-03-15 A | 2007-06-07 A | 100% | 2005-03-15 | 2007-06-07 | 583d? | finish no earlier than 2007-06-07 | S4 | 4664h | 4664h | DIMS | Streamezzo | gaelle.martin-cocher@streamezzo.com | Rel-7 | Paolo |  |
| 845 | 257 | 3G-324M Video Telephony Call Setup Times Improvements |  | 341d? | 2005-06-08 A | 2006-09-27 A | 100% | 2005-06-08 | 2006-09-27 | 341d? | finish no earlier than 2006-09-27 | S4 | 2728h | 2728h | VTCSTI | Vodafone | edward.hall@vodafone.co.uk | Rel-7 | Paolo |  |
| 846 | 258 | **Optimizations for Multimedia Telephony over IMS** |  | 0d? | 2005-09-28 A | 2005-09-28 A | 100% | 2005-09-28 | 2005-09-28 | 0d? |  | S4 |  |  | OMTIMS | Ericsson | olle.franceschi@ericsson.com | Rel-7 | Paolo |  |
| 847 | 258.1 | Deleted - Characterisation of Adaptive Jitter Management Performance for VoIP Services | milestone | 0d? | 2005-09-28 A | 2005-09-28 A | 100% | 2005-09-28 | 2005-09-28 | 0d? | start no earlier than 2007-03-15 | S4 |  |  | OMTIMS-CAJMP | Lucent | dhuo@lucent.com | Rel-7 | Paolo | SP-35 |
| 848 | 259 | End-to-End Multimedia Services Performance Metrics |  | 382d? | 2005-09-28 A | 2007-03-15 A | 100% | 2005-09-28 | 2007-03-15 | 382d? | finish no earlier than 2007-03-15 | S4 | 3056h | 3056h | E2EMSPM | China Mobile | zhangyanyf@chinamobile.com | Rel-7 | Paolo |  |
| 849 | 260 | Packet Switched Streaming Enhancements |  | 261d? | 2006-06-08 A | 2007-06-07 A | 100% | 2006-06-08 | 2007-06-07 | 261d? | finish no earlier than 2007-06-07 | S4 | 2088h | 2088h | PSSe | Ericsson | olle.franceschi@ericsson.com | Rel-7 | Paolo |  |
| 850 | 261 | **OAM&P** |  | 472.86d? | 2005-09-02 A | 2007-06-26 A | 100% | 2005-09-02 | 2007-06-26 | 472.86d? |  | S5 | 82725.8h | 82725.8h | OAM7 | Huawei | Christian.Toche@huawei.com | Rel-7 | Dionisio |  |
| 851 | 261.1 | **Network Infrastructure Management** |  | 465d? | 2005-09-02 A | 2007-06-14 A | 100% | 2005-09-02 | 2007-06-14 | 465d? |  | S5 | 41800h | 41800h | OAM7-NIM |  |  | Rel-7 | Dionisio |  |
| 852 | 261.1.1 | Enhance NRM to accommodate NGN (IMS as basis of the Next Generation Network) |  | 465d? | 2005-09-02 A | 2007-06-14 A | 100% | 2005-09-02 | 2007-06-14 | 465d? | finish no earlier than 2007-06-14 | S5 | 3720h | 3720h | OAM7-NIM | Motorola |  | Rel-7 | Dionisio |  |
| 853 | 261.1.2 | Co-operative Element Management interface (CO-OP) (Study + Implementation) |  | 400d? | 2005-09-02 A | 2007-03-15 A | 100% | 2005-09-02 | 2007-03-15 | 400d? | finish no earlier than 2007-03-15 | S5 | 3200h | 3200h | OAM7-NIM | Motorola |  | Rel-7 | Dionisio |  |
| 854 | 261.1.3 | Network Management (NM) Itf-N performance criteria |  | 465d? | 2005-09-02 A | 2007-06-14 A | 100% | 2005-09-02 | 2007-06-14 | 465d? | finish no earlier than 2007-06-14 | S5 | 3720h | 3720h | OAM7-NIM | China Mobile |  | Rel-7 | Dionisio |  |
| 855 | 261.1.4 | Delta synchronization between IRP Manager and IRP Agent (Study + Implementation) |  | 465d? | 2005-09-02 A | 2007-06-14 A | 100% | 2005-09-02 | 2007-06-14 | 465d? | finish no earlier than 2007-06-14 | S5 | 3720h | 3720h | OAM7-NIM | Siemens |  | Rel-7 | Dionisio |  |
| 856 | 261.1.5 | Subscription Management (SuM) IRP Solution Sets |  | 330d? | 2005-09-02 A | 2006-12-07 A | 100% | 2005-09-02 | 2006-12-07 | 330d? | finish no earlier than 2006-12-07 | S5 | 2640h | 2640h | OAM7-NIM | Ericsson |  | Rel-7 | Dionisio |  |
| 857 | 261.1.6 | Integration Reference Point (IRP) Security Management |  | 400d? | 2005-09-02 A | 2007-03-15 A | 100% | 2005-09-02 | 2007-03-15 | 400d? | finish no earlier than 2007-03-15 | S5 | 3200h | 3200h | OAM7-NIM | Huawei | Christian.Toche@huawei.com | Rel-7 | Dionisio |  |
| 858 | 261.1.7 | Partial suspension of Itf-N during maintenance/testing (Study + Implementation) |  | 465d? | 2005-09-02 A | 2007-06-14 A | 100% | 2005-09-02 | 2007-06-14 | 465d? | finish no earlier than 2007-06-14 | S5 | 3720h | 3720h | OAM7-NIM | Siemens |  | Rel-7 | Dionisio |  |
| 859 | 261.1.8 | Deleted - Management of Legacy Equipment |  | 336d? | 2005-09-02 A | 2006-12-15 A | 100% | 2005-09-02 | 2006-12-15 | 336d? | finish no earlier than 2006-12-15 | S5 | 2688h | 2688h | OAM7-NIM | Siemens |  | Rel-7 | Dionisio | SP-35 |
| 860 | 261.1.9 | Deleted - Rules for Vendor Specific Extensions |  | 400d? | 2005-09-02 A | 2007-03-15 A | 100% | 2005-09-02 | 2007-03-15 | 400d? | finish no earlier than 2007-03-15 | S5 | 3200h | 3200h | OAM7-NIM | Siemens |  | Rel-7 | Dionisio | SP-35 |
| 861 | 261.1.10 | Backward and Forward Compatibility of IRP systems |  | 465d? | 2005-09-02 A | 2007-06-14 A | 100% | 2005-09-02 | 2007-06-14 | 465d? | finish no earlier than 2007-06-14 | S5 | 3720h | 3720h | OAM7-NIM | Ericsson |  | Rel-7 | Dionisio |  |
| 862 | 261.1.11 | Repeater Network Resource Model (NRM) definition |  | 214d? | 2006-02-13 A | 2006-12-07 A | 100% | 2006-02-13 | 2006-12-07 | 214d? | finish no earlier than 2006-12-07 | S5 | 1712h | 1712h | OAM7-NIM | China Mobile |  | Rel-7 | Dionisio |  |
| 863 | 261.1.12 | UTRAN radio channel power monitoring |  | 284d? | 2006-02-13 A | 2007-03-15 A | 100% | 2006-02-13 | 2007-03-15 | 284d? | finish no earlier than 2007-03-15 | S5 | 2272h | 2272h | OAM7-NIM | China Mobile |  | Rel-7 | Dionisio |  |
| 864 | 261.1.13 | Notification XML Schema |  | 71d? | 2006-12-07 A | 2007-03-15 A | 100% | 2006-12-07 | 2007-03-15 | 71d? | finish no earlier than 2007-03-15 | S5 | 568h | 568h | OAM7-NIM | Huawei | Christian.Toche@huawei.com | Rel-7 | Dionisio |  |

Notes:
- 835: Text3: 24.229
- 836: CT#34: CT3 not involved in Mp interface definition / Text3: 29.162
- 837: Text3: 23.333
- 838: Text3: 29.333
- 839: WID approved in CT#34 / Text3: 23.040, 29.002
- 840: Text3: 23.008, 23.012, 23.018, 23.078, 23.079, 29.002
- 841: reported complete when checked after CT6#44 / Text3: 31.103, 102 241
- 842: Following ETSI publication of TS 102 600, expected to be completed at CT6#45 / Text3: 31.101
- 843: Text3: 26.234, 26.235, 26.346, 26.140, 26.902
- 844: Text3: 26.140, 26.142, 26.234, 26.244, 23.346
- 845: Text3: 26.911
- 846: Text3: 26.235, 26.236
- 847: SP-35 stopped
- 848: Text3: 26.944
- 849: Text3: 26.234, 26.244
- 852: Text3: 32.731/2/3/5, 32.631/2/3/5
- 853: Text3: 32.806, 32.814, 32.101
- 854: Text3: 32.811
- 855: Text3: 32.391/2/3/5
- 856: Text3: 32.307/317/607/667/665, 32.101, 32.175
- 857: Text3: 32.372/3/5, 32.111,32.30x,32.32x,32.33x,32.34x,32.35x,32.36x,32.41x,32.60x,32.61x,32.66x
- 858: Text3: 32.381/2/3/5
- 859: Request to TSG#35 to STOP the WI / Text3: new 32.xxx
- 860: Request to TSG#35 to STOP the WI / Text3: 32.62n; For n = 1 to 5
- 861: Submit extension Sheet for TSG#35 Approval / Text3: 32.154
- 862: Text3: 32.721/2/3/5
- 863: Text3: 32.405, 32.64n; For n = 1 to 5
- 864: 12/2006 SA#34 WID approved / Text3: New 32.325/345/365/415, CR to 32.335/615/665

| ID | WBS | Task | Type | Duration | Start | Finish | Complete | Baseline start | Baseline finish | Baseline duration | Constraint | Resources | Work | Actual work | Text1 | Text6 | Text8 | Text4 | Text12 | Text5 | Text11 |
| --- | --- | --- | --- | --- | --- | --- | --- | --- | --- | --- | --- | --- | --- | --- | --- | --- | --- | --- | --- | --- | --- |
| 865 | 261.2 | **Performance Management** |  | 465d? | 2005-09-02 A | 2007-06-14 A | 100% | 2005-09-02 | 2007-06-14 | 465d? |  | S5 | 22992h | 22992h | OAM7-PM | Rel-7 | Dionisio |  |  |  |  |
| 866 | 261.2.1 | Performance measurements definition for CN CS |  | 400d? | 2005-09-02 A | 2007-03-15 A | 100% | 2005-09-02 | 2007-03-15 | 400d? | finish no earlier than 2007-03-15 | S5 | 3200h | 3200h | OAM7-PM | Rel-7 | Dionisio | China Mobile |  |  |  |
| 867 | 261.2.2 | Enhancement UTRAN performance measurements definition |  | 465d? | 2005-09-02 A | 2007-06-14 A | 100% | 2005-09-02 | 2007-06-14 | 465d? | finish no earlier than 2007-06-14 | S5 | 3720h | 3720h | OAM7-PM | Rel-7 | Dionisio | China Mobile |  |  |  |
| 868 | 261.2.3 | Add TDD specific counters in Performance measurement |  | 330d? | 2005-09-02 A | 2006-12-07 A | 100% | 2005-09-02 | 2006-12-07 | 330d? | finish no earlier than 2006-12-15 | S5 | 2640h | 2640h | OAM7-PM | Rel-7 | Dionisio | CATT |  |  |  |
| 869 | 261.2.4 | ATM bearer network Performance measurements |  | 400d? | 2005-09-02 A | 2007-03-15 A | 100% | 2005-09-02 | 2007-03-15 | 400d? | finish no earlier than 2007-03-15 | S5 | 3200h | 3200h | OAM7-PM | Rel-7 | Dionisio | ZTE |  |  |  |
| 870 | 261.2.5 | Performance measurements definition for IMS |  | 465d? | 2005-09-02 A | 2007-06-14 A | 100% | 2005-09-02 | 2007-06-14 | 465d? | finish no earlier than 2007-06-14 | S5 | 3720h | 3720h | OAM7-PM | Rel-7 | Dionisio | China Mobile |  |  |  |
| 871 | 261.2.6 | HSDPA performance measurements |  | 349d? | 2006-02-13 A | 2007-06-14 A | 100% | 2006-02-13 | 2007-06-14 | 349d? | finish no earlier than 2007-06-14 | S5 | 2792h | 2792h | OAM7-PM | Rel-7 | Dionisio | China Mobile |  |  |  |
| 872 | 44.5 | **Trace Management** |  | 472.86d? | 2005-09-02 A | 2007-06-26 A | 100% | 2005-09-02 | 2007-06-26 | 472.86d? |  | S5 | 14150.9h | 14150.9h | OAM7-Trace | Rel-7 | Dionisio | Vodafone |  |  |  |
| 873 | 261.3.1 | End-to-end Service Level tracing for IMS |  | 350d? | 2005-11-11 A | 2007-03-15 A | 100% | 2005-11-11 | 2007-03-15 | 350d? | finish no earlier than 2007-03-15 | S5 | 2800h | 2800h | OAM7-Trace | Rel-7 | Dionisio | Vodafone | SP-31 |  |  |
| 874 | 261.3.2 | Trace record content for UTRAN TDD |  | 330d? | 2005-09-02 A | 2006-12-07 A | 100% | 2005-09-02 | 2006-12-07 | 330d? | finish no earlier than 2006-12-07 | S5 | 2640h | 2640h | OAM7-Trace | Rel-7 | Dionisio | Nokia |  |  |  |
| 875 | 261.3.3 | IRP for Subscriber and Equipment Trace Management |  | 465d? | 2005-09-02 A | 2007-06-14 A | 100% | 2005-09-02 | 2007-06-14 | 465d? | finish no earlier than 2007-06-14 | S5 | 3720h | 3720h | OAM7-Trace | Rel-7 | Dionisio | Nokia |  |  |  |
| 876 | 261.3.4 | Deleted - SIP enhancements for trace | milestone | 0d? | 2007-06-15 A | 2007-06-26 A | 100% | 2007-06-15 | 2007-06-26 | 0d? | start no earlier than 2007-06-15 | C1 |  |  | OAM7-Trace | Rel-7 | Frederic |  | CP-32 |  |  |
| 877 | 261.3.5 | Deleted - duplicated with UID 35063 - IRP for Subscriber and Equipment Trace Management |  | 336d? | 2005-09-02 A | 2006-12-15 A | 100% | 2005-09-02 | 2006-12-15 | 336d? | finish no earlier than 2006-12-15 | S5 | 2688h | 2688h | OAM7-Trace | Rel-7 | Dionisio | Nokia | SP-33 |  |  |
| 878 | 262 | **Charging Management small Enhancements Rel-7** |  | 279d? | 2006-05-22 A | 2007-06-14 A | 100% | 2006-05-22 | 2007-06-14 | 279d? |  | S5 | 5952h | 5952h | CH7 | Rel-7 | Dionisio | Orange |  | alain.bibas@orange-ft.com |  |
| 879 | 262.1 | Alternate Charged Party (ACP) for IMS |  | 279d? | 2006-05-22 A | 2007-06-14 A | 100% | 2006-05-22 | 2007-06-14 | 279d? | finish no earlier than 2007-06-14 | S5 | 2232h | 2232h | CH7-IMS-ACP | Rel-7 | Dionisio | Lucent |  | njmazzarella@alcatel-lucent.com |  |
| 880 | 262.2 | Align 3GPP Charging with OMA PoC Enabler Release 2.0 |  | 186d? | 2006-09-28 A | 2007-06-14 A | 100% | 2006-09-28 | 2007-06-14 | 186d? | finish no earlier than 2007-06-14 | S5 | 1488h | 1488h | CH7-PoC | Rel-7 | Dionisio | Siemens |  | Gerald GÖRMER |  |
| 881 | 8.5 | **Multiple Input Multiple Output antennas (MIMO)** |  | 1177d? | 2003-03-14 A | 2007-09-17 A | 100% | 2003-03-14 | 2007-09-17 | 1177d? |  | R1 | 40272h | 40272h | MIMO | Rel-7 | Patrick | Alcatel-Lucent |  | hchuang@Alcatel-Lucent.com | RP-070037, RP-070531 |
| 882 | 263.1 | MIMO - Physical layer |  | 915d? | 2003-09-12 A | 2007-03-15 A | 100% | 2003-09-12 | 2007-03-15 | 915d? | finish no earlier than 2007-03-15 | R1 | 7320h | 7320h | MIMO-Phys | Rel-7 | Patrick | Alcatel-Lucent |  | hchuang@Alcatel-Lucent.com | RP-070037 |
| 883 | 263.2 | MIMO - Layer 2,3 aspects |  | 915d? | 2003-09-12 A | 2007-03-15 A | 100% | 2003-09-12 | 2007-03-15 | 915d? | finish no earlier than 2007-03-15 | R2 | 7320h | 7320h | MIMO-L23 | Rel-7 | Joern | Alcatel-Lucent |  | hchuang@Alcatel-Lucent.com | RP-070037 |
| 884 | 263.3 | MIMO - Iub/Iur Protocol Aspects |  | 1045d? | 2003-03-14 A | 2007-03-15 A | 100% | 2003-03-14 | 2007-03-15 | 1045d? | finish no earlier than 2007-03-15 | R3 | 8360h | 8360h | MIMO-IurIub | Rel-7 | Gert | Alcatel-Lucent |  | hchuang@Alcatel-Lucent.com | RP-070037 |
| 885 | 263.4 | MIMO - RF Radio Transmission/Reception, System Performance Requirements and Conformance Testing |  | 982d? | 2003-12-12 A | 2007-09-17 A | 100% | 2003-12-12 | 2007-09-17 | 982d? | finish no earlier than 2007-09-17 | R4 | 7856h | 7856h | MIMO-RF | Rel-7 | Stefania | Alcatel-Lucent |  | ngm@Alcatel-Lucent.com | RP-070531 |
| 886 | 264 | **Rel-7 Improvements of the Radio Interface** |  | 709d? | 2004-09-15 A | 2007-06-04 A | 100% | 2004-09-15 | 2007-06-04 | 709d? |  | RP | 29696h | 29696h | RInImp | Rel-7 | Stefania |  |  |  |  |
| 887 | 264.1 | Extended UMTS 1.7/2.1 GHz |  | 198d? | 2006-03-15 A | 2006-12-15 A | 100% | 2006-03-15 | 2006-12-15 | 198d? | finish no earlier than 2006-12-15 | R4 | 1584h | 1584h | RInImp-UMTS1721Ext | Rel-7 | Stefania | Ericsson |  | Johan Sköld (johan.skold@ericsson.com) | RP-060681 |
| 888 | 264.2 | UMTS 2.6 GHz 7.68 Mcps TDD |  | 67d? | 2006-06-15 A | 2006-09-15 A | 100% | 2006-06-15 | 2006-09-15 | 67d? | finish no earlier than 2006-09-15 | R4 | 536h | 536h | RInImp-UMTS26VHCRTDD | Rel-7 | Stefania | IPWireless |  | Shin Horng Wong (shwong@ipwireless.com) | RP-060451 |
| 889 | 264.3 | UMTS 2.6 GHz |  | 195d? | 2004-09-15 A | 2005-06-14 A | 100% | 2004-09-15 | 2005-06-14 | 195d? | finish no earlier than 2005-06-14 | R4 | 1560h | 1560h | RInImp-UMTS2600 | Rel-7 | Stefania | Nokia |  | jussi.numminen@nokia.com | RP-050184 |
| 890 | 264.4 | UMTS 2.6 GHz TDD |  | 261d? | 2004-12-15 A | 2005-12-14 A | 100% | 2004-12-15 | 2005-12-14 | 261d? | finish no earlier than 2005-12-15 | R4 | 2088h | 2088h | RInImp-UMTS2600TDD | Rel-7 | Stefania | IPWireless |  | Shin Horng Wong (shwong@ipwireless.com) | RP-050661 |
| 891 | 264.5 | UMTS 900 MHz |  | 261d? | 2004-12-15 A | 2005-12-14 A | 100% | 2004-12-15 | 2005-12-14 | 261d? | finish no earlier than 2005-12-15 | R4 | 2088h | 2088h | RInImp-UMTS900 | Rel-7 | Stefania | Nortel |  | Yannick Li (yli@nortelnetworks.com) | RP-050662 |
| 892 | 264.6 | UMTS 1700 MHz |  | 197d? | 2005-03-15 A | 2005-12-14 A | 100% | 2005-03-15 | 2005-12-14 | 197d? | finish no earlier than 2005-12-15 | R4 | 1576h | 1576h | RInImp-UMTS1700 | Rel-7 | Stefania | NTT DoCoMo |  | Takehiro Nakamura (takehiro@wsp.yrp.nttdocomo.co.jp) | RP-050824 |
| 893 | 264.7 | UE Antenna Performance Evaluation Method and Requirements |  | 644d? | 2004-12-15 A | 2007-06-04 A | 100% | 2004-12-15 | 2007-06-04 | 644d? | finish no earlier than 2007-06-04 | R4 | 5152h | 5152h | RInImp-UEAnt | Rel-7 | Stefania | TeliaSonera |  | Christian.Bergljung@TeliaSonera.com | RP-070281 |
| 894 | 264.8 | Improved Performance Requirements for HSDPA UE based on Rx Diversity (type 1) & LMMSE equalizer (type 2) | milestone | 0d? | 2005-03-15 A | 2005-03-15 A | 100% | 2005-03-15 | 2005-03-15 | 0d? | finish no earlier than 2005-03-15 | R4 |  |  | RInImp-HSPerf-Type3 | Rel-7 | Stefania | Cingular |  | Marc Grant | RP-060015 |

Notes:
- 866: Text3: 32.407, 32.408
- 867: Submit extension Sheet for TSG#35 Approval / Text3: 32.405
- 868: Text3: 32.405
- 869: Text3: No impact on 32.404, 32.405, 32.406, 32.407
- 870: Submit extension Sheet for TSG#35 Approval / Text3: 32.404,32.409,32.437, 32.632/3/4/5
- 871: Submit extension Sheet for TSG#35 Approval / Text3: 32.405
- 873: 07/2005: OMA (Stage 1), Stage 2/3 SA5, CT1/3/4 / Text3: CR 32.101, 32.421/2/3.
- 874: Text3: CR 32.421/2/3.
- 875: Submit extension Sheet for TSG#35 Approval / Text3: 32.441/2/3/5, CRs 32.632/3/5
- 876: combined with UID 11067
- 877: Text3: 32.421,32.422,32.423. 3 new 32.4x1,2,3
- 879: Text3: 32.240, 32.260, 32.298, 32.299
- 880: 09/2006 SA#33 WID approved / Text3: 32.240, 32.272, 32.299, 32.298
- 881: Completed Sep 2007; SR in RP-070037and RP-070531 / Text3: 25.876, 25.996
- 882: Completed Sep 2007; SR in RP-070037 / Text3: 25.211, 25.212, 25.213, 25.214, 25.215, 25.221
- 883: Completed Sep 2007; SR in RP-070037 / Text3: 25.876
- 884: Completed Sep 2007; SR in RP-070037
- 885: Completed Sep 2007; SR in RP-070531
- 886: Generic feature
- 887: Completed Dec 2006; SR in RP-060681 / Text3: 25.806, 25.101, 25.104, 25.133, 24.141, 25.331, 25.306, 25.307, 25.423, 25.461, 25.463, 34.121
- 888: Completed Sep 2006; SR in RP-060451 / Text3: 25.102, 25.105, 25.123, 25.113, 25.142, 34.124
- 889: Completed Jun 2005, SR in RP-050184 / Text3: 25.101, 25.104, 25.133, 25.141, 25.331, 25.942, 25.306, 25.307, 34.121
- 890: Completed Dec 2005, SR in RP-050661 / Text3: 25.102, 25.105, 25.113, 25.123, 25.142, 25.331, 25.942, 25.306, 25.307, 34.122, 34.124
- 891: Completed Dec 2005, SR in RP-050662 / Text3: 25.101, 25.104, 25.113, 25.133, 25.141, 25.331, 25.942, 25.306, 25.307, 34.121
- 892: Completed Dec 2005; SR in RP-050824 / Text3: 25.101, 25.104, 25.113, 25.133, 25.141, 25.306, 25.307, 25.331, 34.121
- 893: RP#36 (May 2007) completed. SR in RP-070281 / Text3: 25.101, 25.963
- 894: Completed Mar 2006, SR in RP-060015 / Text3: 25.101

| ID | WBS | Task | Type | Duration | Start | Finish | Complete | Baseline start | Baseline finish | Baseline duration | Constraint | Deadline | Resources | Work | Actual work | Text1 | Text4 | Text5 | Text6 | Text8 | Text11 | Text12 | Text9 | Text10 |
| --- | --- | --- | --- | --- | --- | --- | --- | --- | --- | --- | --- | --- | --- | --- | --- | --- | --- | --- | --- | --- | --- | --- | --- | --- |
| 895 | 264.9 | **Additional minimum UE performance requirement for non-HSDPA channels based on type 1 enhanced receiver (Rx Diversity)** |  | 327d? | 2005-09-15 A | 2006-12-15 A | 100% | 2005-09-15 | 2006-12-15 | 327d? |  |  | R4 | 7344h | 7344h | RInImp-RxDiv | Qualcomm | Serge Willenegger (sergew@qualcomm.com) | Rel-7 | Stefania |  |  |  |  |
| 896 | 264.9.1 | Additional minimum UE performance requirement for DL physical channels in support of DCH/HS-DSCH operation based on type 1 enhanced receiver (RX-Diversity) |  | 195d? | 2005-09-15 A | 2006-06-14 A | 100% | 2005-09-15 | 2006-06-14 | 195d? | finish no earlier than 2006-06-15 |  | R4 | 1560h | 1560h | RInImp-RxDiv-DCH | Cingular | Marc Grant | Rel-7 | Stefania | RP-060235 |  |  |  |
| 897 | 264.9.2 | Additional minimum UE performance requirement for downlink physical channels in support of MTCH and MCCH operation based on type 1 enhanced receiver (Rx-Diversity) |  | 198d? | 2006-03-15 A | 2006-12-15 A | 100% | 2006-03-15 | 2006-12-15 | 198d? | finish no earlier than 2006-12-15 |  | R4 | 1584h | 1584h | RInImp-RxDiv-MBMS | Qualcomm | Serge Willenegger (sergew@qualcomm.com) | Rel-7 | Stefania | RP-060678 |  |  |  |
| 898 | 264.9.3 | Additional minimum UE performance requirement for downlink physical channels in support of E-DCH operation based on type 1 enhanced receiver (Rx-Diversity) |  | 198d? | 2006-03-15 A | 2006-12-15 A | 100% | 2006-03-15 | 2006-12-15 | 198d? | finish no earlier than 2006-12-15 |  | R4 | 1584h | 1584h | RInImp-RxDiv-EDCH | Qualcomm | Serge Willenegger (sergew@qualcomm.com) | Rel-7 | Stefania | RP-060679 |  |  |  |
| 899 | 264.10 | Deleted Improved support of gaming over HSDPA/EDCH |  | 262d? | 2005-12-15 A | 2006-12-15 A | 100% | 2005-12-15 | 2006-12-15 | 262d? | finish no earlier than 2006-12-15 |  | R2 | 2096h | 2096h | RInImp-Gaming | Cingular | Don Zelmer (dz1069@att.com) | Rel-7 | Joern | RP-060680 | RP-34 |  |  |
| 900 | 264.11 | Deleted (not approved at PCG) - UMTS 2.6 GHz FDD DL External | milestone | 0d? | 2005-09-15 A | 2005-09-15 A | 100% | 2005-09-15 | 2005-09-15 | 0d? | finish no earlier than 2005-09-15 |  | R4 |  |  | RInImp-UMTS2600Ext | T-mobile | han.van.bussel@t-mobile.de | Rel-7 | Stefania |  | RP-31 | PCG-16 |  |
| 901 | 265 | **Rel-7 Improvements of the Radio Interface - UE Conformance Testing** |  | 741d? | 2005-11-11 A | 2008-09-12 A | 100% | 2005-11-11 | 2008-09-12 | 741d? |  |  | R5 | 17568h | 17568h | RInImp-UEConTest |  |  | Rel-7 | Ingbert |  |  |  |  |
| 902 | 16.5.1 | UE conformance testing for UMTS 2600 MHz |  | 146d | 2005-11-11 A | 2006-06-02 A | 100% | 2005-11-11 | 2006-06-02 | 146d | finish no earlier than 2006-06-02 | 2006-06-02 | R5 | 1168h | 1168h | RInImp-UMTS2600_Test | Nokia | Aleksi.Heino@nokia.com | Rel-7 | Ingbert |  |  |  | Fri 7/11/05 |
| 903 | 16.5.1 | UE Conformance Test for UMTS 900 MHz (band VIII) |  | 146d | 2005-11-11 A | 2006-06-02 A | 100% | 2005-11-11 | 2006-06-02 | 146d | finish no earlier than 2006-06-02 | 2006-06-02 | R5 | 1168h | 1168h | RInImp-UMTS900_Test | Qualcomm | hanye@qualcomm.com | Rel-7 | Ingbert |  |  |  | Fri 11/03/05 |
| 904 | 265.3 | Conformance Test Aspects – Improved Performance of HSDPA Receiver type 3 |  | 191d? | 2006-03-10 A | 2006-12-01 A | 100% | 2006-03-10 | 2006-12-01 | 191d? | finish no earlier than 2006-12-01 |  | R5 | 1528h | 1528h | RInImp-HSPerf-Type3_Test | Motorola | carolyn.taylor@motorola.com | Rel-7 | Ingbert |  |  |  |  |
| 905 | 265.4 | UE antenna Over The Air (OTA) conformance testing |  | 518d? | 2006-09-20 A | 2008-09-12 A | 100% | 2006-09-20 | 2008-09-12 | 518d? | finish no earlier than 2008-09-12 |  | R5 | 4144h | 4144h | RInImp-UEAnt_Test | Nokia | Aleksi.Heino@nokia.com | Rel-7 | Ingbert | RP-080535 |  |  |  |
| 906 | 265.5 | UE conformance testing for FDD Inter-Band Operation |  | 131d? | 2006-06-02 A | 2006-12-01 A | 100% | 2006-06-02 | 2006-12-01 | 131d? | finish no earlier than 2006-12-01 |  | R5 | 1048h | 1048h | RInImp-InterBand_Test | NEC, Motorola | Jacob.John@motorola.com | Rel-7 | Ingbert |  |  |  |  |
| 907 | 265.6 | Conformance Test Aspects – Extended UMTS 1.7/2.1 GHz |  | 131d? | 2006-12-01 A | 2007-06-01 A | 100% | 2006-12-01 | 2007-06-01 | 131d? | finish no earlier than 2007-06-01 |  | R5 | 1048h | 1048h | RInImp-UEConTest_UMTS1721Ext | Motorola | carolyn.taylor@motorola.com | Rel-7 | Ingbert |  |  |  |  |
| 908 | 265.7 | Conformance Test Aspects – Minimum UE performance requirement for downlink physical channels in support of E-DCH operation based on type 1 enhanced receiver (Rx-Diversity) |  | 136d? | 2007-06-01 A | 2007-12-07 A | 100% | 2007-06-01 | 2007-12-07 | 136d? | finish no earlier than 2007-12-07 |  | R5 | 1088h | 1088h | RInImp-UEConTest_RxDivEDCH | Motorola | carolyn.taylor@motorola.com | Rel-7 | Ingbert |  |  |  |  |
| 909 | 265.8 | Conformance Test Aspects – Minimum UE performance requirement for downlink physical channels in support of MTCGH and MCCH operation based on type 1 enhanced receiver (Rx-Diversity) |  | 201d? | 2007-06-01 A | 2008-03-07 A | 100% | 2007-06-01 | 2008-03-07 | 201d? | finish no earlier than 2008-03-07 |  | R5 | 1608h | 1608h | RInImp-UEConTest_RxDivMBMS | Ericsson | leif.mattisson@ericsson.com | Rel-7 | Ingbert | RP-080056 |  |  |  |
| 910 | 266 | **Rel-7 RAN improvements** |  | 653d? | 2004-12-15 A | 2007-06-15 A | 100% | 2004-12-15 | 2007-06-15 | 653d? |  |  | RP | 29920h | 29920h | RANimp |  |  | Rel-7 | Stefania |  |  |  |  |
| 911 | 266.1 | Optimisation of channelisation code utilisation for 1.28 Mcps TDD |  | 523d? | 2004-12-15 A | 2006-12-15 A | 100% | 2004-12-15 | 2006-12-15 | 523d? | finish no earlier than 2006-12-15 |  | R1 | 4184h | 4184h | RANimp-RABSE-CodOptLCRTDD | UTStarcom | Ka Leong Lo (kaleong.lo@UTSTAR.COM) | Rel-7 | Patrick | RP-060682 |  |  |  |
| 912 | 266.2 | Delay optimisation for procedures applicable to CS and PS Connections |  | 394d? | 2005-03-15 A | 2006-09-15 A | 100% | 2005-03-15 | 2006-09-15 | 394d? | finish no earlier than 2006-09-15 |  | R2 | 3152h | 3152h | RANimp-DelayOpt | Nokia | juho.pirskanen@nokia.com | Rel-7 | Joern | RP-060453 |  |  |  |
| 913 | 266.3 | Improved support of IMS Realtime Services using HSDPA/HSUPA |  | 197d? | 2005-03-15 A | 2005-12-14 A | 100% | 2005-03-15 | 2005-12-14 | 197d? | start no earlier than 2005-03-15 |  | R2 | 1576h | 1576h | RANimp-IMSRealTime | Cingular | Don Zelmer (dz1069@att.com) | Rel-7 | Joern | RP-050667 |  |  |  |
| 914 | 266.4 | UE Performance Requirements for MBMS (TDD) |  | 328d? | 2005-03-15 A | 2006-06-15 A | 100% | 2005-03-15 | 2006-06-15 | 328d? | finish no earlier than 2006-06-15 |  | R4 | 2624h | 2624h | MBMS-RAN-RF-TDD | IPwireless | shwong@ipwireless.com | Rel-7 | Stefania | RP-060477 |  |  |  |
| 915 | 266.5 | Continuous connectivity for packet data users |  | 524d? | 2005-03-14 A | 2007-03-15 A | 100% | 2005-03-14 | 2007-03-15 | 524d? | finish no earlier than 2007-03-15 |  | R1 | 4192h | 4192h | RANimp-CPC | Siemens | Joern.Krause@siemens.com | Rel-7 | Patrick | RP-070033 |  |  |  |
| 916 | 266.6 | Extended WCDMA Cell Range |  | 198d? | 2006-03-15 A | 2006-12-15 A | 100% | 2006-03-15 | 2006-12-15 | 198d? | finish no earlier than 2006-12-15 |  | R3 | 1584h | 1584h | RANimp-ExtCell | Ericsson | Muhammad Kazmi | Rel-7 | Gert | RP-060685 |  |  |  |
| 917 | 266.7 | 7.68 Mcps TDD Enhanced Uplink |  | 198d? | 2006-03-15 A | 2006-12-15 A | 100% | 2006-03-15 | 2006-12-15 | 198d? | finish no earlier than 2006-12-15 |  | R1 | 1584h | 1584h | RANimp-VHCRTDD-EDCH | IPwireless | nanderson@ipwireless.com | Rel-7 | Patrick | RP-060684 |  |  |  |
| 918 | 266.8 | Enhanced CELL_FACH State in FDD |  | 181d? | 2006-09-25 A | 2007-06-04 A | 100% | 2006-09-25 | 2007-06-04 | 181d? | finish no earlier than 2007-06-04 |  | R2 | 1448h | 1448h | RANimp-EnhState | Nokia | juho.pirskanen@nokia.com | Rel-7 | Joern | RP-070286 |  |  |  |
| 919 | 266.9 | 64QAM for HSDPA (FDD) |  | 110d? | 2006-12-15 A | 2007-06-04 A | 100% | 2006-12-15 | 2007-06-04 | 110d? | finish no earlier than 2007-06-04 |  | R1 | 880h | 880h | RANimp-64QamDownlink | Ericsson | Johan.Bergman@ericsson.com | Rel-7 | Patrick | RP-070287 |  |  |  |
| 920 | 266.10 | Improved L2 support for high data rates |  | 122d? | 2006-12-15 A | 2007-06-04 A | 100% | 2006-12-15 | 2007-06-04 | 122d? | finish no earlier than 2007-06-04 |  | R2 | 976h | 976h | RANimp-L2DataRates | Ericsson | Janne.Peisa@ericsson.com | Rel-7 | Joern | RP-070289 |  |  |  |
| 921 | 266.11 | Introduction of 16QAM in HSUPA (FDD) |  | 110d? | 2006-12-15 A | 2007-06-04 A | 100% | 2006-12-15 | 2007-06-04 | 110d? | finish no earlier than 2007-06-04 |  | R1 | 880h | 880h | RANimp-16QamUplink | Nokia | Karri.Ranta-aho@nsn.com | Rel-7 | Patrick | RP-070288 |  |  |  |

Notes:
- 895: Text3: 25.101
- 896: Completed Jun 2006, SR in RP-060235 / Text3: 25.101
- 897: Completed Dec 2006, SR in RP-060678 / Text3: 25.101
- 898: Completed Dec 2006, SR in RP-060679 / Text3: 25.101
- 899: RP#34 (Dec 2006) stopped. SR in RP-060680
- 900: This item was conditionnaly approved pending decision of PCG 16 who decided not to approve it / Text3: 25.101, 25.104, 25.133, 25.141, 25.331, 25.942, 25.306, 25.307, 34.121
- 901: 05/08: Linked to Feature UID_20028 (RInImp)
- 902: Text3: 34.108, 34.121
- 903: Text3: 34.108, 34.121
- 904: Text3: 34.121, 34.108
- 905: SR in RP-080535. RP#41 completed (GERAN aspects might need to be included later) / Text3: 34.114
- 906: Text3: 34.108, 34.123-1, 34.123-2, 34.123-3
- 907: Text3: 34.108, 34.121-1, 34.121-2
- 909: SR in RP-080056
- 910: Generic feature
- 911: Completed Dec 2006; SR in RP-060682
- 912: Completed Sep 2006; SR in RP-060453 / Text3: 25.815, 25.321, 25.322, 25.331
- 913: Closed Dec 2005; SR in RP-050667
- 914: Completed Sep 2006; SR in RP-060477 / Text3: 25.102, 25.123
- 915: Completed at Mar 2007; SR in RP-070033 / Text3: 25.903, 25.201, 25.211, 25.212, 25.214, 25.308, 25.321, 25.331, 25.423, 25.433, 25.101, 25.133
- 916: Completed Dec 2006; SR in RP-060685 / Text3: 25.133, 25.423, 25.425, 25.433, 25.435, 25.453, 25.331
- 917: Completed Dec 2006; SR in RP-060684 / Text3: 25.201, 25.202, 25.221, 25.222, 25.223, 25.224, 25.225, 25.331, 23.321, 25.306, 25.302, 25.401, 25.420, 25.423, 25.427, 25.433, 25.102, 25.105, 25.142
- 918: Completed May 2007; SR in RP-070286 / Text3: 25.308, 25.304, 25.306, 25.321, 25.331, 25.433, 25.435, 25.423, 25.425,
- 919: Completed May 2007; SR in RP-070287 / Text3: 25.308, 25.211, 25.212, 25.213, 25.306, 25.331, 25.433, 25.435, 25.423, 25.425, 25.101, 25.104, 25.141
- 920: Completed May 2007; SR in RP-070289 / Text3: 25.301, 25.308,25.306, 25.321, 25.322, 25.331, 25.433, 25.435, 25.423, 25.425, 25.999
- 921: Completed May 2007; SR in RP-070288 / Text3: 25.319, 25.101, 25.104, 25.133, 25.141, 25.211, 25.212, 25.213, 25.214, 25.306, 25.321, 25.331, 25.423, 25.433

| ID | WBS | Task | Duration | Start | Finish | Complete | Remaining | Baseline start | Baseline finish | Baseline duration | Total slack | Constraint | Resources | Work | Actual work | Text1 | Text4 | Text5 | Text6 | Text8 | Text11 |
| --- | --- | --- | --- | --- | --- | --- | --- | --- | --- | --- | --- | --- | --- | --- | --- | --- | --- | --- | --- | --- | --- |
| 922 | 266.12 | **Interface to control Tower Mounted Amplifiers (TMAs)** | 101d? | 2007-01-26 A | 2007-06-15 A | 100% |  | 2007-01-26 | 2007-06-15 | 101d? |  |  | R3 | 1616h | 1616h | RANImp-TMA | Vodafone | alexej.kulakov@vodafone.com | Rel-7 | Gert | RP-070140 |
| 923 | 266.12.1 | OAM aspects to Interface to control TMAs | 101d? | 2007-01-26 A | 2007-06-15 A | 100% |  | 2007-01-26 | 2007-06-15 | 101d? |  | finish no earlier than 2007-06-15 | S5 | 808h | 808h | RANImp-TMA-OAM | Vodafone | Adrian.Neal@vodafone.com | Rel-7 | Dionisio |  |
| 924 | 267 | **Rel-7 RAN improvements - UE Conformance Testing** | 703d? | 2006-09-20 A | 2009-05-29 | 96% | 26.42d? | 2006-09-20 | 2009-05-29 | 703d? | 205d |  | R5 | 24176h | 20886.8h | RANimp-UEConTest |  |  | Rel-7 | Ingbert |  |
| 925 | 267.1 | Conformance Test Aspects - 3.84 Mcps and 7.68 Mcps TDD Enhanced Uplink | 518d? | 2006-09-20 A | 2008-09-12 A | 100% |  | 2006-09-20 | 2008-09-12 | 518d? |  | finish no earlier than 2008-09-12 | R5 | 4144h | 4144h | RANimp-UEConTest_EDCHTDH | IPWireless | tspeight@ipwireless.com | Rel-7 | Ingbert | RP-080536 |
| 926 | 267.2 | Conformance Test Aspects – 64QAM for HSDPA (FDD) | 257d? | 2007-03-09 A | 2008-03-03 A | 100% |  | 2007-03-09 | 2008-03-03 | 257d? |  | finish no earlier than 2008-03-03 | R5 | 2056h | 2056h | RANimp-UEConTest_64QamDownlink | Ericsson | leif.mattisson@ericsson.com | Rel-7 | Ingbert | RP-080059 |
| 927 | 267.3 | Conformance Test Aspects – 16QAM for HSUPA (FDD) | 321d? | 2007-03-09 A | 2008-05-30 A | 100% |  | 2007-03-09 | 2008-05-30 | 321d? |  | finish no earlier than 2008-05-30 | R5 | 2568h | 2568h | RANimp-UEConTest_16QamUplink | Motorola | carolyn.taylor@motorola.com | Rel-7 | Ingbert | RP-080281 |
| 928 | 267.4 | Conformance Test Aspects – Improved L2 support for high data rates | 321d? | 2007-03-09 A | 2008-05-30 A | 100% |  | 2007-03-09 | 2008-05-30 | 321d? |  | finish no earlier than 2008-05-30 | R5 | 2568h | 2568h | RANimp-UEConTest_L2DataRates | Ericsson | leif.mattisson@ericsson.com | Rel-7 | Ingbert | RP-080256 |
| 929 | 267.5 | Conformance Test Aspects – Continuous connectivity for packet data users | 321d? | 2007-03-09 A | 2008-05-30 A | 100% |  | 2007-03-09 | 2008-05-30 | 321d? |  | finish no earlier than 2008-05-30 | R5 | 2568h | 2568h | RANimp-UEConTest_CPC | Nokia | jarkko.hellsten@nokia.com | Rel-7 | Ingbert | RP-080282 |
| 930 | 267.6 | Conformance Test Aspects – Enhanced CELL_FACH state in FDD | 581d? | 2007-03-09 A | 2009-05-29 | 85% | 87.15d? | 2007-03-09 | 2009-05-29 | 581d? | 205d | finish no earlier than 2009-05-29 | R5 | 4648h | 3950.8h | RANimp–UEConTest_EnhancedCellFACHState | Nokia | jarkko.hellsten@nokia.com | Rel-7 | Ingbert | RP-090055 |
| 931 | 268 | **7.68Mcps TDD option** | 457d? | 2004-09-15 A | 2006-06-15 A | 100% |  | 2004-09-15 | 2006-06-15 | 457d? |  |  | RP | 19824h | 19824h | VHCRTDD | IPwireless | Martin Beale (mbeale@ipwireless.com) | Rel-7 | Stefania | RP-060684 |
| 932 | 268.1 | VHCRTDD: Stage 2 | 391d? | 2004-09-15 A | 2006-03-15 A | 100% |  | 2004-09-15 | 2006-03-15 | 391d? |  | finish no earlier than 2006-03-15 | R1 | 3128h | 3128h | VHCRTDD-Stage2 | IPwireless | Martin Beale (mbeale@ipwireless.com) | Rel-7 | Patrick |  |
| 933 | 268.2 | VHCRTDD: Physical Layer | 391d? | 2004-09-15 A | 2006-03-15 A | 100% |  | 2004-09-15 | 2006-03-15 | 391d? |  | finish no earlier than 2006-03-15 | R1 | 3128h | 3128h | VHCRTDD-Phys | IPwireless | Martin Beale (mbeale@ipwireless.com) | Rel-7 | Patrick |  |
| 934 | 268.3 | VHCRTDD: Layer 2 and layer 3 protocol aspects | 391d? | 2004-09-15 A | 2006-03-15 A | 100% |  | 2004-09-15 | 2006-03-15 | 391d? |  | finish no earlier than 2006-03-15 | R2 | 3128h | 3128h | VHCRTDD-L23 | IPwireless | drichards@ipwireless.com | Rel-7 | Joern |  |
| 935 | 268.4 | VHCRTDD: UTRAN Iub/Iur Protocol Aspects | 391d? | 2004-09-15 A | 2006-03-15 A | 100% |  | 2004-09-15 | 2006-03-15 | 391d? |  | finish no earlier than 2006-03-15 | R3 | 3128h | 3128h | VHCRTDD-IurIub | IPwireless | Peter Legg (plegg@ipwireless.com) | Rel-7 | Gert |  |
| 936 | 268.5 | VHCRTDD: RF Radio Transmission/ Reception, System Performance Requirements and Conformance Testing | 457d? | 2004-09-15 A | 2006-06-15 A | 100% |  | 2004-09-15 | 2006-06-15 | 457d? |  | finish no earlier than 2006-06-15 | R4 | 3656h | 3656h | VHCRTDD-RF | IPwireless | Shin Horng Wong (shwong@ipwireless.com) | Rel-7 | Stefania |  |
| 937 | 269 | **3.84 Mcps TDD Enhanced Uplink** | 394d? | 2005-03-15 A | 2006-09-15 A | 100% |  | 2005-03-15 | 2006-09-15 | 394d? |  |  | RP | 18384h | 18384h | EDCHTDD | IPwireless | nanderson@ipwireless.com | Rel-7 | Stefania | RP-060684 |
| 938 | 269.1 | EDCHTDD: Stage 2 | 328d? | 2005-03-15 A | 2006-06-15 A | 100% |  | 2005-03-15 | 2006-06-15 | 328d? |  | finish no earlier than 2006-06-15 | R2 | 2624h | 2624h | EDCHTDD-Stage2 | IPwireless | nanderson@ipwireless.com | Rel-7 | Joern |  |
| 939 | 269.2 | EDCHTDD: Physical Layer | 394d? | 2005-03-15 A | 2006-09-15 A | 100% |  | 2005-03-15 | 2006-09-15 | 394d? |  | finish no earlier than 2006-09-15 | R1 | 3152h | 3152h | EDCHTDD-Phys | IPwireless | nanderson@ipwireless.com | Rel-7 | Patrick |  |
| 940 | 269.3 | EDCHTDD: Layer 2 and 3 Protocol Aspects | 394d? | 2005-03-15 A | 2006-09-15 A | 100% |  | 2005-03-15 | 2006-09-15 | 394d? |  | finish no earlier than 2006-09-15 | R2 | 3152h | 3152h | EDCHTDD-L23 | IPwireless | drichards@ipwireless.com | Rel-7 | Joern |  |
| 941 | 269.4 | EDCHTDD: UTRAN Iub/Iur Protocol Aspects | 394d? | 2005-03-15 A | 2006-09-15 A | 100% |  | 2005-03-15 | 2006-09-15 | 394d? |  | finish no earlier than 2006-09-15 | R3 | 3152h | 3152h | EDCHTDD-IurIub | Interdigital | jim.miller@interdigital.com | Rel-7 | Gert |  |
| 942 | 269.5 | EDCHTDD: RF Radio Transmission/ Reception, System Performance Requirements and Conformance Testing | 394d? | 2005-03-15 A | 2006-09-15 A | 100% |  | 2005-03-15 | 2006-09-15 | 394d? |  | finish no earlier than 2006-09-15 | R4 | 3152h | 3152h | EDCHTDD-RF | IPwireless | Shin Horng Wong (shwong@ipwireless.com) | Rel-7 | Stefania |  |
| 943 | 270 | **1.28 Mcps TDD Enhanced Uplink** | 328d? | 2006-03-15 A | 2007-06-15 A | 100% |  | 2006-03-15 | 2007-06-15 | 328d? |  |  | RP | 11536h | 11536h | LCRTDD-EDCH | CATT | Haijing Hu | Rel-7 | Stefania | RP-070296 |
| 944 | 270.1 | 1.28 Mcps TDD Enhanced Uplink: Physical Layer | 262d? | 2006-03-15 A | 2007-03-15 A | 100% |  | 2006-03-15 | 2007-03-15 | 262d? |  | finish no earlier than 2007-03-15 | R1 | 2096h | 2096h | LCRTDD-EDCH-Phys | CATT | Ke Wang | Rel-7 | Patrick |  |
| 945 | 270.2 | 1.28 Mcps TDD Enhanced Uplink: Layer 2 and 3 Protocol Aspects | 262d? | 2006-03-15 A | 2007-03-15 A | 100% |  | 2006-03-15 | 2007-03-15 | 262d? |  | finish no earlier than 2007-03-15 | R2 | 2096h | 2096h | LCRTDD-EDCH-L23 | CATT | Haiyang Quan | Rel-7 | Joern |  |
| 946 | 270.3 | 1.28 Mcps TDD Enhanced Uplink: UTRAN Iub/Iur Protocol Aspects | 262d? | 2006-03-15 A | 2007-03-15 A | 100% |  | 2006-03-15 | 2007-03-15 | 262d? |  | finish no earlier than 2007-03-15 | R3 | 2096h | 2096h | LCRTDD-EDCH-IubIur | CATT | Yincheng Zhang | Rel-7 | Gert |  |
| 947 | 270.4 | 1.28 Mcps TDD Enhanced Uplink: RF Radio Transmission/ Reception, System Performance Requirements and Conformance Testing | 328d? | 2006-03-15 A | 2007-06-15 A | 100% |  | 2006-03-15 | 2007-06-15 | 328d? |  | finish no earlier than 2007-06-15 | R4 | 2624h | 2624h | LCRTDD-EDCH-RF | CATT | Yuexia Song | Rel-7 | Stefania |  |
| 948 | 271 | 1.28 Mcps TDD Enhanced Uplink - UE Conformance Testing | 257d? | 2007-09-20 A | 2008-09-12 A | 100% |  | 2007-09-20 | 2008-09-12 | 257d? |  | finish no earlier than 2008-09-11 | R5 | 624h | 624h | LCRTDD-EDCH-UEConTest | CATT | chenxiaozhong@datangmobile.cn | Rel-7 | Ingbert | RP-080539 |
| 949 | 272 | MS Antenna Performance Evaluation Method and Requirements | 731d? | 2005-01-28 A | 2007-11-16 A | 100% |  | 2005-01-28 | 2007-11-16 | 731d? |  | finish no earlier than 2007-11-16 | GP | 5848h | 5848h | APEMR | TeliaSonera | Ulf.Tegth@teliasonera.com | Rel-7 | Paolo |  |

Notes:
- 922: Completed Mar 2007; SR in RP-070140
- 923: SA#36 Jun 2007 completed / Text3: 32.642/3/5 – Align with RAN 25.466
- 924: 05/08: Linked to Feature UID_20029 (RANimp)
- 925: SR in RP-080536. RP#41 completed / Text3: 34.108, 34.122, 34.123-1, 34.123-2, 34.123-3
- 926: SR in RP-080059. RP#39 completed. / Text3: 34.108, 34.121-1, 34.121-2, 34.123-1, 34.123-2, 34.123-3
- 927: SR in RP-080281. RP#40 completed / Text3: 34.108, 34.121-1, 34.121-2, 34.123-1, 34.123-2, 34.123-3
- 928: SR in RP-080256. RP#40 completed / Text3: 34.108, 34.123-1, 34.123-2, 34.123-3
- 929: SR in RP-080282. RP#40 completed / Text3: 34.108, 34.121-1, 34.121-2, 34.123-1, 34.123-2, 34.123-3
- 930: RP#43 Completion target 03/09=>05/09 / Text3: 34.108, 34.123-1, 34.123-2, 34.123-3
- 931: Completed Dec 2006, SR in RP-060684
- 932: Feature completed and closed at RP#33 with the presentation of the test WI / Text3: 25.202
- 933: Feature completed and closed at RP#33 with the presentation of the test WI / Text3: 25.221, 25.222, 25.223, 25.224,25.225
- 934: Feature completed and closed at RP#33 with the presentation of the test WI / Text3: 25.301, 25.302, 25.305, 25.306, 25.321, 25.331
- 935: Feature completed and closed at RP#33 with the presentation of the test WI / Text3: 25.401, 25.420, 25.423, 25.425, 25.427, 25.430, 25.433, 25.435
- 936: Feature completed and closed at RP#33 with the presentation of the test WI / Text3: 25.102, 25.105, 25.123, 25.133, 25.142
- 937: Completed Dec 2006, SR in RP-060684
- 939: Text3: 25.201, 25.221,25.222, 25.223, 25.224, 25.225
- 940: Text3: 25.301, 25.302, 25.306, 25.321, 25.331
- 941: Text3: 25.401, 25.420, 25.423, 25.427, 25.430, 25.433, 25.435
- 942: Text3: 25.102, 25.105, 25.123, 25.142
- 943: Completed May 2007; SR in RP-070038 and RP-070296
- 944: Text3: 25.201, 25.221, 25.222, 25.223, 25.224, 25.225
- 945: Text3: 25.301, 25.302, 25.306, 25.321, 25.331
- 946: Text3: 25.401, 25.420, 25.423, 25.425, 25.427, 25.430, 25.433, 25.435
- 947: Text3: 25.102, 25.105, 25.123, 25.142
- 948: UID_350046->350146. 05/08: Linked to Feature UID_20055 (LCRTDD-EDCH). SR in RP-080539. RP#41 completed / Text3: 34.108, 34.122, 34.123-1/2/3
- 949: GP#36 completed for R7 / Text3: 25.914, 25.144, 45.005

| ID | WBS | Task | Type | Duration | Start | Finish | Complete | Remaining | Baseline start | Baseline finish | Baseline duration | Total slack | Constraint | Resources | Work | Actual work | Text1 | Text4 | Text5 | Text6 | Text8 | Text12 |
| --- | --- | --- | --- | --- | --- | --- | --- | --- | --- | --- | --- | --- | --- | --- | --- | --- | --- | --- | --- | --- | --- | --- |
| 950 | 273 | **Lower 700 MHz Inclusion in the GERAN Specifications** |  | 390d? | 2005-01-03 A | 2006-06-30 A | 100% |  | 2005-01-03 | 2006-06-30 | 390d? |  |  | GP | 7632h | 7632h | GSM710 | UTC | dcotton@mtview.union-tel.com | Rel-7 | Paolo |  |
| 951 | 273.1 | Inclusion of the 698 – 746 MHz band into GERAN core specifications |  | 129d? | 2005-01-03 A | 2005-06-30 A | 100% |  | 2005-01-03 | 2005-06-30 | 129d? |  | finish no earlier than 2005-06-30 | G1 | 1032h | 1032h | GSM710-core |  |  | Rel-7 | Paolo |  |
| 952 | 273.2 | G1 aspects of GSM710 |  | 217.5d? | 2005-08-31 A | 2006-06-30 A | 100% |  | 2005-08-31 | 2006-06-30 | 217.5d? |  | finish no earlier than 2006-06-30 | G1 | 1740h | 1740h | GSM-710-test |  |  | Rel-7 | Paolo |  |
| 953 | 273.3 | G3 aspects of GSM710 |  | 217.5d? | 2005-08-31 A | 2006-06-30 A | 100% |  | 2005-08-31 | 2006-06-30 | 217.5d? |  | finish no earlier than 2006-06-30 | G3new | 1740h | 1740h | GSM-710-test |  |  | Rel-7 | Ingbert |  |
| 954 | 274 | **Support of Conversational Services in A/Gb mode via the PS domain** |  | 626d? | 2005-04-08 A | 2007-08-31 A | 100% |  | 2005-04-08 | 2007-08-31 | 626d? |  |  | GP | 15442.8h | 15442.8h | SCSAGB | Ericsson | gunnar.hedby@ericsson.com | Rel-7 | Paolo |  |
| 955 | 274.1 | Minimise the transfer delay between the SGSN and the MS |  | 604.95d? | 2005-04-08 A | 2007-08-31 A | 100% |  | 2005-04-08 | 2007-08-31 | 604.95d? |  | finish no earlier than 2007-08-31 | GP | 4839.6h | 4839.6h | SCSAGB-MTD | Ericsson | gunnar.hedby@ericsson.com | Rel-7 | Paolo |  |
| 956 | 274.2 | Definition of radio resource management functionality |  | 626d? | 2005-04-08 A | 2007-08-31 A | 100% |  | 2005-04-08 | 2007-08-31 | 626d? |  | finish no earlier than 2007-08-31 | G1 | 5008h | 5008h | SCSAGB-RRM | Ericsson | gunnar.hedby@ericsson.com | Rel-7 | Paolo |  |
| 957 | 274.3 | Support of Conversational Services in A/Gb mode via the PS domain – RLC Non-Persistent mode |  | 101d? | 2006-06-30 A | 2006-11-17 A | 100% |  | 2006-06-30 | 2006-11-17 | 101d? |  | finish no earlier than 2006-11-17 | G2 | 808h | 808h | SCSAGB-RLCNP | Ericsson | gunnar.hedby@ericsson.com | Rel-7 | Juha |  |
| 958 | 274.4 | Deleted- Radio Channel Support | milestone | 0d? | 2006-07-17 A | 2006-07-17 A | 100% |  | 2006-07-17 | 2006-07-17 | 0d? |  | start no earlier than 2006-07-17 | G2 |  |  | SCSAGB-RCHS | Ericsson | gunnar.hedby@ericsson.com | Rel-7 | Juha | SP-32 |
| 959 | 274.5 | Deleted- Modifications to FLO | milestone | 0d? | 2006-07-17 A | 2006-07-17 A | 100% |  | 2006-07-17 | 2006-07-17 | 0d? |  | start no earlier than 2006-07-17 | G2 |  |  | SCSAGB-FLO | Ericsson | gunnar.hedby@ericsson.com | Rel-7 | Juha | SP-32 |
| 960 | 275 | **Addition of new frequency band to GSM (T-GSM810)** |  | 626d? | 2005-04-08 A | 2007-08-31 A | 100% |  | 2005-04-08 | 2007-08-31 | 626d? |  |  | GP | 12112h | 12112h | TGSM810 | Huawei | chende@huawei.com | Rel-7 | Paolo |  |
| 961 | 275.1 | Changes to core specification |  | 106d? | 2005-04-08 A | 2005-09-02 A | 100% |  | 2005-04-08 | 2005-09-02 | 106d? |  | finish no earlier than 2005-09-02 | GP | 848h | 848h | TGSM810-Core | Huawei | chende@huawei.com | Rel-7 | Paolo |  |
| 962 | 275.2 | Changes to MS testing specification |  | 626d? | 2005-04-08 A | 2007-08-31 A | 100% |  | 2005-04-08 | 2007-08-31 | 626d? |  | finish no earlier than 2007-08-31 | G3new | 5008h | 5008h | TGSM810-MStest | Huawei | chende@huawei.com | Rel-7 | Ingbert |  |
| 963 | 275.3 | Changes to BTS testing specification |  | 156d? | 2005-04-08 A | 2005-11-11 A | 100% |  | 2005-04-08 | 2005-11-11 | 156d? |  | finish no earlier than 2005-11-11 | G1 | 1248h | 1248h | TGSM810-BTStest | Huawei | chende@huawei.com | Rel-7 | Paolo |  |
| 964 | 276 | **Handover of dedicated and shared resources while in dual transfer mode** |  | 421d? | 2005-04-08 A | 2006-11-17 A | 100% |  | 2005-04-08 | 2006-11-17 | 421d? |  |  | GP | 12672h | 12672h | HODSRDTM | Nokia | rami.vaittinen@nokia.com | Rel-7 | Paolo |  |
| 965 | 276.1 | Handover of dedicated and shared resources while in dual transfer mode |  | 321d? | 2005-04-08 A | 2006-06-30 A | 100% |  | 2005-04-08 | 2006-06-30 | 321d? |  | finish no earlier than 2006-06-30 | G2 | 2568h | 2568h | HODSRDTM-G2 | Nokia | rami.vaittinen@nokia.com | Rel-7 | Juha |  |
| 966 | 276.2 | Deleted - MS Conformance Testing |  | 421d? | 2005-04-08 A | 2006-11-17 A | 100% |  | 2005-04-08 | 2006-11-17 | 421d? |  | finish no earlier than 2006-11-17 | G3new | 3368h | 3368h | HODSRDTM-Mstest | Nokia | rami.vaittinen@nokia.com | Rel-7 | Ingbert | GP-32 |
| 967 | 276.3 | Deleted - BTS conformance testing |  | 421d? | 2005-04-08 A | 2006-11-17 A | 100% |  | 2005-04-08 | 2006-11-17 | 421d? |  | finish no earlier than 2006-11-17 | G1 | 3368h | 3368h | HODSRDTM-BTStest | Nokia | rami.vaittinen@nokia.com | Rel-7 | Paolo | GP-32 |
| 968 | 277 | **Mobile Station Receive Diversity (DARP Phase II)** |  | 526d? | 2005-11-11 A | 2007-11-16 A | 100% |  | 2005-11-11 | 2007-11-16 | 526d? |  |  | GP | 16360h | 16360h | MSRD2 | Nokia | kent.pedersen@nokia.com | Rel-7 | Paolo |  |
| 969 | 277.1 | Performance Requirements for Mobile Station Receive Diversity, DARP Phase II |  | 331d? | 2005-11-11 A | 2007-02-16 A | 100% |  | 2005-11-11 | 2007-02-16 | 331d? |  | finish no earlier than 2007-02-16 | GP | 2648h | 2648h | MSRD2-PerfReq | Nokia | kent.pedersen@nokia.com | Rel-7 | Paolo |  |
| 970 | 277.2 | Capability signalling of Mobile Station Receive Diversity, DARP Phase II |  | 331d? | 2005-11-11 A | 2007-02-16 A | 100% |  | 2005-11-11 | 2007-02-16 | 331d? |  | finish no earlier than 2007-02-16 | GP | 2648h | 2648h | MSRD2-CapSig | Nokia | kent.pedersen@nokia.com | Rel-7 | Paolo |  |
| 971 | 277.3 | Test Scenarios for Mobile Station Receive Diversity, DARP Phase II |  | 331d? | 2005-11-11 A | 2007-02-16 A | 100% |  | 2005-11-11 | 2007-02-16 | 331d? |  | finish no earlier than 2007-02-16 | GP | 2648h | 2648h | MSRD2-TestSc | Nokia | kent.pedersen@nokia.com | Rel-7 | Paolo |  |
| 972 | 277.4 | MS conformance test of DARP Phase II (MSRD) |  | 526d? | 2005-11-11 A | 2007-11-16 A | 100% |  | 2005-11-11 | 2007-11-16 | 526d? |  | finish no earlier than 2007-11-16 | GP | 4208h | 4208h | MSRD2-Msconf | Nokia | kent.pedersen@nokia.com | Rel-7 | Ingbert |  |
| 973 | 278 | **Downlink Dual Carrier** |  | 1066d? | 2006-01-20 A | 2010-02-19 | 67% | 355.5d? | 2006-01-20 | 2010-02-19 | 1066d? | 15d |  | GP | 17350.6h | 11564.3h | GDCDL | Nokia Siemens Networks | leonardo.provvedi@roke.co.uk | Rel-7 | Paolo |  |
| 974 | 278.1 | Downlink Dual Carrier Stage 2 |  | 116d? | 2006-01-20 A | 2006-06-30 A | 100% |  | 2006-01-20 | 2006-06-30 | 116d? |  | finish no earlier than 2006-06-30 | G1 | 928h | 928h | GDCDL-Stage2 | Nokia Siemens Networks | leonardo.provvedi@roke.co.uk | Rel-7 | Paolo |  |
| 975 | 278.2 | Downlink Dual Carrier Stage 3 |  | 421d? | 2006-01-20 A | 2007-08-31 A | 100% |  | 2006-01-20 | 2007-08-31 | 421d? |  | finish no earlier than 2007-08-31 | G1 | 3368h | 3368h | GDCDL-Stage2 | Nokia Siemens Networks | leonardo.provvedi@roke.co.uk | Rel-7 | Paolo |  |
| 976 | 278.3 | Downlink Dual Carrier – MS Conformance Test |  | 565.83d? | 2006-01-20 A | 2010-02-19 | 35% | 367.79d? | 2006-01-20 | 2010-02-19 | 565.83d? | 15d | finish no earlier than 2010-02-19 | G3new | 4526.6h | 1584.31h | GDCDL-Stage3 | Nokia Siemens Networks | leonardo.provvedi@roke.co.uk | Rel-7 | Ingbert |  |
| 977 | 279 | Support of SIGTRAN in GERAN |  | 116d? | 2006-01-20 A | 2006-06-30 A | 100% |  | 2006-01-20 | 2006-06-30 | 116d? |  | finish no earlier than 2006-06-30 | G3new | 928h | 928h | GDCDL-MStest | Ericsson | peter.ostrup@ericsson.com | Rel-7 | Paolo |  |

Notes:
- 950: Text3: 24.008, 43.022, 44.018, 44.118, 45, 001, 45.005, 51.010, 51.021
- 951: Completed / Text3: 24.008, 43.022, 44.018, 44.118, 45, 001, 45.005,
- 952: Text3: 51.021
- 953: Text3: 51.010
- 954: Originally started Nov. 2003 as GP-030443
- 957: Text3: 43.955, 43.064, 44.060, 45.001, 45.002, 45.003, 45.005, 45.010, 51.010, 51.021
- 960: Text3: 45.005, 45.050, 24.008, 45.008, 45.001, 43.022, 43.030, 44.018, 44.060, 51.010-1, 51.021
- 961: Text3: 45.005, 45.050, 24.008, 45.008, 45.001, 43.022, 43.030, 44.018, 44.060
- 962: Text3: 51010-1
- 963: Text3: 51021
- 964: GP#30 completed. Started at GP#24
- 965: GP#30 completed / Text3: 43.055, 44.018, 44.060
- 966: Stopped, no work done. 12/2008 Marked as stopped ("deleted") / Text3: 51-010
- 967: Stopped, no work done. 12/2008 Marked as stopped ("deleted") / Text3: 51.026
- 968: GP#36 completed / Text3: 24.008, 45.005, 51.010
- 969: GP#33 completed / Text3: 45.005
- 970: GP#33 completed / Text3: 24.008
- 971: GP#33 completed / Text3: 45.005
- 972: GP#36 completed / Text3: 51.010
- 973: GP#30 completed / Text3: 24.008, 43.055, 43.064, 44.018, 44.060, 45.001, 45.002, 45.005, 45.008, 51.010
- 974: GP#35 completed / Text3: 43.055, 43.064
- 975: GP#35 completed / Text3: 24.008, 44.018, 44.060, 45.001, 45.002, 45.005, 45.008
- 976: GP#41 completion 09/09=>02/10. GP#40 completion 11/08=>09/09 / Text3: 51.010
- 977: GP#30 completed / Text3: 48.001, 48.006, 43.059, 49.031

| ID | WBS | Task | Type | Duration | Start | Finish | Complete | Remaining | Baseline start | Baseline finish | Baseline duration | Total slack | Constraint | Resources | Work | Actual work | Text1 | Text4 | Text5 | Text6 | Text8 | Text12 |
| --- | --- | --- | --- | --- | --- | --- | --- | --- | --- | --- | --- | --- | --- | --- | --- | --- | --- | --- | --- | --- | --- | --- |
| 978 | 280 | **Latency Reductions** |  | 306d? | 2006-06-30 A | 2007-08-31 A | 100% |  | 2006-06-30 | 2007-08-31 | 306d? |  |  | GP | 7344h | 7344h | LATRED | Ericsson | Hakan.Persson@Ericsson.com | Rel-7 | Paolo |  |
| 979 | 280.1 | Improved Ack/Nack reporting |  | 306d? | 2006-06-30 A | 2007-08-31 A | 100% |  | 2006-06-30 | 2007-08-31 | 306d? |  | finish no earlier than 2007-08-31 | G2 | 2448h | 2448h | LATRED-ACKNAR | Ericsson | Hakan.Persson@Ericsson.com | Rel-7 | Juha |  |
| 980 | 280.2 | Reduced TTI |  | 306d? | 2006-06-30 A | 2007-08-31 A | 100% |  | 2006-06-30 | 2007-08-31 | 306d? |  | finish no earlier than 2007-08-31 | G2 | 2448h | 2448h | LATRED-REDTTI | Ericsson | Hakan.Persson@Ericsson.com | Rel-7 | Juha |  |
| 981 | 281 | PS Handover between GERAN/UTRAN mode and GAN Mode |  | 166d? | 2006-06-30 A | 2007-02-16 A | 100% |  | 2006-06-30 | 2007-02-16 | 166d? |  | finish no earlier than 2007-02-16 | G2 | 1328h | 1328h | GUGAN | Ericsson | John.Diachina@Ericsson.com | Rel-7 | Juha |  |
| 982 | 282 | **Higher Uplink performance for GERAN Evolution** |  | 516d? | 2006-09-08 A | 2008-08-29 A | 100% |  | 2006-09-08 | 2008-08-29 | 516d? |  |  | GP | 15440h | 15440h | HUGE | Nokia Siemens Networks, Ericsson | eddie.riddington@nokia.com, stefan.g.eriksson@ericsson.com | Rel-7 | Paolo |  |
| 983 | 282.1 | Stage 2 of HUGE |  | 261d? | 2006-09-08 A | 2007-09-07 A | 100% |  | 2006-09-08 | 2007-09-07 | 261d? |  | finish no earlier than 2007-09-07 | G1 | 2088h | 2088h | HUGE-Stage2 | Nokia Siemens Networks, Ericsson | eddie.riddington@nokia.com, stefan.g.eriksson@ericsson.com | Rel-7 | Paolo |  |
| 984 | 282.2 | Layer 1 Support of HUGE |  | 381d? | 2006-09-08 A | 2008-02-22 A | 100% |  | 2006-09-08 | 2008-02-22 | 381d? |  | finish no earlier than 2008-02-22 | G1 | 3048h | 3048h | HUGE-Layer1 | Nokia Siemens Networks, Ericsson | eddie.riddington@nokia.com, stefan.g.eriksson@ericsson.com | Rel-7 | Paolo |  |
| 985 | 282.3 | Layer 2/3 Support of HUGE |  | 256d? | 2006-09-08 A | 2007-08-31 A | 100% |  | 2006-09-08 | 2007-08-31 | 256d? |  | finish no earlier than 2007-08-31 | G2 | 2048h | 2048h | HUGE-Layer23 | Nokia Siemens Networks, Ericsson | eddie.riddington@nokia.com, stefan.g.eriksson@ericsson.com | Rel-7 | Juha |  |
| 986 | 282.4 | Performance requirements |  | 516d? | 2006-09-08 A | 2008-08-29 A | 100% |  | 2006-09-08 | 2008-08-29 | 516d? |  | finish no earlier than 2008-08-29 | G1 | 4128h | 4128h | HUGE-Perfreq | Nokia Siemens Networks, Ericsson | eddie.riddington@nokia.com, stefan.g.eriksson@ericsson.com | Rel-7 | Paolo |  |
| 987 | 283 | **HUGE Conformance Testing** |  | 901d? | 2006-09-08 A | 2010-02-19 | 44% | 501.12d? | 2006-09-08 | 2010-02-19 | 901d? | 15d |  | GP | 20024h | 5838.55h | HUGE | Nokia Siemens Networks, Ericsson | eddie.riddington@nokia.com, stefan.g.eriksson@ericsson.com | Rel-7 | Paolo |  |
| 988 | 283.1 | MS Conformance Test |  | 901d? | 2006-09-08 A | 2010-02-19 | 5% | 855.95d? | 2006-09-08 | 2010-02-19 | 901d? | 15d | finish no earlier than 2010-02-19 | G3new | 7208h | 360.4h | HUGE-Mstest | Nokia Siemens Networks, Ericsson | eddie.riddington@nokia.com, stefan.g.eriksson@ericsson.com | Rel-7 | Ingbert |  |
| 989 | 283.2 | BTS Conformance Test |  | 701d? | 2006-09-08 A | 2009-05-15 | 95% | 35.05d? | 2006-09-08 | 2009-05-15 | 701d? | 215d | finish no earlier than 2009-05-15 | G1 | 5608h | 5327.6h | HUGE-BTStest | Nokia Siemens Networks, Ericsson | eddie.riddington@nokia.com, stefan.g.eriksson@ericsson.com | Rel-7 | Paolo |  |
| 990 | 284 | **REduced symbol Duration, Higher Order modulation and Turbo coding (RED HOT) for downlink** |  | 391d? | 2006-11-17 A | 2008-05-16 A | 100% |  | 2006-11-17 | 2008-05-16 | 391d? |  |  | GP | 7904h | 7904h | REDHOT | Ericsson, Nokia Siemens Networks, Marvell | stefan.g.eriksson@ericsson.com | Rel-7 | Paolo |  |
| 991 | 284.1 | Stage 2 for REDHOT |  | 206d? | 2006-11-17 A | 2007-08-31 A | 100% |  | 2006-11-17 | 2007-08-31 | 206d? |  | finish no earlier than 2007-08-31 | G1 | 1648h | 1648h | REDHOT-Stage2 | Ericsson, Nokia Siemens Networks, Marvell | stefan.g.eriksson@ericsson.com | Rel-7 | Paolo |  |
| 992 | 284.2 | Stage 3 for REDHOT |  | 391d? | 2006-11-17 A | 2008-05-16 A | 100% |  | 2006-11-17 | 2008-05-16 | 391d? |  | finish no earlier than 2008-05-16 | G1 | 3128h | 3128h | REDHOT-Stage3 | Ericsson, Nokia Siemens Networks, Marvell | stefan.g.eriksson@ericsson.com | Rel-7 | Paolo |  |
| 993 | 285 | **REDHOT Conformance Testing** |  | 851d? | 2006-11-17 A | 2010-02-19 | 44% | 476.49d? | 2006-11-17 | 2010-02-19 | 851d? | 15d |  | GP | 18824h | 5343.47h | REDHOT | Ericsson, Nokia Siemens Networks, Marvell | stefan.g.eriksson@ericsson.com | Rel-7 | Paolo |  |
| 994 | 285.1 | MS Conformance Tests |  | 851d? | 2006-11-17 A | 2010-02-19 | 5% | 808.45d? | 2006-11-17 | 2010-02-19 | 851d? | 15d | finish no earlier than 2010-02-19 | G3new | 6808h | 340.4h | REDHOT-Mstest | Ericsson | stefan.g.eriksson@ericsson.com | Rel-7 | Ingbert |  |
| 995 | 285.2 | BTS Conformance Tests |  | 651d? | 2006-11-17 A | 2009-05-15 | 95% | 32.55d? | 2006-11-17 | 2009-05-15 | 651d? | 215d | finish no earlier than 2009-05-15 | G1 | 5208h | 4947.6h | REDHOT-BTStest | Ericsson, Nokia Siemens Networks, Marvell | stefan.g.eriksson@ericsson.com | Rel-7 | Paolo |  |
| 996 | 286 | (Small) Technical Enhancements and Improvements for Rel-7 | milestone | 0d? | 2007-03-26 A | 2007-03-26 A | 100% |  | 2007-03-26 | 2007-03-26 | 0d? |  | start no earlier than 2007-03-26 | All |  |  | TEI7 |  |  | Rel-7 |  |  |
| 997 | 287 | **Deleted - PS domain and IMS support for IMS Emergency sessions** |  | 63.69d? | 2006-06-23 A | 2006-09-21 A | 100% |  | 2006-06-23 | 2006-09-21 | 63.69d? |  |  | S2 |  |  | IMS-EMER | Nokia | curt.c.wong@nokia.com | Rel-7 | Maurice | SP-30 |
| 998 | 287.1 | Deleted - IMS aspects to support IMS Emergency sessions | milestone | 0d? | 2006-06-23 A | 2006-09-21 A | 100% |  | 2006-06-23 | 2006-09-21 | 0d? |  | start no earlier than 2006-06-23 | S2 |  |  | IMS-EMER | Nokia | curt.c.wong@nokia.com | Rel-7 | Maurice | SP-30 |
| 999 | 287.2 | Deleted - PS domain aspects to support IMS Emergency sessions | milestone | 0d? | 2006-06-23 A | 2006-09-21 A | 100% |  | 2006-06-23 | 2006-09-21 | 0d? |  | start no earlier than 2006-06-23 | S2 |  |  | IMS-EMER | Nokia | curt.c.wong@nokia.com | Rel-7 | Maurice | SP-30 |
| 1000 | 288 | Deleted - Covered by SI - Personal Network (PN) and Personal Area Network (PAN) | milestone | 0d? | 2005-12-08 A | 2005-12-20 A | 100% |  | 2005-12-08 | 2005-12-20 | 0d? |  | start no earlier than 2005-12-08 | S1 |  |  | PNPAN | Vodafone | armin.toepfer@vodafone.com | Rel-7 | Alain | SP-30 |
| 1001 | 289 | Deleted - Covered by SI - Multimedia Telephony Capabilities for IMS | milestone | 0d? | 2005-12-08 A | 2005-12-20 A | 100% |  | 2005-12-08 | 2005-12-20 | 0d? |  | start no earlier than 2005-12-08 | S1 |  |  | MITE | Ericsson | peter.bleckert@ericsson.com | Rel-7 | Alain | SP-30 |
| 1002 | 290 | Deleted - Covered by SI - Transferring of emergency Call data | milestone | 0d? | 2005-12-08 A | 2005-12-08 A | 100% |  | 2005-12-08 | 2005-12-08 | 0d? |  | start no earlier than 2005-12-08 | S1 |  |  | eCALL | Motorola | steven.vardy@motorola.com | Rel-7 | Alain | SP-30 |
| 1003 | 291 | Deleted - Covered by SI - MBMS Enhancements | milestone | 0d? | 2005-12-08 A | 2005-12-08 A | 100% |  | 2005-12-08 | 2005-12-08 | 0d? |  | start no earlier than 2005-12-08 | S1 |  |  | MBMSE | China Mobile | liuhongyfw@chinamobile.com | Rel-7 | Alain | SP-30 |

Notes:
- 978: GP#35 completed / Text3: 45.001, 45.002, 45.003, 45.005, 45.010, 43.055, 43.064, 44.060, 51.010-1, 51.021
- 979: GP#35 completed / Text3: 45.001, 45.002, 45.003, 45.005, 45.010, 43.055, 43.064, 44.060, 51.010-1, 51.021
- 980: GP#35 completed / Text3: 45.001, 45.002, 45.003, 45.005, 45.010, 43.055, 43.064, 44.060, 51.010-1, 51.021
- 981: GP#33 completed / Text3: 43.318, 44.318, 43.129, 25.306, 24.008, 44.060, 25.331, 51.010
- 982: GP#39 completed. SA#42 split core from testing specification work. / Text3: 24.008, 43.055, 43.064, 44.018, 44.060, 45.001, 45.002, 45.003, 45.004, 45.005, 45.008, 45.010, 51.010, 51.021
- 983: GP#35 completed / Text3: 43.055, 43.064
- 984: GP#37 completed / Text3: 45.001, 45.002, 45.003, 45.004, 45.008
- 985: GP#35 completed / Text3: 24.008, 44.018, 44.060
- 986: GP#39 completed / Text3: 45.005
- 987: GP#40 Target completion 05/08=>11/08=>02/09. SA#42 split core from testing specification work. / Text3: 24.008, 43.055, 43.064, 44.018, 44.060, 45.001, 45.002, 45.003, 45.004, 45.005, 45.008, 45.010, 51.010, 51.021
- 988: GP#40 target 02/09=>02/10. GP#40 target 05/08=>02/09 / Text3: 51.010
- 989: GP#41 completion 02/09=>05/09. GP#40 completion 05/08=>11/08=>02/09 / Text3: 51.021
- 990: GP#38 completed. SA#42 split core from testing specification work. / Text3: 24.008, 43.064, 43.055, 44.018, 44.060, 45.001, 45.002, 45.003, 45.004, 45.005, 45.008, 51.010, 51.021
- 991: GP#35 completed / Text3: 43.055, 43.064
- 992: GP#38 completed / Text3: 24.008, 44.018, 44.060, 45.001, 45.002, 45.003, 45.004, 45.005, 45.008
- 993: GP#40 completion target 05/08=>11/08=>02/09. SA#42 split core from testing specification work. / Text3: 24.008, 43.064, 43.055, 44.018, 44.060, 45.001, 45.002, 45.003, 45.004, 45.005, 45.008, 51.010, 51.021
- 994: GP#41 completion 02/09=>02/10. GP#40 completion 08/08=>02/09 / Text3: 51.010
- 995: GP#41 completion 02/09=>05/09. GP#40 completion 05/08=>11/08=>02/09 / Text3: 51.021
- 996: Text3: CP-070260
- 997: Approved at SA#29 / Text3: 23.867, 23.abc, 23.060, 23.002, 23.271
- 998: Approved at SA#29 / Text3: 23.867, 23.abc, 23.060, 23.002, 23.271
- 999: Approved at SA#29 / Text3: 23.867, 23.abc, 23.060, 23.002, 23.271

| ID | WBS | Task | Type | Duration | Start | Finish | Complete | Baseline start | Baseline finish | Baseline duration | Total slack | Constraint | Resources | Work | Actual work | Text1 | Text6 | Text8 | Text12 | Text3 | Text4 | Text5 | Text11 |
| --- | --- | --- | --- | --- | --- | --- | --- | --- | --- | --- | --- | --- | --- | --- | --- | --- | --- | --- | --- | --- | --- | --- | --- |
| 1004 | 292 | **Deleted - VoIMS bearer related enhancements** |  | 0d? | 2006-07-21 A | 2006-07-21 A | 100% | 2006-07-21 | 2006-07-21 | 0d? |  |  | S2 |  |  | VoIMS | Rel-7 | Maurice | SP-32 |  |  |  |  |
| 1005 | 292.1 | Deleted - FS on enhancement of radio performance for VoIMS | milestone | 0d? | 2006-07-21 A | 2006-07-21 A | 100% | 2006-07-21 | 2006-07-21 | 0d? |  | start no earlier than 2006-07-21 | S2 |  |  | VoIMS | Rel-7 | Maurice | SP-32 | 23.807 | Nortel | Laurence Lautier (lautierl@nortel.com) |  |
| 1006 | 293 | Release 7 Feasibility Studies |  | 1d? | 2000-01-03 | 2000-01-03 |  | 2000-01-03 | 2000-01-03 | 1d? | 2659d |  | CP,GP, RP,SP | 8h |  |  | Rel-7 |  |  |  |  |  |  |
| 1007 | 294 | **Study on Multimedia Telephony Capabilities for IMS** |  | 276d? | 2005-07-11 A | 2006-07-31 A | 100% | 2005-07-11 | 2006-07-31 | 276d? |  |  | S1 | 4353.6h | 4353.6h | MITE | Rel-7 | Alain |  | 22.973 | Ericsson | peter.bleckert@ericsson.com |  |
| 1008 | 294.1 | Deleted covered by UID_31082 - Study of (MITe) - IMS Multimedia Telephony Communication Enabler and supplementary services |  | 276d? | 2005-07-11 A | 2006-07-31 A | 100% | 2005-07-11 | 2006-07-31 | 276d? |  | start no earlier than 2005-07-11 | S1 | 2208h | 2208h | MITE | Rel-7 | Alain | SP-28 | 22.973 | Ericsson | peter.bleckert@ericsson.com |  |
| 1009 | 295 | Study on Behaviour of Multi system UEs |  | 384d? | 2004-06-28 A | 2005-12-15 A | 100% | 2004-06-28 | 2005-12-15 | 384d? |  | start no earlier than 2004-06-28 | S1 | 3072h | 3072h | BMSU | Rel-7 | Alain |  | 22.936 | Qualcomm | dwilliams@qualcomm.com |  |
| 1010 | 296 | Study on Combining CS calls and IMS sessions |  | 189d? | 2004-06-28 A | 2005-03-17 A | 100% | 2004-06-28 | 2005-03-17 | 189d? |  | start no earlier than 2004-06-28 | S1 | 1512h | 1512h | IRTSD-CS_IMS | Rel-7 | Alain |  | 22.979 |  | Robert Frank |  |
| 1011 | 297 | Study on All-IP Network |  | 188d? | 2004-06-28 A | 2005-03-16 A | 100% | 2004-06-28 | 2005-03-16 | 188d? |  | start no earlier than 2004-06-28 | S1 | 1504h | 1504h | FS_AIPN | Rel-7 | Alain |  | 22.978 | NTT DoCoMo | c.masyu@nttdocomo.co.jp |  |
| 1012 | 298 | Study on Videotelephony teleservice |  | 231d? | 2005-03-01 A | 2006-01-17 A | 100% | 2005-03-01 | 2006-01-17 | 231d? |  |  | S1 | 1848h | 1848h | VidTel | Rel-7 | Alain |  | 22.903 | T-Mobile | kurt.bischinger@t-mobile.at |  |
| 1013 | 299 | Study on Network Selection Principles |  | 193d? | 2005-03-15 A | 2005-12-08 A | 100% | 2005-03-15 | 2005-12-08 | 193d? |  |  | S1 | 1544h | 1544h | NetSel | Rel-7 | Alain |  | 22.811 | O2 | chris.friel@o2.com |  |
| 1014 | 300 | Study on Multimedia Priority Service |  | 851d? | 2003-03-28 A | 2006-06-30 A | 100% | 2003-03-28 | 2006-06-30 | 851d? |  | finish no earlier than 2005-12-16 | S1 | 6808h | 6808h | PRIOR-MM | Rel-7 | Alain |  | 22.953 | Telcordia | jgarraha@telcordia.com |  |
| 1015 | 301 | Study on Transferring of emergency Call data |  | 190d? | 2005-07-11 A | 2006-03-31 A | 100% | 2005-07-11 | 2006-03-31 | 190d? |  | finish no earlier than 2005-12-08 | S1 | 1520h | 1520h | eCALL | Rel-7 | Alain |  | 22.967 | Motorola | steven.vardy@motorola.com |  |
| 1016 | 302 | Study on Enhancement of E2E QoS |  | 281.4d? | 2004-06-28 A | 2005-09-15 A | 100% | 2004-06-28 | 2005-09-15 | 281.4d? |  | finish no earlier than 2005-12-01 | S2 | 2251.2h | 2251.2h | QoS7 | Rel-7 | Maurice |  | 23.802 | Huawei | Robert Jaksa |  |
| 1017 | 303 | Study on Bandwidth Saving at Nb Interface with IP transport |  | 261d? | 2006-03-10 A | 2007-03-09 A | 100% | 2006-03-10 | 2007-03-09 | 261d? |  | finish no earlier than 2007-03-09 | C3 | 2088h | 2088h | BSNbIP | Rel-7 | Gwiho |  | 29.814 | Siemens | Thomas.Belling@nsn.com |  |
| 1018 | 304 | Study on Routeing of MT-SMs via the HPLMN |  | 301d? | 2005-10-07 A | 2006-12-01 A | 100% | 2005-10-07 | 2006-12-01 | 301d? |  | finish no earlier than 2006-12-01 | C4 | 2408h | 2408h | SMS7 | Rel-7 | Kimmo |  | 23.840 | Vodafone | Nick.Russell@vodafone.com |  |
| 1019 | 305 | Study on the TCAPsec Gateway concept |  | 96d? | 2005-10-28 A | 2006-03-10 A | 100% | 2005-10-28 | 2006-03-10 | 96d? |  | finish no earlier than 2006-03-10 | C4 | 768h | 768h | SEC7-TCAP | Rel-7 | Kimmo |  | 29.800 | Siemens | Ulrich.wiehe@gksag.de |  |
| 1020 | 306 | Study on using M2PA in 3GPP network |  | 318d? | 2006-03-22 A | 2007-06-08 A | 100% | 2006-03-22 | 2007-06-08 | 318d? |  | finish no earlier than 2007-06-08 | C4 | 2544h | 2544h | FS-M2PA | Rel-7 | Kimmo |  | 29.801 | China Mobile | zhaoyuyi@chinamobile.com |  |
| 1021 | 307 | **Study on Support of (G)MSC-S - (G)MSC-S Nc Interface based on the SIP-I protocol** |  | 350d? | 2006-05-15 A | 2007-09-14 A | 100% | 2006-05-15 | 2007-09-14 | 350d? |  |  | C4 | 7800h | 7800h | NcSIP | Rel-7 | Kimmo |  | 29.802 | Vodafone | david.hutton@vodafone.com |  |
| 1022 | 307.1 | CT4 aspects of NcSIP |  | 275d? | 2006-05-15 A | 2007-06-01 A | 100% | 2006-05-15 | 2007-06-01 | 275d? |  | finish no earlier than 2007-06-01 | C4 | 2200h | 2200h | NcSIP | Rel-7 | Kimmo |  | 29.802 | Vodafone | david.hutton@vodafone.com |  |
| 1023 | 307.2 | CT3 aspects of NcSIP |  | 350d? | 2006-05-15 A | 2007-09-14 A | 100% | 2006-05-15 | 2007-09-14 | 350d? |  | finish no earlier than 2007-09-14 | C3 | 2800h | 2800h | NcSIP | Rel-7 | Gwiho |  | 29.802 | Ericsson | ragnar.huslende@ericsson.com |  |
| 1024 | 308 | Study on SOAP/HTTP IRP Solution Sets |  | 330d? | 2005-09-02 A | 2006-12-07 A | 100% | 2005-09-02 | 2006-12-07 | 330d? |  | finish no earlier than 2006-12-07 | S5 | 2640h | 2640h | OAM7-NIM-XML | Rel-7 | Dionisio |  | 32.809 | Nortel |  |  |
| 1025 | 309 | Study on Itf-N Implementation Conformance Statement (ICS) template |  | 400d? | 2005-09-02 A | 2007-03-15 A | 100% | 2005-09-02 | 2007-03-15 | 400d? |  | finish no earlier than 2007-03-15 | S5 | 3200h | 3200h | OAM7-NIM-ICS | Rel-7 | Dionisio |  | 32.812 | China Mobile |  |  |
| 1026 | 310 | Study on IRP Information Model |  | 400d? | 2005-09-02 A | 2007-03-15 A | 100% | 2005-09-02 | 2007-03-15 | 400d? |  | finish no earlier than 2007-03-15 | S5 | 3200h | 3200h | OAM7-NIM-IM | Rel-7 | Dionisio |  | 32.810 | Motorola |  |  |
| 1027 | 311 | Study on Evolved UTRA and UTRAN |  | 458d? | 2004-12-15 A | 2006-09-15 A | 100% | 2004-12-15 | 2006-09-15 | 458d? |  | finish no earlier than 2006-09-15 | RP | 3664h | 3664h | RANFS-Evo | Rel-7 | Stefania |  | 25.912 | NTT DoCoMo | nakamurata@NTTDOCOMO.CO.JP | RP-060472 |
| 1028 | 312 | Study on Performance Evaluation of the UE behaviour in high speed trains with speeds up to 350 kmph |  | 328d? | 2005-03-15 A | 2006-06-15 A | 100% | 2005-03-15 | 2006-06-15 | 328d? |  | finish no earlier than 2006-06-15 | R4 | 2624h | 2624h | RANFS-HSTrains | Rel-7 | Stefania |  | none | Vodafone | Mike.vogel@vodafone.com,tim.frost@vodafone.com | RP-060412 |
| 1029 | 313 | Study on UTRA Tower Mounted Amplifier (FDD) |  | 195d? | 2005-06-15 A | 2006-03-14 A | 100% | 2005-06-15 | 2006-03-14 | 195d? |  | finish no earlier than 2006-03-15 | R4 | 1560h | 1560h | RANFS-TMA | Rel-7 | Stefania |  | 25.818 | Ericsson | Klas.Sjerling@ericsson.com | RP-060035 |
| 1030 | 314 | Study on Continuous connectivity for packet data users |  | 132d? | 2005-03-15 A | 2005-09-15 A | 100% | 2005-03-15 | 2005-09-15 | 132d? |  | finish no earlier than 2005-09-15 | R1 | 1056h | 1056h | RANFS-cont-packet | Rel-7 | Patrick |  | none | Siemens | joerg.gustrau@siemens.com | RP-050427 |
| 1031 | 315 | Study on Improvement of the Multimedia Broadcast Multicast Service (MBMS) in UTRAN |  | 262d? | 2005-12-15 A | 2006-12-15 A | 100% | 2005-12-15 | 2006-12-15 | 262d? |  | finish no earlier than 2006-12-15 | R2 | 2096h | 2096h | RANFS-MBMSImp | Rel-7 | Joern |  | 25.905 | LG Electronics | leego@lge.com | RP-060692 |
| 1032 | 316 | Study on Performance Improvements in Small Cells using HSDPA/EDCH |  | 131d? | 2005-12-15 A | 2006-06-15 A | 100% | 2005-12-15 | 2006-06-15 | 131d? |  | finish no earlier than 2006-06-15 | R4 | 1048h | 1048h | SMALLCELLS | Rel-7 | Stefania |  | none | Cingular | Marc Grant | RP-060263 |
| 1033 | 317 | Study on Further Improved Performance Requirements for UMTS/HSDPA UE (FDD) |  | 383d? | 2005-12-15 A | 2007-06-04 A | 100% | 2005-12-15 | 2007-06-04 | 383d? |  | finish no earlier than 2007-06-04 | R4 | 3064h | 3064h | RANFS-IC | Rel-7 | Stefania |  | 25.963 | Cingular | Marc Grant | RP-070499 |
| 1034 | 318 | Study on Scope of future FDD HSPA Evolution |  | 394d? | 2006-03-15 A | 2007-09-17 A | 100% | 2006-03-15 | 2007-09-17 | 394d? |  | finish no earlier than 2007-09-17 | RP | 3152h | 3152h | RANFS-HSPAEvo | Rel-7 | Stefania |  | 25.999 | Cingular | Don Zelmer (dz1069@att.com) | RP-070533 |
| 1035 | 319 | Study on Dynamically reconfiguring a FDD UE receiver to reduce power consumption when desired Quality of Service is met | milestone | 0d? | 2007-06-22 A | 2007-06-22 A | 100% | 2007-06-22 | 2007-06-22 | 0d? |  |  | R4 |  |  | FSUEPow | Rel-7 | Stefania |  | 25.906 | Nokia | Chris.callender@nokia.com, tiina.s.koskinen@nokia.com | RP-070534 |
| 1036 | 320 | Study on Future GERAN Evolution |  | 486d? | 2005-04-08 A | 2007-02-16 A | 100% | 2005-04-08 | 2007-02-16 | 486d? |  | finish no earlier than 2007-02-16 | GP | 3888h | 3888h | FGE | Rel-7 | Paolo |  | 45.912 | Nokia | eddie.riddington@nokia.com |  |
| 1037 | 321 | Study on GAN Enhancements | milestone | 0d? | 2007-08-31 A | 2007-08-31 A | 100% | 2007-08-31 | 2007-08-31 | 0d? |  | start no earlier than 2007-08-31 | GP |  |  | EGAN | Rel-7 | Paolo |  | 43.902 | T-Mobile | janne.linkola@t-mobile.com |  |
| 1038 | 322 | Deleted - covered by UID33027 - IMS security extensions | milestone | 0d? | 2005-12-08 A | 2005-12-08 A | 100% | 2005-12-08 | 2005-12-08 | 0d? |  | start no earlier than 2005-12-08 | S3 |  |  | IMS-SE | Rel-7 | Dionisio | SP-30 |  | Ericsson | Bengt.Sahlin@ericsson.com |  |
| 1039 | 323 | Deleted - covered by 32108 - Study of work on an LCS architecture for I-WLAN | milestone | 0d? | 2006-12-08 A | 2006-12-08 A | 100% | 2006-12-08 | 2006-12-08 | 0d? |  | start no earlier than 2006-12-08 | S2 |  |  | IMS-SE | Rel-7 | Maurice | SP-33 |  | LG Electronics | Donghee Shim dhshim@lge.com ; phede@lge.com |  |

Notes:
- 1004: Created by MCC to group all VoIMS related items, after consultation of chairs
- 1005: WID approved SA#28: SA2#52: CLOSED - To be removed from the work plan
- 1007: Spin-off Feature UID_7038 (MTSI)
- 1008: Duplicate entry with 31082
- 1011: 25/07/08 Moved as FS to Rel-7 out of the stopped Rel-8 Feature UID_31067 Deleted - All-IP Network (AIPN)
- 1013: Spin-off Feature Network selection enhancements (NSP-CR) UID_7041
- 1014: Spin-off Feature PRIOR UID_340044
- 1017: Moved to FS at CT32 (in line with slides)
- 1018: Previously known as "Study of a SMS Centre for MT SMS"
- 1019: TR 29.800 content moved to TS 29.204 under implementation WI UID_310005 TCAPsec Gateway
- 1024: SA#34 completed
- 1025: SA#35 completed
- 1026: SA#35 completed
- 1027: RP#33 (Sep 2006) completed. SR in RP-060472
- 1028: RP#32 (Jun 2006) completed. SR in RP-060412
- 1029: RP#31 (Mar 2006) completed. SR in RP-060035
- 1030: RP#29 (Sep 2006) completed. SR in RP-050427
- 1031: RP#34 (Dec 2006) completed. SR in RP-060692
- 1032: RP#32 (Jun 2006) closed (no progress). SR in RP-060263
- 1033: RP#36 (May 2007) completed. SR in RP-070499
- 1034: RP#37 (Sep 2007) completed. SR in RP-070533
- 1035: RP#37 (Sep 2007) completed. SR in RP-070534
- 1036: GP#33 completed
- 1037: GP#35 completed
- 1039: S2#52: Entry created

| ID | WBS | Task | Type | Duration | Start | Finish | Complete | Baseline start | Baseline finish | Baseline duration | Total slack | Constraint | Resources | Work | Actual work | Text1 | Text6 | Text8 | Text12 | Text3 | Text4 | Text5 |
| --- | --- | --- | --- | --- | --- | --- | --- | --- | --- | --- | --- | --- | --- | --- | --- | --- | --- | --- | --- | --- | --- | --- |
| 1040 | 324 | **Deleted: Study on applicability of GALILEO for LCS** |  | 0d? | 2005-06-30 A | 2005-06-30 A | 100% | 2005-06-30 | 2005-06-30 | 0d? |  |  | S2 |  |  | Galileo | Rel-7 | Maurice | SP-25 |  |  |  |
| 1041 | 324.1 | Deleted - TR on Stage 2 | milestone | 0d? | 2005-06-30 A | 2005-06-30 A | 100% | 2005-06-30 | 2005-06-30 | 0d? |  | finish no earlier than 2005-06-30 | S2 |  |  | Galileo | Rel-7 | Maurice | SP-25 |  |  |  |
| 1042 | 324.2 | Deleted - GERAN review of the TR | milestone | 0d? | 2005-06-30 A | 2005-06-30 A | 100% | 2005-06-30 | 2005-06-30 | 0d? |  | start no earlier than 2005-06-30 | GP |  |  | Galileo | Rel-7 | Paolo | SP-26 |  |  |  |
| 1043 | 16.7 | **Deleted - IMS Local services** |  | 0d? | 2006-01-06 A | 2006-01-06 A | 100% | 2006-01-06 | 2006-01-06 | 0d? |  |  | S2 |  |  | IMSLocal | Rel-7 | Maurice | SP-28 | 23.228 |  |  |
| 1044 | 16.7.1 | Deleted - Stage 2 | milestone | 0d | 2006-01-06 A | 2006-01-06 A | 100% | 2006-01-06 | 2006-01-06 | 0d |  | start no earlier than 2006-01-06 | S2 |  |  | IMSLocal | Rel-7 | Maurice | SP-26 |  |  |  |
| 1045 | 325.2 | Deleted - Stage 3 for IMS Local services | milestone | 0d? | 2006-01-06 A | 2006-01-06 A | 100% | 2006-01-06 | 2006-01-06 | 0d? |  | finish no earlier than 2006-01-06 | C1 |  |  | IMSLocal | Rel-7 | Frederic | SP-25 |  | Lucent | Keith Drage (drage@alcatel-lucent.com) |
| 1046 | 326 | Deleted - IMS Phase 3 | milestone | 0d? | 2006-01-06 A | 2006-01-06 A | 100% | 2006-01-06 | 2006-01-06 | 0d? |  | start no earlier than 2006-01-06 | S2 |  |  |  | Rel-7 | Maurice | SP-25 |  |  |  |
| 1047 | 327 | Deleted - Improvements of Radio Interface | milestone | 0d? | 2004-09-15 A | 2004-09-15 A | 100% | 2004-09-15 | 2004-09-15 | 0d? |  | start no earlier than 2004-09-15 | RP |  |  | RInImp | Rel-7 | Stefania | SP-24 |  |  |  |
| 1048 | 328 | Deleted: Generic User Profile Phase 2 | milestone | 0d | 2005-08-08 A | 2006-06-30 A | 100% | 2005-08-08 | 2006-06-30 | 0d |  |  | C4 |  |  |  | Rel-7 | Kimmo | SP-27 |  |  |  |
| 1049 | 30.4 | Deleted - Stage 3 - Common objects | milestone | 0d | 2005-08-08 A | 2006-06-30 A | 100% | 2005-08-08 | 2006-06-30 | 0d |  | finish no earlier than 2006-06-30 | C4 |  |  |  | Rel-7 | Kimmo | SP-27 | 24.241 |  |  |
| 1050 | 330 | Delete was duplicated- Study of Customised Alerting Tone (CAT) Requirements | milestone | 0d? | 2006-06-30 A | 2006-06-30 A | 100% | 2006-06-30 | 2006-06-30 | 0d? |  | start no earlier than 2006-06-30 | S1 |  |  | CAT | Rel-7 | Alain | SP-31 |  |  |  |
| 1051 | 331 | Deleted - FS of enhanced support of Video Telephony | milestone | 0d? | 2006-06-30 A | 2006-06-30 A | 100% | 2006-06-30 | 2006-06-30 | 0d? |  | start no earlier than 2006-06-30 | GP |  |  | VIDGER | Rel-7 | Paolo | SP-32 |  | Ericsson | stefan.g.eriksson@ericsson.com |
| 1052 | 332 | Deleted (moved to Rel8) - Study on Transferring of emergency call data – in-band modem solution | milestone | 0d? | 2007-06-22 A | 2007-06-22 A | 100% | 2007-06-22 | 2007-06-22 | 0d? |  | start no earlier than 2007-06-22 | S4 |  |  | eCALLIBMS | Rel-7 | Paolo | SP-38 | 26.967 | Airbiquity | lhong@airbiquity.com |
| 1053 | 333 | Deleted - covered by UID 20053 - Study on Interference Cancellation for UTRA FDD UE |  | 1d? | 2007-03-28 A | 2007-03-28 A | 100% | 2007-03-28 | 2007-03-28 | 1d? |  | start no earlier than 2007-03-28 | R4 | 8h | 8h | RANFS-InterfCanc | Rel-7 | Stefania | SP-38 |  |  |  |
| 1054 | 334 | Deleted - Study of Personal Network and Personal Area Network | milestone | 0d? | 2006-10-20 A | 2006-10-20 A | 100% | 2006-10-20 | 2006-10-20 | 0d? |  | finish no earlier than 2006-10-20 | S1 |  |  | PNPAN | Rel-7 | Alain | SP-31 |  |  |  |
| 1055 | 335 | Deleted - Study on IMS with real time services deployment |  | 316d? | 2004-06-28 A | 2005-09-12 A | 100% | 2004-06-28 | 2005-09-12 | 316d? |  |  | S1 | 2528h | 2528h | IRTSD | Rel-7 | Alain | SP-30 |  |  |  |
| 1056 | 336 | Deleted - Study on Stage 2 (IMS services using CS bearers) |  | 316d? | 2004-06-28 A | 2005-09-12 A | 100% | 2004-06-28 | 2005-09-12 | 316d? |  | finish no earlier than 2005-09-12 | S2 | 2528h | 2528h | IRTSD-IMSCS | Rel-7 | Maurice | SP-30 | 23.899 | Nortel | Mark Watson |
| 1057 | 337 | Deleted - Study on IMS enhancements and optimisations for real time communication. |  | 430d? | 2005-10-10 A | 2007-06-01 A | 100% | 2005-10-10 | 2007-06-01 | 430d? |  | finish no earlier than 2007-06-01 | S2 | 3440h | 3440h | IMS-RT | Rel-7 | Maurice | SP-35 | 23.818 | Ericsson | stephen.terrill@ericsson.com |
| 1058 | 338 | Deleted - Study on Terminating Session handling |  | 255d? | 2006-01-09 A | 2006-12-29 A | 100% | 2006-01-09 | 2006-12-29 | 255d? |  | finish no earlier than 2006-12-29 | S2 | 2040h | 2040h | CSIterm | Rel-7 | Maurice | SP-32 | 23.819 | Samsung |  |
| 1059 | 339 | Deleted - Study on IRP usage scenarios |  | 330d? | 2005-09-02 A | 2006-12-07 A | 100% | 2005-09-02 | 2006-12-07 | 330d? |  | finish no earlier than 2006-12-07 | S5 | 2640h | 2640h | OAM-Study | Rel-7 | Dionisio | SP-32 | 32.8xy | Lucent |  |
| 1060 | 340 | Release 6 Features |  | 1d? | 2000-01-03 | 2000-01-03 |  | 2000-01-03 | 2000-01-03 | 1d? | 2659d |  | CP,GP, RP,SP,TP | 8h |  |  | Rel-6 |  |  |  |  |  |
| 1061 | 8 | **Rel-6 Improvements of Radio Interface** |  | 1393d? | 2000-08-14 A | 2005-12-14 A | 100% | 2000-08-14 | 2005-12-14 | 1393d? |  |  | RP | 38664h | 38664h | RInImp | Rel-6 | Stefania |  |  |  |  |
| 1062 | 341.1 | Improved support of IMS Realtime Services using HSDPA/EDCH |  | 197d? | 2005-03-15 A | 2005-12-14 A | 100% | 2005-03-15 | 2005-12-14 | 197d? |  | finish no earlier than 2005-12-14 | R2 | 1576h | 1576h | RInImp-IMSRealTime | Rel-6 | Joern |  |  | Cingular | Don Zelmer (dz1069@att.com) |
| 1063 | 341.2 | Improving Receiver Performance Requirements for the FDD UE |  | 401d | 2002-03-08 A | 2003-09-19 A | 100% | 2002-03-08 | 2003-09-19 | 401d |  | start no earlier than 2002-03-08 | R4 | 3208h | 3208h | RInImp-UERecPerf | Rel-6 | Stefania |  | 25.101 | Intel | shimon.moshavi@INTEL.COM |

Notes:
- 1044: DAB - Not yet required in SA2 as it exists in previous releases
- 1047: Stage 2 description of Interim conclusion
- 1048: Created at TSG#27 by A. Sultan because of the move to Rel-7 of "Common Objects".
- 1049: No progress in CN4#26. This have to be moved to Rel-7. It was deleted from WID
- 1050: Awaiting MCC SA3 input
- 1051: FS CLOSED at G#28 (no input)
- 1052: SP-38 stopped
- 1053: Deleted. Same as FS on Further Improved Performance Requirements for UMTS/HSDPA UE (FDD)
- 1054: Moved from FS section Feb 06
- 1056: SP-30: S2 has no intention for TR completion
- 1057: abandoned at 65%
- 1058: SA#32 Jun 2006 Study abandoned => spin-off Implementation work UID_320029
- 1061: This is a generic feature without particular end date

| ID | WBS | Task | Duration | Start | Finish | Complete | Baseline start | Baseline finish | Baseline duration | Constraint | Resources | Work | Actual work | Text1 | Text6 | Text8 | Text3 | Text4 | Text5 | Text10 | Text12 |
| --- | --- | --- | --- | --- | --- | --- | --- | --- | --- | --- | --- | --- | --- | --- | --- | --- | --- | --- | --- | --- | --- |
| 1064 | 8.2 | **Base station classification** | 603d | 2000-08-14 A | 2002-12-04 A | 100% | 2000-08-14 | 2002-12-04 | 603d |  | R4 | 9648h | 9648h | RInImp-BSClass | Rel-6 | Stefania |  |  |  |  |  |
| 1065 | 8.2.1 | FDD Base station classification | 603d | 2000-08-14 A | 2002-12-04 A | 100% | 2000-08-14 | 2002-12-04 | 603d | finish no earlier than 2002-12-04 | R4 | 4824h | 4824h | RInImp-BSClass-FDD | Rel-6 | Stefania | 25.104, 25.141 | Nokia | antti.toskala@nokia.com |  |  |
| 1066 | 341.4 | UMTS-850 | 266d | 2002-12-06 A | 2003-12-12 A | 100% | 2002-12-06 | 2003-12-12 | 266d | finish no earlier than 2003-12-15 | R4 | 2128h | 2128h | RInImp-UMTS850 | Rel-6 | Stefania | 25.101, 25.104, 25.133, 25.141, 25.307, 25.331, 25.942 | Cingular | Don Zelmer (dz1069@att.com) |  |  |
| 1067 | 341.5 | DS-CDMA introduction in the 800 MHz band | 196d | 2003-03-14 A | 2003-12-12 A | 100% | 2003-03-14 | 2003-12-12 | 196d | finish no earlier than 2003-12-15 | R4 | 1568h | 1568h | RInImp-UMTS800 | Rel-6 | Stefania | 25.101, 25.104, 25.133, 25.141, 25.307, 25.331 | NTT DoCoMo | Takehiro Nakamura (takehiro@wsp.yrp.nttdocomo.co.jp) |  |  |
| 1068 | 341.6 | UMTS 1.7/2.1 GHz | 261d | 2003-03-14 A | 2004-03-12 A | 100% | 2003-03-14 | 2004-03-12 | 261d | finish no earlier than 2004-03-15 | R4 | 2088h | 2088h | RInImp-UMTS1721 | Rel-6 | Stefania | 25.101, 25.104, 25.133, 25.141, 25.307, 25.331 | Nokia | jussi.numminen@NOKIA.COM |  |  |
| 1069 | 341.7 | **Improved Receiver Performance Requirements for HSDPA** | 392d? | 2003-12-15 A | 2005-06-14 A | 100% | 2003-12-15 | 2005-06-14 | 392d? |  | R4 | 7304h | 7304h | RInImp-HSPerf | Rel-6 | Stefania |  | Nokia | jussi.numminen@NOKIA.COM |  |  |
| 1070 | 341.7.1 | Improved Minimum Performance Requirements for HSDPA UE categories 7 and 8 | 195d? | 2004-09-15 A | 2005-06-14 A | 100% | 2004-09-15 | 2005-06-14 | 195d? | finish no earlier than 2005-06-14 | R4 | 1560h | 1560h | RInImp-HSPerf-10code | Rel-6 | Stefania | 25.101 | Nokia | jussi.numminen@nokia.com |  |  |
| 1071 | 341.7.2 | Performance Requirements of Receive Diversity for HSDPA | 326d | 2003-12-15 A | 2005-03-14 A | 100% | 2003-12-15 | 2005-03-14 | 326d | finish no earlier than 2005-03-14 | R4 | 2608h | 2608h | RInImp-HSPerf-RxDiv | Rel-6 | Stefania | 25.101 | NTT DoCoMo | Takehiro Nakamura (takehiro@wsp.yrp.nttdocomo.co.jp) |  |  |
| 1072 | 342 | **Rel-6 RAN Feasibility Studies** | 1196d? | 2000-08-14 A | 2005-03-14 A | 100% | 2000-08-14 | 2005-03-14 | 1196d? |  | RP | 43048h | 43048h |  | Rel-6 | Stefania |  |  |  |  |  |
| 1073 | 342.1 | FS of the improved access to UE measurement data for CRNC to support TDD RRM | 270d? | 2002-12-06 A | 2003-12-18 A | 100% | 2002-12-06 | 2003-12-18 | 270d? | finish no earlier than 2003-09-19 | R3 | 2160h | 2160h | RANimp-RRMopt-FSUEMsD | Rel-6 | Gert |  | Interdigital | jim.miller@interdigital.com | SP-24 |  |
| 1074 | 342.2 | FS on Radio link performance enhancements | 1067d | 2000-08-14 A | 2004-09-14 A | 100% | 2000-08-14 | 2004-09-14 | 1067d | finish no earlier than 2004-09-14 | R1 | 8536h | 8536h | RInImp-Rlperf | Rel-6 | Patrick | 25.899 | Nokia | antti.toskala@nokia.com |  |  |
| 1075 | 342.3 | FS on Improvement of inter-frequency and inter-system measurements for 1.28 Mcps TDD | 461d | 2001-12-14 A | 2003-09-19 A | 100% | 2001-12-14 | 2003-09-19 | 461d | start no earlier than 2001-12-14 | R1 | 3688h | 3688h | RInImp-IfIsMLCR | Rel-6 | Patrick | 25.888 | Samsung | Li Xiao Qiang (xqli@samsung.co.kr) |  |  |
| 1076 | 342.4 | FS for the analysis of OFDM for UTRAN enhancement | 526d | 2002-06-10 A | 2004-06-14 A | 100% | 2002-06-10 | 2004-06-14 | 526d | start no earlier than 2002-06-10 | R1 | 4208h | 4208h | RInImp-FSOFDM | Rel-6 | Patrick | 25.892 | Nortel | Sarah Boumendil |  |  |
| 1077 | 342.5 | FS on Uplink Enhancements for Dedicated Transport Channels | 396d | 2002-09-06 A | 2004-03-12 A | 100% | 2002-09-06 | 2004-03-12 | 396d | finish no earlier than 2004-03-12 | R1 | 3168h | 3168h | RInImp-FSUpDTrCh | Rel-6 | Patrick | 25.896 | Nokia | Karri.Ranta-aho@nsn.com |  |  |
| 1078 | 342.6 | FS on Analysis on Higher Chip Rates for UTRA TDD evolutions | 528d | 2002-09-06 A | 2004-09-14 A | 100% | 2002-09-06 | 2004-09-14 | 528d | finish no earlier than 2004-09-14 | R1 | 4224h | 4224h | RInImp-FSVHCRTDD | Rel-6 | Patrick | 25.895 | IPWireless | mbeale@ipwireless.com |  |  |
| 1079 | 342.7 | FS on Low Output Powers for general purpose FDD BSs | 128d | 2003-06-13 A | 2004-03-12 A | 100% | 2003-06-13 | 2004-03-12 | 128d | finish no earlier than 2004-03-12 | R3 | 1024h | 1024h | RInImp-FSLoPw | Rel-6 | Gert | 25.807 | Telefonica | Ana Burgos (burgos_a@tsm.es) |  |  |
| 1080 | 342.8 | FS on Uplink enhancements for UTRA TDD | 462d | 2003-06-06 A | 2005-03-14 A | 100% | 2003-06-06 | 2005-03-14 | 462d | finish no earlier than 2005-03-14 | R1 | 3696h | 3696h | RInImp-FSUpEnhTDD | Rel-6 | Patrick | 25.804 | Interdigital | Marian.Rudolf@InterDigital.com |  |  |
| 1081 | 8.8 | FS on UE antenna efficiency test methods performance requirements (2) | 131d | 2002-03-08 A | 2002-09-06 A | 100% | 2002-03-08 | 2002-09-06 | 131d | finish no earlier than 2002-09-06 | R4 | 1048h | 1048h | RInImp-UEAnTM2 | Rel-6 | Stefania |  | Allgon | Alf Ahlström |  |  |
| 1082 | 9.4 | Deleted - FS on the evolution of the UTRAN architecture | 592d | 2002-09-09 A | 2004-12-15 A | 100% | 2002-09-09 | 2004-12-15 | 592d | finish no earlier than 2004-12-15 | R3 | 4736h | 4736h | RANimp-FSEvo | Rel-6 | Gert |  | Nokia | woonhee.hwang@nsn.com, Antti.Toskala@nokia.com |  | RP-26 |
| 1083 | 343 | **FDD Enhanced Uplink** | 393d | 2004-03-15 A | 2005-09-15 A | 100% | 2004-03-15 | 2005-09-15 | 393d |  | RP | 14128h | 14128h | EDCH | Rel-6 | Stefania |  | Ericsson | Joakim Bergström |  |  |
| 1084 | 343.1 | FDD Enhanced Uplink - Stage 2 | 197d | 2004-03-15 A | 2004-12-14 A | 100% | 2004-03-15 | 2004-12-14 | 197d | finish no earlier than 2004-12-14 | R2 | 1576h | 1576h | EDCH-Stage2 | Rel-6 | Joern | 25.309 |  |  |  |  |
| 1085 | 343.2 | FDD Enhanced Uplink - Physical Layer | 261d | 2004-03-15 A | 2005-03-14 A | 100% | 2004-03-15 | 2005-03-14 | 261d | finish no earlier than 2005-03-14 | R1 | 2088h | 2088h | EDCH-Phys | Rel-6 | Patrick | 25.211, 25.212, 25.213, 25.214, 25.215 | Nokia | Karri.Ranta-aho@nsn.com |  |  |
| 1086 | 343.3 | FDD Enhanced Uplink - Layer 2 and 3 Protocol Aspects | 261d | 2004-03-15 A | 2005-03-14 A | 100% | 2004-03-15 | 2005-03-14 | 261d | finish no earlier than 2005-03-14 | R2 | 2088h | 2088h | EDCH-L23 | Rel-6 | Joern | 25.301, 25.302, 25.306, 25.321, 25.331 | Ericsson | Joakim Bergström |  |  |
| 1087 | 343.4 | FDD Enhanced Uplink - UTRAN Iub/Iur Protocol Aspects | 261d | 2004-03-15 A | 2005-03-14 A | 100% | 2004-03-15 | 2005-03-14 | 261d | finish no earlier than 2005-03-14 | R3 | 2088h | 2088h | EDCH-IurIub | Rel-6 | Gert | 25.401, 25.420, 25.423, 25.430, 25.433 | Nortel | Saso Stojanovski |  |  |
| 1088 | 343.5 | FDD Enhanced Uplink - RF Radio Transmission/ Reception, System Performance Requirements and Conformance Testing | 393d | 2004-03-15 A | 2005-09-15 A | 100% | 2004-03-15 | 2005-09-15 | 393d | finish no earlier than 2005-09-15 | R4 | 3144h | 3144h | EDCH-RF | Rel-6 | Stefania | 25.101, 25.104, 25.133, 25.141 | Ericsson | thomas.unshelm@ERICSSON.COM |  |  |

Notes:
- 1070: Approved at RP#25 as RP-040375
- 1074: Study finished at RP#25
- 1078: Study finished at RP#25
- 1081: The RInImp-UEAnTM FS was re-opened at TSG RP#15 upon request from WG4
- 1082: Study Closed, work will continue within the FS on evolved UTRA and UTRAN

| ID | WBS | Task | Type | Duration | Start | Finish | Complete | Baseline start | Baseline finish | Baseline duration | Constraint | Resources | Work | Actual work | Text1 | Text6 | Text8 | Text3 | Text4 | Text5 | Text12 | Text10 |
| --- | --- | --- | --- | --- | --- | --- | --- | --- | --- | --- | --- | --- | --- | --- | --- | --- | --- | --- | --- | --- | --- | --- |
| 1089 | 344 | **Rel-6 RAN improvements** |  | 656d? | 2002-09-09 A | 2005-03-14 A | 100% | 2002-09-09 | 2005-03-14 | 656d? |  | RP | 28312h | 28312h | RANimp | Rel-6 | Stefania |  |  |  |  |  |
| 1090 | 9.2 | **RAB support enhancement** |  | 522d? | 2003-03-14 A | 2005-03-14 A | 100% | 2003-03-14 | 2005-03-14 | 522d? |  | R2 | 9360h | 9360h | RANimp-RABSE | Rel-6 | Joern | 25.862 | Nokia | Jussi Kähtävä (juha.mikola@nokia.com) |  |  |
| 1091 | 344.1.1 | Optimisation of downlink channelisation code utilisation |  | 262d | 2004-03-12 A | 2005-03-14 A | 100% | 2004-03-12 | 2005-03-14 | 262d | finish no earlier than 2005-03-14 | R1 | 2096h | 2096h | RANimp-RABSE-CodeOptFDD | Rel-6 | Patrick |  | Nortel | Sarah Boumendil |  |  |
| 1092 | 344.1.2 | Optimisation of channelisation code utilisation for 3.84 Mcps TDD |  | 261d | 2004-03-15 A | 2005-03-14 A | 100% | 2004-03-15 | 2005-03-14 | 261d | finish no earlier than 2005-03-15 | R1 | 2088h | 2088h | RANimp-RABSE-CodOptTDD | Rel-6 | Patrick |  | IPWireless | Nicholas Anderson |  |  |
| 1093 | 344.1.3 | HS-DPCCH ACK/NACK Enhancement |  | 65d? | 2004-09-15 A | 2004-12-14 A | 100% | 2004-09-15 | 2004-12-14 | 65d? | finish no earlier than 2004-12-15 | R1 | 520h | 520h | RANimp-RABSE-ACKNACK | Rel-6 | Patrick | 25.212, 25.214, 24.331, 25.433 | Nokia | Jussi Kähtävä (juha.mikola@nokia.com) |  |  |
| 1094 | 344.1.4 | Deleted - Iu enhancements for IMS support in RAN |  | 320d? | 2003-03-14 A | 2004-06-03 A | 100% | 2003-03-14 | 2004-06-03 | 320d? | start no earlier than 2003-03-14 | R3 | 2560h | 2560h | RANimp-RABSE-IuEnhIMS | Rel-6 | Gert |  | Nortel | Philippe.Godin@nortelnetworks.com | RP-24 |  |
| 1095 | 344.1.5 | Deleted - Improvement of RRM across RNS and RNS/BSS | milestone | 0d? | 2003-12-05 A | 2003-12-05 A | 100% | 2003-12-05 | 2003-12-05 | 0d? | finish no earlier than 2003-12-05 | R3 |  |  | RANimp-RRM1 | Rel-6 | Gert |  | Nokia | antti.toskala@nokia.com | RP-23 |  |
| 1096 | 9.1 | Beamforming Enhancements |  | 66d | 2003-09-19 A | 2003-12-19 A | 100% | 2003-09-19 | 2003-12-19 | 66d | finish no earlier than 2004-03-12 | R1 | 528h | 528h | RANimp-BFE | Rel-6 | Patrick | 24.215, 25.423, 25.425, 25.433, 25.435 | Nokia | Jussi Kähtävä (juha.mikola@nokia.com) |  |  |
| 1097 | 344.3 | **Rel6 RRM optimization for Iur and Iub** |  | 126d | 2003-09-19 A | 2004-03-12 A | 100% | 2003-09-19 | 2004-03-12 | 126d |  | R3 | 2016h | 2016h | RANimp-RRMopt | Rel-6 | Gert |  | Ericsson | Gert-Jan.van.Lieshout@eln.ericsson.se |  |  |
| 1098 | 344.3.1 | Improved access to UE measurement data for CRNC to support TDD RRM |  | 126d | 2003-09-19 A | 2004-03-12 A | 100% | 2003-09-19 | 2004-03-12 | 126d | finish no earlier than 2004-03-15 | R3 | 1008h | 1008h | RANimp-RRMopt-UEMsD | Rel-6 | Gert | 25.423 | Interdigital | jim.miller@interdigital.com | RP-22 |  |
| 1099 | 344.4 | **Remote Control of Electrical Tilting Antennas** |  | 395d? | 2003-03-14 A | 2004-09-16 A | 100% | 2003-03-14 | 2004-09-16 | 395d? |  | R3 | 7464h | 7464h | RANimp-TiltAnt | Rel-6 | Gert |  | Vodafone | Andreas.Hauser@vodafone.com |  |  |
| 1100 | 344.4.1 | Tilting Antenna - RAN aspects |  | 393d? | 2003-03-14 A | 2004-09-14 A | 100% | 2003-03-14 | 2004-09-14 | 393d? | finish no earlier than 2004-09-14 | R3 | 3144h | 3144h | RANimp-TiltAnt | Rel-6 | Gert | 25.460, 25.461, 25.462, 25.463 | Vodafone | Andreas.Hauser@vodafone.com |  |  |
| 1101 | 344.4.2 | OAM&P impacts |  | 145d | 2004-02-27 A | 2004-09-16 A | 100% | 2004-02-27 | 2004-09-16 | 145d | finish no earlier than 2004-09-16 | S5 | 1160h | 1160h | RANimp-TiltAnt-OAM | Rel-6 | Dionisio | 32.804, 32.64x | Vodafone | Adrian.Neal@vodafone.com |  | SP-24 |
| 1102 | 344.5 | Network Assisted Cell Change (NACC) from UTRAN to GERAN - network-side aspects |  | 462d? | 2002-09-09 A | 2004-06-15 A | 100% | 2002-09-09 | 2004-06-15 | 462d? | finish no earlier than 2004-06-15 | R3 | 3696h | 3696h | RANimp-NACC | Rel-6 | Gert |  | Vodafone | Brendan.McWilliams@gb.vodafone.co.uk |  |  |
| 1103 | 12 | **Location Services enhancements 2** |  | 1024d? | 2001-01-15 A | 2004-12-16 A | 100% | 2001-01-15 | 2004-12-16 | 1024d? |  | S2,S5,N4,RP | 78152h | 78152h | LCS2 | Rel-6 | Maurice | 23.271 |  |  |  |  |
| 1104 | 12.1 | **Improvement on Le interface** |  | 653d? | 2002-06-17 A | 2004-12-15 A | 100% | 2002-06-17 | 2004-12-15 | 653d? |  | S2 | 9872h | 9872h |  | Rel-6 | Maurice |  |  |  |  |  |
| 1105 | 345.1.1 | Stage 2 |  | 331d? | 2002-06-17 A | 2003-09-22 A | 100% | 2002-06-17 | 2003-09-22 | 331d? | start no earlier than 2002-06-17 | S2 | 2648h | 2648h |  | Rel-6 | Maurice |  |  |  |  |  |
| 1106 | 345.1.2 | Stage 3 - impacts MLP (Mobile Location Protocol) |  | 250d? | 2004-01-01 A | 2004-12-15 A | 100% | 2004-01-01 | 2004-12-15 | 250d? | finish no earlier than 2004-12-15 | OMA | 2000h | 2000h |  | Rel-6 |  |  |  | OMA-LIAISON@mail.openmobilealliance.org |  |  |
| 1107 | 12.2 | **Enhanced support for anonymity and user privacy** |  | 638d? | 2002-07-08 A | 2004-12-15 A | 100% | 2002-07-08 | 2004-12-15 | 638d? |  | S2 | 9144h | 9144h |  | Rel-6 | Maurice |  |  |  |  |  |
| 1108 | 345.2.1 | Stage 2 |  | 255d? | 2002-07-08 A | 2003-06-27 A | 100% | 2002-07-08 | 2003-06-27 | 255d? | finish no earlier than 2003-06-27 | S2 | 2040h | 2040h |  | Rel-6 | Maurice |  |  |  |  |  |
| 1109 | 345.2.2 | Stage 3 - impacts MLP and RLP |  | 250d? | 2004-01-01 A | 2004-12-15 A | 100% | 2004-01-01 | 2004-12-15 | 250d? | finish no earlier than 2004-12-15 | OMA | 2000h | 2000h |  | Rel-6 |  |  |  | OMA-LIAISON@mail.openmobilealliance.org |  |  |
| 1110 | 12.3 | **Enhanced inter-GMLC interface** |  | 648d? | 2002-06-24 A | 2004-12-15 A | 100% | 2002-06-24 | 2004-12-15 | 648d? |  | S2 | 9704h | 9704h |  | Rel-6 | Maurice |  |  |  |  |  |
| 1111 | 345.3.1 | Stage 2 |  | 315d? | 2002-06-24 A | 2003-09-05 A | 100% | 2002-06-24 | 2003-09-05 | 315d? | finish no earlier than 2003-09-05 | S2 | 2520h | 2520h |  | Rel-6 | Maurice |  |  |  |  |  |
| 1112 | 345.3.2 | Stage 3 - definition of RLP and PCP |  | 250d? | 2004-01-01 A | 2004-12-15 A | 100% | 2004-01-01 | 2004-12-15 | 250d? | finish no earlier than 2004-12-15 | OMA | 2000h | 2000h |  | Rel-6 |  |  |  | OMA-LIAISON@mail.openmobilealliance.org |  |  |

Notes:
- 1089: Generic feature
- 1090: building block without particular end date
- 1092: WIDS modified in RP#26, RP-040551
- 1093: Approved at RP#25 as RP-040390
- 1094: Closed RP#24 due to the lack of progress
- 1095: abandoned RP-23
- 1100: Finished at RP#25
- 1101: SA#25 09/2004 completed
- 1106: Updated according to SP-040232
- 1109: Updated according to SP-040232
- 1112: Updated according to SP-040232

| ID | WBS | Task | Type | Duration | Start | Finish | Complete | Baseline start | Baseline finish | Baseline duration | Constraint | Resources | Work | Actual work | Text6 | Text8 | Text5 | Text1 | Text4 | Text12 |
| --- | --- | --- | --- | --- | --- | --- | --- | --- | --- | --- | --- | --- | --- | --- | --- | --- | --- | --- | --- | --- |
| 1113 | 12.4 | **Location Services support for IMS public identities** |  | 473d? | 2003-02-24 A | 2004-12-15 A | 100% | 2003-02-24 | 2004-12-15 | 473d? |  | S2 | 7704h | 7704h | Rel-6 | Maurice |  |  |  |  |
| 1114 | 345.4.1 | Stage 2 |  | 240d? | 2003-02-24 A | 2004-01-23 A | 100% | 2003-02-24 | 2004-01-23 | 240d? | finish no earlier than 2004-01-23 | S2 | 1920h | 1920h | Rel-6 | Maurice |  |  |  |  |
| 1115 | 345.4.2 | Stage 3 - impacts MLP, RLP and PCP |  | 250d? | 2004-01-01 A | 2004-12-15 A | 100% | 2004-01-01 | 2004-12-15 | 250d? | finish no earlier than 2004-12-15 | OMA | 2000h | 2000h | Rel-6 |  | OMA-LIAISON@mail.openmobilealliance.org |  |  |  |
| 1116 | 12.5 | **New area event for location service triggering reports** |  | 663d? | 2002-06-03 A | 2004-12-15 A | 100% | 2002-06-03 | 2004-12-15 | 663d? |  | S2 | 11416h | 11416h | Rel-6 | Maurice |  |  |  |  |
| 1117 | 345.5.1 | Stage 2 |  | 280d? | 2002-06-03 A | 2003-06-27 A | 100% | 2002-06-03 | 2003-06-27 | 280d? | finish no earlier than 2003-06-27 | S2 | 2240h | 2240h | Rel-6 | Maurice |  |  |  |  |
| 1118 | 345.5.2 | Stage 3 for UE-CN signalling |  | 234d? | 2003-10-09 A | 2004-08-31 A | 100% | 2003-10-09 | 2004-08-31 | 234d? | start no earlier than 2003-10-09 | N4 | 1872h | 1872h | Rel-6 | Kimmo |  |  |  |  |
| 1119 | 345.5.3 | Stage 3 - impacts MLP, RLP and PCP |  | 250d? | 2004-01-01 A | 2004-12-15 A | 100% | 2004-01-01 | 2004-12-15 | 250d? | finish no earlier than 2004-12-15 | OMA | 2000h | 2000h | Rel-6 |  | OMA-LIAISON@mail.openmobilealliance.org |  |  |  |
| 1120 | 12.7 | **UE positioning** |  | 957d? | 2001-01-15 A | 2004-09-14 A | 100% | 2001-01-15 | 2004-09-14 | 957d? |  | RP | 18480h | 18480h | Rel-6 | Stefania |  | LCS2-UEpos |  |  |
| 1121 | 12.8 | Open SMLC-SRNC Interface within the UTRAN to support UTRAN Rel4 positioning methods |  | 700d? | 2001-01-15 A | 2003-09-19 A | 100% | 2001-01-15 | 2003-09-19 | 700d? | finish no earlier than 2003-09-19 | R2 | 5600h | 5600h | Rel-6 | Joern | Meik.Kottkamp@siemens.com | LCS-Rel4Pos | Siemens |  |
| 1122 | 345.6.2 | A-GPS minimum performance specification |  | 333d? | 2003-06-06 A | 2004-09-14 A | 100% | 2003-06-06 | 2004-09-14 | 333d? | finish no earlier than 2004-09-14 | R4 | 2664h | 2664h | Rel-6 | Stefania | donglin.shen@attws.com | LCS-UEPos-AGPSPerf | AT&T Wireless |  |
| 1123 | 12.7.2 | FS on Enhancements to OTDOA Positioning using advanced blanking methods |  | 320d | 2002-07-01 A | 2003-09-19 A | 100% | 2002-07-01 | 2003-09-19 | 320d | finish no earlier than 2003-09-19 | R2 | 2560h | 2560h | Rel-6 | Joern | david.bartlett@cursor-system.com | LCS2-UEpos-FSBlank | Cambridge Positioning Systems |  |
| 1124 | 345.6.4 | Deleted - UE positioning enhancements - other methods | milestone | 0d? | 2003-09-26 A | 2003-09-26 A | 100% | 2003-09-26 | 2003-09-26 | 0d? | finish no earlier than 2003-09-26 | R2 |  |  | Rel-6 | Joern | Meik.Kottkamp@siemens.com | LCS2-UEpos-enh | Siemens | RP-24 |
| 1125 | 345.7 | LCS charging |  | 455d? | 2003-03-21 A | 2004-12-16 A | 100% | 2003-03-21 | 2004-12-16 | 455d? | start no earlier than 2003-03-21 | S5 | 3640h | 3640h | Rel-6 | Dionisio | alain.bibas@orange-ft.com | LCS2-CH | France Telecom |  |
| 1126 | 14 | **Rel-6 Security enhancements** |  | 1018d? | 2001-01-03 A | 2004-11-26 A | 100% | 2001-01-03 | 2004-11-26 | 1018d? |  | S3 | 28824h | 28824h | Rel-6 | Dionisio | Peter.Howard@vodafone.com | SEC1 | Vodafone |  |
| 1127 | 14.1 | **Enhanced HE control of security (including positive authentication reporting)** |  | 712d | 2001-01-03 A | 2003-09-25 A | 100% | 2001-01-03 | 2003-09-25 | 712d |  | S3 | 14064h | 14064h | Rel-6 | Dionisio | Peter.Howard@vodafone.com |  | Vodafone |  |
| 1128 | 14.1.1 | Deleted - Stage 2 |  | 378d | 2001-01-03 A | 2002-06-14 A | 100% | 2001-01-03 | 2002-06-14 | 378d | finish no earlier than 2002-06-14 | S3 | 3024h | 3024h | Rel-6 | Dionisio |  |  |  | SP-16 |
| 1129 | 14.1.3 | **Network domain security** |  | 334d | 2002-06-17 A | 2003-09-25 A | 100% | 2002-06-17 | 2003-09-25 | 334d |  | S3 | 5344h | 5344h | Rel-6 | Dionisio | Geir-myrdahl.koien@telenor.com | SEC1-NDS | Telenor |  |
| 1130 | 14.1.3.1 | IP network layer security (NDS/IP) |  | 334d | 2002-06-17 A | 2003-09-25 A | 100% | 2002-06-17 | 2003-09-25 | 334d | finish no earlier than 2003-09-25 | S3 | 2672h | 2672h | Rel-6 | Dionisio |  | SEC1-NDS-IP |  |  |
| 1131 | 346.2 | Network Domain Security; Authentication Framework (NDS/AF) |  | 521d? | 2002-02-15 A | 2004-02-13 A | 100% | 2002-02-15 | 2004-02-13 | 521d? | finish no earlier than 2004-02-13 | S3 | 4168h | 4168h | Rel-6 | Dionisio | tommi.viitanen@nokia.com | SEC1-NDS-AF | Nokia |  |
| 1132 | 346.3 | Key Management of group keys for Voice Group Call Services |  | 306d | 2003-09-26 A | 2004-11-26 A | 100% | 2003-09-26 | 2004-11-26 | 306d | finish no earlier than 2004-11-26 | S3 | 2448h | 2448h | Rel-6 | Dionisio | benno.tietz@vodafone.com | SECGKYV | Vodafone |  |
| 1133 | 16 | **IMS Phase 2** |  | 1395d? | 2000-08-28 A | 2005-12-30 A | 100% | 2000-08-28 | 2005-12-30 | 1395d? |  | S1,S2,S3,S5,NP | 130248h | 130248h | Rel-6 | Alain |  | IMS2 |  |  |
| 1134 | 347.1 | Enhancements to the Cx and Sh interfaces |  | 323d? | 2003-06-06 A | 2004-08-31 A | 100% | 2003-06-06 | 2004-08-31 | 323d? | finish no earlier than 2004-08-31 | N4 | 2584h | 2584h | Rel-6 | Kimmo |  | IMS2-CCR |  |  |
| 1135 | 16.12 | **IMS Group Management** |  | 715d? | 2002-03-14 A | 2004-12-08 A | 100% | 2002-03-14 | 2004-12-08 | 715d? |  | S1 | 12680h | 12680h | Rel-6 | Alain | juha.kalliokulju@nokia.com | IMSGM | Nokia |  |
| 1136 | 16.12.1 | Stage 1 - TS on IMS group management |  | 193d | 2002-03-14 A | 2002-12-09 A | 100% | 2002-03-14 | 2002-12-09 | 193d | finish no earlier than 2002-12-09 | S1 | 1544h | 1544h | Rel-6 | Alain | juha.kalliokulju@nokia.com |  | Nokia |  |
| 1137 | 347.2.2 | Stage 2 |  | 158d? | 2003-05-26 A | 2003-12-31 A | 100% | 2003-05-26 | 2003-12-31 | 158d? | finish no earlier than 2003-12-31 | S2 | 1264h | 1264h | Rel-6 | Maurice |  |  |  |  |
| 1138 | 347.2.3 | Stage 3 for IMS Group management (e.g. chat) |  | 519d? | 2002-12-13 A | 2004-12-08 A | 100% | 2002-12-13 | 2004-12-08 | 519d? | finish no earlier than 2004-12-08 | N1 | 4152h | 4152h | Rel-6 | Frederic | Keith Drage (drage@alcatel-lucent.com) |  | Lucent |  |

Notes:
- 1115: Updated according to SP-040232
- 1118: 31/10/2003 work has started. Current stage 3 fullfills the requirements of stage 2. ......
- 1119: Updated according to SP-040232
- 1121: Text3: 25.305, 25.401, 25.450, 25.452, 25.453
- 1122: Finished at RP#25 / Text3: 25.171
- 1124: building block without particular end date
- 1125: SA#26 12/2004 completed / Text3: 32.271
- 1126: Added BB UE authentication and rapporteur added.
- 1127: Added by SP-000575 without any dates. 18/10/00: Change of WI title, added hyperlink rapporteur new end date 03/01. New end date and correct Release to be decided S3#18
- 1128: New end date and correct Release to be decided S3#18. Marked as stopped 12/2008
- 1129: WID approved for Rel-6 at SA#17. Completed 2004-12
- 1130: Should be complete after SA3#27. Completed 2004-12 / Text3: 33.210
- 1131: WID approved SA#19. Work started after FS approved SA#18
- 1132: Approved TSG#21. Completed 2004-12 / Text3: 42.068, 43.068, 44.068, 42.069, 43.069, 44.069, 31.102, 24.008, 48.008, 42.009, 43.020
- 1133: Not yet available: verbally approved at SA15, actual WID to be provided at SA16 by Lucent / Text3: 23.228
- 1134: Shared public user identities need to be solved. If email approval CR is accepted. Work 100% done....
- 1138: Depends on CN decision on CPCP in Rel-6. Complete, if unresolved IETF dependencies are dropped (-> LS to CN plenary)

| ID | WBS | Task | Type | Duration | Start | Finish | Complete | Baseline start | Baseline finish | Baseline duration | Constraint | Resources | Work | Actual work | Text6 | Text8 | Text4 | Text5 | Text1 | Text3 | Text12 |
| --- | --- | --- | --- | --- | --- | --- | --- | --- | --- | --- | --- | --- | --- | --- | --- | --- | --- | --- | --- | --- | --- |
| 1139 | 347.3 | **IMS Conferencing** |  | 548d? | 2002-11-04 A | 2004-12-08 A | 100% | 2002-11-04 | 2004-12-08 | 548d? |  | N1 | 10960h | 10960h | Rel-6 | Frederic |  |  |  |  |  |
| 1140 | 347.3.1 | Stage 2 |  | 303d? | 2002-11-04 A | 2003-12-31 A | 100% | 2002-11-04 | 2003-12-31 | 303d? | finish no earlier than 2003-12-31 | S2 | 2424h | 2424h | Rel-6 | Maurice |  |  |  |  |  |
| 1141 | 347.3.2 | Stage 3 |  | 519d? | 2002-12-13 A | 2004-12-08 A | 100% | 2002-12-13 | 2004-12-08 | 519d? | finish no earlier than 2004-12-08 | N1 | 4152h | 4152h | Rel-6 | Frederic | Lucent | Keith Drage (drage@alcatel-lucent.com) |  |  |  |
| 1142 | 16.11 | **IMS Messaging** |  | 992d? | 2002-03-14 A | 2005-12-30 A | 100% | 2002-03-14 | 2005-12-30 | 992d? |  | S1 | 23912h | 23912h | Rel-6 | Alain | Nokia | juha.kalliokulju@nokia.com | IMSM |  |  |
| 1143 | 16.11.1 | TR on support of messaging in the IMS |  | 193d | 2002-03-14 A | 2002-12-09 A | 100% | 2002-03-14 | 2002-12-09 | 193d | finish no earlier than 2002-12-09 | S1 | 1544h | 1544h | Rel-6 | Alain | Nokia | juha.kalliokulju@nokia.com | IMSM-TR |  |  |
| 1144 | 347.4.2 | Stage 1 22.340 |  | 23d? | 2002-11-11 A | 2002-12-11 A | 100% | 2002-11-11 | 2002-12-11 | 23d? | finish no earlier than 2002-12-11 | S1 | 184h | 184h | Rel-6 | Alain | Nokia | juha.kalliokulju@nokia.com | IMSM-TS | 22.340 |  |
| 1145 | 347.4.3 | CRs to 22.140 & 22.228 |  | 263d? | 2002-03-14 A | 2003-03-17 A | 100% | 2002-03-14 | 2003-03-17 | 263d? | finish no earlier than 2003-03-17 | S1 | 2104h | 2104h | Rel-6 | Alain | Nokia | juha.kalliokulju@nokia.com | IMSM-CR | 22.140,22.228 |  |
| 1146 | 16.11.3 | Stage 2 |  | 477d | 2002-11-04 A | 2004-08-31 A | 100% | 2002-11-04 | 2004-08-31 | 477d | finish no earlier than 2004-08-31 | S2 | 3816h | 3816h | Rel-6 | Maurice |  |  |  |  |  |
| 1147 | 347.4.5 | Stage 3 for IMS Messaging |  | 519d? | 2002-12-13 A | 2004-12-08 A | 100% | 2002-12-13 | 2004-12-08 | 519d? | finish no earlier than 2004-12-08 | N1 | 4152h | 4152h | Rel-6 | Frederic | Lucent | Keith Drage (drage@alcatel-lucent.com) |  |  |  |
| 1148 | 347.4.6 | SIP/SIMPLE Instant messaging |  | 522d? | 2004-01-01 A | 2005-12-30 A | 100% | 2004-01-01 | 2005-12-30 | 522d? | finish no earlier than 2005-06-30 | OMA | 4176h | 4176h | Rel-6 |  |  | OMA-LIAISON@mail.openmobilealliance.org |  |  |  |
| 1149 | 347.5 | **Additional SIP Capabilities support not covered by Rel-5** |  | 680d? | 2002-11-11 A | 2005-06-17 A | 100% | 2002-11-11 | 2005-06-17 | 680d? |  | N1 | 13392h | 13392h | Rel-6 | Frederic |  |  |  |  |  |
| 1150 | 347.5.1 | Stage 2 for add SIP cap (e.g. forking) |  | 335d? | 2002-11-11 A | 2004-02-20 A | 100% | 2002-11-11 | 2004-02-20 | 335d? | finish no earlier than 2004-02-20 | S2 | 2680h | 2680h | Rel-6 | Maurice |  |  |  |  |  |
| 1151 | 347.5.2 | Stage 3 for Additional SIP Capabilities |  | 454d? | 2002-12-13 A | 2004-09-08 A | 100% | 2002-12-13 | 2004-09-08 | 454d? | finish no earlier than 2004-09-08 | N1 | 3632h | 3632h | Rel-6 | Frederic | Lucent | Keith Drage (drage@alcatel-lucent.com) |  |  |  |
| 1152 | 347.5.3 | Procedured associated with IMS-ALG |  | 205d? | 2004-09-06 A | 2005-06-17 A | 100% | 2004-09-06 | 2005-06-17 | 205d? | start no earlier than 2004-09-06 | N1 | 1640h | 1640h | Rel-6 | Frederic |  |  |  |  |  |
| 1153 | 347.6 | Review additional SIP Capabilities against IMS |  | 454d? | 2002-12-13 A | 2004-09-08 A | 100% | 2002-12-13 | 2004-09-08 | 454d? | finish no earlier than 2004-09-08 | N1 | 3632h | 3632h | Rel-6 | Frederic | Lucent | Keith Drage (drage@alcatel-lucent.com) |  |  |  |
| 1154 | 16.5 | **Interworking between IMS and IP networks** |  | 1118d? | 2000-08-28 A | 2004-12-08 A | 100% | 2000-08-28 | 2004-12-08 | 1118d? |  | N3 | 31712h | 31712h | Rel-6 | Gwiho | BT | nigel.holland@bt.com | IMS-CCR-IWIP | 23.821, 29.061, 29.162 |  |
| 1155 | 16.5.1 | Interworking for 3GPP_SIP and IETF_SIP |  | 730d | 2000-08-28 A | 2003-06-13 A | 100% | 2000-08-28 | 2003-06-13 | 730d | finish no earlier than 2003-06-13 | N3 | 5840h | 5840h | Rel-6 | Gwiho | Siemens | Thomas.Belling@nsn.com |  | New 29.962 |  |
| 1156 | 16.5.2 | Interworking for IPv6 to IPv4 |  | 1118d | 2000-08-28 A | 2004-12-08 A | 100% | 2000-08-28 | 2004-12-08 | 1118d | finish no earlier than 2004-12-08 | N3 | 8944h | 8944h | Rel-6 | Gwiho |  |  |  | 29.163 |  |
| 1157 | 347.7.3 | Interworking for IPv6 to IPv4 (SIP / SDP aspects) |  | 87d? | 2004-05-11 A | 2004-09-08 A | 100% | 2004-05-11 | 2004-09-08 | 87d? | finish no earlier than 2004-09-08 | N1 | 696h | 696h | Rel-6 | Frederic |  |  |  |  |  |
| 1158 | 16.8.1 | stage 3 of interworking with non-IMS IP networks |  | 911d | 2001-03-14 A | 2004-09-08 A | 100% | 2001-03-14 | 2004-09-08 | 911d | finish no earlier than 2004-09-08 | N1 | 7288h | 7288h | Rel-6 | Frederic |  |  |  |  |  |
| 1159 | 16.6.1 | Interworking between IMS and CS networks |  | 929d? | 2000-08-28 A | 2004-03-18 A | 100% | 2000-08-28 | 2004-03-18 | 929d? | finish no earlier than 2004-03-18 | N3 | 7432h | 7432h | Rel-6 | Gwiho | Vodafone | Brendan.McWilliams@gb.vodafone.co.uk | IMS-CCR-IWCS | 29.163, 29.061, 24.228, and new CN4 specification |  |
| 1160 | 16.10 | Mn interface (IM-MGW to MGCF) enhancements (CN4 Part) |  | 418d | 2001-08-07 A | 2004-09-01 A | 100% | 2001-08-07 | 2004-09-01 | 418d | finish no earlier than 2004-09-01 | N4 | 3344h | 3344h | Rel-6 | Kimmo |  |  | IMS-CCR-Mn |  |  |
| 1161 | 347.10 | Study of subscriber and operators relationship in IMS and related ISIM requirements for Rel 6” |  | 20d? | 2002-11-15 A | 2002-12-12 A | 100% | 2002-11-15 | 2002-12-12 | 20d? | finish no earlier than 2002-12-12 | S1 | 160h | 160h | Rel-6 | Alain | Nokia | juha.kalliokulju@nokia.com |  |  |  |
| 1162 | 347.11 | Lawful Interception in the 3GPP Rel-6 architecture |  | 269d? | 2002-12-09 A | 2003-12-18 A | 100% | 2002-12-09 | 2003-12-18 | 269d? | finish no earlier than 2003-12-18 | S3 | 2152h | 2152h | Rel-6 | Dionisio | Reg TP | Berthold.Wilhelm@REGTP.DE | SEC1-LI | 33.106, 33.107, 33.108 |  |
| 1163 | 347.12 | IMS Subscription and access scenarios |  | 130d? | 2002-12-16 A | 2003-06-13 A | 100% | 2002-12-16 | 2003-06-13 | 130d? | start no earlier than 2002-12-16 | S1 | 1040h | 1040h | Rel-6 | Alain |  |  |  | 22.800 |  |
| 1164 | 347.13 | IMS charging |  | 455d? | 2003-03-21 A | 2004-12-16 A | 100% | 2003-03-21 | 2004-12-16 | 455d? | finish no earlier than 2004-12-16 | S5 | 3640h | 3640h | Rel-6 | Dionisio |  |  | IMS2-CH | 32.260 |  |
| 1165 | 347.14 | IMS Management objects |  | 306d? | 2004-09-03 A | 2005-11-05 A | 100% | 2004-09-03 | 2005-11-05 | 306d? | finish no earlier than 2005-03-04 | N1 | 2448h | 2448h | Rel-6 | Frederic |  |  |  | 24.167 |  |
| 1166 | 347.15 | Deleted - Stage 2 of IMS Phase 2 | milestone | 0d? | 2003-09-19 A | 2003-09-19 A | 100% | 2003-09-19 | 2003-09-19 | 0d? | finish no earlier than 2003-09-19 | S2 |  |  | Rel-6 | Maurice |  |  |  |  | SP-21 |

Notes:
- 1141: Depends on CN decision on IETF dependencies in Rel-6. Higher figure if CPCP is dropped (-> LS to CN plenary)
- 1148: Updated according to SP-040232
- 1154: [DAB 14.02.02] - end date pushed back to March 2003
- 1155: [DAB - 20.08.03] - CN Part of TR Complete @ CN#20
- 1159: [DAB - 25.05.04] - CN3 consider this work to be complete
- 1160: TISPAN issue is open
- 1164: SA#26 12/2004 completed

| ID | WBS | Task | Type | Duration | Start | Finish | Complete | Baseline start | Baseline finish | Baseline duration | Constraint | Resources | Work | Actual work | Text1 | Text3 | Text4 | Text5 | Text6 | Text8 | Text10 | Text12 |
| --- | --- | --- | --- | --- | --- | --- | --- | --- | --- | --- | --- | --- | --- | --- | --- | --- | --- | --- | --- | --- | --- | --- |
| 1167 | 348 | **3GPP Enablers for services like Push to Talk over Cellular (PoC)** |  | 459d? | 2003-09-08 A | 2005-06-09 A | 100% | 2003-09-08 | 2005-06-09 | 459d? |  | S2,S4,S5 | 10696h | 10696h | PoC | 23.979 | Ericsson | Shabnam Sultana | Rel-6 | Maurice |  |  |
| 1168 | 348.1 | Feasibility Study |  | 322d? | 2003-09-08 A | 2004-11-30 A | 100% | 2003-09-08 | 2004-11-30 | 322d? | finish no earlier than 2004-11-30 | S2 | 2576h | 2576h | PoC | 23.979 | Ericsson | Shabnam Sultana | Rel-6 | Maurice | SP-24 |  |
| 1169 | 348.2 | Dependencies on OMA PoC |  | 303d? | 2004-01-01 A | 2005-02-28 A | 100% | 2004-01-01 | 2005-02-28 | 303d? | finish no earlier than 2004-12-30 | OMA | 2424h | 2424h | PoC |  |  | OMA-LIAISON@mail.openmobilealliance.org | Rel-6 |  | SP-24 |  |
| 1170 | 348.3 | Selection of one or more PoC codec(s) for PoC |  | 69d? | 2004-09-13 A | 2004-12-16 A | 100% | 2004-09-13 | 2004-12-16 | 69d? | start no earlier than 2004-09-13 | S4 | 552h | 552h | PoC | 26.235, 26.236 |  |  | Rel-6 | Paolo | SP-25 |  |
| 1171 | 348.4 | PoC charging |  | 184d? | 2004-09-27 A | 2005-06-09 A | 100% | 2004-09-27 | 2005-06-09 | 184d? | finish no earlier than 2005-06-09 | S5 | 1472h | 1472h | PoC-CH | 32.272 |  |  | Rel-6 | Dionisio |  |  |
| 1172 | 349 | Interworking aspects and migration scenarios for IPv4 based IMS Implementations (Study) |  | 210d? | 2003-09-08 A | 2004-06-25 A | 100% | 2003-09-08 | 2004-06-25 | 210d? | finish no earlier than 2004-06-25 | S2 | 1680h | 1680h | IPv4IMS | 23.881 | Siemens | Alexander Milinski | Rel-6 | Maurice |  |  |
| 1173 | 16.3 | **Interoperability and Commonality between IMS using different "IP-connectivity Networks"** |  | 325d? | 2002-09-16 A | 2003-12-12 A | 100% | 2002-09-16 | 2003-12-12 | 325d? |  | S2 | 9176h | 9176h | IMSCOOP | 23.864 |  |  | Rel-6 | Maurice |  |  |
| 1174 | 16.3.1 | Stage 2 for Interoperability |  | 272d | 2002-09-16 A | 2003-09-30 A | 100% | 2002-09-16 | 2003-09-30 | 272d | finish no earlier than 2003-09-30 | S2 | 2176h | 2176h |  | 23.864 | Nokia | balazs.bertenyi@nsn.com | Rel-6 | Maurice |  |  |
| 1175 | 350.2 | Stage 2 for commonality |  | 265d? | 2002-09-16 A | 2003-09-19 A | 100% | 2002-09-16 | 2003-09-19 | 265d? | start no earlier than 2002-09-16 | S2 | 2120h | 2120h |  | 23.864 | Nokia | balazs.bertenyi@nsn.com | Rel-6 | Maurice |  |  |
| 1176 | 16.3.2 | Stage 3 |  | 305d | 2002-10-14 A | 2003-12-12 A | 100% | 2002-10-14 | 2003-12-12 | 305d | finish no earlier than 2003-12-12 | N1 | 2440h | 2440h |  |  | Lucent | Keith Drage (drage@alcatel-lucent.com) | Rel-6 | Frederic |  |  |
| 1177 | 17 | **Support of Push Services** |  | 823d | 2001-01-03 A | 2004-02-27 A | 100% | 2001-01-03 | 2004-02-27 | 823d |  | S1 | 11390.6h | 11390.6h | PUSH | 23.976 | NTT Comware | Yoshinori Kitada | Rel-6 | Alain |  |  |
| 1178 | 17.1 | Stage 1 |  | 378d | 2001-01-03 A | 2002-06-14 A | 100% | 2001-01-03 | 2002-06-14 | 378d | finish no earlier than 2002-06-14 | S1 | 3024h | 3024h |  |  |  |  | Rel-6 | Alain |  |  |
| 1179 | 17.3 | TR 23.976 on Push Architecture |  | 340d | 2002-11-11 A | 2004-02-27 A | 100% | 2002-11-11 | 2004-02-27 | 340d | finish no earlier than 2004-02-27 | S2 | 2720h | 2720h |  | 23.976 | RIM | Nick Alfano | Rel-6 | Maurice |  |  |
| 1180 | 18 | **Multimedia Messaging (MMS) enhancements** |  | 865d? | 2002-08-15 A | 2005-12-07 A | 100% | 2002-08-15 | 2005-12-07 | 865d? |  | T2,S1,S4,S5 | 31936h | 31936h | MMS6 |  | Siemens | Josef.Laumen@SAL.SIEMENS.DE | Rel-6 | Kimmo |  |  |
| 1181 | 18.1 | **Definition of service requirements** |  | 286d? | 2002-11-15 A | 2003-12-19 A | 100% | 2002-11-15 | 2003-12-19 | 286d? |  | S1 | 4576h | 4576h | MMS6-SR | 22.140 |  |  | Rel-6 | Alain |  |  |
| 1182 | 352.1.1 | Definition of service requirements charging |  | 286d? | 2002-11-15 A | 2003-12-19 A | 100% | 2002-11-15 | 2003-12-19 | 286d? | finish no earlier than 2003-12-20 | S1 | 2288h | 2288h |  | 22.140 | Siemens | Josef.Laumen@SAL.SIEMENS.DE | Rel-6 | Alain |  |  |
| 1183 | 18.2 | Technical realization |  | 591d | 2002-09-06 A | 2004-12-10 A | 100% | 2002-09-06 | 2004-12-10 | 591d | finish no earlier than 2004-12-10 | T2 | 4728h | 4728h |  | 23.140 | Siemens | Josef.Laumen@SAL.SIEMENS.DE | Rel-6 | Kimmo |  |  |
| 1184 | 18.3 | OMA dependencies |  | 446d | 2003-08-15 A | 2005-04-29 A | 100% | 2003-08-15 | 2005-04-29 | 446d | finish no earlier than 2004-12-10 | OMA | 3568h | 3568h |  | OMA specs |  |  | Rel-6 | Kimmo |  |  |
| 1185 | 18.4 | MMS formats and codecs |  | 865d | 2002-08-15 A | 2005-12-07 A | 100% | 2002-08-15 | 2005-12-07 | 865d | finish no earlier than 2005-12-07 | S4 | 6920h | 6920h | MMS6-Codec | 26.140, 26.936 | Nokia | roberto.castagno@nokia.com | Rel-6 | Paolo |  |  |
| 1186 | 352.5 | Handling of private addressing schemes in MMS |  | 263d | 2003-12-10 A | 2004-12-10 A | 100% | 2003-12-10 | 2004-12-10 | 263d | finish no earlier than 2004-12-10 | T2 | 2104h | 2104h |  | 23.140 | T-Mobile | Steffen.Habermann@T-MOBILE.DE | Rel-6 | Kimmo |  |  |
| 1187 | 352.6 | MMS charging |  | 390d? | 2003-03-21 A | 2004-09-16 A | 100% | 2003-03-21 | 2004-09-16 | 390d? | start no earlier than 2003-03-21 | S5 | 3120h | 3120h | MMS6-CH | 32.270 |  |  | Rel-6 | Dionisio |  |  |
| 1188 | 352.7 | Deleted - FS Multiple MMS Relay/Server Architecture | milestone | 0d | 2004-12-10 A | 2004-12-10 A | 100% | 2004-12-10 | 2004-12-10 | 0d | finish no earlier than 2004-12-10 | T2 |  |  |  | probably Annex to 23.140 | Telefónica Móviles | Juan Gorospe (gorospe_j@tsm.es) | Rel-6 | Kimmo |  | TP-26 |
| 1189 | 19 | **Rel-6 MExE enhancements** |  | 326d | 2002-03-08 A | 2003-06-06 A | 100% | 2002-03-08 | 2003-06-06 | 326d |  | T2 | 7328h | 7328h | MEXE6 |  |  |  | Rel-6 | Kimmo |  |  |
| 1190 | 19.1 | MExE Rel-6 Improvements and Investigations |  | 264d | 2002-03-08 A | 2003-03-12 A | 100% | 2002-03-08 | 2003-03-12 | 264d | finish no earlier than 2003-03-12 | T2 | 2112h | 2112h | MEXE6-ENHANC | 22.057, 23.057 | TTPCom | Lars Brenk ( (lsb_ttpcom@HOTMAIL.COM) | Rel-6 |  |  |  |
| 1191 | 19.2 | MExE Run-Time Independent Framework Feasibility Study |  | 326d | 2002-03-08 A | 2003-06-06 A | 100% | 2002-03-08 | 2003-06-06 | 326d | finish no earlier than 2003-06-06 | T2 | 2608h | 2608h | MEXE6-RTIF | 22.857 | Intel | Aaron.Cohen@intel.com | Rel-6 |  |  |  |
| 1192 | 21 | Subscription Management |  | 650d | 2002-09-20 A | 2005-03-17 A | 100% | 2002-09-20 | 2005-03-17 | 650d | finish no earlier than 2005-03-17 | S5 | 5200h | 5200h | SuM | 32.140/1, 32.171/2/5, 32.803 | T-Mobile | istvan.aba@t-mobile.at | Rel-6 | Dionisio |  |  |

Notes:
- 1169: Updated according to SP-040232
- 1170: Completed
- 1171: SA#28 06/2005 completed
- 1174: No contributions assumed that no more will be done in 3GPP hence work may need to be done in 3GPP2
- 1177: AS: Changed from FS to actual support of Push
- 1187: SA#25 09/2004 completed
- 1188: originally it was intended to create a FS TR but most likely the work will become an Annex of 23.140
- 1192: SA#27 03/2005 completed

| ID | WBS | Task | Duration | Start | Finish | Complete | Baseline start | Baseline finish | Baseline duration | Constraint | Resources | Work | Actual work | Text1 | Text4 | Text5 | Text6 | Text8 | Text3 |
| --- | --- | --- | --- | --- | --- | --- | --- | --- | --- | --- | --- | --- | --- | --- | --- | --- | --- | --- | --- |
| 1193 | 22 | **Presence Capability** | 1233d? | 2001-03-19 A | 2005-12-07 A | 100% | 2001-03-19 | 2005-12-07 | 1233d? |  | S1 | 37112h | 37112h | PRESNC | Motorola | Mark Cataldo | Rel-6 | Alain |  |
| 1194 | 22.1 | Stage 1 | 610d | 2001-03-19 A | 2003-07-18 A | 100% | 2001-03-19 | 2003-07-18 | 610d | finish no earlier than 2003-07-18 | S1 | 4880h | 4880h |  |  |  | Rel-6 | Alain | 22.141 |
| 1195 | 22.2 | Stage 2 | 268d | 2001-09-12 A | 2002-09-20 A | 100% | 2001-09-12 | 2002-09-20 | 268d | finish no earlier than 2002-09-20 | S2 | 2144h | 2144h |  | Nokia | balazs.bertenyi@nsn.com | Rel-6 | Maurice |  |
| 1196 | 22.3 | Stage 3 | 703d | 2002-04-01 A | 2004-12-08 A | 100% | 2002-04-01 | 2004-12-08 | 703d | finish no earlier than 2004-12-08 | N1 | 5624h | 5624h |  | Lucent | Keith Drage (drage@alcatel-lucent.com) | Rel-6 | Frederic |  |
| 1197 | 355.4 | Stage 3 (CN3 Part Pk interface) | 770d? | 2002-04-01 A | 2005-03-11 A | 100% | 2002-04-01 | 2005-03-11 | 770d? | finish no earlier than 2005-03-11 | N3 | 6160h | 6160h |  |  |  | Rel-6 | Gwiho |  |
| 1198 | 355.5 | Media Codecs and Formats for IMS Messaging and Presence | 650d? | 2003-06-12 A | 2005-12-07 A | 100% | 2003-06-12 | 2005-12-07 | 650d? | finish no earlier than 2005-12-07 | S4 | 5200h | 5200h | PRESNC-COFIMP | Nokia | harri.honko@nokia.com | Rel-6 | Paolo | 26.141, 26.936 |
| 1199 | 22.4 | Security issues | 79d | 2002-08-26 A | 2002-12-12 A | 100% | 2002-08-26 | 2002-12-12 | 79d | finish no earlier than 2002-12-12 | S3 | 632h | 632h |  |  |  | Rel-6 | Dionisio |  |
| 1200 | 355.7 | SIMPLE Presence | 326d? | 2004-01-01 A | 2005-03-31 A | 100% | 2004-01-01 | 2005-03-31 | 326d? | finish no earlier than 2004-12-30 | OMA | 2608h | 2608h |  |  | OMA-LIAISON@mail.openmobilealliance.org | Rel-6 |  |  |
| 1201 | 25 | **Enhanced A/Gb feasibility study** | 51d? | 2002-08-30 A | 2002-11-08 A | 100% | 2002-08-30 | 2002-11-08 | 51d? |  | GP | 3264h | 3264h | AGbEnFS | Vodafone | jose-luis.carrizo@vodafone.co.uk | Rel-6 | Paolo |  |
| 1202 | 25.1 | **Feasibility study on A/Gb enhancements** | 51d? | 2002-08-30 A | 2002-11-08 A | 100% | 2002-08-30 | 2002-11-08 | 51d? |  | G2 | 2856h | 2856h | AGbEnFS-FS |  |  | Rel-6 | Juha |  |
| 1203 | 25.1.1 | Requirements for the support of conversational services | 51d | 2002-08-30 A | 2002-11-08 A | 100% | 2002-08-30 | 2002-11-08 | 51d | finish no earlier than 2002-11-08 | GP | 408h | 408h |  |  |  | Rel-6 | Paolo |  |
| 1204 | 356.1.2 | Identification of the different building blocks for the provision of conversational services on the existing A/Gb protocol stack | 51d? | 2002-08-30 A | 2002-11-08 A | 100% | 2002-08-30 | 2002-11-08 | 51d? | finish no earlier than 2002-11-08 | GP | 408h | 408h |  |  |  | Rel-6 | Paolo |  |
| 1205 | 356.1.3 | Outline of impact and feasibility of these building blocks and their different solutions | 51d? | 2002-08-30 A | 2002-11-08 A | 100% | 2002-08-30 | 2002-11-08 | 51d? | finish no earlier than 2002-11-08 | GP | 408h | 408h |  |  |  | Rel-6 | Paolo |  |
| 1206 | 25.1.4 | Impact on 3GPP architecture and requirement to co-ordinatge with other TSGs (CN, SA) | 51d | 2002-08-30 A | 2002-11-08 A | 100% | 2002-08-30 | 2002-11-08 | 51d | finish no earlier than 2002-11-08 | GP | 408h | 408h |  |  |  | Rel-6 | Paolo |  |
| 1207 | 25.1.5 | Standardisation effort | 51d | 2002-08-30 A | 2002-11-08 A | 100% | 2002-08-30 | 2002-11-08 | 51d | finish no earlier than 2002-11-08 | GP | 408h | 408h |  |  |  | Rel-6 | Paolo |  |
| 1208 | 25.1.6 | Dependency to other features | 51d | 2002-08-30 A | 2002-11-08 A | 100% | 2002-08-30 | 2002-11-08 | 51d | finish no earlier than 2002-11-08 | GP | 408h | 408h |  |  |  | Rel-6 | Paolo |  |
| 1209 | 26 | **Flexible Layer One for GERAN** | 1170d | 2000-01-03 A | 2004-06-25 A | 100% | 2000-01-03 | 2004-06-25 | 1170d |  | GP | 71535h | 71535h | FLOGER | Nokia | benoist.sebire@nokia.com | Rel-6 | Paolo |  |
| 1210 | 26.1 | **Realisation of a Flexible Layer One** | 1125d | 2000-01-03 A | 2004-04-23 A | 100% | 2000-01-03 | 2004-04-23 | 1125d |  | GP | 42808h | 42808h | FLOGER-Real | Nokia | benoist.sebire@nokia.com | Rel-6 | Paolo |  |
| 1211 | 26.1.1 | Technical Report | 471d | 2002-04-19 A | 2004-02-06 A | 100% | 2002-04-19 | 2004-02-06 | 471d | finish no earlier than 2004-02-06 | GP | 3768h | 3768h |  |  |  | Rel-6 | Paolo |  |
| 1212 | 26.1.2 | Architecture in 45.001 and 43.051 | 526d | 2002-04-19 A | 2004-04-23 A | 100% | 2002-04-19 | 2004-04-23 | 526d | finish no earlier than 2004-04-23 | G1 | 4208h | 4208h |  |  |  | Rel-6 |  |  |
| 1213 | 26.1.3 | Multiplexing in 45.002 | 526d | 2002-04-19 A | 2004-04-23 A | 100% | 2002-04-19 | 2004-04-23 | 526d | finish no earlier than 2004-04-23 | G1 | 4208h | 4208h |  |  |  | Rel-6 |  |  |
| 1214 | 26.1.4 | Channel Coding in 45.003 | 526d | 2002-04-19 A | 2004-04-23 A | 100% | 2002-04-19 | 2004-04-23 | 526d | finish no earlier than 2004-04-23 | G1 | 4208h | 4208h |  |  |  | Rel-6 |  |  |
| 1215 | 26.1.5 | Performance Requirements in 45.005 | 1125d | 2000-01-03 A | 2004-04-23 A | 100% | 2000-01-03 | 2004-04-23 | 1125d | finish no earlier than 2004-04-23 | G1 | 9000h | 9000h |  |  |  | Rel-6 |  |  |
| 1216 | 26.1.6 | Radio subsystem link control in 45.008 | 526d | 2002-04-19 A | 2004-04-23 A | 100% | 2002-04-19 | 2004-04-23 | 526d | finish no earlier than 2004-04-23 | G1 | 4208h | 4208h |  |  |  | Rel-6 |  |  |
| 1217 | 26.1.7 | Requirements in 44.004 | 526d | 2002-04-19 A | 2004-04-23 A | 100% | 2002-04-19 | 2004-04-23 | 526d | finish no earlier than 2004-04-23 | G2 | 4208h | 4208h |  |  |  | Rel-6 | Juha |  |

Notes:
- 1193: A Sultan merged "Presence Service Enhancements" (UID31028, PRES1) to this feature as no answer was provided on why Presence and Presence Encmts had same target completion date
- 1196: Dependency to 2 IETF drafts, no known work at the moment
- 1197: No Contributions so far - only requires a little work
- 1199: LSs handled in SA3. WID approved SA#17 Contribution at S3#25 & following e-mail discussion. Marked as closed 12/2008 (was marked 90% complete)
- 1200: Updated according to SP-040232
- 1201: Closed
- 1209: Nokia, Ericsson, Siemens, Telia

| ID | WBS | Task | Type | Duration | Start | Finish | Complete | Baseline start | Baseline finish | Baseline duration | Constraint | Resources | Work | Actual work | Text1 | Text4 | Text5 | Text6 | Text8 | Text12 | Text3 |
| --- | --- | --- | --- | --- | --- | --- | --- | --- | --- | --- | --- | --- | --- | --- | --- | --- | --- | --- | --- | --- | --- |
| 1218 | 26.2 | **Signalling and protocol support for a Flexible Layer One** |  | 571d | 2002-04-19 A | 2004-06-25 A | 100% | 2002-04-19 | 2004-06-25 | 571d |  | G2 | 13704h | 13704h | FLOGER-SigPro | Nokia | benoist.sebire@nokia.com | Rel-6 | Juha |  |  |
| 1219 | 26.2.1 | Modifications to RLC/MAC in 44.060 and 44.160 |  | 571d | 2002-04-19 A | 2004-06-25 A | 100% | 2002-04-19 | 2004-06-25 | 571d | finish no earlier than 2004-06-25 | G2 | 4568h | 4568h |  |  |  | Rel-6 | Juha |  |  |
| 1220 | 26.2.2 | Modifications to RRC in 44.118 and 44.018 |  | 571d | 2002-04-19 A | 2004-06-25 A | 100% | 2002-04-19 | 2004-06-25 | 571d | finish no earlier than 2004-06-25 | G2 | 4568h | 4568h |  |  |  | Rel-6 | Juha |  |  |
| 1221 | 26.3 | **Security for a Flexible Layer One** |  | 356d | 2002-04-19 A | 2003-08-29 A | 100% | 2002-04-19 | 2003-08-29 | 356d |  | S3, G2 | 5663.03h | 5663.03h | FLOGER-SecFLO | Nokia | benoist.sebire@nokia.com | Rel-6 | Dionisio |  |  |
| 1222 | 26.3.1 | Ciphering in 44.160,44.118, 44.060 and 44.018 |  | 356d | 2002-04-19 A | 2003-08-29 A | 100% | 2002-04-19 | 2003-08-29 | 356d | finish no earlier than 2003-08-29 | S3, G2 | 2848h | 2848h |  |  |  | Rel-6 | Dionisio |  |  |
| 1223 | 26.4 | **Deleted at TSG#27 - GERAN MS Conformance test for the Flexible Layer One - DELETE** |  | 0d | 2004-02-06 A | 2004-02-06 A | 100% | 2004-02-06 | 2004-02-06 | 0d |  | G4,G5 |  |  | FLOGER-Msconf | Nokia | benoist.sebire@nokia.com | Rel-6 | Paolo | GP-22 |  |
| 1224 | 26.4.1 | Deleted at TSG #27 - MS Test in 51.010 | milestone | 0d | 2004-02-06 A | 2004-02-06 A | 100% | 2004-02-06 | 2004-02-06 | 0d | finish no earlier than 2004-02-06 | G4,G5 |  |  |  |  |  | Rel-6 | Paolo | GP-22 |  |
| 1225 | 26.5 | **Deleted at TSG#27 - GERAN BTS Conformance test for the Flexible Layer One - DELETE** |  | 0d | 2004-02-06 A | 2004-02-06 A | 100% | 2004-02-06 | 2004-02-06 | 0d |  | G3new |  |  | FLOGER-BTSconf | Nokia | benoist.sebire@nokia.com | Rel-6 | Ingbert | GP-22 |  |
| 1226 | 26.5.1 | Deleted at TGS #27 - BTS Test in 51.021 - DELETE | milestone | 0d | 2004-02-06 A | 2004-02-06 A | 100% | 2004-02-06 | 2004-02-06 | 0d | finish no earlier than 2004-02-06 | G3new |  |  |  |  |  | Rel-6 | Ingbert | GP-22 |  |
| 1227 | 27 | Uplink TDOA feasibility study |  | 151d | 2001-11-30 A | 2002-06-28 A | 100% | 2001-11-30 | 2002-06-28 | 151d | finish no earlier than 2002-06-28 | GP | 1208h | 1208h | TDOAF | TruePosition | Bob Gross (rlgross@trueposition.com) | Rel-6 | Paolo |  | 45.811 |
| 1228 | 28 | **Multimedia Broadcast and Multicast Service** |  | 1781d? | 2001-05-11 A | 2008-03-07 A | 100% | 2001-05-11 | 2008-03-07 | 1781d? |  | S1,S2,S4,S5,RP,GP | 144311h | 144311h | MBMS |  |  | Rel-6 | Alain |  |  |
| 1229 | 28.1 | Stage 1 |  | 232d | 2001-05-11 A | 2002-04-01 A | 100% | 2001-05-11 | 2002-04-01 | 232d | finish no earlier than 2002-04-01 | S1 | 1856h | 1856h | MBMS |  |  | Rel-6 | Alain |  | 22.146, 22.101 |
| 1230 | 28.2 | **Stage 2** |  | 648d | 2001-09-24 A | 2004-03-17 A | 100% | 2001-09-24 | 2004-03-17 | 648d |  | S2 | 10408h | 10408h | MBMS |  |  | Rel-6 | Maurice |  |  |
| 1231 | 28.2.1 | TR on Architectural Study |  | 240d | 2001-09-24 A | 2002-08-23 A | 100% | 2001-09-24 | 2002-08-23 | 240d | finish no earlier than 2002-08-23 | S2 | 1920h | 1920h | MBMS |  |  | Rel-6 | Maurice |  | 23.846 |
| 1232 | 28.2.2 | Stage 2 Specification Work |  | 413d | 2002-08-19 A | 2004-03-17 A | 100% | 2002-08-19 | 2004-03-17 | 413d | finish no earlier than 2004-03-17 | S2 | 3304h | 3304h | MBMS |  |  | Rel-6 | Maurice |  | 23.246 |
| 1233 | 28.3 | **Introduction of MBMS in RAN** |  | 967d? | 2002-01-01 A | 2005-09-15 A | 100% | 2002-01-01 | 2005-09-15 | 967d? |  | R2 | 15992h | 15992h | MBMS-RAN | Nokia | juho.pirskanen@nokia.com | Rel-6 | Joern |  | 25.346, 25.304, 25.321, 25.322, 25.323, 25.331 |
| 1234 | 359.3.1 | Introduction of MBMS in RAN (physical & upper layers, access network interfaces) |  | 771d? | 2002-01-01 A | 2004-12-14 A | 100% | 2002-01-01 | 2004-12-14 | 771d? | finish no earlier than 2004-12-14 | R2 | 6168h | 6168h | MBMS-RAN | Nokia | juho.pirskanen@nokia.com | Rel-6 | Joern |  | 25.346, 25.304, 25.321, 25.322, 25.323 |
| 1235 | 359.3.2 | UE Performance Requirements for MBMS |  | 261d? | 2004-09-15 A | 2005-09-15 A | 100% | 2004-09-15 | 2005-09-15 | 261d? | finish no earlier than 2005-09-15 | R4 | 2088h | 2088h | MBMS-RAN-RF | Ericsson | Torgny.Palenius@ericsson.com | Rel-6 | Stefania |  | 25.101, 25.133 |
| 1236 | 28.4 | Support of the MBMS in CN protocols |  | 647d | 2002-06-18 A | 2004-12-08 A | 100% | 2002-06-18 | 2004-12-08 | 647d | finish no earlier than 2004-12-08 | N1 | 5176h | 5176h | MBMS |  |  | Rel-6 | Frederic |  |  |
| 1237 | 359.5 | Gmb interface for MBMS (CN3 part) |  | 334d | 2003-08-29 A | 2004-12-08 A | 100% | 2003-08-29 | 2004-12-08 | 334d | finish no earlier than 2004-12-08 | N3 | 2672h | 2672h | MBMS |  |  | Rel-6 | Gwiho |  | 29.061 |
| 1238 | 28.5 | Security Aspects of MBMS |  | 710d | 2002-07-01 A | 2005-03-18 A | 100% | 2002-07-01 | 2005-03-18 | 710d | finish no earlier than 2005-03-18 | S3 | 5680h | 5680h | MBMS |  | adrian.escott@three.co.uk | Rel-6 | Dionisio |  |  |
| 1239 | 28.6 | **Support of MBMS in GERAN** |  | 892d? | 2001-08-30 A | 2005-01-28 A | 100% | 2001-08-30 | 2005-01-28 | 892d? |  | GP | 71040h | 71040h | MBMS-GERAN |  |  | Rel-6 | Paolo |  |  |
| 1240 | 28.6.1 | Impact on the logical and physical channels |  | 631d | 2002-08-30 A | 2005-01-28 A | 100% | 2002-08-30 | 2005-01-28 | 631d | finish no earlier than 2005-01-28 | GP | 5048h | 5048h | MBMS-GERAN |  |  | Rel-6 | Paolo |  |  |
| 1241 | 28.6.4 | Re-synchronisation at cell change |  | 631d | 2002-08-30 A | 2005-01-28 A | 100% | 2002-08-30 | 2005-01-28 | 631d | finish no earlier than 2005-01-28 | G2 | 5048h | 5048h | MBMS-GERAN |  |  | Rel-6 | Juha |  |  |
| 1242 | 359.7.3 | Simultaneous support of MBMS services |  | 631d? | 2002-08-30 A | 2005-01-28 A | 100% | 2002-08-30 | 2005-01-28 | 631d? | finish no earlier than 2005-01-28 | GP | 5048h | 5048h | MBMS-GERAN |  |  | Rel-6 | Paolo |  |  |
| 1243 | 359.7.4 | Simultaneous support of MBMS and non-MBMS services |  | 892d? | 2001-08-30 A | 2005-01-28 A | 100% | 2001-08-30 | 2005-01-28 | 892d? | finish no earlier than 2005-01-28 | GP | 7136h | 7136h | MBMS-GERAN |  |  | Rel-6 | Paolo |  |  |
| 1244 | 359.7.5 | Resynchronisation at cell change |  | 892d? | 2001-08-30 A | 2005-01-28 A | 100% | 2001-08-30 | 2005-01-28 | 892d? | finish no earlier than 2005-01-28 | GP | 7136h | 7136h | MBMS-GERAN |  |  | Rel-6 | Paolo |  |  |
| 1245 | 28.6.5 | Decision making process between point-to-point or pont-to-multipoint configurations |  | 631d | 2002-08-30 A | 2005-01-28 A | 100% | 2002-08-30 | 2005-01-28 | 631d | finish no earlier than 2005-01-28 | GP | 5048h | 5048h | MBMS-GERAN |  |  | Rel-6 | Paolo |  |  |
| 1246 | 28.6.6 | MBMS channel allocations procedures to multiple MSs |  | 631d | 2002-08-30 A | 2005-01-28 A | 100% | 2002-08-30 | 2005-01-28 | 631d | finish no earlier than 2005-01-28 | GP | 5048h | 5048h | MBMS-GERAN |  |  | Rel-6 | Paolo |  |  |
| 1247 | 28.6.7 | Changes to the Gb interface |  | 631d | 2002-08-30 A | 2005-01-28 A | 100% | 2002-08-30 | 2005-01-28 | 631d | finish no earlier than 2005-01-28 | GP | 5048h | 5048h | MBMS-GERAN |  |  | Rel-6 | Paolo |  |  |
| 1248 | 28.6.8 | GERAN specific changes to the Iu-ps interface |  | 631d | 2002-08-30 A | 2005-01-28 A | 100% | 2002-08-30 | 2005-01-28 | 631d | finish no earlier than 2005-01-28 | GP | 5048h | 5048h | MBMS-GERAN |  |  | Rel-6 | Paolo |  |  |
| 1249 | 28.6.9 | Interaction between MBMS and Iu-flex |  | 631d | 2002-08-30 A | 2005-01-28 A | 100% | 2002-08-30 | 2005-01-28 | 631d | finish no earlier than 2005-01-28 | GP | 5048h | 5048h | MBMS-GERAN |  |  | Rel-6 | Paolo |  |  |
| 1250 | 28.6.10 | Security aspects |  | 631d | 2002-08-30 A | 2005-01-28 A | 100% | 2002-08-30 | 2005-01-28 | 631d | finish no earlier than 2005-01-28 | GP | 5048h | 5048h | MBMS-GERAN |  |  | Rel-6 | Paolo |  |  |
| 1251 | 359.7.12 | MS conformance tests- G3 |  | 786d? | 2002-01-25 A | 2005-01-28 A | 100% | 2002-01-25 | 2005-01-28 | 786d? | finish no earlier than 2005-01-28 | G3new | 6288h | 6288h | MBMS-GERAN |  |  | Rel-6 | Ingbert |  |  |
| 1252 | 359.7.13 | Deleted - MS conformance tests - G5 | milestone | 0d? | 2003-06-27 A | 2003-06-27 A | 100% | 2003-06-27 | 2003-06-27 | 0d? | start no earlier than 2003-06-27 | G5 |  |  | MBMS-GERAN |  |  | Rel-6 | Paolo | GP-19 |  |

Notes:
- 1223: DELETE
- 1224: DELETE
- 1225: DELETE
- 1226: DELETE
- 1228: Title renamed at SA#13
- 1229: This may or may not be a separate stage 1. In the meantime, CRs are proposed for 22.101
- 1234: Was "Introduction of MBMS in RAN" before RP#25. Created w/o WIDS after RAN approved the WT for RF aspects.Take WIDS from the parent BB
- 1235: Approved at RP#25 as RP-040370
- 1238: WID approved SA#17. 2004-12: Expected completion March 2005
- 1239: Completed
- 1251: Under evaluation

| ID | WBS | Task | Type | Duration | Start | Finish | Complete | Baseline start | Baseline finish | Baseline duration | Constraint | Deadline | Resources | Work | Actual work | Text1 | Text6 | Text8 | Text4 | Text5 | Text10 | Text12 |
| --- | --- | --- | --- | --- | --- | --- | --- | --- | --- | --- | --- | --- | --- | --- | --- | --- | --- | --- | --- | --- | --- | --- |
| 1253 | 28.1 | **MBMS User Services** |  | 743d? | 2003-05-13 A | 2006-03-16 A | 100% | 2003-05-13 | 2006-03-16 | 743d? |  |  | S1 | 13576h | 13576h | MBMS | Rel-6 | Alain |  |  |  |  |
| 1254 | 28.1 | MBMS User Services Stage 1 |  | 233d | 2003-05-13 A | 2004-04-01 A | 100% | 2003-05-13 | 2004-04-01 | 233d | start no earlier than 2003-05-13 |  | S1 | 1864h | 1864h | MBMS | Rel-6 | Alain |  |  |  |  |
| 1255 | 359.8.2 | Definition of MBMS user services, media codecs, formats and transport/application protocols using MBMS |  | 721d? | 2003-06-12 A | 2006-03-16 A | 100% | 2003-06-12 | 2006-03-16 | 721d? | finish no earlier than 2006-03-16 |  | S4 | 5768h | 5768h | MBMS-TSMBMS | Rel-6 | Paolo | Nokia | igor.curcio@nokia.com |  |  |
| 1256 | 359.9 | MBMS charging |  | 108d? | 2005-01-11 A | 2005-06-09 A | 100% | 2005-01-11 | 2005-06-09 | 108d? | start no earlier than 2005-01-11 |  | S5 | 864h | 864h | MBMS-CH | Rel-6 | Dionisio |  |  |  |  |
| 1257 | 359.10 | **MBMS UE Conformance Testing** |  | 521d? | 2006-03-10 A | 2008-03-07 A | 100% | 2006-03-10 | 2008-03-07 | 521d? |  |  | R5 | 17047.2h | 17047.2h | MBMS-UEConTest | Rel-6 | Ingbert |  |  |  |  |
| 1258 | 16.5.1 | RF/RRM Conformance Test Aspects – MBMS (FDD) |  | 461d | 2006-06-02 A | 2008-03-07 A | 100% | 2006-06-02 | 2008-03-07 | 461d | finish no earlier than 2008-03-07 | 2006-06-02 | R5 | 3688h | 3688h | MBMS-RAN-RF_Test | Rel-6 | Ingbert | Ericsson | leif.mattisson@ericsson.com | Fri 11/03/05 |  |
| 1259 | 359.10.2 | Conformance Test Aspects - MBMS for 3.84 Mcps and 7.68 Mcps TDD |  | 318d? | 2006-09-20 A | 2007-12-07 A | 100% | 2006-09-20 | 2007-12-07 | 318d? | finish no earlier than 2007-12-07 |  | R5 | 2544h | 2544h | MBMS-UEConTest_TDH | Rel-6 | Ingbert | IPWireless | Timothy Speight (tspeight@ipwireless.com) |  |  |
| 1260 | 359.10.3 | Signalling Conformance Test Aspects – MBMS for LCR TDD |  | 318d? | 2006-09-20 A | 2007-12-07 A | 100% | 2006-09-20 | 2007-12-07 | 318d? | finish no earlier than 2007-12-07 |  | R5 | 2544h | 2544h | MBMS-UEConTest_SIGTDL | Rel-6 | Ingbert | DATANG | zhaojian@datangmobile.cn |  |  |
| 1261 | 359.10.4 | Conformance Test Aspects – MBMS |  | 396d? | 2006-03-10 A | 2007-09-14 A | 100% | 2006-03-10 | 2007-09-14 | 396d? | finish no earlier than 2007-09-14 |  | R5 | 3168h | 3168h | MBMS_Test | Rel-6 | Ingbert | Qualcomm | Shubhang Vora (svora@qualcomm.com) |  |  |
| 1262 | 16.5.1 | Conformance Test Aspects - 1.28Mcps TDD MBMS RF/RRM |  | 136d | 2007-06-01 A | 2007-12-07 A | 100% | 2007-06-01 | 2007-12-07 | 136d | finish no earlier than 2007-12-07 | 2006-06-02 | R5 | 1088h | 1088h | MBMS-UEConTest_RFTDL | Rel-6 | Ingbert | Datang Mobile | chenxiaozhong@datangmobile.cn | Fri 11/03/05 |  |
| 1263 | 29 | **Speech Recognition and Speech Enabled Services** |  | 1105d? | 2001-10-08 A | 2005-12-30 A | 100% | 2001-10-08 | 2005-12-30 | 1105d? |  |  | S1 | 20176h | 20176h | SRSES | Rel-6 | Alain |  |  |  |  |
| 1264 | 29.1 | Speech Enabled Services Based on Distributed Speech Recognition (DSR) |  | 115d | 2001-10-08 A | 2002-03-15 A | 100% | 2001-10-08 | 2002-03-15 | 115d | finish no earlier than 2002-03-15 |  | S1 | 920h | 920h | DSR | Rel-6 | Alain | Qualcomm | Dwilliams@qualcomm.com |  |  |
| 1265 | 29.2 | TR on Architectural impacts |  | 212d | 2003-05-12 A | 2004-03-02 A | 100% | 2003-05-12 | 2004-03-02 | 212d | finish no earlier than 2004-03-02 |  | S2 | 1696h | 1696h |  | Rel-6 |  |  |  |  |  |
| 1266 | 360.3 | Codec Work to Support Speech Recognition Framework for Automated Voice Services |  | 568d? | 2002-10-15 A | 2004-12-16 A | 100% | 2002-10-15 | 2004-12-16 | 568d? | finish no earlier than 2004-12-16 |  | S4 | 4544h | 4544h | SRSES-Codec | Rel-6 | Paolo | Motorola | David Pearce (bdp003@motorola.com) |  |  |
| 1267 | 360.4 | Multimodal support |  | 522d? | 2004-01-01 A | 2005-12-30 A | 100% | 2004-01-01 | 2005-12-30 | 522d? | finish no earlier than 2005-06-30 |  | OMA | 4176h | 4176h |  | Rel-6 |  |  | OMA-LIAISON@mail.openmobilealliance.org | SP-24 |  |
| 1268 | 360.5 | Deleted - SES codec negotiation at SDP | milestone | 0d? | 2003-06-04 A | 2003-06-04 A | 100% | 2003-06-04 | 2003-06-04 | 0d? | start no earlier than 2003-06-04 |  | N1 |  |  |  | Rel-6 | Frederic |  |  |  | NP-23 |
| 1269 | 30 | **Generic User Profile Rel-6** |  | 889d | 2001-10-08 A | 2005-03-03 A | 100% | 2001-10-08 | 2005-03-03 | 889d |  |  | S1 | 24295.8h | 24295.8h | GUP | Rel-6 | Alain |  |  |  |  |
| 1270 | 30.1 | Stage 1 - Requirements |  | 430d | 2001-10-08 A | 2003-05-30 A | 100% | 2001-10-08 | 2003-05-30 | 430d | finish no earlier than 2002-12-09 |  | S1 | 3440h | 3440h |  | Rel-6 | Alain | T-Mobile | kurt.bischinger@t-mobile.at |  |  |
| 1271 | 30.3 | Stage 2 - Architecture |  | 355d | 2002-01-28 A | 2003-06-06 A | 100% | 2002-01-28 | 2003-06-06 | 355d | finish no earlier than 2003-06-06 |  | S2 | 2840h | 2840h |  | Rel-6 | Maurice | Nokia | harri.o.koskinen@nokia.com |  |  |
| 1272 | 30.2 | Stage 2 - Data Description Method |  | 586d | 2002-12-05 A | 2005-03-03 A | 100% | 2002-12-05 | 2005-03-03 | 586d | finish no earlier than 2005-03-03 |  | N4 | 4688h | 4688h |  | Rel-6 | Kimmo | T-Mobile | kurt.bischinger@t-mobile.at |  |  |
| 1273 | 30.5 | Stage 3 - Network |  | 468.98d | 2003-05-19 A | 2005-03-03 A | 100% | 2003-05-19 | 2005-03-03 | 468.98d | finish no earlier than 2005-03-03 |  | N4 | 3751.83h | 3751.83h |  | Rel-6 | Kimmo |  |  |  |  |
| 1274 | 30.6 | Security Aspects |  | 308d | 2002-07-16 A | 2003-09-18 A | 100% | 2002-07-16 | 2003-09-18 | 308d | finish no earlier than 2003-09-18 |  | S3 | 2464h | 2464h |  | Rel-6 | Dionisio | Lucent | Owen, Bradley (bvowen@lucent.com) |  |  |
| 1275 | 31 | **Digital Rights Management** |  | 690d? | 2001-10-08 A | 2004-05-28 A | 100% | 2001-10-08 | 2004-05-28 | 690d? |  |  | S1 | 10152h | 10152h | DRM | Rel-6 | Alain |  |  |  |  |
| 1276 | 31.1 | Requirements |  | 179d | 2001-10-08 A | 2002-06-13 A | 100% | 2001-10-08 | 2002-06-13 | 179d | finish no earlier than 2002-06-13 |  | S1 | 1432h | 1432h |  | Rel-6 | Alain | Openwave | nicholas.wood@openwave.com |  |  |
| 1277 | 362.2 | Stage 2 |  | 107d? | 2004-01-01 A | 2004-05-28 A | 100% | 2004-01-01 | 2004-05-28 | 107d? | finish no earlier than 2004-05-28 |  | OMA | 856h | 856h |  | Rel-6 |  |  | OMA-LIAISON@mail.openmobilealliance.org | SP-24 |  |
| 1278 | 362.3 | Stage 3 |  | 107d? | 2004-01-01 A | 2004-05-28 A | 100% | 2004-01-01 | 2004-05-28 | 107d? | finish no earlier than 2004-05-28 |  | OMA | 856h | 856h |  | Rel-6 |  |  | OMA-LIAISON@mail.openmobilealliance.org | SP-24 |  |
| 1279 | 31.3 | Security |  | 186d | 2002-06-17 A | 2003-03-03 A | 100% | 2002-06-17 | 2003-03-03 | 186d | finish no earlier than 2003-03-03 |  | OMA | 1488h | 1488h |  | Rel-6 |  |  |  |  |  |
| 1280 | 362.5 | Deleted - Monitoring of Stages 2 and 3 progress (actual work to be done by OMA) | milestone | 0d? | 2003-03-21 A | 2003-03-21 A | 100% | 2003-03-21 | 2003-03-21 | 0d? | start no earlier than 2002-08-19 |  | S1 |  |  |  | Rel-6 | Alain |  |  |  | SP-19 |

Notes:
- 1253: Text3: 22.246
- 1254: Text3: 22.246
- 1255: TR26.946 tbc by March 06 / Text3: 26.346, 26.936, 26.946
- 1256: SA#28 06/2005 completed / Text3: 32.273
- 1257: BB place holder for a number of RAN5 Tasks. Moved in from the Stoyan/Testing WP / Text3: 34.108, 34.109, 34.121-1, 34.121-2, 34.122, 34.123-1, 34.123-2, 34.123-3
- 1258: TS 34.109 is under RAN2; RAN5 need to identify possible new requirements on UE test loop functionality to enable testing / Text3: 34.108, 34.109, 34.121-1, 34.121-2
- 1259: Text3: 34.108, 34.122, 34.123-1, 34.123-2, 34.123-3
- 1260: Text3: 34.108, 34.123-1, 34.123-2, 34.123-3
- 1261: Text3: 34.108, 34.123-1, 34.123-2, 34.123-3
- 1262: Text3: 34.108, 34.109, 34.122
- 1264: Text3: 22.941, 23.207, 22.243
- 1265: Text3: 23.877
- 1266: Completed / Text3: 26.235, 26.236, 26.243, 26.177, 26.943
- 1268: Abandoned NP-23
- 1270: Text3: 22.240, 22.228
- 1271: Text3: 23.240
- 1272: TR approved in CN#26 / Text3: 23.241
- 1273: 17 May no activity in CN4............ / Text3: 29.240
- 1274: WID approved SA#17. SA WG3 progress slow, depends on progress in other groups. / Text3: 33.102, 33.203, 33.210
- 1275: Foreseen start and completion dates introduced by MCC (no indication at all on the WID)
- 1279: SA3 acknowledge role in WI at SA3#20. Active contribution S3#24, S3#25. S3 WID approved SA#17
- 1280: Replaced by UID 60005 and 60006

| ID | WBS | Task | Duration | Start | Finish | Complete | Baseline start | Baseline finish | Baseline duration | Constraint | Resources | Work | Actual work | Text1 | Text4 | Text5 | Text6 | Text8 | Text3 | Text10 |
| --- | --- | --- | --- | --- | --- | --- | --- | --- | --- | --- | --- | --- | --- | --- | --- | --- | --- | --- | --- | --- |
| 1281 | 32 | **WLAN-UMTS Interworking Rel-6** | 1494d? | 2000-01-03 A | 2005-09-22 A | 100% | 2000-01-03 | 2005-09-22 | 1494d? |  | S1 | 48464h | 48464h | WLAN | Telenor | frederic.paint@telenor.com | Rel-6 | Alain |  |  |
| 1282 | 32.1 | Technical Report | 900d? | 2000-01-03 A | 2003-06-13 A | 100% | 2000-01-03 | 2003-06-13 | 900d? | finish no earlier than 2003-06-13 | S1 | 7200h | 7200h | WLAN-TR | Telenor | frederic.paint@telenor.com | Rel-6 | Alain | 22.934, 22.101, 22.105 |  |
| 1283 | 363.2 | **Stage 1** | 375d? | 2003-01-06 A | 2004-06-11 A | 100% | 2003-01-06 | 2004-06-11 | 375d? |  | S1 | 3920h | 3920h | WLAN-TS | Telenor | frederic.paint@telenor.com | Rel-6 | Alain | 22.234 | SP-24 |
| 1284 | 363.2.1 | Global stage 1 | 375d? | 2003-01-06 A | 2004-06-11 A | 100% | 2003-01-06 | 2004-06-11 | 375d? | finish no earlier than 2004-06-11 | S1 | 3000h | 3000h | WLAN-TS | Telenor | frederic.paint@telenor.com | Rel-6 | Alain | 22.234 | SP-24 |
| 1285 | 32.2 | Architecture Definition for scenarii 2 and 3 | 571d | 2002-03-25 A | 2004-05-31 A | 100% | 2002-03-25 | 2004-05-31 | 571d | finish no earlier than 2004-05-31 | S2 | 4568h | 4568h |  |  |  | Rel-6 | Maurice | 23.234 |  |
| 1286 | 32.3 | Security | 125d | 2002-09-30 A | 2003-03-21 A | 100% | 2002-09-30 | 2003-03-21 | 125d | finish no earlier than 2003-03-21 | S3 | 1000h | 1000h |  | Ericsson | luis.lopez-soria@ece.ericsson.se | Rel-6 | Dionisio | 21.133, 33.106, 33.107, 33.108, 33.200, 33.203, 33.210 |  |
| 1287 | 363.5 | Stage 3 - CN4 aspects | 334d? | 2003-05-23 A | 2004-09-01 A | 100% | 2003-05-23 | 2004-09-01 | 334d? | finish no earlier than 2004-09-01 | N4 | 2672h | 2672h | WLAN-IW | Nokia | raquel.rodriguez@nokia.com | Rel-6 | Kimmo | 29.234, 29.061 |  |
| 1288 | 363.6 | Stage 3 - CN3 aspects (Wi Interface for Scenario 3) | 355d? | 2003-05-23 A | 2004-09-30 A | 100% | 2003-05-23 | 2004-09-30 | 355d? | start no earlier than 2003-05-23 | N3 | 2840h | 2840h | WLAN |  |  | Rel-6 | Gwiho | 29.161 | SP-24 |
| 1289 | 363.7 | Stage 3 for scenario 2 | 339d? | 2003-05-23 A | 2004-09-08 A | 100% | 2003-05-23 | 2004-09-08 | 339d? | finish no earlier than 2004-09-08 | N1 | 2712h | 2712h |  |  |  | Rel-6 | Frederic |  |  |
| 1290 | 363.8 | Stage 3 for scenario 3 | 404d? | 2003-05-23 A | 2004-12-08 A | 100% | 2003-05-23 | 2004-12-08 | 404d? | finish no earlier than 2004-12-08 | N1 | 3232h | 3232h |  |  |  | Rel-6 | Frederic |  | SP-24 |
| 1291 | 363.9 | WLAN charging | 655d? | 2003-03-21 A | 2005-09-22 A | 100% | 2003-03-21 | 2005-09-22 | 655d? | finish no earlier than 2005-09-22 | S5 | 5240h | 5240h | WLAN-CH | Nokia | Benni ALEXANDER | Rel-6 | Dionisio | 32.252 |  |
| 1292 | 363.10 | USIM enhancements for WLAN Interworking | 391d? | 2003-09-05 A | 2005-03-04 A | 100% | 2003-09-05 | 2005-03-04 | 391d? | finish no earlier than 2005-03-04 | T3 | 3128h | 3128h |  | Axalto | Jabellan@axalto.com | Rel-6 |  |  |  |
| 1293 | 33 | **Priority Service** | 347d? | 2002-05-30 A | 2003-09-26 A | 100% | 2002-05-30 | 2003-09-26 | 347d? |  | S1 | 6464h | 6464h | NTShar |  |  | Rel-6 | Alain |  |  |
| 1294 | 33.1 | Feasibility Study | 1d | 2002-06-14 A | 2002-06-14 A | 100% | 2002-06-14 | 2002-06-14 | 1d | finish no earlier than 2002-06-14 | S1 | 8h | 8h | PRIOR-FS | Telcordia | Biplab K. Pramanik (bpramani@telcordia.com) | Rel-6 | Alain | 22.950 |  |
| 1295 | 33.2 | Stage 1 - Requirements | 340d | 2002-05-30 A | 2003-09-17 A | 100% | 2002-05-30 | 2003-09-17 | 340d | finish no earlier than 2003-09-17 | S1 | 2720h | 2720h | PRIOR-SR | Telcordia | James J. Garrahan (bpramani@telcordia.com) | Rel-6 | Alain |  |  |
| 1296 | 364.3 | Priority service implementation guide | 131d? | 2003-03-28 A | 2003-09-26 A | 100% | 2003-03-28 | 2003-09-26 | 131d? | finish no earlier than 2003-09-26 | S1 | 1048h | 1048h |  | Telcordia | Biplab K. Pramanik (bpramani@telcordia.com) | Rel-6 | Alain | 22.952 |  |
| 1297 | 34 | **Network Sharing** | 498d? | 2003-01-20 A | 2004-12-15 A | 100% | 2003-01-20 | 2004-12-15 | 498d? |  | S1 | 16608h | 16608h | NTShar |  |  | Rel-6 | Alain |  |  |
| 1298 | 34.1 | Technical Report | 240d? | 2003-01-20 A | 2003-12-19 A | 100% | 2003-01-20 | 2003-12-19 | 240d? |  | S1 | 1920h | 1920h | NTShar-TR |  |  | Rel-6 | Alain | 22.951 |  |
| 1299 | 365.2 | Stage 1 - CRs to implement Network Sharing | 240d? | 2003-01-20 A | 2003-12-19 A | 100% | 2003-01-20 | 2003-12-19 | 240d? | finish no earlier than 2003-12-19 | S1 | 1920h | 1920h | NTShar-CR |  |  | Rel-6 | Alain | 22.011, 22.101, 22.115, 22.129 |  |
| 1300 | 365.3 | Stage 2 | 372d? | 2003-02-27 A | 2004-07-30 A | 100% | 2003-02-27 | 2004-07-30 | 372d? | finish no earlier than 2004-07-30 | S2 | 2976h | 2976h |  |  |  | Rel-6 | Maurice | 23.251 |  |
| 1301 | 365.4 | Network sharing - stage 3 | 404d? | 2003-05-23 A | 2004-12-08 A | 100% | 2003-05-23 | 2004-12-08 | 404d? | finish no earlier than 2004-12-08 | N1 | 3232h | 3232h |  |  |  | Rel-6 | Frederic |  |  |
| 1302 | 365.5 | Enhancement of the support of network sharing in the UTRAN | 324d | 2003-09-19 A | 2004-12-15 A | 100% | 2003-09-19 | 2004-12-15 | 324d | finish no earlier than 2004-12-15 | R2 | 2592h | 2592h | NTShar-UTRANEnh | TeliaSonera | Anders.Dahlen@TeliaSonera.com | Rel-6 | Joern | 25.401, 25.413, 25.331, 25.304 |  |
| 1303 | 35 | **QoS Improvements** | 628d? | 2002-07-15 A | 2004-12-08 A | 100% | 2002-07-15 | 2004-12-08 | 628d? |  | S2 | 13128h | 13128h | QoS1 | Nokia |  | Rel-6 | Maurice |  |  |
| 1304 | 35.1 | FS on Dynamic Policy control enhancements for end-to-end QoS | 465d | 2002-07-15 A | 2004-04-23 A | 100% | 2002-07-15 | 2004-04-23 | 465d | finish no earlier than 2004-04-23 | S2 | 3720h | 3720h | QoS1 | Norte | Claire Mousset | Rel-6 | Maurice | 23.917 |  |
| 1305 | 366.2 | Definition of the Gq interface | 214d? | 2003-07-01 A | 2004-04-23 A | 100% | 2003-07-01 | 2004-04-23 | 214d? | finish no earlier than 2004-04-23 | S2 | 1712h | 1712h |  |  | Janne Rinne | Rel-6 |  | 23.221 |  |
| 1306 | 366.3 | Gq interface specification for Dynamic Policy control enhancements – Stage 3 | 334d | 2003-08-29 A | 2004-12-08 A | 100% | 2003-08-29 | 2004-12-08 | 334d | finish no earlier than 2004-12-08 | N3 | 2672h | 2672h |  | Nokia | Anna.Sillanpaai@nokia.com | Rel-6 | Gwiho | 24,228, 29.207, 29.208 |  |

Notes:
- 1286: Active contribution S3#24, S3#25. WID approved SA#17
- 1287: WID approved at CN#19...............
- 1291: SA#28: delayed 09/2005. WT also under SA5 BB 35017 Charging Management for Bearer level
- 1306: [DAB - 25.05.04] - Delayed to Sept - possibly Dec 2004

| ID | WBS | Task | Type | Duration | Start | Finish | Complete | Baseline start | Baseline finish | Baseline duration | Constraint | Resources | Work | Actual work | Text1 | Text4 | Text5 | Text6 | Text8 | Text10 | Text12 |
| --- | --- | --- | --- | --- | --- | --- | --- | --- | --- | --- | --- | --- | --- | --- | --- | --- | --- | --- | --- | --- | --- |
| 1307 | 36 | **Subscriber certificates** |  | 728d? | 2002-02-25 A | 2004-12-08 A | 100% | 2002-02-25 | 2004-12-08 | 728d? |  | S3 | 12888h | 12888h | SEC1-SC | Nokia | valtteri.niemi@nokia.com | Rel-6 | Maurice |  |  |
| 1308 | 36.1 | Stage 1 |  | 144d | 2002-02-25 A | 2002-09-12 A | 100% | 2002-02-25 | 2002-09-12 | 144d | finish no earlier than 2002-09-12 | S3 | 1152h | 1152h |  |  |  | Rel-6 | Dionisio |  |  |
| 1309 | 36.2 | Architecture review |  | 24d | 2002-10-14 A | 2002-11-14 A | 100% | 2002-10-14 | 2002-11-14 | 24d | finish no earlier than 2002-11-14 | S2 | 192h | 192h |  |  |  | Rel-6 | Maurice |  |  |
| 1310 | 367.3 | Stage 3 |  | 313d? | 2003-09-19 A | 2004-11-30 A | 100% | 2003-09-19 | 2004-11-30 | 313d? | finish no earlier than 2004-11-30 | N4 | 2504h | 2504h | SEC1-SC | Nokia | Lauri Laitinen | Rel-6 | Kimmo |  |  |
| 1311 | 367.4 | Stage 3 Ua & Ub interfaces |  | 288d? | 2003-11-03 A | 2004-12-08 A | 100% | 2003-11-03 | 2004-12-08 | 288d? | finish no earlier than 2004-12-08 | N1 | 2304h | 2304h |  |  |  | Rel-6 | Frederic |  |  |
| 1312 | 367.5 | OMA dependencies on Subscriber certificates |  | 114d? | 2004-01-01 A | 2004-06-08 A | 100% | 2004-01-01 | 2004-06-08 | 114d? | finish no earlier than 2004-06-08 | OMA | 912h | 912h |  |  | OMA-LIAISON@mail.openmobilealliance.org | Rel-6 |  | SP-24 |  |
| 1313 | 368 | **Rel-6 OSA enhancements** |  | 616d? | 2002-10-31 A | 2005-03-10 A | 100% | 2002-10-31 | 2005-03-10 | 616d? |  | N5 | 22576h | 22576h | OSA3 | Alcatel | Chelo.Abarca@alcatel.fr | Rel-6 | Kimmo |  |  |
| 1314 | 368.1 | Scope of the Open Service Access Release 6 |  | 66d? | 2003-03-28 A | 2003-06-27 A | 100% | 2003-03-28 | 2003-06-27 | 66d? | finish no earlier than 2003-06-27 | S1 | 528h | 528h |  |  |  | Rel-6 | Alain |  |  |
| 1315 | 368.2 | OSA Stage 2 |  | 150d? | 2004-08-13 A | 2005-03-10 A | 100% | 2004-08-13 | 2005-03-10 | 150d? | finish no earlier than 2005-03-10 | N5 | 1200h | 1200h |  |  |  | Rel-6 | Kimmo |  |  |
| 1316 | 368.3 | Multi Media Messaging function |  | 487d? | 2002-10-31 A | 2004-09-10 A | 100% | 2002-10-31 | 2004-09-10 | 487d? | finish no earlier than 2004-09-10 | N5 | 3896h | 3896h |  |  |  | Rel-6 | Kimmo |  |  |
| 1317 | 368.4 | Policy management extensions |  | 292d? | 2002-10-31 A | 2003-12-12 A | 100% | 2002-10-31 | 2003-12-12 | 292d? | finish no earlier than 2003-12-12 | N5 | 2336h | 2336h |  |  |  | Rel-6 | Kimmo |  |  |
| 1318 | 368.5 | TS on Presence and Availability Management (from the PRESNC WI) |  | 367d? | 2002-10-31 A | 2004-03-26 A | 100% | 2002-10-31 | 2004-03-26 | 367d? | finish no earlier than 2004-03-26 | N5 | 2936h | 2936h |  |  |  | Rel-6 | Kimmo |  |  |
| 1319 | 368.6 | OSA interfaces at different levels of abstractions (Parlay X, Web services) |  | 305d? | 2003-07-14 A | 2004-09-10 A | 100% | 2003-07-14 | 2004-09-10 | 305d? | finish no earlier than 2004-09-10 | N5 | 2440h | 2440h |  |  |  | Rel-6 | Kimmo |  |  |
| 1320 | 368.7 | Introduction of migration support mechanism |  | 290d? | 2002-10-31 A | 2003-12-10 A | 100% | 2002-10-31 | 2003-12-10 | 290d? | finish no earlier than 2003-12-12 | N5 | 2320h | 2320h |  |  |  | Rel-6 | Kimmo |  |  |
| 1321 | 368.8 | Framework Function for Federation |  | 225d? | 2003-02-03 A | 2003-12-12 A | 100% | 2003-02-03 | 2003-12-12 | 225d? | finish no earlier than 2003-12-12 | N5 | 1800h | 1800h |  |  |  | Rel-6 | Kimmo |  |  |
| 1322 | 368.9 | OMA potential overlaps with 3GPP OSA Stage 3 (Web services) |  | 196d? | 2003-12-18 A | 2004-09-16 A | 100% | 2003-12-18 | 2004-09-16 | 196d? | start no earlier than 2003-12-18 | OMA | 1568h | 1568h |  |  |  | Rel-6 |  | SP-24 |  |
| 1323 | 368.10 | Deleted - TR on Presence and Availability Management (from the PRESNC WI) | milestone | 0d? | 2004-09-17 A | 2004-09-17 A | 100% | 2004-09-17 | 2004-09-17 | 0d? | start no earlier than 2004-09-17 | N5 |  |  |  |  |  | Rel-6 | Kimmo |  | NP-24 |
| 1324 | 39 | **Addition of frequency bands to GSM (TAPS)** |  | 676d | 2002-06-28 A | 2005-01-28 A | 100% | 2002-06-28 | 2005-01-28 | 676d |  | GP | 16640h | 16640h | TAPS | Nokia | Torben Themsen | Rel-6 | Paolo |  |  |
| 1325 | 39.1 | **Addition of frequency bands to GSM – Changes to core specs** |  | 26d | 2002-11-15 A | 2002-12-20 A | 100% | 2002-11-15 | 2002-12-20 | 26d |  | G1 | 416h | 416h | TAPS-Specs | Nokia | Torben Themsen | Rel-6 |  |  |  |
| 1326 | 39.1.1 | Changes to core specs |  | 26d | 2002-11-15 A | 2002-12-20 A | 100% | 2002-11-15 | 2002-12-20 | 26d | finish no earlier than 2002-12-20 | G1 | 208h | 208h |  |  |  | Rel-6 |  |  |  |
| 1327 | 39.2 | **Deleted at TSG #27 - Addition of frequency bands to GSM – Changes for conformance tests** |  | 676d | 2002-06-28 A | 2005-01-28 A | 100% | 2002-06-28 | 2005-01-28 | 676d |  | G4 | 10816h | 10816h | TAPS-Conf | Nokia | Torben Themsen | Rel-6 | Paolo |  | GP-23 |
| 1328 | 39.2.1 | Deleted at TSG #27 - 51.010-1 Add testing |  | 676d | 2002-06-28 A | 2005-01-28 A | 100% | 2002-06-28 | 2005-01-28 | 676d | finish no earlier than 2005-01-28 | G4 | 5408h | 5408h |  |  |  | Rel-6 | Paolo |  | GP-23 |
| 1329 | 40 | **Seamless support of streaming services in A/Gb mode** |  | 1425d? | 2000-01-03 A | 2005-06-17 A | 100% | 2000-01-03 | 2005-06-17 | 1425d? |  | GP | 53088h | 53088h | SSStrea | Vodafone | José Luis Carrizo Martínez | Rel-6 | Paolo |  |  |
| 1330 | 40.1 | **Identification of requirements for streaming** |  | 46d? | 2003-06-27 A | 2003-08-29 A | 100% | 2003-06-27 | 2003-08-29 | 46d? |  | G1 | 736h | 736h |  |  |  | Rel-6 |  |  |  |
| 1331 | 370.1.1 | Requirements |  | 46d? | 2003-06-27 A | 2003-08-29 A | 100% | 2003-06-27 | 2003-08-29 | 46d? | finish no earlier than 2003-08-29 | G1 | 368h | 368h |  |  |  | Rel-6 |  |  |  |

Notes:
- 1307: Approved at SA#14. This may require BBs from CN1, CN4, SA5 and T3 / Text3: 33.102
- 1308: Contribution received S3#24, S3#25
- 1310: Finished in CN4#26
- 1312: Updated according to SP-040420
- 1313: CN#25: Updated WID NP-040351 replaces NP-040144. / Text3: 22.127, 23.198, 29.198, 29.199, 29.998
- 1315: Inherited by CN5 from SA2 at TSG#25 Sep 2004. SA2's 23.127 (OSA/VHE Stage 2) replaced from Rel-6 onwards by a new CN5 TS 23.198 (Stage 2 OSA-only). / Text3: 23.198 OSA Stage 2-ONLY replaces 23.127 (OSA/VHE) from Rel-6 onwards
- 1316: Text3: 29.198-15
- 1317: Text3: 29.198, 29.998
- 1318: N5#26: Split WI into TS & TR. / Text3: 29.198-14
- 1319: Text3: 29.199
- 1320: Text3: 29.198, 29.998
- 1321: Text3: 29.198, 29.998
- 1322: TSG#25 Approved CN5 29.199 Parlay X Web services. Ongoing 3GPP/OMA co-ordination to avoid OMA producing conflicting/OVERLAPING specs (NP-040283/SP-040493).
- 1323: N5#26:TR Completion 09/04; consistent with CN1 delayed Rel-6 completion.
- 1325: Ready
- 1327: DELETE
- 1328: DELETE
- 1330: Started

| ID | WBS | Task | Duration | Start | Finish | Complete | Baseline start | Baseline finish | Baseline duration | Constraint | Resources | Work | Actual work | Text6 | Text8 | Text3 | Text4 | Text5 | Text1 |
| --- | --- | --- | --- | --- | --- | --- | --- | --- | --- | --- | --- | --- | --- | --- | --- | --- | --- | --- | --- |
| 1332 | 40.2 | **Performance study of cell change mechanisms** | 955d? | 2000-01-03 A | 2003-08-29 A | 100% | 2000-01-03 | 2003-08-29 | 955d? |  | G1 | 30560h | 30560h | Rel-6 |  |  |  |  |  |
| 1333 | 370.2.1 | Performance of NACC | 955d? | 2000-01-03 A | 2003-08-29 A | 100% | 2000-01-03 | 2003-08-29 | 955d? | finish no earlier than 2003-08-29 | G1 | 7640h | 7640h | Rel-6 |  |  |  |  |  |
| 1334 | 370.2.2 | Performance of cell change in DTM for the PS domain | 955d? | 2000-01-03 A | 2003-08-29 A | 100% | 2000-01-03 | 2003-08-29 | 955d? | finish no earlier than 2003-08-29 | G1 | 7640h | 7640h | Rel-6 |  |  |  |  |  |
| 1335 | 370.2.3 | Handover | 955d? | 2000-01-03 A | 2003-08-29 A | 100% | 2000-01-03 | 2003-08-29 | 955d? | finish no earlier than 2003-08-29 | G1 | 7640h | 7640h | Rel-6 |  |  |  |  |  |
| 1336 | 40.3 | **Reduction of service interruption times and packet loss during mobility procedures** | 516d? | 2003-06-27 A | 2005-06-17 A | 100% | 2003-06-27 | 2005-06-17 | 516d? |  | G2 | 10800h | 10800h | Rel-6 | Juha |  |  |  |  |
| 1337 | 370.3.1 | Optimisations of existing mechanisms/procedures | 106d? | 2003-06-27 A | 2003-11-21 A | 100% | 2003-06-27 | 2003-11-21 | 106d? | finish no earlier than 2003-11-21 | G2 | 848h | 848h | Rel-6 | Juha |  |  |  |  |
| 1338 | 370.3.2 | Inter-system NACC | 106d? | 2003-06-27 A | 2003-11-21 A | 100% | 2003-06-27 | 2003-11-21 | 106d? | finish no earlier than 2003-11-21 | G2 | 848h | 848h | Rel-6 | Juha |  |  |  |  |
| 1339 | 370.3.3 | PS Handover (within GERAN and between GERAN and UTRAN) | 516d? | 2003-06-27 A | 2005-06-17 A | 100% | 2003-06-27 | 2005-06-17 | 516d? | finish no earlier than 2003-11-21 | G2 | 4128h | 4128h | Rel-6 | Juha |  |  |  |  |
| 1340 | 370.3.4 | Dependency to other features | 106d? | 2003-06-27 A | 2003-11-21 A | 100% | 2003-06-27 | 2003-11-21 | 106d? | finish no earlier than 2003-11-21 | G2 | 848h | 848h | Rel-6 | Juha |  |  |  |  |
| 1341 | 40.5 | **MS conformance testing** | 31d? | 2003-12-19 A | 2004-01-30 A | 100% | 2003-12-19 | 2004-01-30 | 31d? |  | G3new | 248h | 248h | Rel-6 | Ingbert |  |  |  |  |
| 1342 | 370.4.1 | MS conformance tests | 31d? | 2003-12-19 A | 2004-01-30 A | 100% | 2003-12-19 | 2004-01-30 | 31d? | finish no earlier than 2004-01-30 | G4,G5 | 248h | 248h | Rel-6 | Paolo |  |  |  |  |
| 1343 | 370.5 | GERAN A/Gb mode security enhancements | 612d? | 2002-09-26 A | 2005-01-28 A | 100% | 2002-09-26 | 2005-01-28 | 612d? | finish no earlier than 2005-01-28 | S3 | 4896h | 4896h | Rel-6 | Dionisio | 33.102 | Vodafone | peter.howard@vodafone.com |  |
| 1344 | 41 | Performance characterisation of default codecs for PS conversational multimedia application | 455d | 2002-09-13 A | 2004-06-10 A | 100% | 2002-09-13 | 2004-06-10 | 455d | finish no earlier than 2004-06-10 | S4 | 3640h | 3640h | Rel-6 | Paolo | 26.935 | Nokia | pasi.s.ojala@nokia.com | CODCAR |
| 1345 | 43 | Study on Privacy Capability | 83d | 2003-11-10 A | 2004-03-03 A | 100% | 2003-11-10 | 2004-03-03 | 83d | start no earlier than 2003-11-10 | S1 | 664h | 664h | Rel-6 | Alain | 21.949 | Lucent | Liz Daniel | PrivCap |
| 1346 | 44 | **OAM&P Rel-6** | 652d? | 2002-09-12 A | 2005-03-11 A | 100% | 2002-09-12 | 2005-03-11 | 652d? |  | S5 | 30819.5h | 30819.5h | Rel-6 | Dionisio | 32-series | Motorola |  | OAM |
| 1347 | 44.1 | Principles, high level Requirements and Architecture | 526d | 2002-09-12 A | 2004-09-16 A | 100% | 2002-09-12 | 2004-09-16 | 526d | finish no earlier than 2004-09-16 | S5 | 4208h | 4208h | Rel-6 | Dionisio | 32.101, 32.102 | Motorola |  | OAM-AR |
| 1348 | 44.2 | Performance Management | 591d | 2002-09-12 A | 2004-12-16 A | 100% | 2002-09-12 | 2004-12-16 | 591d | finish no earlier than 2004-12-16 | S5 | 4728h | 4728h | Rel-6 | Dionisio | 32.401/3, 52.402, 32.411/2/3, 32.432/5/6 | Nortel |  | OAM-PM |
| 1349 | 44.4 | Network Infrastructure Management | 591d | 2002-09-12 A | 2004-12-16 A | 100% | 2002-09-12 | 2004-12-16 | 591d | finish no earlier than 2004-12-16 | S5 | 4728h | 4728h | Rel-6 | Dionisio | 32.15x, 32.3/6/7xy | Ericsson | thomas.tovinger@ericsson.com | OAM-NIM |
| 1350 | 44.5 | **Trace Management Rel-6** | 646d? | 2002-09-20 A | 2005-03-11 A | 100% | 2002-09-20 | 2005-03-11 | 646d? |  | S5 | 12061.9h | 12061.9h | Rel-6 | Dionisio | 32.42x, 52.008 | Nokia | kari.t.ronka@nokia.com | OAM-Trace |
| 1351 | 373.4.1 | Subscriber and UE trace management | 585d | 2002-09-20 A | 2004-12-16 A | 100% | 2002-09-20 | 2004-12-16 | 585d | finish no earlier than 2004-12-16 | S5 | 4680h | 4680h | Rel-6 | Dionisio | 32.421/2/3, 52.008 | Nokia | kari.t.ronka@nokia.com | OAM-Trace |
| 1352 | 373.4.2 | Subscriber and equipment trace in UTRAN | 268d? | 2003-06-06 A | 2004-06-15 A | 100% | 2003-06-06 | 2004-06-15 | 268d? | finish no earlier than 2004-06-15 | R3 | 2144h | 2144h | Rel-6 | Gert | 25.413, 25.420, 25.423 | Nortel | Yann Sehedi (sehedic@nortelnetworks.com) | OAM-Trace-RAN |
| 1353 | 373.4.3 | Trace Management, Stage3 | 193.74d? | 2004-06-09 A | 2005-03-11 A | 100% | 2004-06-09 | 2005-03-11 | 193.74d? | finish no earlier than 2005-03-11 | N4 | 1549.92h | 1549.92h | Rel-6 | Kimmo | 23.205, 29.232, 29.060, 29.002, 29.228 | Nokia | seppo.kauntola@nokia.com | OAM-Trace |
| 1354 | 374 | **Charging Management** | 666d? | 2002-11-21 A | 2005-06-09 A | 100% | 2002-11-21 | 2005-06-09 | 666d? |  | S5 | 55320h | 55320h | Rel-6 | Dionisio | 32.2xy | T-Mobile | karl-heinz.nenner@t-mobile.de | CH |
| 1355 | 374.1 | Charging architecture and principles | 390d? | 2003-03-21 A | 2004-09-16 A | 100% | 2003-03-21 | 2004-09-16 | 390d? | start no earlier than 2003-03-21 | S5 | 3120h | 3120h | Rel-6 | Dionisio | 32.240 |  |  | CH |
| 1356 | 374.2 | Charging Data Record (CDR) file format and transfer | 260d? | 2003-03-21 A | 2004-03-18 A | 100% | 2003-03-21 | 2004-03-18 | 260d? | start no earlier than 2003-03-21 | S5 | 2080h | 2080h | Rel-6 | Dionisio | 32.297 |  |  | CH |
| 1357 | 374.3 | CDR parameter description | 580d? | 2003-03-21 A | 2005-06-09 A | 100% | 2003-03-21 | 2005-06-09 | 580d? | finish no earlier than 2005-06-09 | S5 | 4640h | 4640h | Rel-6 | Dionisio | 32.298 |  |  | CH |
| 1358 | 374.4 | Diameter charging applications | 390d? | 2003-03-21 A | 2004-09-16 A | 100% | 2003-03-21 | 2004-09-16 | 390d? | start no earlier than 2003-03-21 | S5 | 3120h | 3120h | Rel-6 | Dionisio | 32.299 |  |  | CH |
| 1359 | 374.5 | Online Charging System (OCS) architecture study | 130d? | 2003-03-21 A | 2003-09-18 A | 100% | 2003-03-21 | 2003-09-18 | 130d? | start no earlier than 2003-03-21 | S5 | 1040h | 1040h | Rel-6 | Dionisio | 32.815 |  |  | CH |
| 1360 | 374.6 | OCS: Applications and interfaces | 455d? | 2003-03-21 A | 2004-12-16 A | 100% | 2003-03-21 | 2004-12-16 | 455d? | start no earlier than 2003-03-21 | S5 | 3640h | 3640h | Rel-6 | Dionisio | 32.296 |  |  | CH |

Notes:
- 1332: Started
- 1336: Completed at GERP#17
- 1341: Closed, no work needed
- 1342: Closed, no work needed
- 1343: Possible changes to 33.102 or new specification needed.
- 1346: SA#26: Updated WID SP-040766 was SP-020445. Completion delayed 12/04->03/05 due to OAM-Trace in CN1/4.
- 1347: SA#25 09/2004 completed
- 1348: SA#26 12/2004 completed
- 1349: SA#26 12/2004 completed
- 1350: SA#26 12/2004 SA5 completed 12/04. Signalling Based Trace Activation for IMS (SIP) moved to Rel-7. Reason: CN1 cannot complete 24.229 trace without IETF dependency => estimate 05/2005.
- 1351: SA#26 12/2004 completed
- 1354: SA#28 Target 09/2005 for WLAN Charging 32.252
- 1355: SA#25 09/2004 completed
- 1356: SA#23 03/2004 completed
- 1357: SA#28 06/2005 completed
- 1358: SA#25 09/2004 completed
- 1359: SA#21 09/2003 completed
- 1360: SA#26 12/2004 completed

| ID | WBS | Task | Duration | Start | Finish | Complete | Baseline start | Baseline finish | Baseline duration | Constraint | Resources | Work | Actual work | Text1 | Text4 | Text5 | Text6 | Text8 | Text10 | Text12 |
| --- | --- | --- | --- | --- | --- | --- | --- | --- | --- | --- | --- | --- | --- | --- | --- | --- | --- | --- | --- | --- |
| 1361 | 374.7 | **Charging Management for Bearer level** | 390d? | 2003-03-21 A | 2004-09-16 A | 100% | 2003-03-21 | 2004-09-16 | 390d? |  | S5 | 11440h | 11440h | CH-BC | Nokia | Benni ALEXANDER | Rel-6 | Dionisio |  |  |
| 1362 | 374.7.1 | CS domain charging | 260d? | 2003-03-21 A | 2004-03-18 A | 100% | 2003-03-21 | 2004-03-18 | 260d? | start no earlier than 2003-03-21 | S5 | 2080h | 2080h | CH |  |  | Rel-6 | Dionisio |  |  |
| 1363 | 374.7.2 | PS domain charging | 390d? | 2003-03-21 A | 2004-09-16 A | 100% | 2003-03-21 | 2004-09-16 | 390d? | start no earlier than 2003-03-21 | S5 | 3120h | 3120h | CH |  |  | Rel-6 | Dionisio |  |  |
| 1364 | 374.7.3 | CDR transfer | 390d? | 2003-03-21 A | 2004-09-16 A | 100% | 2003-03-21 | 2004-09-16 | 390d? | start no earlier than 2003-03-21 | S5 | 3120h | 3120h | CH |  |  | Rel-6 | Dionisio |  |  |
| 1365 | 374.8 | Charging Management for the IMS | 455d? | 2003-03-21 A | 2004-12-16 A | 100% | 2003-03-21 | 2004-12-16 | 455d? | finish no earlier than 2004-12-16 | S5 | 3640h | 3640h | IMS2-CH | Ericsson | Patrik TEPPO | Rel-6 | Dionisio |  |  |
| 1366 | 374.9 | Charging Management for the Service domain | 580d? | 2003-03-21 A | 2005-06-09 A | 100% | 2003-03-21 | 2005-06-09 | 580d? | finish no earlier than 2005-06-09 | S5 | 4640h | 4640h | CH | Siemens | Gerald GÖRMER | Rel-6 | Dionisio |  |  |
| 1367 | 374.10 | **Overall architectural aspects of IP flow based bearer level charging** | 602d? | 2002-11-21 A | 2005-03-11 A | 100% | 2002-11-21 | 2005-03-11 | 602d? |  | S2 | 12632h | 12632h | CH-FBC |  |  | Rel-6 | Maurice |  |  |
| 1368 | 374.10.1 | Overall definition of FBC architecture | 334d? | 2002-11-21 A | 2004-03-02 A | 100% | 2002-11-21 | 2004-03-02 | 334d? | start no earlier than 2002-11-21 | S2 | 2672h | 2672h |  |  |  | Rel-6 | Maurice | SP-24 |  |
| 1369 | 374.10.2 | Study on providing policy control with FBC | 130d? | 2004-02-02 A | 2004-07-30 A | 100% | 2004-02-02 | 2004-07-30 | 130d? | start no earlier than 2004-02-01 | S2 | 1040h | 1040h |  |  |  | Rel-6 | Maurice | SP-24 |  |
| 1370 | 374.10.3 | Gx interface for flow based charging | 223d? | 2004-02-02 A | 2004-12-08 A | 100% | 2004-02-02 | 2004-12-08 | 223d? | start no earlier than 2004-02-01 | N3 | 1784h | 1784h | CH-FBC | Nokia | juha.a.rasanen@nokia.com | Rel-6 | Gwiho | SP-25 |  |
| 1371 | 374.10.4 | Rx interface for flow based charging | 290d? | 2004-02-02 A | 2005-03-11 A | 100% | 2004-02-02 | 2005-03-11 | 290d? | finish no earlier than 2005-03-11 | N3 | 2320h | 2320h | CH-FBC | Nortel | Javier Gonzalez Gallego | Rel-6 | Gwiho | SP-25 |  |
| 1372 | 13 | **Rel-6 UICC/USIM enhancements and interworking** | 1164d? | 2000-09-25 A | 2005-03-10 A | 100% | 2000-09-25 | 2005-03-10 | 1164d? |  | T3 | 43088h | 43088h | USAT1 |  |  | Rel-6 | Xavier |  |  |
| 1373 | 13.1 | **UICC API** | 777d | 2002-03-20 A | 2005-03-10 A | 100% | 2002-03-20 | 2005-03-10 | 777d |  | T3 | 15024h | 15024h | USAT1-API |  |  | Rel-6 | Xavier |  |  |
| 1374 | 13.1.1 | Java API Test specification | 59d | 2002-03-20 A | 2002-06-10 A | 100% | 2002-03-20 | 2002-06-10 | 59d | finish no earlier than 2002-09-20 | T3 | 472h | 472h |  | Microelectrónica Española | Mario Pérez | Rel-6 |  |  |  |
| 1375 | 375.1.2 | 2G/3G Java Card™ API based applet interworking | 255d | 2003-03-17 A | 2004-03-05 A | 100% | 2003-03-17 | 2004-03-05 | 255d | finish no earlier than 2004-02-19 | T3 | 2040h | 2040h | USAT1-API | Oberthur Card Systems | Stéphane Andrau | Rel-6 |  |  |  |
| 1376 | 375.1.3 | (U)SIM API for Java Card Testing Work Item | 519d | 2003-03-17 A | 2005-03-10 A | 100% | 2003-03-17 | 2005-03-10 | 519d | finish no earlier than 2005-03-10 | T3 | 4152h | 4152h |  | Axalto | Christophe Begassat (cbegassat@axalto.com) | Rel-6 | Xavier |  |  |
| 1377 | 13.1.2 | Deleted - Java API Test specification (TS 43.019 Rel-5) | 268d | 2002-05-30 A | 2003-06-09 A | 100% | 2002-05-30 | 2003-06-09 | 268d | finish no earlier than 2003-09-17 | T3 | 2144h | 2144h |  | Microelectrónica Española | Mario Pérez | Rel-6 |  |  | TP-20 |
| 1378 | 375.2 | **Rel-6 USIM toolkit enhancements** | 1160d? | 2000-09-25 A | 2005-03-04 A | 100% | 2000-09-25 | 2005-03-04 | 1160d? |  | T3 | 21848h | 21848h |  |  |  | Rel-6 | Xavier |  |  |
| 1379 | 375.2.1 | **C SIM API** | 525d | 2000-09-25 A | 2002-09-27 A | 100% | 2000-09-25 | 2002-09-27 | 525d |  | T3 | 9960h | 9960h | USAT1-API-MULTOS |  |  | Rel-6 |  |  |  |
| 1380 | 375.2.1.1 | Specification | 525d | 2000-09-25 A | 2002-09-27 A | 100% | 2000-09-25 | 2002-09-27 | 525d | finish no earlier than 2002-09-27 | T3 | 4200h | 4200h |  | Aspects Software | Neil Livingston | Rel-6 |  |  |  |
| 1381 | 375.2.1.2 | Test specification | 195d | 2001-01-01 A | 2001-09-28 A | 100% | 2001-01-01 | 2001-09-28 | 195d | finish no earlier than 2001-09-28 | T3 | 1560h | 1560h |  | Aspects Software | Neil Livingston | Rel-6 |  |  |  |
| 1382 | 375.2.2 | USIM application toolkit Conformance Test Specification for Mobile Equipments | 326d? | 2003-12-05 A | 2005-03-04 A | 100% | 2003-12-05 | 2005-03-04 | 326d? | start no earlier than 2003-12-05 | T3 | 2608h | 2608h |  | Gemplus | Eric.laffont@gemplus.com | Rel-6 |  |  |  |
| 1383 | 376 | **Packet Switched Streaming Services Rel-6** | 798d? | 2002-11-18 A | 2005-12-07 A | 100% | 2002-11-18 | 2005-12-07 | 798d? |  | S4 | 11579.4h | 11579.4h | PSSrel6 | Ericsson | olle.franceschi@ericsson.com | Rel-6 | Paolo |  |  |
| 1384 | 376.1 | Stage 1 | 86d? | 2002-11-18 A | 2003-03-17 A | 100% | 2002-11-18 | 2003-03-17 | 86d? | finish no earlier than 2003-03-17 | S1 | 688h | 688h |  |  |  | Rel-6 | Alain |  |  |
| 1385 | 376.2 | Stage 3 | 779d? | 2002-12-13 A | 2005-12-07 A | 100% | 2002-12-13 | 2005-12-07 | 779d? | finish no earlier than 2005-12-07 | S4 | 6232h | 6232h | PSSrel6-Stage3 | Ericsson | olle.franceschi@ericsson.com | Rel-6 | Paolo |  |  |
| 1386 | 377 | AMR-WB extension for high audio quality | 779d | 2002-12-13 A | 2005-12-07 A | 100% | 2002-12-13 | 2005-12-07 | 779d | finish no earlier than 2005-12-07 | S4 | 6232h | 6232h | AMRWB+ | Nokia | janne.m.vainio@nokia.com | Rel-6 | Paolo |  |  |
| 1387 | 378 | Codec Enhancements for Packet Switched Conversational Multimedia Applications | 198d? | 2004-03-16 A | 2004-12-16 A | 100% | 2004-03-16 | 2004-12-16 | 198d? | finish no earlier than 2004-12-16 | S4 | 1584h | 1584h | CEPSCM | Nokia | miska.hannuksela@nokia.com | Rel-6 | Paolo |  |  |
| 1388 | 379 | 3G-324M Improvements | 198d? | 2004-03-16 A | 2004-12-16 A | 100% | 2004-03-16 | 2004-12-16 | 198d? | finish no earlier than 2004-12-16 | S4 | 1584h | 1584h | 3G-324MI | Ericsson | bo.burman@ericsson.com | Rel-6 | Paolo |  |  |
| 1389 | 380 | Single Antenna Receiver Interference Cancellation (SAIC) | 420.92d? | 2002-11-15 A | 2004-08-27 A | 100% | 2002-11-15 | 2004-08-27 | 420.92d? | finish no earlier than 2004-08-27 | GP,G1 | 3367.36h | 3367.36h | SAIC | Cingular | Marc Grant | Rel-6 | Paolo |  |  |

Notes:
- 1361: SA#28 Target 09/2005 for WLAN Charging 32.252
- 1362: SA#23 03/2004 completed / Text3: 32.250
- 1363: SA#25 09/2004 completed / Text3: 32.251
- 1364: SA#25 09/2004 completed / Text3: 32.295
- 1365: SA#26 12/2004 completed / Text3: 32.260
- 1366: SA#26: Updated WID SP-040778 was SP-030050. Target completion 06/2005. Consisting of MMS-CH, LCS-CH, WLAN-CH, POC-CH, MBMS-CH / Text3: 32.252, 32.270/1/2
- 1367: Text3: 23.125
- 1370: Text3: 29.210
- 1371: Text3: 29.209
- 1373: 8/3/2001: test spec is based on R99 core spec, so deleted from Workplan
- 1376: Text3: 31.213
- 1377: MOVED to Rel-5 WP
- 1382: Text3: 31.124
- 1384: 2nd resp SA4 / Text3: 22.233
- 1385: TR tbc by Sept. 05 / Text3: 26.233, 26.234, 26.244, 26.245, 26.246, 26.401, 26.402, 26.403, 26.404, 26.405, 26.406, 26.410, 26.411, 26.412, 26.273, 26.290, 26.304, 26.412, 26.274, 26.936
- 1386: TR tbc by Sept. 05 / Text3: 26.290, 26.304, 26.273, 26.274, 26.412, 26.936
- 1387: Completed / Text3: 26.235, 26.236
- 1388: Completed / Text3: 26.111, 26.911

| ID | WBS | Task | Type | Duration | Start | Finish | Complete | Baseline start | Baseline finish | Baseline duration | Constraint | Resources | Work | Actual work | Text1 | Text4 | Text5 | Text6 | Text8 | Text3 | Text12 |
| --- | --- | --- | --- | --- | --- | --- | --- | --- | --- | --- | --- | --- | --- | --- | --- | --- | --- | --- | --- | --- | --- |
| 1390 | 381 | **Enhancement of dialled service for CAMEL** |  | 199d | 2003-03-28 A | 2003-12-31 A | 100% | 2003-03-28 | 2003-12-31 | 199d |  | S1 | 3184h | 3184h | EDCAMEL | Samsung | Craig Bishop | Rel-6 | Alain |  |  |
| 1391 | 381.1 | Stages 2 and 3 |  | 199d | 2003-03-28 A | 2003-12-31 A | 100% | 2003-03-28 | 2003-12-31 | 199d | finish no earlier than 2003-09-19 | N4 | 1592h | 1592h |  |  |  | Rel-6 | Kimmo |  |  |
| 1392 | 382 | Bandwidth and resource savings in CS networks |  | 273d? | 2003-06-01 A | 2004-06-16 A | 100% | 2003-06-01 | 2004-06-16 | 273d? | finish no earlier than 2004-06-16 | S2 | 2184h | 2184h | BARS |  |  | Rel-6 | Maurice | 23.977 |  |
| 1393 | 383 | FS on (U)SIM Security Reuse by Peripheral Devices on Local Interfaces |  | 127d? | 2003-07-03 A | 2003-12-26 A | 100% | 2003-07-03 | 2003-12-26 | 127d? | finish no earlier than 2003-12-26 | S3 | 1016h | 1016h |  | Toshiba | Raziq Yaqub (ryaqub@tari.toshiba.com) | Rel-6 | Dionisio |  |  |
| 1394 | 384 | **Multiple TBF in A/Gb mode** |  | 736d? | 2002-04-05 A | 2005-01-28 A | 100% | 2002-04-05 | 2005-01-28 | 736d? |  | GP,G2 | 17600h | 17600h | MULTBF | Ericsson | gunnar.mildh@era.ericsson.se | Rel-6 | Paolo |  |  |
| 1395 | 384.1 | **Multiple TBF in A/Gb mode** |  | 366d? | 2002-04-05 A | 2003-08-29 A | 100% | 2002-04-05 | 2003-08-29 | 366d? |  | GP,G2 | 11712h | 11712h | MULTBF-Agbmode | Ericsson | gunnar.mildh@era.ericsson.se | Rel-6 | Paolo |  |  |
| 1396 | 384.1.1 | Multiple TBF Concept paper |  | 366d? | 2002-04-05 A | 2003-08-29 A | 100% | 2002-04-05 | 2003-08-29 | 366d? | finish no earlier than 2003-08-29 | GP,G2 | 2928h | 2928h |  |  |  | Rel-6 | Paolo |  |  |
| 1397 | 384.1.2 | Multiple TBF Stage 2 (43.064) CRs |  | 366d? | 2002-04-05 A | 2003-08-29 A | 100% | 2002-04-05 | 2003-08-29 | 366d? | finish no earlier than 2003-08-29 | GP,G2 | 2928h | 2928h |  |  |  | Rel-6 | Paolo |  |  |
| 1398 | 384.1.3 | Multiple TBF Stage 3 (44.060) CRs |  | 366d? | 2002-04-05 A | 2003-08-29 A | 100% | 2002-04-05 | 2003-08-29 | 366d? | finish no earlier than 2003-08-29 | GP,G2 | 2928h | 2928h |  |  |  | Rel-6 | Paolo |  |  |
| 1399 | 384.2 | Deleted at TGS # 27 - Multiple TBF in A/Gb mode – MS testing | milestone | 0d? | 2005-01-28 A | 2005-01-28 A | 100% | 2005-01-28 | 2005-01-28 | 0d? | start no earlier than 2005-01-28 | G3new |  |  | MULTBF-Testing | Ericsson | gunnar.mildh@era.ericsson.se | Rel-6 | Paolo |  | GP-23 |
| 1400 | 385 | **Alignment between the test-regimes for GERAN capable MS** |  | 526d? | 2003-08-29 A | 2005-09-02 A | 100% | 2003-08-29 | 2005-09-02 | 526d? |  | G3new | 4208h | 4208h | ALTERE | Ericsson | Toubassi | Rel-6 | Ingbert |  |  |
| 1401 | 385.1 | Determine the controversial test cases in the different test regimes and align them with 3GPP GERAN test specifications. Such test cases to be added to TS 51.010. |  | 526d? | 2003-08-29 A | 2005-09-02 A | 100% | 2003-08-29 | 2005-09-02 | 526d? | finish no earlier than 2005-09-02 | G3new | 4208h | 4208h | ALTERE-TC |  |  | Rel-6 | Ingbert |  |  |
| 1402 | 386 | Addition of U-TDOA in the CS domain |  | 111d? | 2003-11-21 A | 2004-04-23 A | 100% | 2003-11-21 | 2004-04-23 | 111d? | finish no earlier than 2004-04-23 | GP | 888h | 888h | UTDOACS | TruePosition | Bob Gross, Rhys Robinson (rlgross@trueposition.com) | Rel-6 | Paolo |  |  |
| 1403 | 387 | Addition of U-TDOA in the PS domain |  | 361d? | 2003-06-27 A | 2004-11-12 A | 100% | 2003-06-27 | 2004-11-12 | 361d? | finish no earlier than 2004-11-12 | GP | 2888h | 2888h | UTDOAPS | TruePosition | Bob Gross, Rhys Robinson (rlgross@trueposition.com) | Rel-6 | Paolo |  |  |
| 1404 | 388 | **Downlink Advanced Receiver Performance** |  | 466d? | 2003-11-21 A | 2005-09-02 A | 100% | 2003-11-21 | 2005-09-02 | 466d? |  | GP | 19160h | 19160h | DARP | Nokia | tommy.bysted@nokia.com | Rel-6 | Paolo |  |  |
| 1405 | 388.1 | DARP test scenarios |  | 201d? | 2003-11-21 A | 2004-08-27 A | 100% | 2003-11-21 | 2004-08-27 | 201d? | finish no earlier than 2004-08-27 | GP | 1608h | 1608h | DARP-TS | Nokia | tommy.bysted@nokia.com | Rel-6 | Paolo |  |  |
| 1406 | 388.2 | **DARP for GMSK modulated voice services** |  | 201d? | 2004-02-06 A | 2004-11-12 A | 100% | 2004-02-06 | 2004-11-12 | 201d? |  | GP | 4824h | 4824h | DARP-GMSK | Nokia | tommy.bysted@nokia.com | Rel-6 | Paolo |  |  |
| 1407 | 388.2.1 | Performance requirements in 45.005 |  | 201d? | 2004-02-06 A | 2004-11-12 A | 100% | 2004-02-06 | 2004-11-12 | 201d? | finish no earlier than 2004-11-12 | GP | 1608h | 1608h | DARP-GMSK-Perf |  |  | Rel-6 | Paolo |  |  |
| 1408 | 388.2.2 | Radio subsystem link control in 45.008 |  | 201d? | 2004-02-06 A | 2004-11-12 A | 100% | 2004-02-06 | 2004-11-12 | 201d? | finish no earlier than 2004-11-12 | GP | 1608h | 1608h | DARP-GMSK-LC |  |  | Rel-6 | Paolo |  |  |
| 1409 | 388.3 | **DARP for GPRS and EGPRS MCS1-MCS4** |  | 201d? | 2004-02-06 A | 2004-11-12 A | 100% | 2004-02-06 | 2004-11-12 | 201d? |  | GP | 4824h | 4824h | DARP-GPRSE | Nokia | tommy.bysted@nokia.com | Rel-6 | Paolo |  |  |
| 1410 | 388.3.1 | Performance requirements in 45.005 |  | 201d? | 2004-02-06 A | 2004-11-12 A | 100% | 2004-02-06 | 2004-11-12 | 201d? | finish no earlier than 2004-11-12 | GP | 1608h | 1608h | DARP-GPRSE-Perf |  |  | Rel-6 | Paolo |  |  |
| 1411 | 388.3.2 | Radio subsystem link control in 45.008 |  | 201d? | 2004-02-06 A | 2004-11-12 A | 100% | 2004-02-06 | 2004-11-12 | 201d? | finish no earlier than 2004-11-12 | GP | 1608h | 1608h | DARP-GPRSE-LC |  |  | Rel-6 | Paolo |  |  |
| 1412 | 388.4 | DARP Capability signalling |  | 256d? | 2003-11-21 A | 2004-11-12 A | 100% | 2003-11-21 | 2004-11-12 | 256d? | finish no earlier than 2004-11-12 | GP | 2048h | 2048h | DARP-CAPSIG | Nokia | tommy.bysted@nokia.com | Rel-6 | Paolo |  |  |
| 1413 | 388.5 | GERAN MS Conformance test for DARP |  | 266d? | 2004-08-27 A | 2005-09-02 A | 100% | 2004-08-27 | 2005-09-02 | 266d? | finish no earlier than 2005-06-24 | G3new | 2128h | 2128h | ARP-ConfTest | Nokia | tommy.bysted@nokia.com | Rel-6 | Ingbert |  |  |

Notes:
- 1393: Approved TSG#20
- 1399: DELETE
- 1401: Completed
- 1402: Completed, except for potential LMU performance specs
- 1413: Started

| ID | WBS | Task | Type | Duration | Start | Finish | Complete | Baseline start | Baseline finish | Baseline duration | Constraint | Resources | Work | Actual work | Text1 | Text4 | Text5 | Text6 | Text8 | Text12 | Text3 | Text10 |
| --- | --- | --- | --- | --- | --- | --- | --- | --- | --- | --- | --- | --- | --- | --- | --- | --- | --- | --- | --- | --- | --- | --- |
| 1414 | 389 | **Reduction of PS service interruption in Dual Transfer Mode** |  | 416d? | 2003-11-21 A | 2005-06-24 A | 100% | 2003-11-21 | 2005-06-24 | 416d? |  | G2 | 8360h | 8360h | PSintDTM | Siemens | toby.proctor@roke.co.uk | Rel-6 | Juha |  |  |  |
| 1415 | 389.1 | Use case and requirement definition |  | 111d? | 2003-11-21 A | 2004-04-23 A | 100% | 2003-11-21 | 2004-04-23 | 111d? | finish no earlier than 2004-04-23 | G2 | 888h | 888h | PSintDTM-Req | Siemens | toby.proctor@roke.co.uk | Rel-6 | Juha |  |  |  |
| 1416 | 389.2 | Performance Study of Current Procedures |  | 111d? | 2003-11-21 A | 2004-04-23 A | 100% | 2003-11-21 | 2004-04-23 | 111d? | start no earlier than 2003-11-21 | G2 | 888h | 888h | PSintDTM-Perf | Siemens | toby.proctor@roke.co.uk | Rel-6 | Juha |  |  |  |
| 1417 | 389.3 | Reduction of service interruption times and packet loss during Dual Transfer Mode and mobility procedures |  | 146d? | 2004-04-23 A | 2004-11-12 A | 100% | 2004-04-23 | 2004-11-12 | 146d? | finish no earlier than 2004-11-12 | G2 | 1168h | 1168h | PSintDTM-Reduct | Siemens | toby.proctor@roke.co.uk | Rel-6 | Juha |  |  |  |
| 1418 | 389.4 | Deleted - MS Conformance testing |  | 261d? | 2004-06-25 A | 2005-06-24 A | 100% | 2004-06-25 | 2005-06-24 | 261d? | finish no earlier than 2005-06-24 | G3new | 2088h | 2088h | PSintDTM-ConfMS |  |  | Rel-6 | Ingbert | GP-25 |  |  |
| 1419 | 389.5 | Deleted - BTS Conformance testing | milestone | 0d? | 2005-06-24 A | 2005-06-24 A | 100% | 2005-06-24 | 2005-06-24 | 0d? | finish no earlier than 2005-06-24 | G3new |  |  | PSintDTM-ConfBTS |  |  | Rel-6 | Ingbert | GP-25 |  |  |
| 1420 | 390 | CAMEL prepay interworking with SCUDIF |  | 206d | 2003-12-08 A | 2004-10-05 A | 100% | 2003-12-08 | 2004-10-05 | 206d |  | N4 | 1648h | 1648h | SCCAMEL |  |  | Rel-6 | Kimmo |  |  |  |
| 1421 | 391 | **Circuit Switched Video and Voice Service Improvements** |  | 430d? | 2004-01-12 A | 2005-09-02 A | 100% | 2004-01-12 | 2005-09-02 | 430d? |  | S1 | 6536h | 6536h | CS_VSS | Vodafone | John Watson | Rel-6 | Alain |  | 23.801 |  |
| 1422 | 391.1 | Stage 1 - Requirements |  | 199d | 2004-01-12 A | 2004-10-14 A | 100% | 2004-01-12 | 2004-10-14 | 199d | finish no earlier than 2004-10-14 | S1 | 1592h | 1592h | CS_VSS | Vodafone | John Watson | Rel-6 | Alain |  |  |  |
| 1423 | 391.2 | Stage 2 Study on architecture alternatives |  | 155d? | 2004-01-12 A | 2004-08-13 A | 100% | 2004-01-12 | 2004-08-13 | 155d? | finish no earlier than 2004-08-13 | S2 | 1240h | 1240h | CS_VSS |  |  | Rel-6 | Maurice |  |  | SP-24 |
| 1424 | 391.3 | Stage 2 description on Redial |  | 164d? | 2004-05-03 A | 2004-12-16 A | 100% | 2004-05-03 | 2004-12-16 | 164d? | finish no earlier than 2004-12-16 | S2 | 1312h | 1312h | CS_VSS |  |  | Rel-6 | Maurice |  | 23.903 | SP-24 |
| 1425 | 391.4 | Switching between voice and video call - Redial solution |  | 120d? | 2005-01-03 A | 2005-06-17 A | 100% | 2005-01-03 | 2005-06-17 | 120d? | start no earlier than 2005-01-03 | C1 | 960h | 960h | CS_VSS |  |  | Rel-6 | Frederic |  |  |  |
| 1426 | 391.5 | Deleted - GERAN2 Part | milestone | 0d | 2005-09-02 A | 2005-09-02 A | 100% | 2005-09-02 | 2005-09-02 | 0d | start no earlier than 2005-09-02 | G2 |  |  | CS_VSS |  |  | Rel-6 | Juha | GP-26 |  |  |
| 1427 | 391.6 | Deleted - CN3 Part | milestone | 0d? | 2004-10-14 A | 2004-10-14 A | 100% | 2004-10-14 | 2004-10-14 | 0d? | start no earlier than 2004-10-14 | N3 |  |  | CS_VSS |  |  | Rel-6 | Gwiho | TP-26 |  |  |
| 1428 | 392 | Network Domain Security; MAP application layer security (NDS/MAPsec) |  | 127d? | 2004-07-06 A | 2004-12-29 A | 100% | 2004-07-06 | 2004-12-29 | 127d? | finish no earlier than 2003-12-26 | S3 | 1016h | 1016h | MAPSEC | Vodafone | Peter.Howard@vodafone.com | Rel-6 | Dionisio |  |  |  |
| 1429 | 393 | FS on Security for early IMS |  | 127d? | 2004-10-01 A | 2005-03-28 A | 100% | 2004-10-01 | 2005-03-28 | 127d? | finish no earlier than 2003-12-26 | S3 | 1016h | 1016h | SEC-IMS | Vodafone | Peter.Howard@vodafone.com | Rel-6 | Dionisio |  |  |  |
| 1430 | 394 | Reorganisation of CS Data Specifications |  | 14d? | 2004-11-19 A | 2004-12-08 A | 100% | 2004-11-19 | 2004-12-08 | 14d? | finish no earlier than 2004-12-24 | N3 | 112h | 112h | CS Data | Siemens | Thomas.Belling@nsn.com | Rel-6 | Gwiho |  |  |  |
| 1431 | 395 | **Generic Access to A/Gb Interface (GAAI)** |  | 411d? | 2004-06-25 A | 2006-01-20 A | 100% | 2004-06-25 | 2006-01-20 | 411d? |  | GP | 9160h | 9160h | GAAI | Motorola |  | Rel-6 | Paolo |  |  |  |
| 1432 | 395.1 | FS on GAAI |  | 46d? | 2004-06-25 A | 2004-08-27 A | 100% | 2004-06-25 | 2004-08-27 | 46d? | finish no earlier than 2004-08-27 | GP | 368h | 368h | GAAG | Motorola |  | Rel-6 | Paolo |  | 43.901 |  |
| 1433 | 395.2 | GAAI – Stage 2 |  | 161d? | 2004-08-27 A | 2005-04-08 A | 100% | 2004-08-27 | 2005-04-08 | 161d? | finish no earlier than 2005-04-08 | GP | 1288h | 1288h | GAAI-Stage2 | Ericsson | jari.vikberg@ericsson.com | Rel-6 | Paolo |  | 43.318 |  |
| 1434 | 395.3 | GAAI – Stage 3 |  | 161d? | 2004-08-27 A | 2005-04-08 A | 100% | 2004-08-27 | 2005-04-08 | 161d? | finish no earlier than 2005-04-08 | GP | 1288h | 1288h | GAAI-Stage3 |  |  | Rel-6 | Paolo |  | 44.318 |  |
| 1435 | 395.4 | MS Conformance Test for GAAI |  | 366d? | 2004-08-27 A | 2006-01-20 A | 100% | 2004-08-27 | 2006-01-20 | 366d? | finish no earlier than 2006-01-20 | GP | 2928h | 2928h | GAAI-CT |  |  | Rel-6 | Ingbert |  |  |  |
| 1436 | 396 | **Support of PS Handover for GERAN A/Gb mode** |  | 473d? | 2003-11-03 A | 2005-08-24 A | 100% | 2003-11-03 | 2005-08-24 | 473d? |  | GP,G2 | 11352h | 11352h | SPSHAGB | Ericsson | gunnar.hedby@ericsson.com | Rel-6 | Paolo |  |  |  |
| 1437 | 396.1 | Stage 2 |  | 473d? | 2003-11-03 A | 2005-08-24 A | 100% | 2003-11-03 | 2005-08-24 | 473d? | finish no earlier than 2005-09-02 | GP,G2 | 3784h | 3784h | SPSHAGB-Stage2 | Ericsson | gunnar.hedby@ericsson.com | Rel-6 | Paolo |  | 43.129 |  |
| 1438 | 396.2 | PS handover |  | 473d? | 2003-11-03 A | 2005-08-24 A | 100% | 2003-11-03 | 2005-08-24 | 473d? | finish no earlier than 2005-09-02 | GP,G2 | 3784h | 3784h | SPSHAGB-PSHO | Ericsson | gunnar.hedby@ericsson.com | Rel-6 | Paolo |  |  |  |
| 1439 | 396.3 | Definition of radio resource management functionality |  | 473d? | 2003-11-03 A | 2005-08-24 A | 100% | 2003-11-03 | 2005-08-24 | 473d? | finish no earlier than 2005-09-02 | GP,G2 | 3784h | 3784h | SPSHAGB-RRM | Ericsson | gunnar.hedby@ericsson.com | Rel-6 | Paolo |  |  |  |

Notes:
- 1418: Marked as stopped 12/2008
- 1428: Approved TSG#24. Marked as closed 12/2008 (was marked 20% complete)
- 1429: Approved TSG#24. TR 33.978 Approved at TSG SA #27
- 1430: Created at TSG#27 as 100 % complete
- 1432: Feasibility Study
- 1433: Completed
- 1434: Completed
- 1435: Marked as closed 12/2008 (was marked 90% complete)
- 1436: Replaces SCSAGB- Originally Started Nov 2003 as GP-030443
- 1437: Replaces SCSAGB-Stage2
- 1438: Replaces SCSAGB-PSH
- 1439: Replaces SCSAGB-RRM

| ID | WBS | Task | Type | Duration | Start | Finish | Complete | Baseline start | Baseline finish | Baseline duration | Total slack | Constraint | Resources | Work | Actual work | Text1 | Text6 | Text3 | Text8 | Text4 | Text5 | Text12 |
| --- | --- | --- | --- | --- | --- | --- | --- | --- | --- | --- | --- | --- | --- | --- | --- | --- | --- | --- | --- | --- | --- | --- |
| 1440 | 397 | **small Technical Enhancements and Improvements for Rel-6** |  | 503d? | 2006-06-02 A | 2008-05-06 A | 100% | 2006-06-02 | 2008-05-06 | 503d? |  |  | All | 4024h | 4024h | TEI6 | Rel-6 |  |  |  |  |  |
| 1441 | 397.1 | Small Technical Enhancements and Improvements for Rel-6 Conformance Testing |  | 503d? | 2006-06-02 A | 2008-05-06 A | 100% | 2006-06-02 | 2008-05-06 | 503d? |  | start no earlier than 2006-06-02 | R5 | 4024h | 4024h | TEI6_Test | Rel-6 | 34.108,34.121-1/2,34.122,34.123-1/2/3 | Ingbert |  |  |  |
| 1442 | 398 | Deleted - Study of Feature Interactions Requirements | milestone | 0d? | 2004-10-01 A | 2004-10-01 A | 100% | 2004-10-01 | 2004-10-01 | 0d? |  | finish no earlier than 2004-10-01 | S1 |  |  | FINTER | Rel-6 |  | Alain |  |  |  |
| 1443 | 399 | Deleted (moved to Rel7) - Enhancements of VGCS in public networks for communication of public authority officials |  | 7d? | 2005-08-24 A | 2005-09-02 A | 100% | 2005-08-24 | 2005-09-02 | 7d? |  | start no earlier than 2005-08-24 | GP,G2 | 56h | 56h | EVGCS | Rel-6 | 44.018, 44.068, 48.008 | Paolo | Siemens | kenneth.isaacs@roke.co.uk | GP-26 |
| 1444 | 400 | **Deleted - Support of Conversational Services in A/Gb mode via the PS domain** |  | 64d? | 2003-11-21 A | 2004-02-19 A | 100% | 2003-11-21 | 2004-02-19 | 64d? |  |  | GP | 512h | 512h | SCSAGB | Rel-6 |  | Paolo | Ericsson | David Bladsjö (david.bladsjo@ericsson.com) |  |
| 1445 | 400.1 | Delete - Creation of a TR | milestone | 0d? | 2003-11-21 A | 2003-11-21 A | 100% | 2003-11-21 | 2003-11-21 | 0d? |  | start no earlier than 2003-11-21 | GP |  |  | SCSAGB-TR | Rel-6 |  | Paolo | Ericsson | David Bladsjö (david.bladsjo@ericsson.com) | GP-17 |
| 1446 | 400.2 | Delete - Stage 2 | milestone | 0d? | 2003-11-21 A | 2003-11-21 A | 100% | 2003-11-21 | 2003-11-21 | 0d? |  | finish no earlier than 2003-11-21 | GP |  |  | SCSAGB-Stage2 | Rel-6 |  | Paolo | Ericsson | David Bladsjö (david.bladsjo@ericsson.com) | GP-17 |
| 1447 | 400.3 | Delete - Radio Channel Support | milestone | 0d? | 2003-11-21 A | 2003-11-21 A | 100% | 2003-11-21 | 2003-11-21 | 0d? |  | finish no earlier than 2003-11-21 | GP |  |  | SCSAGB-RCS | Rel-6 |  | Paolo | Ericsson | David Bladsjö (david.bladsjo@ericsson.com) | GP-17 |
| 1448 | 400.4 | Delete - Definition of radio resource management functionality | milestone | 0d? | 2003-11-21 A | 2003-11-21 A | 100% | 2003-11-21 | 2003-11-21 | 0d? |  | finish no earlier than 2003-11-21 | GP,G2 |  |  | SCSAGB-RRM | Rel-6 |  | Paolo | Ericsson | David Bladsjö (david.bladsjo@ericsson.com) | GP-17 |
| 1449 | 400.5 | Delete, replaced by 50561 - PS Handover |  | 64d | 2003-11-21 A | 2004-02-19 A | 100% | 2003-11-21 | 2004-02-19 | 64d |  | start no earlier than 2003-11-21 | GP,GP, N1 | 512h | 512h | SCSAGB-PSH | Rel-6 |  | Paolo | Ericsson | David Bladsjö (david.bladsjo@ericsson.com) | GP-18 |
| 1450 | 400.6 | Delete - Modifications to FLO | milestone | 0d? | 2003-11-21 A | 2003-11-21 A | 100% | 2003-11-21 | 2003-11-21 | 0d? |  | finish no earlier than 2003-11-21 | GP,G2 |  |  | SCSAGB-FLO | Rel-6 |  | Paolo | Ericsson | David Bladsjö (david.bladsjo@ericsson.com) | RP-29 |
| 1451 | 401 | Deleted - Rel-6 Evolutions of the transport in the UTRAN | milestone | 0d | 2003-12-31 A | 2003-12-31 A | 100% | 2003-12-31 | 2003-12-31 | 0d |  | start no earlier than 2003-12-31 | RP |  |  | ETRAN | Rel-6 |  | Stefania | Alcatel | Francois Courau | RP-22 |
| 1452 | 402 | Release 5 Features |  | 1d? | 2000-01-03 | 2000-01-03 |  | 2000-01-03 | 2000-01-03 | 1d? | 2659d |  | CP,GP, RP,SP,TP | 8h |  |  | Rel-5 |  |  |  |  |  |
| 1453 | 75 | IP transport in the UTRAN |  | 445d | 2000-07-17 A | 2002-03-29 A | 100% | 2000-07-17 | 2002-03-29 | 445d |  | finish no earlier than 2002-03-29 | R3 | 3560h | 3560h | ETRAN-IPtrans | Rel-5 |  | Gert | Alcatel | Nicolas Drevon |  |
| 1454 | 76 | FS on Usage of SUA |  | 205d | 2001-03-12 A | 2001-12-21 A | 100% | 2001-03-12 | 2001-12-21 | 205d |  | finish no earlier than 2001-12-21 | N4 | 1640h | 1640h | SS7IP | Rel-5 |  | Kimmo |  |  |  |
| 1455 | 77 | **High Speed Downlink Packet Access** |  | 570d | 2001-04-02 A | 2003-06-06 A | 100% | 2001-04-02 | 2003-06-06 | 570d |  |  | R2 | 15272h | 15272h | HSDPA | Rel-5 |  | Joern | Motorola | Ravi Kuchibhotla |  |
| 1456 | 77.1 | Physical Layer |  | 257d | 2001-04-05 A | 2002-03-29 A | 100% | 2001-04-05 | 2002-03-29 | 257d |  | finish no earlier than 2002-03-29 | R1 | 2056h | 2056h | HSDPA-Phys |  |  | Patrick | Motorola | Amitava Ghosh |  |
| 1457 | 77.2 | Layer 2 and 3 aspects |  | 257d | 2001-04-05 A | 2002-03-29 A | 100% | 2001-04-05 | 2002-03-29 | 257d |  | finish no earlier than 2002-03-29 | R2 | 2056h | 2056h | HSDPA-L23 |  |  | Joern | Motorola | Ravi Kuchibhotla |  |
| 1458 | 77.3 | Iub/Iur protocol aspects |  | 260d | 2001-04-02 A | 2002-03-29 A | 100% | 2001-04-02 | 2002-03-29 | 260d |  | finish no earlier than 2002-03-29 | R3 | 2080h | 2080h | HSDPA-IubIur |  |  | Gert | Motorola | Mike Diesen |  |
| 1459 | 77.4 | RF Radio Transmission/ Reception, System Performance Requirements and Conformance Testing |  | 565d | 2001-04-09 A | 2003-06-06 A | 100% | 2001-04-09 | 2003-06-06 | 565d |  | finish no earlier than 2003-06-06 | R4 | 4520h | 4520h | HSDPA-RF |  |  | Stefania | Motorola | Howard Benn |  |
| 1460 | 78 | **Rel-5 Improvements of Radio Interface** |  | 535d | 2000-08-14 A | 2002-08-30 A | 100% | 2000-08-14 | 2002-08-30 | 535d |  |  | RP | 30376h | 30376h | RInImp | NA |  | Stefania |  |  |  |
| 1461 | 78.1 | **Base station classification** |  | 480d | 2000-08-14 A | 2002-06-14 A | 100% | 2000-08-14 | 2002-06-14 | 480d |  |  | R4 | 9208h | 9208h | RInImp-BSClass | Rel-5 |  | Stefania | Nokia | antti.toskala@nokia.com |  |
| 1462 | 78.1.1 | TDD Base station classification |  | 410d | 2000-08-14 A | 2002-03-08 A | 100% | 2000-08-14 | 2002-03-08 | 410d |  | finish no earlier than 2002-03-08 | R4 | 3280h | 3280h | RInImp-BSClass-TDD |  |  | Stefania | Nokia | antti.toskala@nokia.com |  |
| 1463 | 78.1.2 | Base Station Classification for 1.28 Mcps TDD option |  | 261d | 2001-06-15 A | 2002-06-14 A | 100% | 2001-06-15 | 2002-06-14 | 261d |  | finish no earlier than 2002-06-14 | R4 | 2088h | 2088h | RInImp-BSClass-LCRTDD |  |  | Stefania | Siemens | Meik.Kottkamp@siemens.com |  |
| 1464 | 78.2 | Enhancement on the DSCH hard split mode |  | 271d | 2001-03-16 A | 2002-03-29 A | 100% | 2001-03-16 | 2002-03-29 | 271d |  | finish no earlier than 2002-03-29 | R1 | 2168h | 2168h | RInImp-DSCHhsp | Rel-5 |  | Patrick | Samsung | Jaeyoel KIM |  |
| 1465 | 78.3 | Hybrid ARQ II/III |  | 355d | 2000-08-21 A | 2001-12-28 A | 100% | 2000-08-21 | 2001-12-28 | 355d |  | finish no earlier than 2001-12-28 | R2 | 2840h | 2840h | RInImp-HARQ | Rel-5 |  | Joern | Siemens | A. Sitte | RP-14 |
| 1466 | 78.4 | FS on USTS |  | 355d | 2000-08-14 A | 2001-12-21 A | 100% | 2000-08-14 | 2001-12-21 | 355d |  | finish no earlier than 2001-12-21 | R1 | 2840h | 2840h | RInImp-USTS | Rel-5 |  | Patrick | SK Telecom | D. Kim |  |
| 1467 | 78.5 | FS on UE antenna efficency test method performance requirements |  | 255d | 2000-09-25 A | 2001-09-14 A | 100% | 2000-09-25 | 2001-09-14 | 255d |  | finish no earlier than 2001-09-14 | R4 | 2040h | 2040h | RInImp-UEAnTM | Rel-5 |  | Stefania | Allgon | O. Edvardsson |  |
| 1468 | 78.6 | FS on the re-introduction of the downlink SIR measurement |  | 200d | 2001-03-12 A | 2001-12-14 A | 100% | 2001-03-12 | 2001-12-14 | 200d |  | finish no earlier than 2001-12-14 | R4 | 1600h | 1600h | RInImp-SIR | Rel-5 |  | Stefania | Ericsson | Torgny.Palenius@ericsson.com |  |
| 1469 | 78.7 | FS on mitigating the effect of CPICH interference at the UE |  | 255d | 2001-03-19 A | 2002-03-08 A | 100% | 2001-03-19 | 2002-03-08 | 255d |  | finish no earlier than 2002-03-08 | R4 | 2040h | 2040h | RInImp-CPICH_Intf | Rel-5 |  | Stefania | Intel | shimon.moshavi@INTEL.COM |  |

Notes:
- 1440: "Joker" WI, to be used for a Rel 6 CR not related to any feature and with very limited impact on the system. Moved in from Stoyan/Testing WP
- 1441: "Joker" WI, to be used for small modifications applicable to Rel 4 conformance testing
- 1442: SP-23 - To be abandoned?
- 1443: Started
- 1446: Started
- 1447: Not started
- 1448: Not started
- 1449: Started
- 1450: Not started
- 1451: Generic feature
- 1454: update WID / 30.11.2001: To CN #14 for approval
- 1457: 30 November: Completion date shifted to March 2002
- 1465: Stopped at RP#14; work on this task was performed as part of High Speed Downlink Packet Access feature

| ID | WBS | Task | Duration | Start | Finish | Complete | Baseline start | Baseline finish | Baseline duration | Constraint | Resources | Work | Actual work | Text8 | Text12 | Text6 | Text1 | Text4 | Text5 | Text3 |
| --- | --- | --- | --- | --- | --- | --- | --- | --- | --- | --- | --- | --- | --- | --- | --- | --- | --- | --- | --- | --- |
| 1470 | 78.8 | **Deleted - Conformance Test Spec. improvements in Radio Interface** | 140d | 2002-02-18 A | 2002-08-30 A | 100% | 2002-02-18 | 2002-08-30 | 140d |  | T1 | 3360h | 3360h | Ingbert | TP-22 |  |  |  |  |  |
| 1471 | 78.8.1 | Deleted - Testing improvement of inter-frequency and inter-system measurement | 140d | 2002-02-18 A | 2002-08-30 A | 100% | 2002-02-18 | 2002-08-30 | 140d | finish no earlier than 2002-08-30 | T1 | 1120h | 1120h | Ingbert | TP-22 | Rel-5 |  |  |  |  |
| 1472 | 78.8.2 | Deleted - Testing Hybrid ARQ II/III | 140d | 2002-02-18 A | 2002-08-30 A | 100% | 2002-02-18 | 2002-08-30 | 140d | finish no earlier than 2002-08-30 | T1 | 1120h | 1120h | Ingbert | TP-22 | Rel-5 |  |  |  |  |
| 1473 | 79 | **Rel-5 RAN improvements** | 772d? | 2001-03-16 A | 2004-03-01 A | 100% | 2001-03-16 | 2004-03-01 | 772d? |  | RP | 39984h | 39984h | Stefania |  | NA | RANimp |  |  |  |
| 1474 | 79.1 | **RRM optimization for Iur and Iub** | 318d | 2001-03-16 A | 2002-06-04 A | 100% | 2001-03-16 | 2002-06-04 | 318d |  | R3 | 8904h | 8904h | Gert |  | Rel-5 | RANimp-RRMopt | Ericsson | Gert-Jan.van.Lieshout@eln.ericsson.se |  |
| 1475 | 79.1.1 | Iur common transport channel efficiency optimisation | 271d | 2001-03-16 A | 2002-03-29 A | 100% | 2001-03-16 | 2002-03-29 | 271d | finish no earlier than 2002-03-29 | R3 | 2168h | 2168h | Gert |  |  | RANimp-RRMopt-ctc | Ericsson | Shahrokh Amirijoo |  |
| 1476 | 79.1.2 | Iur neighbouring cell reporting efficiency optimisation | 271d | 2001-03-16 A | 2002-03-29 A | 100% | 2001-03-16 | 2002-03-29 | 271d | finish no earlier than 2002-03-29 | R3 | 2168h | 2168h | Gert |  |  | RANimp-RRMopt-ncr | Ericsson | Shahrokh Amirijoo |  |
| 1477 | 79.1.3 | FS Introduction of direct transport bearers between SRNC and Node-B | 253d | 2001-06-15 A | 2002-06-04 A | 100% | 2001-06-15 | 2002-06-04 | 253d | finish no earlier than 2002-06-28 | R3 | 2024h | 2024h | Gert |  |  | RAN-imp-RRMopt-DTB | Ericsson | Risto Sepponen |  |
| 1478 | 79.2 | RL Timing Adjustment | 271d | 2001-03-16 A | 2002-03-29 A | 100% | 2001-03-16 | 2002-03-29 | 271d | finish no earlier than 2002-03-29 | R3 | 2168h | 2168h | Gert |  | Rel-5 | RANimp-RLTA | Ericsson | Elena Voltolina |  |
| 1479 | 79.3 | Separation of resource reservation and radio link activation | 271d | 2001-03-16 A | 2002-03-29 A | 100% | 2001-03-16 | 2002-03-29 | 271d | finish no earlier than 2002-03-29 | R3 | 2168h | 2168h | Gert |  | Rel-5 | RANimp-SepRR | Ericsson | Gert-Jan.van.Lieshout@eln.ericsson.se |  |
| 1480 | 79.4 | FS SRNS Relocation Procedure Enhancement | 318d | 2001-06-15 A | 2002-09-03 A | 100% | 2001-06-15 | 2002-09-03 | 318d | finish no earlier than 2002-09-06 | R3 | 2544h | 2544h | Gert |  | Rel-5 | RANimp-SRNS | Nokia | Olivier Guyot |  |
| 1481 | 79.5 | FS Improvement of Radio Resource Management across RNS and RNS/PSS | 201d | 2001-03-16 A | 2001-12-21 A | 100% | 2001-03-16 | 2001-12-21 | 201d | finish no earlier than 2001-12-21 | R3 | 1608h | 1608h | Gert |  | Rel-5 | RANimp-ImpRRM | Nokia | antti.toskala@nokia.com |  |
| 1482 | 79.6 | Re-arrangements of Iub transport bearers | 271d | 2001-03-16 A | 2002-03-29 A | 100% | 2001-03-16 | 2002-03-29 | 271d | finish no earlier than 2002-03-29 | R3 | 2168h | 2168h | Gert |  | Rel-5 | RANimp-TTPS | Nokia | antti.toskala@nokia.com |  |
| 1483 | 79.7 | RAB support enhancement for Rel-5 | 325d | 2001-04-02 A | 2002-06-28 A | 100% | 2001-04-02 | 2002-06-28 | 325d | finish no earlier than 2002-06-28 | R2 | 2600h | 2600h | Joern |  | Rel-5 | RANimp-RABSE5 | Nokia | Juha Mikola |  |
| 1484 | 79.8 | Beamforming requirements for UE | 61d | 2001-09-21 A | 2001-12-14 A | 100% | 2001-09-21 | 2001-12-14 | 61d | finish no earlier than 2001-12-14 | R1 | 488h | 488h | Patrick |  | Rel-5 | RANimp-BFR-UE | Nokia | Jussi Kähtävä (juha.mikola@nokia.com) |  |
| 1485 | 79.9 | Support of Site Selection Diversity Transmission in UTRAN | 123d | 2001-12-14 A | 2002-06-04 A | 100% | 2001-12-14 | 2002-06-04 | 123d | finish no earlier than 2002-06-04 | R1 | 984h | 984h | Patrick |  | Rel-5 | RANimp-SSDT | NEC |  |  |
| 1486 | 79.10 | Node B Synchronisation for 1.28 Mcps TDD | 271d | 2001-03-16 A | 2002-03-29 A | 100% | 2001-03-16 | 2002-03-29 | 271d | finish no earlier than 2002-03-29 | R1 | 2168h | 2168h | Patrick |  | Rel-5 | RANimp-NBSLCR | CATT | Jinling HU |  |
| 1487 | 79.12 | **Deleted - Conformance Test Aspects - RAN Improvements** | 565d? | 2002-01-01 A | 2004-03-01 A | 100% | 2002-01-01 | 2004-03-01 | 565d? |  | T1 | 8008h | 8008h | Ingbert |  | Rel-5 |  |  |  | 0% |
| 1488 | 79.12.1 | Deleted - Testing Radio access bearer support enhancments | 175d | 2002-01-01 A | 2002-09-02 A | 100% | 2002-01-01 | 2002-09-02 | 175d | finish no earlier than 2002-09-02 | T1 | 1400h | 1400h | Ingbert | TP-22 |  |  |  |  |  |
| 1489 | 407.11.2 | Deleted - General changes to TS34.121 and TS34.122 corresponding to release 5 | 261d? | 2003-03-03 A | 2004-03-01 A | 100% | 2003-03-03 | 2004-03-01 | 261d? | finish no earlier than 2004-03-01 | T1 | 2088h | 2088h | Ingbert |  | Rel-5 | RANimp-test |  |  | 34.108, 34.121, 34.122 |
| 1490 | 80 | UTRAN Sharing in Connected Mode | 197d | 2001-12-03 A | 2002-09-03 A | 100% | 2001-12-03 | 2002-09-03 | 197d | finish no earlier than 2002-09-06 | R3 | 1576h | 1576h | Gert |  | Rel-5 | NETSHARE | Ericsson | Martin Israelsson |  |
| 1491 | 81 | **Provisioning of IP-based multimedia services** | 1088d | 2000-01-03 A | 2004-03-03 A | 100% | 2000-01-03 | 2004-03-03 | 1088d |  | S1,S2,S5 | 187140h | 187140h | Alain |  | Rel-5 | IMS | Openwave | Mark Cataldo |  |
| 1492 | 81.1 | **Call control and roaming to support IMS in UMTS** | 640d | 2000-01-03 A | 2002-06-14 A | 100% | 2000-01-03 | 2002-06-14 | 640d |  | S2 | 82520h | 82520h | Maurice |  | Rel-5 | IMS-CCR | Lucent | Liz Daniel |  |
| 1493 | 81.1.1 | Stage 1 | 215d | 2000-02-21 A | 2000-12-15 A | 100% | 2000-02-21 | 2000-12-15 | 215d | finish no earlier than 2000-09-21 | S1 | 1720h | 1720h | Alain |  |  |  | Motorola | Mark Cataldo | 22.228 |
| 1494 | 81.1.2 | Stage 2 (Architecture and Main flows) | 246d | 2000-04-14 A | 2001-03-23 A | 100% | 2000-04-14 | 2001-03-23 | 246d | finish no earlier than 2001-03-23 | S2 | 1968h | 1968h | Maurice |  |  |  | Lucent | Liz Daniel | 23.228 |
| 1495 | 81.1.3 | Impact on MM/CC/SM | 400d | 2000-08-28 A | 2002-03-08 A | 100% | 2000-08-28 | 2002-03-08 | 400d | finish no earlier than 2002-03-08 | N1 | 3200h | 3200h | Frederic |  |  | IMS-CCR-IWMM | Lucent | Keith Drage (drage@alcatel-lucent.com) |  |

Notes:
- 1470: Marked as stopped 12/2008
- 1471: start/finish dates set...Marked as stopped 12/2008
- 1472: start/finish dates set...Marked as stopped 12/2008
- 1477: FS was closed and introduction of WI not agreed at RAN #16
- 1481: FS was closed and WI was introduced at RAN #14
- 1483: RFC 3095 context relocation
- 1485: RP-020356
- 1487: Marked as stopped 12/2008
- 1488: duration set to 6 months (was 0)...Marked as stopped 12/2008
- 1489: Marked as stopped 12/2008
- 1490: Formerly 'Shared Network support in connected mode', renamed at RAN #16.
- 1491: S1 WI proposed S1-000290 / TR22.976, WI Rapporteur, Mark Cataldo, Motorola
- 1493: Issues include e.g.: Roaming requirements, Requirements on supplementary services, Interworking requirements
- 1494: Issues include e.g.: Mobile IP, RAB selection principles, Optimized VoIP bearer mechanisms, SIP multimedia protocol
- 1495: Per 26/2-02: This is understood to be the PCO & TFT CRs which CN1 provides to TSGN #15 for approval. If this is correct understanding, then the task is 100 % complete.

| ID | WBS | Task | Duration | Start | Finish | Complete | Baseline start | Baseline finish | Baseline duration | Constraint | Resources | Work | Actual work | Text3 | Text4 | Text5 | Text8 | Text1 | Text6 |
| --- | --- | --- | --- | --- | --- | --- | --- | --- | --- | --- | --- | --- | --- | --- | --- | --- | --- | --- | --- |
| 1496 | 81.1.4 | **SIP Call Control protocol for the IMS** | 640d | 2000-01-03 A | 2002-06-14 A | 100% | 2000-01-03 | 2002-06-14 | 640d |  | N1 | 70800h | 70800h | 24.228, 24.229, 23.218 | Lucent | Keith Drage (drage@alcatel-lucent.com) | Frederic |  |  |
| 1497 | 81.1.4.1 | IMS signalling flows | 385d | 2000-10-02 A | 2002-03-22 A | 100% | 2000-10-02 | 2002-03-22 | 385d | finish no earlier than 2002-03-22 | N1 | 3080h | 3080h | 24.228 |  |  | Frederic |  |  |
| 1498 | 81.1.4.2 | IMS stage 3 | 385d | 2000-10-02 A | 2002-03-22 A | 100% | 2000-10-02 | 2002-03-22 | 385d | finish no earlier than 2002-03-22 | N1 | 3080h | 3080h | 24.229 |  |  | Frederic |  |  |
| 1499 | 81.1.4.3 | IMS Session Handling; stage 2 | 385d | 2000-10-02 A | 2002-03-22 A | 100% | 2000-10-02 | 2002-03-22 | 385d | finish no earlier than 2002-03-22 | N1 | 3080h | 3080h | 23.218 |  |  | Frederic |  |  |
| 1500 | 81.1.4.4 | **Main IETF dependencies** | 635d | 2000-01-03 A | 2002-06-07 A | 100% | 2000-01-03 | 2002-06-07 | 635d |  | NP | 45392h | 45392h |  |  |  | Kimmo |  |  |
| 1501 | 81.1.4.4.1 | IETF: RFC 3261 (Session Initiation Protocol) | 346d | 2000-11-24 A | 2002-03-22 A | 100% | 2000-11-24 | 2002-03-22 | 346d | finish no earlier than 2002-03-22 | N1 | 2768h | 2768h |  |  |  | Frederic |  |  |
| 1502 | 81.1.4.4.2 | IETF: RFC 3262 (Reliability of provisional responses) | 346d | 2000-11-24 A | 2002-03-22 A | 100% | 2000-11-24 | 2002-03-22 | 346d | finish no earlier than 2002-03-22 | N1 | 2768h | 2768h |  |  |  | Frederic |  |  |
| 1503 | 81.1.4.4.3 | IETF: RFC 3312 (Without COMET)(Integration of resource management and SIP) | 382d | 2000-11-24 A | 2002-05-13 A | 100% | 2000-11-24 | 2002-05-13 | 382d | finish no earlier than 2002-05-13 | N1 | 3056h | 3056h |  |  |  | Frederic |  |  |
| 1504 | 81.1.4.4.4 | IETF: RFC 3323 (SIP extensions for caller identity and privacy) | 382d | 2000-11-24 A | 2002-05-13 A | 100% | 2000-11-24 | 2002-05-13 | 382d | finish no earlier than 2002-05-13 | N1 | 3056h | 3056h |  |  |  | Frederic |  |  |
| 1505 | 81.1.4.4.5 | IETF: RFC 3313 (SIP extensions for media authorization) | 382d | 2000-11-24 A | 2002-05-13 A | 100% | 2000-11-24 | 2002-05-13 | 382d | finish no earlier than 2002-05-13 | N1 | 3056h | 3056h |  |  |  | Frederic |  |  |
| 1506 | 81.1.4.4.6 | IETF: RFC 3265 (specific event notification) | 346d | 2000-11-24 A | 2002-03-22 A | 100% | 2000-11-24 | 2002-03-22 | 346d | finish no earlier than 2002-03-22 | N1 | 2768h | 2768h |  |  |  | Frederic |  |  |
| 1507 | 81.1.4.4.7 | IETF: RFC editor Queue (refer method) | 401d | 2000-11-24 A | 2002-06-07 A | 100% | 2000-11-24 | 2002-06-07 | 401d | finish no earlier than 2002-06-07 | N1 | 3208h | 3208h |  |  |  | Frederic |  |  |
| 1508 | 81.1.4.4.8 | IETF: RFC editor Queue (DHCP options for SIP servers) | 382d | 2000-11-24 A | 2002-05-13 A | 100% | 2000-11-24 | 2002-05-13 | 382d | finish no earlier than 2002-05-13 | N1 | 3056h | 3056h |  |  |  | Frederic |  |  |
| 1509 | 81.1.4.4.10 | IETF: RFC 3267 (AMR and AMR WB RTP and SDP) | 346d | 2000-11-24 A | 2002-03-22 A | 100% | 2000-11-24 | 2002-03-22 | 346d | finish no earlier than 2002-03-22 | N1 | 2768h | 2768h |  |  |  | Frederic |  |  |
| 1510 | 81.1.4.4.11 | IETF: RFC 3266 (IPv6 support within SDP) | 580d | 2000-01-03 A | 2002-03-22 A | 100% | 2000-01-03 | 2002-03-22 | 580d | finish no earlier than 2002-03-22 | N1 | 4640h | 4640h |  |  |  | Frederic |  |  |
| 1511 | 81.1.4.4.12 | IETF: RFC 3311 (The Update method) | 382d | 2000-11-24 A | 2002-05-13 A | 100% | 2000-11-24 | 2002-05-13 | 382d | finish no earlier than 2002-05-13 | N1 | 3056h | 3056h |  |  |  | Frederic |  |  |
| 1512 | 81.1.4.4.13 | IETF: RFC 3324 (Network Asserted Identity) | 382d | 2000-11-24 A | 2002-05-13 A | 100% | 2000-11-24 | 2002-05-13 | 382d | finish no earlier than 2002-05-13 | N1 | 3056h | 3056h |  |  |  | Frederic |  |  |
| 1513 | 81.1.4.4.14 | IETF: RFC editor Queue (Various 3GPP Private Extensions) | 382d | 2000-11-24 A | 2002-05-13 A | 100% | 2000-11-24 | 2002-05-13 | 382d | finish no earlier than 2002-05-13 | N1 | 3056h | 3056h |  |  |  | Frederic |  |  |
| 1514 | 81.1.4.5 | **Addressing** | 380d | 2000-10-09 A | 2002-03-22 A | 100% | 2000-10-09 | 2002-03-22 | 380d |  | S2 | 7744h | 7744h |  |  |  | Maurice |  |  |
| 1515 | 81.1.4.5.1 | Architectural issues | 235d | 2000-10-09 A | 2001-08-31 A | 100% | 2000-10-09 | 2001-08-31 | 235d | finish no earlier than 2001-03-16 | S2 | 1880h | 1880h |  |  |  | Maurice |  |  |
| 1516 | 81.1.4.5.2 | Impact on HSS | 353d | 2000-11-15 A | 2002-03-22 A | 100% | 2000-11-15 | 2002-03-22 | 353d | finish no earlier than 2002-03-22 | N4 | 2824h | 2824h |  |  |  | Kimmo |  |  |
| 1517 | 81.1.4.6 | **Service Examples (Work stopped)** | 304d | 2001-04-17 A | 2002-06-14 A | 100% | 2001-04-17 | 2002-06-14 | 304d |  | S1 | 4864h | 4864h | 22.928 | Motorola | Mark Cataldo | Alain | IMS-Sex |  |
| 1518 | 81.1.4.6.1 | IMS Framework Report (work stopped) | 304d | 2001-04-17 A | 2002-06-14 A | 100% | 2001-04-17 | 2002-06-14 | 304d | finish no earlier than 2002-06-14 | S1 | 2432h | 2432h | 22.941 | SBC | Randolph Wohlert (rwohlert@tri.sbc.com) | Alain | IMS-FrWk |  |
| 1519 | 81.2 | **Access Security for IMS** | 190d | 2001-10-08 A | 2002-06-28 A | 100% | 2001-10-08 | 2002-06-28 | 190d |  | S3 | 4120h | 4120h |  | Ericsson | krister.boman@emw.ericsson.se | Dionisio | IMS-ASEC | Rel-5 |
| 1520 | 81.2.2 | IMS impacts on UICC (ISIM application) | 185d | 2001-10-08 A | 2002-06-21 A | 100% | 2001-10-08 | 2002-06-21 | 185d | finish no earlier than 2002-06-21 | T3 | 1480h | 1480h |  | Vodafone | Jeremy Norris |  |  |  |
| 1521 | 81.2.3 | SIP extensions for Integrity protection | 140d | 2001-12-17 A | 2002-06-28 A | 100% | 2001-12-17 | 2002-06-28 | 140d | finish no earlier than 2002-06-28 | N1 | 1120h | 1120h |  |  |  | Frederic |  |  |
| 1522 | 81.3 | Security Aspects of Requirement for Network Configuration Independence | 130d | 2001-07-02 A | 2001-12-28 A | 100% | 2001-07-02 | 2001-12-28 | 130d | finish no earlier than 2001-12-28 | S3 | 1040h | 1040h |  | AT&T Wireless | hugh.shieh@attws.com | Dionisio | SEC1-NCI | Rel-5 |
| 1523 | 81.4 | Lawful interception | 410d | 2000-09-04 A | 2002-03-29 A | 100% | 2000-09-04 | 2002-03-29 | 410d | finish no earlier than 2002-03-29 | S3 | 3280h | 3280h |  | Reg TP | berthold.wilhelm@regtp.de | Dionisio | IMS-LI | Rel-5 |
| 1524 | 81.5 | Charging and OAM&P for IMS | 383d | 2000-12-25 A | 2002-06-12 A | 100% | 2000-12-25 | 2002-06-12 | 383d | finish no earlier than 2002-06-12 | S5 | 3064h | 3064h | 32-series | VoiceStream, Motorola |  | Dionisio | IMS-OAM | Rel-5 |

Notes:
- 1496: TSGN_10 approved the change:CN1 - SA2 SIP joint meeting spotted one more place for improvement: work tasks with ID 1998 and 1278 are actually subtasks under of single CN1 WT. One WI has been approved for the CN1 WT with title "SIP Call Control protocol...
- 1497: TS 24.228...
- 1498: TS 24.229...
- 1499: TS 23.218...
- 1516: 17th May, KK: This is cover by 29.228 & 29228. Work complete.
- 1519: TS33.203 will be presented for info at SA#14 and is scheduled for approval at SA#15. Dependencies on IETF exist. Approved SA#15
- 1521: Per 26/2-02: CN1 is not aware of any requirements and is not doing anything on this task.
- 1522: Incorporated into IMS access security TS (33.203) which will be presented for info at SA#14 and is scheduled for approval at SA#15.Editors notes removed SA#16&17
- 1523: Rel-5 33.106 and 33.107 approved at SA#12.Revised WID including new Rel-5 specification (33.108) scheduled for approval at SA#14. 33.108 approved SA#16. CR at SA#17

| ID | WBS | Task | Duration | Start | Finish | Complete | Baseline start | Baseline finish | Baseline duration | Constraint | Resources | Work | Actual work | Text1 | Text3 | Text4 | Text5 | Text6 | Text8 |
| --- | --- | --- | --- | --- | --- | --- | --- | --- | --- | --- | --- | --- | --- | --- | --- | --- | --- | --- | --- |
| 1525 | 81.6 | **Multimedia codecs and protocols for conversational PS services** | 568d | 2000-07-26 A | 2002-09-27 A | 100% | 2000-07-26 | 2002-09-27 | 568d |  | S4 | 15640h | 15640h | IMS-CODEC | 26.235, 26.236 | Toshiba, Nokia | B. Aronson (Toshiba), pasi.s.ojala@nokia.com | Rel-5 | Paolo |
| 1526 | 81.6.1 | Codecs | 427d | 2000-07-26 A | 2002-03-14 A | 100% | 2000-07-26 | 2002-03-14 | 427d | finish no earlier than 2001-03-21 | S4 | 3416h | 3416h |  | 26.235, 26.236 |  |  |  | Paolo |
| 1527 | 81.6.2 | Transport protocols | 1d | 2002-03-12 A | 2002-03-12 A | 100% | 2002-03-12 | 2002-03-12 | 1d | finish no earlier than 2002-03-12 | S4 | 8h | 8h | IMS-CODEC | 26.236 | Nokia | P. Ojala | Rel-5 | Paolo |
| 1528 | 81.6.4 | recommendation for QoS parameter values for various media types | 195d | 2001-12-31 A | 2002-09-27 A | 100% | 2001-12-31 | 2002-09-27 | 195d | finish no earlier than 2002-09-27 | S4 | 1560h | 1560h |  |  |  |  |  | Paolo |
| 1529 | 81.6.5 | IETF: RFC 3310 (HTTP Digest Authentication using AKA) | 382d | 2000-11-24 A | 2002-05-13 A | 100% | 2000-11-24 | 2002-05-13 | 382d | finish no earlier than 2002-05-13 | N1 | 3056h | 3056h |  |  |  |  |  | Frederic |
| 1530 | 81.6.6 | IETF: RFC 3329 (Security mechanism agreement for SIP connections) | 382d | 2000-11-24 A | 2002-05-13 A | 100% | 2000-11-24 | 2002-05-13 | 382d | finish no earlier than 2002-05-13 | N1 | 3056h | 3056h |  |  |  |  |  | Frederic |
| 1531 | 81.7 | **SIP message compression** | 185d | 2001-09-24 A | 2002-06-07 A | 100% | 2001-09-24 | 2002-06-07 | 185d |  | S2 | 3128h | 3128h |  |  |  |  | Rel-5 | Maurice |
| 1532 | 81.7.1 | Stage 2 | 25d | 2001-09-24 A | 2001-10-26 A | 100% | 2001-09-24 | 2001-10-26 | 25d | finish no earlier than 2001-10-26 | S2 | 200h | 200h |  |  |  |  |  | Maurice |
| 1533 | 81.7.2 | Compression signalling | 181d | 2001-09-28 A | 2002-06-07 A | 100% | 2001-09-28 | 2002-06-07 | 181d | finish no earlier than 2002-06-07 | N1 | 1448h | 1448h |  |  |  |  |  | Frederic |
| 1534 | 81.8 | **Stage 3 description of IMS interfaces** | 383d | 2001-03-14 A | 2002-08-30 A | 100% | 2001-03-14 | 2002-08-30 | 383d |  | NP | 29531.6h | 29531.6h |  |  |  |  | Rel-5 | Kimmo |
| 1535 | 81.8.1 | Cx interface (HSS to CSCF) | 135.95d | 2001-03-14 A | 2002-06-07 A | 100% | 2001-03-14 | 2002-06-07 | 135.95d | finish no earlier than 2002-06-07 | N4 | 1087.58h | 1087.58h |  |  |  |  |  | Kimmo |
| 1536 | 81.8.2 | Mp interface (MRFC - MRFP) enhancements | 258d | 2001-03-14 A | 2002-03-08 A | 100% | 2001-03-14 | 2002-03-08 | 258d | finish no earlier than 2002-06-07 | N4 | 2064h | 2064h |  |  |  |  |  | Kimmo |
| 1537 | 81.8.3 | Mw interface (CSCF to P-CSCF) | 323d | 2001-03-14 A | 2002-06-07 A | 100% | 2001-03-14 | 2002-06-07 | 323d | finish no earlier than 2002-06-07 | N1 | 2584h | 2584h |  |  |  |  |  | Frederic |
| 1538 | 81.8.4 | Mr interface (CSCF to MRF) | 273d | 2001-03-14 A | 2002-03-29 A | 100% | 2001-03-14 | 2002-03-29 | 273d | finish no earlier than 2002-03-29 | N1 | 2184h | 2184h |  |  |  |  |  | Frederic |
| 1539 | 81.8.5 | Dx interface (I-CSCF to SLF) | 323d | 2001-03-14 A | 2002-06-07 A | 100% | 2001-03-14 | 2002-06-07 | 323d | finish no earlier than 2002-06-07 | N4 | 2584h | 2584h |  |  |  |  |  | Kimmo |
| 1540 | 81.8.6 | Go interface (GGSN to PCF) | 323d | 2001-03-14 A | 2002-06-07 A | 100% | 2001-03-14 | 2002-06-07 | 323d | finish no earlier than 2002-06-07 | N3 | 2584h | 2584h |  |  |  |  |  | Gwiho |
| 1541 | 81.8.7 | ISC (IMS Service Control) Interface | 323d | 2001-03-14 A | 2002-06-07 A | 100% | 2001-03-14 | 2002-06-07 | 323d | finish no earlier than 2002-06-07 | N1 | 2584h | 2584h |  |  |  |  |  | Frederic |
| 1542 | 81.8.8 | Sh interface (HSS to AS) | 82d | 2002-02-14 A | 2002-06-07 A | 100% | 2002-02-14 | 2002-06-07 | 82d | finish no earlier than 2002-06-07 | N4 | 656h | 656h |  |  |  |  |  | Kimmo |
| 1543 | 81.8.9 | Si interface (HSS to IM-SSF) | 162.5d | 2002-01-16 A | 2002-08-30 A | 100% | 2002-01-16 | 2002-08-30 | 162.5d | finish no earlier than 2002-06-07 | N4 | 1300h | 1300h |  |  |  |  |  | Kimmo |
| 1544 | 81.8.10 | Gm interface (UE to CSCF) | 323d | 2001-03-14 A | 2002-06-07 A | 100% | 2001-03-14 | 2002-06-07 | 323d | finish no earlier than 2002-06-07 | N1 | 2584h | 2584h |  |  |  |  |  | Frederic |
| 1545 | 81.8.11 | Mi interface (CSCF to BGCF) | 323d | 2001-03-14 A | 2002-06-07 A | 100% | 2001-03-14 | 2002-06-07 | 323d | finish no earlier than 2002-06-07 | N1 | 2584h | 2584h |  |  |  |  |  | Frederic |
| 1546 | 81.8.12 | Mj interface (BGCF to MGCF) | 323d | 2001-03-14 A | 2002-06-07 A | 100% | 2001-03-14 | 2002-06-07 | 323d | finish no earlier than 2002-06-07 | N1 | 2584h | 2584h |  |  |  |  |  | Frederic |
| 1547 | 81.8.13 | Mk interface (BGCF to BGCF) | 323d | 2001-03-14 A | 2002-06-07 A | 100% | 2001-03-14 | 2002-06-07 | 323d | finish no earlier than 2002-06-07 | N1 | 2584h | 2584h |  |  |  |  |  | Frederic |
| 1548 | 81.9 | Support of VHE/OSA by entities and protocols of the IMS (e.g. CSCF) | 186d | 2001-09-21 A | 2002-06-07 A | 100% | 2001-09-21 | 2002-06-07 | 186d | finish no earlier than 2002-06-07 | N5 | 1488h | 1488h | IMS-ONOSA | 29.198, 29.998 | Ericsson | Ard.Jan.Moerdijk@eln.ericsson.se | Rel-5 | Kimmo |

Notes:
- 1535: DAB 12/12/01 to 75% / CN4 14/02/02 to 79% / 17th May work complete. 3GPP TSs 29.228 and 29.229 will be sent for proval in CN#16
- 1536: [DAB 08-03-02] - No work required in CN4
- 1539: CN4#11 30/11/01: No inputs received in CN4 / 14/02/02 Completed(introduced in 29.228)
- 1540: [DAB - 23/05/03] - 100 % complete
- 1542: CN4#11 30/11/01: No inputs received in CN4 / CN4#12bis 14/02/02: WID approved / 17th May 100% complete. 3GPP TS 29.329 will be sent for approval in CN#16
- 1543: SA16: Part of Rel5 only if completed in September 02. Marked as closed 12/2008 (was marked 72% complete)

| ID | WBS | Task | Duration | Start | Finish | Predecessors | Complete | Baseline start | Baseline finish | Baseline duration | Constraint | Resources | Work | Actual work | Text1 | Text4 | Text5 | Text6 | Text8 | Text12 | Text3 |
| --- | --- | --- | --- | --- | --- | --- | --- | --- | --- | --- | --- | --- | --- | --- | --- | --- | --- | --- | --- | --- | --- |
| 1549 | 81.10 | **CAMEL control of IMS services** | 365d | 2001-04-16 A | 2002-09-06 A |  | 100% | 2001-04-16 | 2002-09-06 | 365d |  | N2 | 9952h | 9952h | IMS-CAMEL | Lucent | Angelica Remoquillo | Rel-5 | Kimmo |  |  |
| 1550 | 81.10.1 | Stage2 work 'general' | 365d | 2001-04-16 A | 2002-09-06 A |  | 100% | 2001-04-16 | 2002-09-06 | 365d | finish no earlier than 2002-09-06 | N2 | 2920h | 2920h |  |  |  |  | Kimmo |  |  |
| 1551 | 81.10.2 | Stage3 work 'CAP' | 175d | 2002-01-07 A | 2002-09-06 A |  | 100% | 2002-01-07 | 2002-09-06 | 175d | finish no earlier than 2002-09-06 | N2 | 1400h | 1400h |  |  |  |  | Kimmo |  |  |
| 1552 | 81.10.3 | Stage2 work 'Si interface' | 175d | 2002-01-07 A | 2002-09-06 A |  | 100% | 2002-01-07 | 2002-09-06 | 175d | finish no earlier than 2002-09-06 | N2 | 1400h | 1400h |  |  |  |  | Kimmo |  |  |
| 1553 | 81.10.4 | Stage3 work 'Si interface' | 82d | 2002-02-14 A | 2002-06-07 A |  | 100% | 2002-02-14 | 2002-06-07 | 82d | finish no earlier than 2002-06-07 | N4 | 656h | 656h |  |  |  |  | Kimmo |  |  |
| 1554 | 81.10.5 | Deleted - SDM issues for CAMEL control of IMS | 82d | 2002-02-14 A | 2002-06-07 A |  | 100% | 2002-02-14 | 2002-06-07 | 82d | finish no earlier than 2002-06-07 | N4 | 656h | 656h |  |  |  |  | Kimmo | NP-21 |  |
| 1555 | 81.11 | Pre-pay/real-time charging in IMS | 196d | 2001-06-15 A | 2002-03-15 A |  | 100% | 2001-06-15 | 2002-03-15 | 196d | finish no earlier than 2002-03-15 | S1 | 1568h | 1568h |  |  |  | Rel-5 | Alain |  |  |
| 1556 | 81.12 | **Charging** | 289d | 2001-08-06 A | 2002-09-12 A |  | 100% | 2001-08-06 | 2002-09-12 | 289d |  | S2,S5 | 6632h | 6632h | OAM-CH | T-Mobile | karl-heinz.nenner@t-mobile.de | Rel-5 | Dionisio |  | 32.2xy |
| 1557 | 81.12.1 | Charging Implications of IMS architecture | 75d | 2001-08-06 A | 2001-11-16 A |  | 100% | 2001-08-06 | 2001-11-16 | 75d | finish no earlier than 2001-11-16 | S2 | 600h | 600h |  |  |  | Rel-5 | Maurice |  |  |
| 1558 | 81.12.2 | Charging management for IMS (off-line & on-line) | 214d | 2001-11-19 A | 2002-09-12 A | 1557 | 100% | 2001-11-19 | 2002-09-12 | 214d | finish no earlier than 2002-09-12 | S5 | 1712h | 1712h | OAM-CH |  |  | Rel-5 | Dionisio |  |  |
| 1559 | 86.1.6.10 | Billing, accounting and call detail record aspects | 251d | 2001-09-27 A | 2002-09-12 A |  | 100% | 2001-09-27 | 2002-09-12 | 251d | finish no earlier than 2002-09-12 | S5 | 2008h | 2008h |  | T-Mobile | Karl-Heinz.Nenner@T-MOBILE.DE | Rel-5 | Dionisio |  | 32.2xy |
| 1560 | 81.13 | **Other IETF depencies** | 401d | 2000-11-24 A | 2002-06-07 A |  | 100% | 2000-11-24 | 2002-06-07 | 401d |  | NP | 9624h | 9624h |  |  |  | Rel-5 |  |  |  |
| 1561 | 81.13.1 | IETF: draft-ietf-aaa-diameter - should be CN4 | 401d | 2000-11-24 A | 2002-06-07 A |  | 100% | 2000-11-24 | 2002-06-07 | 401d | finish no earlier than 2002-06-07 | NP | 3208h | 3208h |  |  |  |  |  |  |  |
| 1562 | 81.13.2 | IETF: draft-johansson-aaa-diameter-mm-app - should be CN4 | 401d | 2000-11-24 A | 2002-06-07 A |  | 100% | 2000-11-24 | 2002-06-07 | 401d | finish no earlier than 2002-06-07 | NP | 3208h | 3208h |  |  |  |  |  |  |  |
| 1563 | 81.15 | Conformance Test Aspects - Provisioning of IMS | 205d | 2002-03-18 A | 2002-12-27 A |  | 100% | 2002-03-18 | 2002-12-27 | 205d | finish no earlier than 2002-12-27 | T1 | 1640h | 1640h | IMS-TEST |  |  |  | Ingbert |  |  |
| 1564 | 81.16 | Testing of support for IMS - prose | 270d | 2002-09-18 A | 2003-09-30 A |  | 100% | 2002-09-18 | 2003-09-30 | 270d | finish no earlier than 2003-09-30 | T1 | 2160h | 2160h |  | Anritsu | dan.fox@eu.anritsu.com | Rel-5 | Ingbert |  | 34.108, 34.123 |
| 1565 | 81.17 | Testing of support for IMS - TTCN | 381d | 2002-09-18 A | 2004-03-03 A |  | 100% | 2002-09-18 | 2004-03-03 | 381d | finish no earlier than 2004-03-03 | T1 | 3048h | 3048h |  | Anritsu | dan.fox@eu.anritsu.com | Rel-5 | Ingbert |  | 34.108, 34.123 |
| 1566 | 82 | **Extended Transparent End-to-End PS Streaming Service** | 313d? | 2002-01-03 A | 2003-03-17 A |  | 100% | 2002-01-03 | 2003-03-17 | 313d? |  | S4 | 6224h | 6224h | PSS-E | Ericsson | olle.franceschi@ericsson.com | Rel-5 | Paolo |  | 26.233, 26.234 |
| 1567 | 82.1 | **Stage 1** | 86d? | 2002-11-18 A | 2003-03-17 A |  | 100% | 2002-11-18 | 2003-03-17 | 86d? |  | S1 | 1376h | 1376h |  | Vodafone | stephen.wolak@vodafone.com |  | Alain |  | 22.233 |
| 1568 | 410.1.1 | Interaction with other services | 86d? | 2002-11-18 A | 2003-03-17 A |  | 100% | 2002-11-18 | 2003-03-17 | 86d? | finish no earlier than 2003-03-17 | S1 | 688h | 688h |  | Vodafone | stephen.wolak@vodafone.com |  | Alain |  | 22.233 |
| 1569 | 82.2 | Stage 2 (version Rel5 of TS 26.234) | 51d | 2002-01-03 A | 2002-03-14 A |  | 100% | 2002-01-03 | 2002-03-14 | 51d | finish no earlier than 2002-03-26 | S4 | 408h | 408h |  |  |  |  | Paolo |  | 26.234 |
| 1570 | 82.3 | RTP usage model | 242d | 2002-01-03 A | 2002-12-06 A |  | 100% | 2002-01-03 | 2002-12-06 | 242d | finish no earlier than 2002-12-06 | S4 | 1936h | 1936h |  |  |  |  | Paolo |  | 26.937 |
| 1571 | 83 | **Rel-5 OSA enhancements** | 954d | 1999-04-27 A | 2002-12-20 A |  | 100% | 1999-04-27 | 2002-12-20 | 954d |  | S1 | 62480h | 62480h | OSA1 | Siemens | Joerg Swetina (joerg.swetina@nw.neclab.eu) | Rel-5 | Alain |  | 22.127, 23.127, 29.198-x, 29.998-x |
| 1572 | 83.1 | General Stage 2 for Rel5 | 194d | 2001-09-11 A | 2002-06-07 A |  | 100% | 2001-09-11 | 2002-06-07 | 194d |  | S2 | 1232h | 1232h |  |  |  | Rel-5 | Maurice |  |  |

Notes:
- 1549: SA16: Part of Rel5 only if Si completed in September 02
- 1550: DAB 12.12.01 split into cn4 and cn2 parts
- 1551: DAB 12.12.01 split into cn4 and cn2 parts
- 1552: DAB 12.12.01 split into cn4 and cn2 parts
- 1553: [DAB 08-03-02] - UID 12004 is MASTER of UID 14998 / 17 May need to be recearch possible impact on 23.008 & 23.016, changes to 29.002 are done.
- 1554: [DAB 08-03-02] - No activity on this in CN4. Marked as stopped 12/2008
- 1555: Marked as closed 12/2008 (was marked 60% complete)
- 1556: Changed Rapp email
- 1560: Was introduced at SA#13 by Ileana Leuca (exact position in the WP and related WG have to be defined)
- 1561: Marked as closed 12/2008 (was marked 90% complete)
- 1562: Marked as closed 12/2008 (was marked 50% complete)
- 1563: The task is a building block, individual work items are being considered but are constrained by lack of supporting companies. Marked as stopped 12/2008
- 1564: Marked as stopped 12/2008
- 1565: Marked as stopped 12/2008
- 1567: 2nd resp SA4
- 1568: 2nd resp SA4. Marked as closed 12/2008 (was marked 65% complete)
- 1569: 2nd resp SA2
- 1570: Marked as closed 12/2008 (was marked 90% complete)
- 1572: Marked as closed 12/2008 (was marked 47% complete)

| ID | WBS | Task | Duration | Start | Finish | Predecessors | Complete | Baseline start | Baseline finish | Baseline duration | Constraint | Resources | Work | Actual work | Text1 | Text6 | Text8 | Text3 | Text4 | Text5 |
| --- | --- | --- | --- | --- | --- | --- | --- | --- | --- | --- | --- | --- | --- | --- | --- | --- | --- | --- | --- | --- |
| 1573 | 83.2 | **OSA APIs for Multimedia Call Control** | 499d | 2000-07-11 A | 2002-06-07 A |  | 100% | 2000-07-11 | 2002-06-07 | 499d |  | S2 | 5960h | 5960h | OSA1-CSCF | Rel-5 | Maurice |  |  |  |
| 1574 | 83.2.1 | Stage 1 | 438d | 2000-07-11 A | 2002-03-14 A |  | 100% | 2000-07-11 | 2002-03-14 | 438d | finish no earlier than 2002-03-14 | S1 | 3504h | 3504h |  |  | Alain | 22.127 | Siemens | Manfred.leitgeb@siemens.at |
| 1575 | 83.2.2 | (Multimedia) Call Control - Stages 2 and 3 | 194d | 2001-09-11 A | 2002-06-07 A |  | 100% | 2001-09-11 | 2002-06-07 | 194d | finish no earlier than 2002-06-07 | N5 | 1552h | 1552h |  |  | Kimmo | 29.198-04 |  |  |
| 1576 | 83.3 | Generic user interaction - Stage 3 | 194d | 2001-09-11 A | 2002-06-07 A |  | 100% | 2001-09-11 | 2002-06-07 | 194d | finish no earlier than 2002-06-07 | N5 | 1552h | 1552h |  | Rel-5 | Kimmo | 29.198-05 |  |  |
| 1577 | 83.4 | Charging - Stage 3 | 194d | 2001-09-11 A | 2002-06-07 A |  | 100% | 2001-09-11 | 2002-06-07 | 194d | finish no earlier than 2002-06-07 | N5 | 1552h | 1552h |  | Rel-5 | Kimmo | 29.198-12 |  |  |
| 1578 | 83.5 | Call Control Service Mapping; Multiparty Call Control SIP - Stage 3 | 194d | 2001-09-11 A | 2002-06-07 A |  | 100% | 2001-09-11 | 2002-06-07 | 194d | finish no earlier than 2002-06-07 | N5 | 1552h | 1552h |  | Rel-5 | Kimmo | 29.998-04-4 |  |  |
| 1579 | 83.6 | WSDL APIs for SOAP/HTTP - Stage 3 | 455d | 2000-09-11 A | 2002-06-07 A |  | 100% | 2000-09-11 | 2002-06-07 | 455d | finish no earlier than 2002-06-07 | N5 | 3640h | 3640h |  | Rel-5 | Kimmo | 29.198, 29.998 |  |  |
| 1580 | 83.7 | **OSA security** | 639d | 2000-07-11 A | 2002-12-20 A |  | 100% | 2000-07-11 | 2002-12-20 | 639d |  | S3 | 15000h | 15000h | OSA1-SEC | Rel-5 | Dionisio |  | BT | colin.blanchard@bt.com |
| 1581 | 83.7.1 | Stage 1 | 349d | 2000-07-11 A | 2001-11-09 A |  | 100% | 2000-07-11 | 2001-11-09 | 349d | finish no earlier than 2001-11-09 | S1 | 2792h | 2792h |  |  | Alain | 22.127 | Siemens | Manfred.leitgeb@siemens.at |
| 1582 | 83.7.2 | Stage 3 | 430d | 2000-10-23 A | 2002-06-14 A |  | 100% | 2000-10-23 | 2002-06-14 | 430d | finish no earlier than 2002-06-14 | S3 | 3440h | 3440h |  |  | Dionisio | ??? |  |  |
| 1583 | 83.7.3 | security related SCF(s) definition | 186d | 2001-09-21 A | 2002-06-07 A |  | 100% | 2001-09-21 | 2002-06-07 | 186d | finish no earlier than 2002-06-07 | N5 | 1488h | 1488h |  |  | Kimmo | 29.198, 29.998 | Ericsson | Ard.Jan.Moerdijk@eln.ericsson.se |
| 1584 | 83.7.4 | (possibly) changes required from supporting platforms, e.g. gsmSCF, HLR | 69d | 2000-09-11 A | 2000-12-14 A |  | 100% | 2000-09-11 | 2000-12-14 | 69d | finish no earlier than 2000-12-14 | S3 | 552h | 552h |  |  | Dionisio | ??? |  |  |
| 1585 | 411.7.5 | Security (moved from Rel-6) | 202d | 2002-03-14 A | 2002-12-20 A |  | 100% | 2002-03-14 | 2002-12-20 | 202d | finish no earlier than 2002-12-20 | S3 | 1616h | 1616h |  |  | Dionisio |  |  |  |
| 1586 | 83.8 | **Interactions OSA - e-commerce** | 814d | 1999-04-27 A | 2002-06-07 A |  | 100% | 1999-04-27 | 2002-06-07 | 814d |  | S2 | 6152h | 6152h | OSA1-ECOM | Rel-5 | Maurice |  |  |  |
| 1587 | 83.8.1 | Stage 1 | 438d | 1999-04-27 A | 2000-12-28 A |  | 100% | 1999-04-27 | 2000-12-28 | 438d | finish no earlier than 2000-12-28 | S1 | 3504h | 3504h |  |  | Alain | 22.127 | Siemens | Joerg Swetina (joerg.swetina@nw.neclab.eu) |
| 1588 | 83.8.2 | Stages 2 and 3 | 186d | 2001-09-21 A | 2002-06-07 A |  | 100% | 2001-09-21 | 2002-06-07 | 186d | finish no earlier than 2002-06-07 | N5 | 1488h | 1488h |  |  | Kimmo | 29.198, 29.998 | Ericsson | Ard.Jan.Moerdijk@eln.ericsson.se |
| 1589 | 83.9 | Policy Management - Stage 3 | 194d | 2001-09-11 A | 2002-06-07 A |  | 100% | 2001-09-11 | 2002-06-07 | 194d | finish no earlier than 2002-06-07 | N5 | 1552h | 1552h |  | Rel-5 | Kimmo | 29.198-13 |  |  |
| 1590 | 83.10 | Presence and Availability Management (PAM) - Stage 3 | 194d | 2001-09-11 A | 2002-06-07 A |  | 100% | 2001-09-11 | 2002-06-07 | 194d | finish no earlier than 2002-06-07 | N5 | 1552h | 1552h |  | Rel-5 | Kimmo | 29.198-14 |  |  |
| 1591 | 83.11 | **CHECK STATUS - LCS - OSA interfaces** | 455d | 2000-09-11 A | 2002-06-07 A |  | 100% | 2000-09-11 | 2002-06-07 | 455d |  | S1 | 5656h | 5656h | OSA1-LCSI | Rel-5 | Alain |  | Siemens | Joerg Swetina (joerg.swetina@nw.neclab.eu) |
| 1592 | 83.11.1 | Stage 1 | 65d | 2000-09-11 A | 2000-12-08 A |  | 100% | 2000-09-11 | 2000-12-08 | 65d | finish no earlier than 2000-12-08 | S1 | 520h | 520h |  |  | Alain | 22.127 | Siemens | Joerg Swetina (joerg.swetina@nw.neclab.eu) |
| 1593 | 83.11.2 | Stage 2 | 1d | 2000-12-11 A | 2000-12-11 A | 1592 | 100% | 2000-12-11 | 2000-12-11 | 1d | finish no earlier than 2000-12-11 | S2 | 8h | 8h |  |  | Maurice | 23.127 | Ericsson | Christophe GOURRAUD |
| 1594 | 83.11.3 | Stage 3 | 186d | 2001-09-21 A | 2002-06-07 A | 1593 | 100% | 2001-09-21 | 2002-06-07 | 186d | finish no earlier than 2002-06-07 | N5 | 1488h | 1488h |  |  | Kimmo | 29.198, 29.998 | Ericsson | Ard.Jan.Moerdijk@eln.ericsson.se |
| 1595 | 411.12 | Access to User Profile | 145d | 2001-06-01 A | 2001-12-20 A |  | 100% | 2001-06-01 | 2001-12-20 | 145d | finish no earlier than 2001-12-20 | S1 | 1160h | 1160h | OSA2-UP | Rel-5 | Alain |  |  |  |
| 1596 | 411.13 | **Retrieval of Terminal capabilities** | 634d | 2000-07-11 A | 2002-12-13 A |  | 100% | 2000-07-11 | 2002-12-13 | 634d |  | S2 | 10808h | 10808h | OSA2-TC | Rel-5 | Maurice |  |  |  |
| 1597 | 411.13.1 | Stage 1 | 132d | 2000-07-11 A | 2001-01-10 A |  | 100% | 2000-07-11 | 2001-01-10 | 132d | finish no earlier than 2001-01-10 | S1 | 1056h | 1056h |  | Rel-5 | Alain | 22.127 | Siemens | Joerg Swetina (joerg.swetina@nw.neclab.eu) |
| 1598 | 411.13.2 | Stages 2 and 3 | 321d | 2001-09-21 A | 2002-12-13 A | 1597 | 100% | 2001-09-21 | 2002-12-13 | 321d | finish no earlier than 2002-12-13 | N5 | 2568h | 2568h |  | Rel-5 | Kimmo | 29.198, 29.998 | Ericsson | Ard.Jan.Moerdijk@eln.ericsson.se |
| 1599 | 411.13.3 | Provisionning of the terminal capabilities | 445d | 2001-04-02 A | 2002-12-13 A |  | 100% | 2001-04-02 | 2002-12-13 | 445d | finish no earlier than 2002-12-13 | T2 | 3560h | 3560h |  | Rel-5 |  | 23.057 |  |  |

Notes:
- 1573: For Rel5 even if completed by March
- 1580: CR to correct security specifications in 29.198 scheduled for approval at CN#15
- 1582: Marked as closed 12/2008 (was marked 80% complete)
- 1585: Contribution at S3#25
- 1587: Marked as closed 12/2008 (was marked 95% complete)
- 1591: az: CN#13 - changed to Rel5
- 1593: az 24/05/01: Rel4 completion 90->100%.
- 1599: According to T2 SWG1 M. Cataldo this is automatically supported by the MExE support of UAProf therefore 100% complete

| ID | WBS | Task | Duration | Start | Finish | Predecessors | Complete | Baseline start | Baseline finish | Baseline duration | Constraint | Resources | Work | Actual work | Text1 | Text4 | Text5 | Text6 | Text8 | Text3 |
| --- | --- | --- | --- | --- | --- | --- | --- | --- | --- | --- | --- | --- | --- | --- | --- | --- | --- | --- | --- | --- |
| 1600 | 84 | **CAMEL phase 4** | 625d | 2000-04-17 A | 2002-09-06 A |  | 100% | 2000-04-17 | 2002-09-06 | 625d |  | S1 | 41104h | 41104h | CAMEL4 | Nokia | keijo.palviainen@nokia.com | Rel-5 | Alain |  |
| 1601 | 84.1 | Service requirements | 565d | 2000-04-17 A | 2002-06-14 A |  | 100% | 2000-04-17 | 2002-06-14 | 565d | finish no earlier than 2002-06-14 | S1 | 4520h | 4520h |  |  |  |  | Alain |  |
| 1602 | 84.2 | Call Party Handling | 500d | 2000-07-10 A | 2002-06-07 A |  | 100% | 2000-07-10 | 2002-06-07 | 500d | finish no earlier than 2002-06-07 | N2 | 4000h | 4000h | CAMEL4-CPH |  |  |  | Kimmo |  |
| 1603 | 84.3 | Mid call procedure for MO and MT calls | 495d | 2000-07-17 A | 2002-06-07 A |  | 100% | 2000-07-17 | 2002-06-07 | 495d | finish no earlier than 2002-06-07 | N2 | 3960h | 3960h | CAMEL4-MCP |  |  |  | Kimmo |  |
| 1604 | 84.4 | Interactions with Optimal Routing | 430d | 2000-07-17 A | 2002-03-08 A |  | 100% | 2000-07-17 | 2002-03-08 | 430d | finish no earlier than 2002-03-08 | N2 | 3440h | 3440h | CAMEL4-IOR |  |  |  | Kimmo |  |
| 1605 | 84.5 | Inclusion of flexible tone injection | 430d | 2000-07-17 A | 2002-03-08 A |  | 100% | 2000-07-17 | 2002-03-08 | 430d | finish no earlier than 2002-03-08 | N2 | 3440h | 3440h | CAMEL4-IFTI |  |  |  | Kimmo |  |
| 1606 | 84.6 | CSE control over MT SMS | 430d | 2000-07-17 A | 2002-03-08 A |  | 100% | 2000-07-17 | 2002-03-08 | 430d | finish no earlier than 2002-03-08 | N2 | 3440h | 3440h | CAMEL4-CCSMS |  |  |  | Kimmo |  |
| 1607 | 84.7 | Notification of GPRS mobility management to CSE | 331d | 2001-03-02 A | 2002-06-07 A |  | 100% | 2001-03-02 | 2002-06-07 | 331d | finish no earlier than 2002-06-07 | N2 | 2648h | 2648h | CAMEL4-NMM |  |  |  | Kimmo |  |
| 1608 | 84.8 | Provision of location information of called subscriber | 266d | 2001-03-02 A | 2002-03-08 A |  | 100% | 2001-03-02 | 2002-03-08 | 266d | finish no earlier than 2002-03-08 | N2 | 2128h | 2128h | CAMEL4-LOCB |  |  |  | Kimmo |  |
| 1609 | 84.9 | Inclusion of ODB data in the CSE_HLR interface | 175d | 2001-07-09 A | 2002-03-08 A |  | 100% | 2001-07-09 | 2002-03-08 | 175d | finish no earlier than 2002-03-08 | N2 | 1400h | 1400h | CAMEL4-ODB |  |  |  | Kimmo |  |
| 1610 | 84.10 | Location information during an ongoing call (Handover DP) | 280d | 2001-05-14 A | 2002-06-07 A |  | 100% | 2001-05-14 | 2002-06-07 | 280d | finish no earlier than 2002-06-07 | N2 | 2240h | 2240h | CAMEL4-HODP |  |  |  | Kimmo |  |
| 1611 | 84.11 | GPRS Any Time Interrogation | 240d | 2001-07-09 A | 2002-06-07 A |  | 100% | 2001-07-09 | 2002-06-07 | 240d | finish no earlier than 2002-06-07 | N2 | 1920h | 1920h | CAMEL4-ATI |  |  |  | Kimmo |  |
| 1612 | 84.12 | Transfer of IMEI (with SW version) to CSE | 240d | 2001-07-09 A | 2002-06-07 A |  | 100% | 2001-07-09 | 2002-06-07 | 240d | finish no earlier than 2002-06-07 | N2 | 1920h | 1920h | CAMEL4-ATI |  |  |  | Kimmo |  |
| 1613 | 84.13 | Handling of partial implementations of CAMEL4 | 131d | 2002-03-08 A | 2002-09-06 A |  | 100% | 2002-03-08 | 2002-09-06 | 131d | finish no earlier than 2002-06-07 | N2 | 1048h | 1048h | CAMEL4-SUB |  |  |  | Kimmo |  |
| 1614 | 85 | **Rel-5 MExE enhancements** | 250d | 2001-03-26 A | 2002-03-08 A |  | 100% | 2001-03-26 | 2002-03-08 | 250d |  | T2 | 2880h | 2880h | MEXE5 |  |  | Rel-5 | Kimmo |  |
| 1615 | 85.1 | MExE Rel-5 Improvements and Investigations | 110d | 2001-03-26 A | 2002-03-08 A |  | 100% | 2001-03-26 | 2002-03-08 | 110d | finish no earlier than 2001-12-17 | T2 | 880h | 880h | MEXE5-ENHANC | Motorola | Mark Cataldo |  |  | 22.057, 23.057 |
| 1616 | 86 | **Wideband Telephony Service - AMR** | 1035d | 2000-01-01 A | 2003-12-19 A |  | 100% | 2000-01-01 | 2003-12-19 | 1035d |  | S4 | 81432h | 81432h | AMRWB | Siemens | Imre.Varga@mch.siemens.de | Rel-5 | Paolo |  |
| 1617 | 86.1 | **Specification** | 635d | 2000-01-01 A | 2002-06-07 A |  | 100% | 2000-01-01 | 2002-06-07 | 635d |  | S4 | 19952h | 19952h |  |  |  | Rel-5 | Paolo |  |
| 1618 | 86.1.1 | Stage 1 | 125d | 2001-10-01 A | 2002-03-22 A |  | 100% | 2001-10-01 | 2002-03-22 | 125d | finish no earlier than 2002-03-22 | S1 | 1000h | 1000h |  |  |  | Rel-5 | Alain |  |
| 1619 | 86.1.2 | **Stage 2** | 76d | 2000-01-03 A | 2000-04-17 A |  | 100% | 2000-01-03 | 2000-04-17 | 76d |  | S4 | 1224h | 1224h |  |  |  | Rel-5 | Paolo |  |
| 1620 | 86.1.2.1 | Design Constraints | 26d | 2000-01-03 A | 2000-02-07 A |  | 100% | 2000-01-03 | 2000-02-07 | 26d |  | S4 | 208h | 208h |  |  |  | Rel-5 | Paolo |  |
| 1621 | 86.1.2.2 | General Description | 51d | 2000-02-07 A | 2000-04-17 A | 1620 | 100% | 2000-02-07 | 2000-04-17 | 51d | start no earlier than 2000-09-25 | S4 | 408h | 408h |  |  |  | Rel-5 | Paolo |  |
| 1622 | 86.1.3 | Feasibility Study | 26d | 2000-04-28 A | 2000-06-02 A | 1621 | 100% | 2000-04-28 | 2000-06-02 | 26d | finish no earlier than 2000-06-02 | S4 | 208h | 208h |  |  |  | Rel-5 | Paolo | 26.901 |
| 1623 | 86.1.4 | N1 Aspects | 66d | 2001-09-21 A | 2001-12-21 A |  | 100% | 2001-09-21 | 2001-12-21 | 66d | finish no earlier than 2001-12-21 | N1 | 528h | 528h |  |  |  | Rel-5 | Frederic |  |
| 1624 | 86.1.5 | N4 work | 83d | 2002-02-13 A | 2002-06-07 A |  | 100% | 2002-02-13 | 2002-06-07 | 83d | finish no earlier than 2002-06-07 | N4 | 664h | 664h |  |  |  | Rel-5 | Kimmo |  |

Notes:
- 1609: Added on May 29, 2001
- 1613: stage2 and stage3 CRs for approval at CN#17
- 1622: S4,TD SP-000024: TR 26.901 v.4.0.0
- 1623: Some of N1 tasks: Indication of supported codecs by the MS, Bearer cap negociation, codec indication to MS... / One common set of codec negotiation procedures will be specified as in ID1657.
- 1624: CN4#11 30/11/01: No inputs to CN4 at this meeting / 14/02/02 work started 50% reached / 17 May work is done 100%

| ID | WBS | Task | Duration | Start | Finish | Predecessors | Complete | Baseline start | Baseline finish | Baseline duration | Constraint | Resources | Work | Actual work | Text6 | Text8 | Text1 | Text3 | Text12 | Text4 | Text5 |
| --- | --- | --- | --- | --- | --- | --- | --- | --- | --- | --- | --- | --- | --- | --- | --- | --- | --- | --- | --- | --- | --- |
| 1625 | 86.1.6 | **Codec issues** | 635d | 2000-01-03 A | 2002-06-07 A |  | 100% | 2000-01-03 | 2002-06-07 | 635d |  | S4 | 9496h | 9496h | Rel-5 | Paolo |  |  |  |  |  |
| 1626 | 86.1.6.1 | Codec qualification | 86d | 2000-02-02 A | 2000-05-31 A |  | 100% | 2000-02-02 | 2000-05-31 | 86d | finish no earlier than 2000-05-31 | S4 | 688h | 688h | Rel-5 | Paolo |  |  |  |  |  |
| 1627 | 86.1.6.2 | Codec selection tests | 102d | 2000-06-01 A | 2000-10-20 A | 1626 | 100% | 2000-06-01 | 2000-10-20 | 102d | finish no earlier than 2000-10-20 | S4 | 816h | 816h | Rel-5 | Paolo |  |  |  |  |  |
| 1628 | 86.1.6.3 | Codec selection | 5d | 2000-10-23 A | 2000-10-27 A | 1627 | 100% | 2000-10-23 | 2000-10-27 | 5d | finish no earlier than 2000-10-27 | S4 | 40h | 40h | Rel-5 | Paolo |  |  |  |  |  |
| 1629 | 86.1.6.4 | TFO AMR-WB | 63d | 2001-12-18 A | 2002-03-14 A |  | 100% | 2001-12-18 | 2002-03-14 | 63d | finish no earlier than 2002-03-14 | S4 | 504h | 504h | Rel-5 | Paolo | AMRWB-TFO |  |  |  |  |
| 1630 | 86.1.6.5 | Other codec issues (verif., caracterisation) | 441d | 2000-09-29 A | 2002-06-07 A |  | 100% | 2000-09-29 | 2002-06-07 | 441d | finish no earlier than 2002-06-07 | S4 | 3528h | 3528h | Rel-5 | Paolo |  | 26.976 |  |  |  |
| 1631 | 86.1.6.6 | AMR-WB and narrrowband interworking | 121d | 2001-09-27 A | 2002-03-14 A |  | 100% | 2001-09-27 | 2002-03-14 | 121d | finish no earlier than 2002-03-14 | S4 | 968h | 968h | Rel-5 | Paolo | AMRWB-IWG |  |  |  |  |
| 1632 | 86.1.6.7 | Interworking with fixed broadband networks | 121d | 2001-09-27 A | 2002-03-14 A |  | 100% | 2001-09-27 | 2002-03-14 | 121d | finish no earlier than 2002-03-14 | S4 | 968h | 968h | Rel-5 | Paolo |  |  |  |  |  |
| 1633 | 86.1.6.8 | Tones and announcements | 121d | 2001-09-27 A | 2002-03-14 A |  | 100% | 2001-09-27 | 2002-03-14 | 121d | finish no earlier than 2002-03-14 | S4 | 968h | 968h | Rel-5 | Paolo |  |  |  |  |  |
| 1634 | 86.1.6.9 | Deleted - WB Conferencing and WB Voice Group calls | 1d | 2000-01-03 A | 2000-01-03 A |  | 100% | 2000-01-03 | 2000-01-03 | 1d | finish no earlier than 2000-01-03 | S1 | 8h | 8h | Rel-5 | Alain |  |  | SP-07 |  |  |
| 1635 | 86.1.8 | **Conformance tests (CRs to 34 series)** | 73d | 2000-01-01 A | 2000-04-12 A |  | 100% | 2000-01-01 | 2000-04-12 | 73d |  | T1 | 1752h | 1752h | Rel-5 | Ingbert |  |  |  |  |  |
| 1636 | 86.1.8.1 | **Terminal Acoustic Characteristics** | 73d | 2000-01-01 A | 2000-04-12 A |  | 100% | 2000-01-01 | 2000-04-12 | 73d |  | S4 | 1168h | 1168h | Rel-5 | Paolo |  |  |  |  |  |
| 1637 | 86.1.8.1.1 | Definition | 21d | 2000-01-01 A | 2000-01-31 A |  | 100% | 2000-01-01 | 2000-01-31 | 21d | finish no earlier than 2000-01-28 | S4 | 168h | 168h | Rel-5 | Paolo |  | 26.131 |  |  |  |
| 1638 | 86.1.8.1.2 | Test specification | 52d | 2000-02-01 A | 2000-04-12 A | 1637 | 100% | 2000-02-01 | 2000-04-12 | 52d | finish no earlier than 2000-03-13 | S4 | 416h | 416h | Rel-5 | Paolo |  | 26.132 |  |  |  |
| 1639 | 86.2 | Floating-point ANSI-C code for the AMR-WB speech codec | 123d | 2001-09-25 A | 2002-03-14 A |  | 100% | 2001-09-25 | 2002-03-14 | 123d | finish no earlier than 2002-03-14 | S4 | 984h | 984h | Rel-5 | Paolo | AMRWB-FP | 26.204 |  | Nokia | janne.m.vainio@nokia.com |
| 1640 | 86.3 | **Support of AMR-WB in GERAN: GMSK and 8PSK WB FR / HR** | 650d | 2000-01-03 A | 2002-06-28 A |  | 100% | 2000-01-03 | 2002-06-28 | 650d |  | GP | 23480h | 23480h | Rel-5 | Paolo | GAMRWB |  |  |  |  |
| 1641 | 86.3.1 | Channel coding in 45.003 | 590d | 2000-01-03 A | 2002-04-05 A |  | 100% | 2000-01-03 | 2002-04-05 | 590d |  | GP | 4720h | 4720h | Rel-5 | Paolo |  |  |  |  |  |
| 1642 | 86.3.2 | Signalling for the A interface | 390d | 2000-01-03 A | 2001-06-29 A |  | 100% | 2000-01-03 | 2001-06-29 | 390d | finish no earlier than 2001-06-29 | GP | 3120h | 3120h | Rel-5 | Paolo |  |  |  |  |  |
| 1643 | 86.3.3 | Signalling for Iu | 650d | 2000-01-03 A | 2002-06-28 A |  | 100% | 2000-01-03 | 2002-06-28 | 650d | finish no earlier than 2002-06-28 | GP | 5200h | 5200h | Rel-5 | Paolo |  |  |  |  |  |
| 1644 | 86.3.4 | Receiver performance in TS 45.005 | 325d | 2001-04-02 A | 2002-06-28 A |  | 100% | 2001-04-02 | 2002-06-28 | 325d | finish no earlier than 2002-06-28 | GP | 2600h | 2600h | Rel-5 | Paolo |  |  |  |  |  |
| 1645 | 86.3.5 | Link Adaptation in 45.009 | 330d | 2001-03-26 A | 2002-06-28 A |  | 100% | 2001-03-26 | 2002-06-28 | 330d | finish no earlier than 2002-06-28 | GP | 2640h | 2640h | Rel-5 | Paolo |  |  |  |  |  |
| 1646 | 86.4 | **GERAN MS conformance test for AMR-WB** | 1035d | 2000-01-03 A | 2003-12-19 A |  | 100% | 2000-01-03 | 2003-12-19 | 1035d |  | GP | 16560h | 16560h | Rel-5 | Paolo |  |  |  |  |  |
| 1647 | 86.4.1 | Deleted - MS test | 1035d | 2000-01-03 A | 2003-12-19 A |  | 100% | 2000-01-03 | 2003-12-19 | 1035d | finish no earlier than 2003-12-19 | GP | 8280h | 8280h | Rel-5 | Paolo |  |  | GP-17 |  |  |
| 1648 | 86.5 | **GERAN BTS conformance test for AMR-WB** | 761d | 2000-01-03 A | 2002-12-02 A |  | 100% | 2000-01-03 | 2002-12-02 | 761d |  | GP | 12176h | 12176h | Rel-5 | Paolo |  |  |  |  |  |
| 1649 | 86.5.1 | BTS test | 761d | 2000-01-03 A | 2002-12-02 A |  | 100% | 2000-01-03 | 2002-12-02 | 761d | finish no earlier than 2002-12-02 | GP | 6088h | 6088h | Rel-5 | Paolo |  |  |  |  |  |

Notes:
- 1630: ANSI C-Code , Test Sequences, Speech Transcoding Functions, Error Concealment of lost frames, Source Controlled Bit-Rate Operation, Voice Activity Detector, Frame Structure
- 1641: 50098 -> 50298
- 1646: Not started 02/2003. Marked as stopped 12/2008
- 1647: Marked as stopped 12/2008

| ID | WBS | Task | Duration | Start | Finish | Complete | Baseline start | Baseline finish | Baseline duration | Constraint | Resources | Work | Actual work | Text1 | Text6 | Text8 | Text3 | Text4 | Text5 |
| --- | --- | --- | --- | --- | --- | --- | --- | --- | --- | --- | --- | --- | --- | --- | --- | --- | --- | --- | --- |
| 1650 | 11 | **Terminal interfaces** | 223d | 2001-05-14 A | 2002-03-20 A | 100% | 2001-05-14 | 2002-03-20 | 223d |  | T2 | 3568h | 3568h | TI | Rel-5 | Kimmo |  |  |  |
| 1651 | 87 | Terminal local model enhancements | 223d | 2001-05-14 A | 2002-03-20 A | 100% | 2001-05-14 | 2002-03-20 | 223d | finish no earlier than 2002-03-20 | T2 | 1784h | 1784h | TLM5 | Rel-5 |  | 23.227 |  |  |
| 1652 | 88 | **Rel-5 Location Services enhancements** | 845d | 2000-04-03 A | 2003-06-27 A | 100% | 2000-04-03 | 2003-06-27 | 845d |  | S2,S5 | 86804h | 86804h | LCS1 | Rel-5 | Maurice |  | Nokia | Jan Kall |
| 1653 | 88.1 | **UE positioning** | 315d | 2001-01-15 A | 2002-03-29 A | 100% | 2001-01-15 | 2002-03-29 | 315d |  | RP | 5560h | 5560h | LCS1-UEpos | NA | Stefania |  |  |  |
| 1654 | 88.1.1 | UE positioning enhancements for 1.28 Mcps TDD | 255d | 2001-04-09 A | 2002-03-29 A | 100% | 2001-04-09 | 2002-03-29 | 255d | finish no earlier than 2002-03-29 | R2 | 2040h | 2040h | LCS-128Pos | Rel-5 | Joern |  | CATT | Xiaohua Mei |
| 1655 | 88.1.2 | Open SMLC-SRNC Interface within the UTRAN to support A-GPS Positioning | 195d | 2001-01-15 A | 2001-10-12 A | 100% | 2001-01-15 | 2001-10-12 | 195d |  | R2 | 1560h | 1560h | LCS-INTF | Rel-5 | Joern |  | Qualcomm | Kirk Burroughs |
| 1656 | 88.2 | **Event based and Periodic LCS** | 535d | 2000-05-22 A | 2002-06-07 A | 100% | 2000-05-22 | 2002-06-07 | 535d |  | S1 | 6288h | 6288h | LCS1-EBP | Rel-5 | Alain |  |  |  |
| 1657 | 88.2.1 | Stage 1 | 130d | 2000-05-22 A | 2000-11-17 A | 100% | 2000-05-22 | 2000-11-17 | 130d | finish no earlier than 2000-07-21 | S1 | 1040h | 1040h |  |  | Alain | 22.071 | Pacific Bell Wireless | Randolph Wohlert (rwohlert@tri.sbc.com) |
| 1658 | 88.2.2 | Stage 2 specification | 60d | 2000-11-06 A | 2001-01-26 A | 100% | 2000-11-06 | 2001-01-26 | 60d | finish no earlier than 2001-01-26 | S2 | 480h | 480h |  |  | Maurice |  |  |  |
| 1659 | 88.2.3 | Impact on MAP | 61d | 2002-03-15 A | 2002-06-07 A | 100% | 2002-03-15 | 2002-06-07 | 61d | finish no earlier than 2002-06-07 | N4 | 488h | 488h |  |  | Kimmo |  |  |  |
| 1660 | 88.3 | **Location Services for GERAN in A/Gb Mode** | 485d | 2000-04-03 A | 2002-02-08 A | 100% | 2000-04-03 | 2002-02-08 | 485d |  | GP | 14760h | 14760h | LCS-GERAN | Rel-5 | Paolo |  |  |  |
| 1661 | 88.3.1 | GERAN LCS Stage 2 (first release) | 485d | 2000-04-03 A | 2002-02-08 A | 100% | 2000-04-03 | 2002-02-08 | 485d | finish no earlier than 2002-02-08 | GP,S2,G1,G2 | 3880h | 3880h |  |  | Paolo |  |  |  |
| 1662 | 88.3.2 | Gb interface support for LCS | 370d | 2000-04-03 A | 2001-08-31 A | 100% | 2000-04-03 | 2001-08-31 | 370d | finish no earlier than 2001-08-31 | GP | 2960h | 2960h |  |  | Paolo |  |  |  |
| 1663 | 88.3.3 | L3 protocol support for LCS | 305d | 2000-04-03 A | 2001-06-01 A | 100% | 2000-04-03 | 2001-06-01 | 305d | finish no earlier than 2001-06-01 | GP | 2440h | 2440h |  |  | Paolo |  |  |  |
| 1664 | 88.3.4 | Stage 3 specifications | 305d | 2000-04-03 A | 2001-06-01 A | 100% | 2000-04-03 | 2001-06-01 | 305d | finish no earlier than 2001-06-01 | GP | 2440h | 2440h |  |  | Paolo |  |  |  |
| 1665 | 88.4 | **Location Services for GERAN in Iu Mode** | 585d | 2000-04-03 A | 2002-06-28 A | 100% | 2000-04-03 | 2002-06-28 | 585d |  | GP | 20996h | 20996h |  | Rel-5 | Paolo |  |  |  |
| 1666 | 88.4.1 | GERAN LCS Stage 2 | 585d | 2000-04-03 A | 2002-06-28 A | 100% | 2000-04-03 | 2002-06-28 | 585d | finish no earlier than 2002-06-28 | GP,R2,R3,S2,G1,G2 | 4680h | 4680h |  |  | Paolo |  |  |  |
| 1667 | 88.4.2 | Iu-ps interface support for LCS | 585d | 2000-04-03 A | 2002-06-28 A | 100% | 2000-04-03 | 2002-06-28 | 585d | finish no earlier than 2002-06-28 | GP,R2,R3,S2,G1,G2 | 4680h | 4680h |  |  | Paolo |  |  |  |
| 1668 | 88.4.3 | Iu-cs interface support for LCS | 585d | 2000-04-03 A | 2002-06-28 A | 100% | 2000-04-03 | 2002-06-28 | 585d | finish no earlier than 2002-06-28 | GP,R2,R3,S2,G1,G2 | 4680h | 4680h |  |  | Paolo |  |  |  |
| 1669 | 88.4.4 | Iur-g interface support for LCS | 62.5d | 2002-01-23 A | 2002-04-19 A | 100% | 2002-01-23 | 2002-04-19 | 62.5d | finish no earlier than 2002-04-19 | GP,R2,R3,S2,G1,G2 | 500h | 500h |  |  | Paolo |  |  |  |
| 1670 | 88.4.5 | RRC protocol support for LCS | 75d | 2001-08-20 A | 2001-11-30 A | 100% | 2001-08-20 | 2001-11-30 | 75d | finish no earlier than 2001-11-30 | GP,R2,R3,S2,G1,G2 | 600h | 600h |  |  | Paolo |  |  |  |
| 1671 | 88.4.6 | Additional impacts on Broadcast of LCS data on packet channels | 77.5d | 2001-08-20 A | 2001-12-05 A | 100% | 2001-08-20 | 2001-12-05 | 77.5d | finish no earlier than 2001-12-05 | GP,R2,R3,S2,G1,G2 | 620h | 620h |  |  | Paolo |  |  |  |
| 1672 | 88.4.7 | Stage 3 specifications | 69.5d | 2002-03-25 A | 2002-06-28 A | 100% | 2002-03-25 | 2002-06-28 | 69.5d | finish no earlier than 2002-06-28 | GP,R2,R3,S2,G1,G2 | 556h | 556h |  |  | Paolo |  |  |  |
| 1673 | 88.5 | **GERAN MS Conformance test for LCS** | 280d | 2002-06-03 A | 2003-06-27 A | 100% | 2002-06-03 | 2003-06-27 | 280d |  | GP | 6720h | 6720h | LCS-GERAN-MSconf |  | Paolo |  |  |  |
| 1674 | 88.5.1 | Develop LCS MS test case work plan (Release 98/99/4) | 280d | 2002-06-03 A | 2003-06-27 A | 100% | 2002-06-03 | 2003-06-27 | 280d | finish no earlier than 2003-06-27 | G4,G5 | 2240h | 2240h |  |  | Paolo |  |  |  |
| 1675 | 88.5.2 | Develop LCS MS test cases | 280d | 2002-06-03 A | 2003-06-27 A | 100% | 2002-06-03 | 2003-06-27 | 280d | finish no earlier than 2003-06-27 | G4,G5 | 2240h | 2240h |  |  | Paolo |  |  |  |

Notes:
- 1655: Finished at RP#13
- 1657: Evaluate Event based and Periodic LCS to be included in R00, corresponding Stage 1 description
- 1658: Marked as closed 12/2008 (was marked 51% complete)
- 1659: Possible impact on UTRAN of LCS quality level request / 17 May No stage 2 for event-based & periodic LCS. Work 100% completefor current stage 2
- 1669: FFS
- 1673: On-going
- 1674: Marked as closed 12/2008 (was marked 60% complete)
- 1675: Marked as closed 12/2008 (was marked 60% complete)

| ID | WBS | Task | Duration | Start | Finish | Predecessors | Complete | Baseline start | Baseline finish | Baseline duration | Constraint | Resources | Work | Actual work | Text1 | Text8 | Text12 | Text6 | Text3 | Text4 | Text5 |
| --- | --- | --- | --- | --- | --- | --- | --- | --- | --- | --- | --- | --- | --- | --- | --- | --- | --- | --- | --- | --- | --- |
| 1676 | 88.6 | **Deleted - GERAN BTS Conformance test for LCS** | 280d | 2002-06-03 A | 2003-06-27 A |  | 100% | 2002-06-03 | 2003-06-27 | 280d |  | GP | 6720h | 6720h | LCS-GERAN-BTSconf | Paolo | GP-15 |  |  |  |  |
| 1677 | 88.6.1 | Deleted - Develop LCS BTS test case work plan (Release 98/99/4) | 280d | 2002-06-03 A | 2003-06-27 A |  | 100% | 2002-06-03 | 2003-06-27 | 280d | finish no earlier than 2003-06-27 | G4,G5 | 2240h | 2240h |  | Paolo | GP-15 |  |  |  |  |
| 1678 | 88.6.2 | Deleted - Develop LCS BTS test cases | 280d | 2002-06-03 A | 2003-06-27 A |  | 100% | 2002-06-03 | 2003-06-27 | 280d | finish no earlier than 2003-06-27 | G4,G5 | 2240h | 2240h |  | Paolo | GP-15 |  |  |  |  |
| 1679 | 88.7 | LCS interoperation stage 2 aspects | 480d | 2000-08-28 A | 2002-06-28 A |  | 100% | 2000-08-28 | 2002-06-28 | 480d |  | S2 | 3840h | 3840h |  | Maurice |  |  |  |  |  |
| 1680 | 88.8 | **LCS interoperability aspects to GERAN** | 480d | 2000-08-28 A | 2002-06-28 A |  | 100% | 2000-08-28 | 2002-06-28 | 480d |  | GP,S5 | 7680h | 7680h | LCS-GERAN | Paolo |  | Rel-5 |  |  |  |
| 1681 | 88.8.1 | Co-ordinated development of GSM LCS Phase 2 and UMTS LCS, S2 and GERAN | 480d | 2000-08-28 A | 2002-06-28 A |  | 100% | 2000-08-28 | 2002-06-28 | 480d | finish no earlier than 2002-06-28 | GP,S2,S5,R2,R3,G2,G1 | 3840h | 3840h | LCS-GERAN | Paolo |  | Rel-5 |  |  |  |
| 1682 | 88.9 | FS on LCS support in the IMS | 90d | 2001-02-12 A | 2002-01-18 A |  | 100% | 2001-02-12 | 2002-01-18 | 90d | start no earlier than 2001-02-12 | S1 | 720h | 720h |  | Alain |  |  |  |  |  |
| 1683 | 88.10 | Charging and OAM&P for LCS enhancements | 201d | 2001-09-21 A | 2002-06-28 A |  | 100% | 2001-09-21 | 2002-06-28 | 201d | finish no earlier than 2002-06-28 | S5 | 1608h | 1608h | LCS1-OAM | Dionisio |  | Rel-5 | 32-series | VoiceStream, Motorola |  |
| 1684 | 88.11 | New security aspects of LCS (not identified) | 446d | 2000-04-14 A | 2001-12-28 A |  | 100% | 2000-04-14 | 2001-12-28 | 446d | finish no earlier than 2001-12-28 | S3 | 3568h | 3568h | LCS1-SEC | Dionisio |  | Rel-5 |  | Nokia | valtteri.niemi@nokia.com |
| 1685 | 88.12 | Specification for the Le Interface | 45d | 2002-01-14 A | 2002-03-15 A |  | 100% | 2002-01-14 | 2002-03-15 | 45d | start no earlier than 2002-01-14 | S2 | 360h | 360h | LCS1-Le | Maurice |  | Rel-5 |  |  |  |
| 1686 | 88.13 | Deleted - CHECK STATUS - Inter-GMLC interface | 153d | 2002-05-30 A | 2002-12-30 A |  | 100% | 2002-05-30 | 2002-12-30 | 153d | finish no earlier than 2002-12-30 | S2 | 1224h | 1224h |  | Maurice | SP-10 |  |  |  |  |
| 1687 | 89 | **Rel-5 Security enhancements** | 615d | 2000-02-21 A | 2002-06-28 A |  | 100% | 2000-02-21 | 2002-06-28 | 615d |  | S3 | 29974.9h | 29974.9h | SEC1 | Dionisio |  | Rel-5 |  | Vodafone | Peter.Howard@vodafone.com |
| 1688 | 89.1 | **Network domain security** | 615d | 2000-02-21 A | 2002-06-28 A |  | 100% | 2000-02-21 | 2002-06-28 | 615d |  | S3 | 25054.9h | 25054.9h | SEC1-NDS | Dionisio |  | Rel-5 |  | Telenor | Geir-myrdahl.koien@telenor.com |
| 1689 | 89.1.1 | **Deleted -Control plane protection in core network (e.g., GTP, CAP, MAP/IP, provided by IPsec)** | 541d | 2000-05-12 A | 2002-06-07 A |  | 100% | 2000-05-12 | 2002-06-07 | 541d |  | S3 | 7118.9h | 7118.9h |  | Dionisio | SP-16 |  |  |  |  |
| 1690 | 89.1.1.1 | Deleted - Main aspects | 290d | 2000-05-12 A | 2001-06-21 A |  | 100% | 2000-05-12 | 2001-06-21 | 290d | finish no earlier than 2001-06-21 | S3 | 2320h | 2320h |  | Dionisio | SP-12 |  |  |  |  |
| 1691 | 89.1.1.2 | Deleted -Integration of GTP signalling security architecture | 191d | 2001-09-14 A | 2002-06-07 A |  | 100% | 2001-09-14 | 2002-06-07 | 191d | finish no earlier than 2002-06-07 | N4 | 1528h | 1528h |  | Kimmo | NP-16 |  |  |  |  |
| 1692 | 89.1.2 | **Deleted -User plane protection in core network (e.g., provided by IPsec)** | 615d | 2000-02-21 A | 2002-06-28 A |  | 100% | 2000-02-21 | 2002-06-28 | 615d |  | S3 | 9360h | 9360h |  | Dionisio | SP-16 |  |  |  |  |
| 1693 | 89.1.2.1 | Deleted -Main aspects | 349d | 2000-02-21 A | 2001-06-21 A |  | 100% | 2000-02-21 | 2001-06-21 | 349d | finish no earlier than 2001-06-21 | S3 | 2792h | 2792h |  | Dionisio | SP-12 |  |  |  |  |
| 1694 | 89.1.2.2 | Deleted -Integration of GTP signalling security architecture | 206d | 2001-09-14 A | 2002-06-28 A |  | 100% | 2001-09-14 | 2002-06-28 | 206d | finish no earlier than 2002-06-28 | N4 | 1648h | 1648h |  | Kimmo | NP-16 |  |  |  |  |
| 1695 | 89.1.3 | IP network layer security (NDS/IP) | 457d | 2000-06-15 A | 2002-03-15 A |  | 100% | 2000-06-15 | 2002-03-15 | 457d | finish no earlier than 2002-03-15 | S3 | 3656h | 3656h | SEC1-NDS-IP | Dionisio |  |  | 33.210 | Telenor | Geir-myrdahl.koien@telenor.com |
| 1696 | 90 | **Intra Domain Connection of RAN Nodes to Multiple CN Nodes** | 455d | 2000-10-02 A | 2002-06-28 A |  | 100% | 2000-10-02 | 2002-06-28 | 455d |  | S2 | 15136h | 15136h | IUFLEX | Alain |  | Rel-5 | 23.236 | Ericsson | stephen.terrill@ericsson.com |
| 1697 | 90.1 | Overall System Architecture | 188d | 2001-01-03 A | 2001-09-21 A |  | 100% | 2001-01-03 | 2001-09-21 | 188d | finish no earlier than 2001-06-01 | S2 | 1504h | 1504h |  | Maurice |  |  |  |  |  |
| 1698 | 90.2 | Stage 3: RAN node selecting CN node | 130d | 2001-09-24 A | 2002-03-22 A | 1697 | 100% | 2001-09-24 | 2002-03-22 | 130d | finish no earlier than 2002-03-22 | R3 | 1040h | 1040h |  | Gert |  |  |  | Vodafone | Brendan.McWilliams@gb.vodafone.co.uk |
| 1699 | 90.3 | N1 work | 205d | 2001-09-17 A | 2002-06-28 A |  | 100% | 2001-09-17 | 2002-06-28 | 205d | start no earlier than 2001-09-17 | N1 | 1640h | 1640h |  | Frederic |  |  | 24.008 and check 29.018 |  |  |
| 1700 | 90.4 | N4 work | 375d | 2000-10-02 A | 2002-03-08 A |  | 100% | 2000-10-02 | 2002-03-08 | 375d | finish no earlier than 2002-03-15 | N4 | 3000h | 3000h |  | Kimmo |  |  |  |  |  |

Notes:
- 1676: Not started 02/3003. Marked as stopped 12/2008
- 1677: Marked as stopped 12/2008
- 1678: Marked as stopped 12/2008
- 1679: Marked as closed 12/2008 (was marked 17% complete)
- 1682: Marked as closed 12/2008 (was marked 75% complete)
- 1684: 14/09/00: WI may need to be split to improve on this date. S3#17 15% complete. No progress since S3#17
- 1686: Marked as stopped 12/2008
- 1687: Added BB UE authentication and rapporteur added. TO BE DELETED
- 1688: S3#17: All due in Rel5. (WI Update at S3#18). Replaced by NDS-IP and NDS-MAP. TO BE DELETED OR MOVED TO HISTORY FILE
- 1689: Marked as stopped 12/2008
- 1690: TO BE DELETED. Marked as stopped 12/2008
- 1691: Waiting for input from SA3!.... Marked as stopped 12/2008
- 1692: TO BE DELETED. Marked as stopped 12/2008
- 1693: ??
- 1694: 14/02/2002 requirements are not clear/not received...Marked as closed 12/2008 (was marked 95 complete)
- 1695: 2002/12: All IPsec RFCs are stable STD Track RFCs. WID updated SA#17
- 1696: No clear indication on the end date. Put to Rel5 by AS.
- 1698: Not identified
- 1700: DAB 12.12.01 - % complete to 66% / 14/02/02 Work completed

| ID | WBS | Task | Duration | Start | Finish | Complete | Baseline start | Baseline finish | Baseline duration | Constraint | Resources | Work | Actual work | Text1 | Text4 | Text5 | Text6 | Text8 | Text12 | Text3 |
| --- | --- | --- | --- | --- | --- | --- | --- | --- | --- | --- | --- | --- | --- | --- | --- | --- | --- | --- | --- | --- |
| 1701 | 90.5 | **GERAN work for Intra Domain Connection of RAN Nodes to Multiple CN Nodes** | 101d | 2002-02-08 A | 2002-06-28 A | 100% | 2002-02-08 | 2002-06-28 | 101d |  | GP | 4848h | 4848h | IDCRAN-GERAN | Ericsson | ingemar.backlund@era.ericsson.se | Rel-5 | Paolo |  |  |
| 1702 | 90.5.1 | Stage 2 (changes to ) | 101d | 2002-02-08 A | 2002-06-28 A | 100% | 2002-02-08 | 2002-06-28 | 101d | finish no earlier than 2002-06-28 | G1 | 808h | 808h |  |  |  |  |  |  |  |
| 1703 | 90.5.2 | 43.051 Introduction of support for IDNNS in GERAN Iu mode | 101d | 2002-02-08 A | 2002-06-28 A | 100% | 2002-02-08 | 2002-06-28 | 101d | finish no earlier than 2002-06-28 | G1 | 808h | 808h |  |  |  |  |  |  |  |
| 1704 | 90.5.3 | Stage 3 (changes to ) | 101d | 2002-02-08 A | 2002-06-28 A | 100% | 2002-02-08 | 2002-06-28 | 101d | finish no earlier than 2002-06-28 | G2 | 808h | 808h |  |  |  |  | Juha |  |  |
| 1705 | 90.5.4 | 48.016 Use of Gb interface concepts when a network applies IDNNS | 101d | 2002-02-08 A | 2002-06-28 A | 100% | 2002-02-08 | 2002-06-28 | 101d | finish no earlier than 2002-06-28 | G2 | 808h | 808h |  |  |  |  | Juha |  |  |
| 1706 | 90.5.5 | 48.018 Include MSC/VLR identity in CS IMSI paging | 101d | 2002-02-08 A | 2002-06-28 A | 100% | 2002-02-08 | 2002-06-28 | 101d | finish no earlier than 2002-06-28 | G2 | 808h | 808h |  |  |  |  | Juha |  |  |
| 1707 | 91 | **Deleted - GERAN improvements 3 (new transport layer on interface A)** | 446d | 2001-04-06 A | 2002-12-20 A | 100% | 2001-04-06 | 2002-12-20 | 446d |  | GP | 14272h | 14272h | GEIMP3 |  |  | Rel-5 | Paolo |  |  |
| 1708 | 91.1 | **Deleted - Evolution of the transport for A** | 446d | 2001-04-06 A | 2002-12-20 A | 100% | 2001-04-06 | 2002-12-20 | 446d |  | GP | 10704h | 10704h | GEIMP3-EtA |  |  |  | Paolo | GP-12 |  |
| 1709 | 91.1.1 | Deleted - Definition of a new A/Ater interface Transport Layer option based on the Iu Interface Transport Layer | 446d | 2001-04-06 A | 2002-12-20 A | 100% | 2001-04-06 | 2002-12-20 | 446d | finish no earlier than 2002-12-20 | GP | 3568h | 3568h |  |  |  |  | Paolo | GP-12 |  |
| 1710 | 91.1.2 | Deleted - Adaptation of the Layer 3 BSSMAP procedures as required | 446d | 2001-04-06 A | 2002-12-20 A | 100% | 2001-04-06 | 2002-12-20 | 446d | finish no earlier than 2002-12-20 | GP | 3568h | 3568h |  |  |  |  | Paolo | GP-12 |  |
| 1711 | 92 | **Rel-5 Charging and OAM&P** | 264d | 2001-09-10 A | 2002-09-12 A | 100% | 2001-09-10 | 2002-09-12 | 264d |  | S5 | 9976h | 9976h | OAM | VoiceStream, Motorola |  | Rel-5 | Dionisio |  | 32-series |
| 1712 | 92.1 | Rel5 Principles, high level Requirements and Architecture | 205d | 2001-09-17 A | 2002-06-28 A | 100% | 2001-09-17 | 2002-06-28 | 205d | finish no earlier than 2002-06-28 | S5 | 1640h | 1640h | OAM-AR/PR | Motorola |  | Rel-5 | Dionisio |  | 32.101, 32.102 |
| 1713 | 92.2 | Rel5 Performance Management | 259d | 2001-09-17 A | 2002-09-12 A | 100% | 2001-09-17 | 2002-09-12 | 259d | finish no earlier than 2002-09-12 | S5 | 2072h | 2072h | OAM-PM | Nortel |  | Rel-5 | Dionisio |  | 32.4xy, 52.402 |
| 1714 | 92.3 | Rel5 Charging Management | 264d | 2001-09-10 A | 2002-09-12 A | 100% | 2001-09-10 | 2002-09-12 | 264d | finish no earlier than 2002-09-12 | S5 | 2112h | 2112h | OAM-CH | T-Mobile | Karl-Heinz.Nenner@T-MOBILE.DE | Rel-5 | Dionisio |  | 32.2xy |
| 1715 | 92.4 | Rel5 Network Infrastructure Management | 255d | 2001-09-21 A | 2002-09-12 A | 100% | 2001-09-21 | 2002-09-12 | 255d | finish no earlier than 2002-09-12 | S5 | 2040h | 2040h | OAM-NIM | Ericsson | thomas.tovinger@ericsson.com | Rel-5 | Dionisio |  | 32.6xy, 32.3xy |
| 1716 | 93 | **GERAN enhancements for streaming services 1 (RLC enhancements)** | 430d | 2000-11-06 A | 2002-06-28 A | 100% | 2000-11-06 | 2002-06-28 | 430d |  | GP | 8944h | 8944h |  |  |  | Rel-5 | Paolo |  |  |
| 1717 | 93.1 | Concept | 258d | 2000-11-06 A | 2001-10-31 A | 100% | 2000-11-06 | 2001-10-31 | 258d | finish no earlier than 2001-10-31 | GP | 2064h | 2064h |  |  |  |  | Paolo |  |  |
| 1718 | 93.2 | RLC protocol enhancement (SDU Discard) | 430d | 2000-11-06 A | 2002-06-28 A | 100% | 2000-11-06 | 2002-06-28 | 430d | finish no earlier than 2002-06-28 | GP | 3440h | 3440h |  |  |  |  | Paolo |  |  |
| 1719 | 94 | **GERAN enhancements for streaming services 2 (usage of ECSD)** | 430d | 2000-11-06 A | 2002-06-28 A | 100% | 2000-11-06 | 2002-06-28 | 430d |  | GP | 19840h | 19840h |  | Ericsson | Frank Muller | Rel-5 | Paolo |  |  |
| 1720 | 94.1 | Usage of ECSD Concept | 380d | 2000-11-06 A | 2002-04-19 A | 100% | 2000-11-06 | 2002-04-19 | 380d | finish no earlier than 2002-04-19 | GP | 3040h | 3040h |  |  |  |  | Paolo |  |  |
| 1721 | 94.2 | Stage 2 | 380d | 2000-11-06 A | 2002-04-19 A | 100% | 2000-11-06 | 2002-04-19 | 380d | finish no earlier than 2002-04-19 | GP | 3040h | 3040h |  |  |  |  | Paolo |  |  |
| 1722 | 94.3 | Stage 3 | 430d | 2000-11-06 A | 2002-06-28 A | 100% | 2000-11-06 | 2002-06-28 | 430d | finish no earlier than 2002-06-28 | GP | 3440h | 3440h |  |  |  |  | Paolo |  |  |
| 1723 | 94.4 | RLC PDU formats | 430d | 2000-11-06 A | 2002-06-28 A | 100% | 2000-11-06 | 2002-06-28 | 430d | finish no earlier than 2002-06-28 | GP | 3440h | 3440h |  |  |  |  | Paolo |  |  |
| 1724 | 94.5 | MAC header | 430d | 2000-11-06 A | 2002-06-28 A | 100% | 2000-11-06 | 2002-06-28 | 430d | finish no earlier than 2002-06-28 | GP | 3440h | 3440h |  |  |  |  | Paolo |  |  |

Notes:
- 1701: Accept changes Gb over IP
- 1705: Closed, accept changes for Gb over IP
- 1707: TERMINATED - NOT STANDARDIZED. Marked as stopped 12/2008
- 1708: TERMINATED - NOT STANDARDIZED. Marked as stopped 12/2008
- 1709: TERMINATED - NOT STANDARDIZED. Marked as stopped 12/2008
- 1710: TERMINATED - NOT STANDARDIZED. Marked as stopped 12/2008
- 1719: AWS, Nokia, Ericsson, Nortel, Siemens, Motorola, Vodafone

| ID | WBS | Task | Duration | Start | Finish | Predecessors | Complete | Baseline start | Baseline finish | Baseline duration | Constraint | Resources | Work | Actual work | Text1 | Text4 | Text5 | Text6 | Text8 |
| --- | --- | --- | --- | --- | --- | --- | --- | --- | --- | --- | --- | --- | --- | --- | --- | --- | --- | --- | --- |
| 1725 | 95 | **GERAN/UTRAN interface evolution 1 (evolution of Iu PS)** | 476d | 2000-09-01 A | 2002-06-28 A |  | 100% | 2000-09-01 | 2002-06-28 | 476d |  | GP,R3 | 10688h | 10688h | GERUEV1 | SBC | Marc Grant | Rel-5 | Paolo |
| 1726 | 95.1 | **Evolution of Iu ps** | 476d | 2000-09-01 A | 2002-06-28 A |  | 100% | 2000-09-01 | 2002-06-28 | 476d |  | GP,R3 | 7248h | 7248h | GERUEV1-IuPS |  |  |  | Paolo |
| 1727 | 95.1.1 | Identification of GERAN requirements on Iu ps | 326d | 2000-09-01 A | 2001-11-30 A |  | 100% | 2000-09-01 | 2001-11-30 | 326d | finish no earlier than 2001-11-30 | GP,R3 | 2608h | 2608h |  |  |  |  | Paolo |
| 1728 | 95.1.2 | Update of specifications | 150d | 2001-12-03 A | 2002-06-28 A | 1727 | 100% | 2001-12-03 | 2002-06-28 | 150d | finish no earlier than 2002-06-28 | GP,R3 | 1200h | 1200h |  |  |  |  | Paolo |
| 1729 | 96 | **GERAN/UTRAN interface evolution 2 (evolution of Iu CS)** | 476d | 2000-09-01 A | 2002-06-28 A |  | 100% | 2000-09-01 | 2002-06-28 | 476d |  | GP,R3 | 12816h | 12816h | GERUEV2 |  |  | Rel-5 | Paolo |
| 1730 | 96.1 | **Evolution of Iu cs** | 476d | 2000-09-01 A | 2002-06-28 A |  | 100% | 2000-09-01 | 2002-06-28 | 476d |  | GP,R3 | 10016h | 10016h | GERUEV2-IuCS | Lucent | Krishna Balachandran |  | Paolo |
| 1731 | 96.1.1 | Identification of GERAN requirements on Iu cs | 426d | 2000-09-01 A | 2002-06-24 A |  | 100% | 2000-09-01 | 2002-06-24 | 426d | finish no earlier than 2002-04-19 | GP,R3 | 3408h | 3408h |  |  |  |  | Paolo |
| 1732 | 96.1.2 | Update of specifications | 476d | 2000-09-01 A | 2002-06-28 A |  | 100% | 2000-09-01 | 2002-06-28 | 476d | finish no earlier than 2002-06-28 | GP,R3 | 3808h | 3808h |  |  |  |  | Paolo |
| 1733 | 97 | **End to End QoS for PS Domain including IMS** | 480d | 2000-08-28 A | 2002-06-28 A |  | 100% | 2000-08-28 | 2002-06-28 | 480d |  | S2 | 9856h | 9856h | E2EQoS | Ericsson | Johnson.oyama@era.ericcson.se | Rel-5 | Maurice |
| 1734 | 97.1 | E2E QoSConcept and Architecture | 178d | 2001-01-03 A | 2001-09-07 A |  | 100% | 2001-01-03 | 2001-09-07 | 178d | finish no earlier than 2001-09-07 | S2 | 1424h | 1424h |  |  |  |  | Maurice |
| 1735 | 97.2 | E2E QoS interworking | 465d | 2000-08-28 A | 2002-06-07 A |  | 100% | 2000-08-28 | 2002-06-07 | 465d | finish no earlier than 2002-06-07 | N3 | 3720h | 3720h | E2EQoS-IW | Lucent | Daisuke Yokota (yokota@lucent.com) |  | Gwiho |
| 1736 | 97.3 | QoS Management (Provisioning and Monitoring) | 201d | 2001-09-21 A | 2002-06-28 A |  | 100% | 2001-09-21 | 2002-06-28 | 201d | finish no earlier than 2002-06-28 | S5 | 1608h | 1608h | E2EQoS-OAM | VoiceStream, Motorola |  | Rel-5 | Dionisio |
| 1737 | 98 | **Messaging enhancements Rel-5** | 467d | 2001-06-15 A | 2003-03-31 A |  | 100% | 2001-06-15 | 2003-03-31 | 467d |  | T2 | 19000h | 19000h | MESS5 |  |  | Rel-5 | Kimmo |
| 1738 | 98.1 | **Multimedia Messaging (MMS) enhancements** | 467d | 2001-06-15 A | 2003-03-31 A |  | 100% | 2001-06-15 | 2003-03-31 | 467d |  | T2 | 11688h | 11688h | MESS5-MMS | Siemens | Josef.Laumen@SAL.SIEMENS.DE |  | Alain |
| 1739 | 98.1.1 | Definition of service requirements | 196d | 2001-06-15 A | 2002-03-15 A |  | 100% | 2001-06-15 | 2002-03-15 | 196d | finish no earlier than 2002-03-15 | S1 | 1568h | 1568h | MESS5-SR | Siemens | Josef.Laumen@SAL.SIEMENS.DE | Rel-5 |  |
| 1740 | 98.1.2 | Technical realization | 256d | 2001-06-15 A | 2002-06-07 A |  | 100% | 2001-06-15 | 2002-06-07 | 256d | finish no earlier than 2002-06-07 | T2 | 2048h | 2048h |  | Siemens | Josef.Laumen@SAL.SIEMENS.DE |  |  |
| 1741 | 98.1.3 | WAP Forum dependency: MM1 stage 3 | 467d | 2001-06-15 A | 2003-03-31 A |  | 100% | 2001-06-15 | 2003-03-31 | 467d | finish no earlier than 2003-03-31 | T2 | 3736h | 3736h |  |  |  |  |  |
| 1742 | 98.1.4 | MMS formats and codecs | 75d | 2001-12-03 A | 2002-03-15 A |  | 100% | 2001-12-03 | 2002-03-15 | 75d | finish no earlier than 2002-03-15 | S4 | 600h | 600h |  |  |  |  | Paolo |
| 1743 | 98.2 | **Enhanced Messaging Service (EMS) enhancements** | 191d | 2001-06-15 A | 2002-03-08 A |  | 100% | 2001-06-15 | 2002-03-08 | 191d |  | T2 | 3584h | 3584h | MESS5-EMS | Ericsson | Alan.Baldwin@EML.ERICSSON.SE |  |  |
| 1744 | 98.2.1 | Definition of service requirements | 66d | 2001-06-15 A | 2001-09-14 A |  | 100% | 2001-06-15 | 2001-09-14 | 66d | finish no earlier than 2001-09-14 | S1 | 528h | 528h |  | Ericsson | Alan.Baldwin@EML.ERICSSON.SE |  | Alain |
| 1745 | 98.2.2 | Technical realization | 191d | 2001-06-15 A | 2002-03-08 A |  | 100% | 2001-06-15 | 2002-03-08 | 191d | finish no earlier than 2002-03-08 | T2 | 1528h | 1528h |  | Ericsson | Alan.Baldwin@EML.ERICSSON.SE |  |  |
| 1746 | 99 | **GERAN Inter BSC NACC improvements over the Gb Interface** | 215d | 2001-09-03 A | 2002-06-28 A |  | 100% | 2001-09-03 | 2002-06-28 | 215d |  | GP | 8200h | 8200h | GERNACC |  |  | Rel-5 | Paolo |
| 1747 | 99.1 | **Modification of core network protocols for GERAN Inter BSC NACC over Gb Interface** | 165d | 2001-09-03 A | 2002-04-19 A |  | 100% | 2001-09-03 | 2002-04-19 | 165d |  | N4,S2 | 4064h | 4064h | GERNACC-Cnmod |  |  |  | Kimmo |
| 1748 | 99.1.1 | Stage 2 - Concept | 43d | 2001-09-03 A | 2001-10-31 A |  | 100% | 2001-09-03 | 2001-10-31 | 43d | finish no earlier than 2001-10-31 | N4,S2 | 344h | 344h |  |  |  |  | Kimmo |
| 1749 | 99.1.2 | Stage 2 - 23.060 change - Definition of Inter BSC NACC | 165d | 2001-09-03 A | 2002-04-19 A |  | 100% | 2001-09-03 | 2002-04-19 | 165d | finish no earlier than 2002-04-19 | N4,S2 | 1320h | 1320h |  |  |  |  | Kimmo |
| 1750 | 99.1.3 | Stage 3 (changes to TS 29.060) | 135d | 2001-09-03 A | 2002-03-08 A |  | 100% | 2001-09-03 | 2002-03-08 | 135d | finish no earlier than 2002-03-08 | N4 | 1080h | 1080h |  |  |  |  | Kimmo |

Notes:
- 1725: SBC, Motorola, Nokia, Ericsson, Nortel
- 1730: Lucent, Ericsson, AWS, Nortel
- 1734: Text3: 23.207
- 1735: [DAB - 30/07/02] - % complete to 95% (if we exclude Diffserv). Marked as closed 12/2008 (was marked 95% complete) / Text3: 29.208, 29.207, 27.060, 29.061, 24.008, 24.228, , 24.229, 29.060, 29.163
- 1736: Text3: 32-series
- 1737: support of UAProf, so this in my opinion is 100% complete
- 1739: Text3: 22.140
- 1740: stage 3 MM7 is missing / Text3: 23.140
- 1741: Marked as closed 12/2008 (was marked 80% complete)
- 1742: Text3: 26.140
- 1743: Text3: 23.040
- 1745: Text3: 23.040
- 1750: IP 30/11/01: Input awaited from GERAN2 to CN4 / 17 May Work complete 100%

| ID | WBS | Task | Duration | Start | Finish | Complete | Baseline start | Baseline finish | Baseline duration | Constraint | Resources | Work | Actual work | Text1 | Text8 | Text6 | Text12 | Text3 | Text4 | Text5 |
| --- | --- | --- | --- | --- | --- | --- | --- | --- | --- | --- | --- | --- | --- | --- | --- | --- | --- | --- | --- | --- |
| 1751 | 99.2 | **Modification of Gb protocols for GERAN Inter BSC NACC over Gb Interface** | 151d | 2001-11-30 A | 2002-06-28 A | 100% | 2001-11-30 | 2002-06-28 | 151d |  | GP | 2416h | 2416h | GERNACC-Gbmod | Paolo |  |  |  |  |  |
| 1752 | 99.2.1 | Stage 3 (changes to TS 48.018) | 151d | 2001-11-30 A | 2002-06-28 A | 100% | 2001-11-30 | 2002-06-28 | 151d | finish no earlier than 2002-06-28 | GP | 1208h | 1208h |  | Paolo |  |  |  |  |  |
| 1753 | 100 | **Enhanced Power Control** | 540d | 2001-11-26 A | 2003-12-19 A | 100% | 2001-11-26 | 2003-12-19 | 540d |  | GP | 12840h | 12840h | EPC | Paolo | Rel-5 |  |  |  |  |
| 1754 | 100.1 | Realization of Enhanced power control and signaling support | 5d | 2001-11-26 A | 2001-11-30 A | 100% | 2001-11-26 | 2001-11-30 | 5d | finish no earlier than 2001-11-30 | GP | 40h | 40h |  | Paolo |  |  |  |  |  |
| 1755 | 100.2 | Deleted - GERAN MS Conformance test for Enhanced Power Control | 530d | 2001-12-10 A | 2003-12-19 A | 100% | 2001-12-10 | 2003-12-19 | 530d | finish no earlier than 2003-12-19 | GP | 4240h | 4240h |  | Paolo |  | GP-17 |  |  |  |
| 1756 | 100.3 | Deleted - GERAN BTS Conformance test for Enhanced Power Control | 530d | 2001-12-10 A | 2003-12-19 A | 100% | 2001-12-10 | 2003-12-19 | 530d | finish no earlier than 2003-12-19 | GP | 4240h | 4240h |  | Paolo |  | GP-17 |  |  |  |
| 1757 | 101 | **8PSK AMR HR** | 530d | 2001-12-10 A | 2003-12-19 A | 100% | 2001-12-10 | 2003-12-19 | 530d |  | GP | 21080h | 21080h | 8PSK-AH | Paolo | Rel-5 |  |  |  |  |
| 1758 | 101.1 | **Definition of channel coding, performance requirements and signaling support** | 145d | 2001-12-10 A | 2002-06-28 A | 100% | 2001-12-10 | 2002-06-28 | 145d |  | GP | 10440h | 10440h |  | Paolo |  |  |  |  |  |
| 1759 | 101.1.1 | Concept | 145d | 2001-12-10 A | 2002-06-28 A | 100% | 2001-12-10 | 2002-06-28 | 145d | finish no earlier than 2002-06-28 | GP | 1160h | 1160h |  | Paolo |  |  |  |  |  |
| 1760 | 101.1.2 | Changes to 44.018 | 145d | 2001-12-10 A | 2002-06-28 A | 100% | 2001-12-10 | 2002-06-28 | 145d | finish no earlier than 2002-06-28 | G2 | 1160h | 1160h |  | Juha |  |  |  |  |  |
| 1761 | 101.1.3 | Changes to 45.001 | 145d | 2001-12-10 A | 2002-06-28 A | 100% | 2001-12-10 | 2002-06-28 | 145d | finish no earlier than 2002-06-28 | G1 | 1160h | 1160h |  |  |  |  |  |  |  |
| 1762 | 101.1.4 | Changes to 45.002 | 145d | 2001-12-10 A | 2002-06-28 A | 100% | 2001-12-10 | 2002-06-28 | 145d | finish no earlier than 2002-06-28 | G1 | 1160h | 1160h |  |  |  |  |  |  |  |
| 1763 | 101.1.5 | Changes to 45.003 | 145d | 2001-12-10 A | 2002-06-28 A | 100% | 2001-12-10 | 2002-06-28 | 145d | finish no earlier than 2002-06-28 | G1 | 1160h | 1160h |  |  |  |  |  |  |  |
| 1764 | 101.1.6 | Changes to 45.005 | 145d | 2001-12-10 A | 2002-06-28 A | 100% | 2001-12-10 | 2002-06-28 | 145d | finish no earlier than 2002-06-28 | G1 | 1160h | 1160h |  |  |  |  |  |  |  |
| 1765 | 101.1.7 | Changes to 24.008 | 145d | 2001-12-10 A | 2002-06-28 A | 100% | 2001-12-10 | 2002-06-28 | 145d | finish no earlier than 2002-06-28 | G2 | 1160h | 1160h |  | Juha |  |  |  |  |  |
| 1766 | 101.1.8 | Changes to 48.058 | 145d | 2001-12-10 A | 2002-06-28 A | 100% | 2001-12-10 | 2002-06-28 | 145d | finish no earlier than 2002-06-28 | G2 | 1160h | 1160h |  | Juha |  |  |  |  |  |
| 1767 | 101.2 | GERAN MS Conformance test for 8PSK HR | 530d | 2001-12-10 A | 2003-12-19 A | 100% | 2001-12-10 | 2003-12-19 | 530d | finish no earlier than 2003-12-19 | GP | 4240h | 4240h |  | Paolo |  |  |  |  |  |
| 1768 | 101.3 | GERAN BTS Conformance test for 8PSK HR | 270d | 2001-12-10 A | 2002-12-20 A | 100% | 2001-12-10 | 2002-12-20 | 270d | finish no earlier than 2002-12-20 | GP | 2160h | 2160h |  | Paolo |  |  |  |  |  |
| 1769 | 102 | Service Change and UDI Fallback | 175d | 2001-10-08 A | 2002-06-07 A | 100% | 2001-10-08 | 2002-06-07 | 175d | finish no earlier than 2002-06-07 | N3 | 1400h | 1400h | SCUDIF | Gwiho | Rel-5 |  | 29.007, 27.001, 24.008 | Ericsson | Rune.Werner.Wiik@ericsson.no |
| 1770 | 103 | **Rel-5 USIM toolkit enhancements** | 865d | 2000-06-05 A | 2003-09-26 A | 100% | 2000-06-05 | 2003-09-26 | 865d |  | T3 | 24352h | 24352h | USAT1 | Xavier | Rel-5 |  |  |  |  |
| 1771 | 103.1 | Deleted - Test specification for USIM toolkit security mechanims | 349d | 2002-05-28 A | 2003-09-26 A | 100% | 2002-05-28 | 2003-09-26 | 349d | finish no earlier than 2003-09-26 | T3 | 2792h | 2792h |  |  | Rel-5 | TP-21 |  | Gemplus | Sophie Viallet |
| 1772 | 103.2 | **Protocol Standardisation of a SIM Toolkit Interpreter** | 688d | 2000-06-05 A | 2003-01-22 A | 100% | 2000-06-05 | 2003-01-22 | 688d |  | T3 | 12512h | 12512h | USAT1-Interpr |  | Rel-5 |  | 27.103 | G & D | Michael Meyer |
| 1773 | 103.2.1 | Stage 1 | 205d | 2000-06-05 A | 2001-03-16 A | 100% | 2000-06-05 | 2001-03-16 | 205d | finish no earlier than 2001-03-16 | T3 | 1640h | 1640h |  |  |  |  |  |  |  |
| 1774 | 103.2.2 | Stage 2 and 3 | 308d | 2001-01-03 A | 2002-03-08 A | 100% | 2001-01-03 | 2002-03-08 | 308d | finish no earlier than 2002-03-08 | T3 | 2464h | 2464h |  |  |  |  |  |  |  |
| 1775 | 103.2.3 | Test specification | 363d | 2001-09-03 A | 2003-01-22 A | 100% | 2001-09-03 | 2003-01-22 | 363d | finish no earlier than 2003-01-22 | T3 | 2904h | 2904h |  |  |  |  |  | Gemplus | Gérald MAUNIER |

Notes:
- 1754: Completed 11/2001
- 1755: Not started. Marked as stopped 12/2008
- 1756: Not started. Marked as stopped 12/2008
- 1757: Completed for Rel-5
- 1767: Marked as stopped 12/2008
- 1769: [DAB - 23/05/03] - 100 % complete some issues with CAMEL
- 1771: Marked as stopped 12/2008
- 1772: 28/5/2001: T3-19 proposed that since the stage 2 and 3 will not be presented to TP-12 for approval as expected, the WI will be moved to rel-5, with completion expected at TP-13.
- 1773: 5/10/2001: Stage one comepeted at TP-12.
- 1774: 5/10/2001: TS 31.112 and 31.113 approved at TP-13. TS 31.114 to be presented to TP-14.
- 1775: 5/10/2001: Work started on test specification. Marked as closed 12/2008 (was marked 12% complete)

| ID | WBS | Task | Duration | Start | Finish | Complete | Baseline start | Baseline finish | Baseline duration | Constraint | Resources | Work | Actual work | Text1 | Text6 | Text4 | Text5 | Text8 | Text12 |
| --- | --- | --- | --- | --- | --- | --- | --- | --- | --- | --- | --- | --- | --- | --- | --- | --- | --- | --- | --- |
| 1776 | 103.4 | **(U)SIM API** | 133d | 2002-03-20 A | 2002-09-20 A | 100% | 2002-03-20 | 2002-09-20 | 133d |  | T3 | 2128h | 2128h | USAT1-API | NA |  |  |  |  |
| 1777 | 103.4.1 | Java API Test specification | 133d | 2002-03-20 A | 2002-09-20 A | 100% | 2002-03-20 | 2002-09-20 | 133d | finish no earlier than 2002-09-20 | T3 | 1064h | 1064h |  |  | Microelectrónica Española | Mario Pérez |  |  |
| 1778 | 104 | **small Technical Enhancements and Improvements for Rel5** | 2348d? | 2000-01-03 A | 2008-12-31 A | 100% | 2000-01-03 | 2008-12-31 | 2348d? |  | All | 18784h | 18784h | TEI5 | Rel-5 |  |  |  |  |
| 1779 | 432.1 | Small Technical Enhancements and Improvements for Rel-5 Conformance Testing | 2348d? | 2000-01-03 A | 2008-12-31 A | 100% | 2000-01-03 | 2008-12-31 | 2348d? | finish no earlier than 2008-12-31 | R5 | 18784h | 18784h | TEI5_Test | Rel-5 |  |  | Ingbert |  |
| 1780 | 105 | Deleted - Technical Report on UE Functionality Split | 86d | 2000-01-03 A | 2000-05-01 A | 100% | 2000-01-03 | 2000-05-01 | 86d |  | S1 | 688h | 688h | UESPLIT | Rel-5 | Motorola | sanjay.gupta@motorola.com | Alain | SP-08 |
| 1781 | 106 | **User Equipment Management** | 267d | 2001-06-21 A | 2002-06-28 A | 100% | 2001-06-21 | 2002-06-28 | 267d |  | S5 | 3752h | 3752h | UEM | Rel-5 | Vodafone | john.mudge@vf.vodafone.co.uk | Dionisio |  |
| 1782 | 106.1 | FS on User Equipment (UE) Management | 267d | 2001-06-21 A | 2002-06-28 A | 100% | 2001-06-21 | 2002-06-28 | 267d | finish no earlier than 2002-06-28 | S5 | 2136h | 2136h | OAM-UEM | Rel-5 | Vodafone | john.mudge@vf.vodafone.co.uk | Dionisio |  |
| 1783 | 107 | **Flow control supporting an MS with multiple data flows with different QoS over the Gb interface** | 50d | 2002-06-24 A | 2002-08-30 A | 100% | 2002-06-24 | 2002-08-30 | 50d |  | GP | 1288h | 1288h | FlowCon | Rel-5 | Ericsson | ingemar.backlund@era.ericsson.se | Paolo |  |
| 1784 | 107.1 | **Update of stage 2 specifications** | 50d | 2002-06-24 A | 2002-08-30 A | 100% | 2002-06-24 | 2002-08-30 | 50d |  | GP | 808h | 808h |  |  |  |  | Paolo |  |
| 1785 | 107.1.1 | Concept document 23.060 (changes to) | 46d | 2002-06-28 A | 2002-08-30 A | 100% | 2002-06-28 | 2002-08-30 | 46d | finish no earlier than 2002-08-30 | S2 | 368h | 368h |  |  |  |  | Maurice |  |
| 1786 | 107.1.2 | Flow Control | 5d | 2002-06-24 A | 2002-06-28 A | 100% | 2002-06-24 | 2002-06-28 | 5d | finish no earlier than 2002-06-28 | GP | 40h | 40h |  |  |  |  | Paolo |  |
| 1787 | 107.2 | **Modification of BSSGP protocol** | 5d | 2002-06-24 A | 2002-06-28 A | 100% | 2002-06-24 | 2002-06-28 | 5d |  | GP | 80h | 80h |  |  | Ericsson | ingemar.backlund@era.ericsson.se | Paolo |  |
| 1788 | 107.2.1 | Stage 3 (changes to 48.018) | 5d | 2002-06-24 A | 2002-06-28 A | 100% | 2002-06-24 | 2002-06-28 | 5d | finish no earlier than 2002-06-28 | G2 | 40h | 40h |  |  |  |  | Juha |  |
| 1789 | 108 | **Multiple TBF in A/Gb mode** | 421d | 2002-04-19 A | 2003-11-28 A | 100% | 2002-04-19 | 2003-11-28 | 421d |  | GP | 17480h | 17480h | MULTBF | Rel-5 | Ericsson | gunnar.mildh@era.ericsson.se | Paolo |  |
| 1790 | 108.1 | **Multiple TBF in A/Gb mode** | 351d | 2002-04-19 A | 2003-08-22 A | 100% | 2002-04-19 | 2003-08-22 | 351d |  | GP | 8112h | 8112h | MULTBF-Agbmode |  |  |  | Paolo |  |
| 1791 | 108.1.1 | Multiple TBF Concept paper | 351d | 2002-04-19 A | 2003-08-22 A | 100% | 2002-04-19 | 2003-08-22 | 351d | finish no earlier than 2003-08-22 | GP | 2808h | 2808h |  |  |  |  | Paolo |  |
| 1792 | 108.1.2 | Deleted - Multiple TBF Stage 2 (43.064) CRs | 156d | 2002-04-19 A | 2002-11-22 A | 100% | 2002-04-19 | 2002-11-22 | 156d | finish no earlier than 2002-11-22 | G1 | 1248h | 1248h |  |  |  |  |  | GP-12 |
| 1793 | 108.1.3 | Deleted - Multiple TBF Stage 3 (44.060) CRs | 156d | 2002-04-19 A | 2002-11-22 A | 100% | 2002-04-19 | 2002-11-22 | 156d | finish no earlier than 2002-11-22 | G2 | 1248h | 1248h |  |  |  |  | Juha | GP-12 |
| 1794 | 108.2 | **Deleted - Multiple TBF in A/Gb mode – MS testing** | 375d | 2002-06-24 A | 2003-11-28 A | 100% | 2002-06-24 | 2003-11-28 | 375d |  | GP | 6000h | 6000h |  |  | Ericsson | ingemar.backlund@era.ericsson.se | Paolo | GP-17 |
| 1795 | 108.2.1 | Deleted - MS conformance tests | 375d | 2002-06-24 A | 2003-11-28 A | 100% | 2002-06-24 | 2003-11-28 | 375d | finish no earlier than 2003-11-28 | G4 | 3000h | 3000h |  |  |  |  | Paolo | GP-17 |
| 1796 | 109 | **Alignment of 3G functional split and Iu** | 922d | 2000-06-08 A | 2003-12-19 A | 100% | 2000-06-08 | 2003-12-19 | 922d |  | GP | 126664h | 126664h | GER3GAL | Rel-5 | Ericsson | Frank Muller | Paolo |  |
| 1797 | 109.1 | **GERAN user / control plane** | 540d | 2000-08-07 A | 2002-08-30 A | 100% | 2000-08-07 | 2002-08-30 | 540d |  | GP | 36232h | 36232h | GER3GAL-GUCOPL |  | Ericsson | Frank Muller | Paolo |  |
| 1798 | 109.1.1 | **Alignment with UMTS bearer concept** | 540d | 2000-08-07 A | 2002-08-30 A | 100% | 2000-08-07 | 2002-08-30 | 540d |  | GP | 24952h | 24952h |  |  |  |  | Paolo |  |
| 1799 | 109.1.1.1 | Enhanced power control | 1d | 2001-08-31 A | 2001-08-31 A | 100% | 2001-08-31 | 2001-08-31 | 1d | finish no earlier than 2001-08-31 | GP | 8h | 8h |  |  |  |  | Paolo |  |
| 1800 | 109.1.1.2 | Stage 2 | 235d | 2000-08-07 A | 2001-06-29 A | 100% | 2000-08-07 | 2001-06-29 | 235d | finish no earlier than 2001-06-29 | GP | 1880h | 1880h |  |  |  |  | Paolo |  |
| 1801 | 109.1.1.3 | Adoption of the UTRAN PDCP | 295d | 2000-11-06 A | 2001-12-21 A | 100% | 2000-11-06 | 2001-12-21 | 295d | finish no earlier than 2001-12-21 | GP | 2360h | 2360h |  |  |  |  | Paolo |  |
| 1802 | 109.1.1.4 | Development of RLC / MAC | 261d | 2001-08-31 A | 2002-08-30 A | 100% | 2001-08-31 | 2002-08-30 | 261d | finish no earlier than 2002-08-30 | GP | 2088h | 2088h |  |  |  |  | Paolo |  |
| 1803 | 109.1.1.5 | Development of GERAN RRC | 266d | 2001-06-22 A | 2002-06-28 A | 100% | 2001-06-22 | 2002-06-28 | 266d | finish no earlier than 2002-06-28 | GP | 2128h | 2128h |  |  |  |  | Paolo |  |
| 1804 | 109.1.1.6 | Ciphering and integrity protection concept paper | 166d | 2001-08-31 A | 2002-04-19 A | 100% | 2001-08-31 | 2002-04-19 | 166d | finish no earlier than 2002-04-19 | GP | 1328h | 1328h |  |  |  |  | Paolo |  |
| 1805 | 109.1.1.7 | Multiple TBF or equivalent Concept paper | 116d | 2001-08-31 A | 2002-02-08 A | 100% | 2001-08-31 | 2002-02-08 | 116d | finish no earlier than 2002-02-08 | GP | 928h | 928h |  |  |  |  | Paolo |  |
| 1806 | 109.1.1.8 | Paging concept | 166d | 2001-08-31 A | 2002-04-19 A | 100% | 2001-08-31 | 2002-04-19 | 166d | finish no earlier than 2002-04-19 | GP | 1328h | 1328h |  |  |  |  | Paolo |  |
| 1807 | 109.1.1.9 | Dedicated Physical subchannels, includes traffic and control channels | 66d | 2001-08-31 A | 2001-11-30 A | 100% | 2001-08-31 | 2001-11-30 | 66d | finish no earlier than 2001-11-30 | GP | 528h | 528h |  |  |  |  | Paolo |  |
| 1808 | 109.1.1.10 | Iu support and broadcast concept | 166d | 2001-08-31 A | 2002-04-19 A | 100% | 2001-08-31 | 2002-04-19 | 166d | finish no earlier than 2002-04-19 | GP | 1328h | 1328h |  |  |  |  | Paolo |  |
| 1809 | 109.1.1.11 | Impact of using RLC instead of LAPDm concept | 116d | 2001-08-31 A | 2002-02-08 A | 100% | 2001-08-31 | 2002-02-08 | 116d | finish no earlier than 2002-02-08 | GP | 928h | 928h |  |  |  |  | Paolo |  |
| 1810 | 109.1.1.12 | Contention resolution, mobile station identity, and access concept | 66d | 2001-08-31 A | 2001-11-30 A | 100% | 2001-08-31 | 2001-11-30 | 66d | finish no earlier than 2001-11-30 | GP | 528h | 528h |  |  |  |  | Paolo |  |
| 1811 | 109.1.1.13 | PDCP concept | 166d | 2001-08-31 A | 2002-04-19 A | 100% | 2001-08-31 | 2002-04-19 | 166d | finish no earlier than 2002-04-19 | GP | 1328h | 1328h |  |  |  |  | Paolo |  |
| 1812 | 109.1.1.14 | Downlink delayed TBF release | 261d | 2001-08-31 A | 2002-08-30 A | 100% | 2001-08-31 | 2002-08-30 | 261d | finish no earlier than 2002-08-30 | GP | 2088h | 2088h |  |  |  |  | Paolo |  |
| 1813 | 109.1.1.15 | Add transparent RLC Concept | 116d | 2001-08-31 A | 2002-02-08 A | 100% | 2001-08-31 | 2002-02-08 | 116d | finish no earlier than 2002-02-08 | GP | 928h | 928h |  |  |  |  | Paolo |  |
| 1814 | 109.1.1.16 | Handover concept | 116d | 2001-08-31 A | 2002-02-08 A | 100% | 2001-08-31 | 2002-02-08 | 116d | finish no earlier than 2002-02-08 | GP | 928h | 928h |  |  |  |  | Paolo |  |

Notes:
- 1776: 8/3/2001: test spec is based on R99 core spec, so deleted from Workplan
- 1778: "Joker" WI, to be used for a Rel 5 CR not related to any feature and with very limited impact on the system
- 1779: "Joker" WI, to be used for small modifications applicable to Rel 5 conformance testing. Moved in from Stoyan/testing WP. / Text3: 34.108, 34.109, 34.121-1, 34.121-2, 34.122, 34.123-1, 34.123-2, 34.123-3, 34.171, 34.229-1, 34.229-2, 34.229-3
- 1782: Text3: 32.802
- 1783: 50101 -> 50201
- 1784: 50102 -> 50202
- 1786: 50103 -> 50203
- 1790: Marked as closed 12/2008 (was marked 26% complete)
- 1791: Marked as closed 12/2008 (was marked 50% complete)
- 1792: Marked as stopped 12/2008
- 1793: Marked as stopped 12/2008
- 1794: 08/08: duplicate UID_50106=-> 50206. Marked as stopped 12/2008
- 1795: Not started. Marked as stopped 12/2008
- 1796: AWS, Nokia, Ericsson, Nortel, Siemens, Vodafone
- 1797: AWS, Nokia, Ericsson, Nortel, Siemens, Vodafone
- 1801: Responsible is GERAN; RAN WG2 help may be needed.

| ID | WBS | Task | Duration | Start | Finish | Complete | Baseline start | Baseline finish | Baseline duration | Constraint | Resources | Work | Actual work | Text8 | Text1 | Text4 | Text5 |
| --- | --- | --- | --- | --- | --- | --- | --- | --- | --- | --- | --- | --- | --- | --- | --- | --- | --- |
| 1815 | 109.1.2 | **Physical layer alignment with UMTS bearer concept** | 280d | 2000-11-06 A | 2001-11-30 A | 100% | 2000-11-06 | 2001-11-30 | 280d |  | GP | 6960h | 6960h | Paolo |  |  |  |
| 1816 | 109.1.2.1 | PDTCH/TCH in 45.003 | 155d | 2000-11-06 A | 2001-06-08 A | 100% | 2000-11-06 | 2001-06-08 | 155d | finish no earlier than 2001-06-08 | GP | 1240h | 1240h | Paolo |  |  |  |
| 1817 | 109.1.2.2 | Control channels in 45.003 | 155d | 2000-11-06 A | 2001-06-08 A | 100% | 2000-11-06 | 2001-06-08 | 155d | finish no earlier than 2001-06-08 | GP | 1240h | 1240h | Paolo |  |  |  |
| 1818 | 109.1.2.3 | Receiver performance in 45.005 for PDTCH/TCH and control channels | 280d | 2000-11-06 A | 2001-11-30 A | 100% | 2000-11-06 | 2001-11-30 | 280d | finish no earlier than 2001-11-30 | GP | 2240h | 2240h | Paolo |  |  |  |
| 1819 | 109.2 | **Iu rg interface** | 430d | 2000-11-06 A | 2002-06-28 A | 100% | 2000-11-06 | 2002-06-28 | 430d |  | GP,RP | 39560h | 39560h | Paolo | GER3GAL-Iurg | Ericsson | Frank Muller |
| 1820 | 109.2.1 | **Inter BSS interface** | 430d | 2000-11-06 A | 2002-06-28 A | 100% | 2000-11-06 | 2002-06-28 | 430d |  | GP,RP | 20640h | 20640h | Paolo |  |  |  |
| 1821 | 109.2.1.1 | Identification of requirements | 430d | 2000-11-06 A | 2002-06-28 A | 100% | 2000-11-06 | 2002-06-28 | 430d | finish no earlier than 2002-06-28 | GP | 3440h | 3440h | Paolo |  |  |  |
| 1822 | 109.2.1.2 | Stage 2 | 430d | 2000-11-06 A | 2002-06-28 A | 100% | 2000-11-06 | 2002-06-28 | 430d | finish no earlier than 2002-06-28 | GP | 3440h | 3440h | Paolo |  |  |  |
| 1823 | 109.2.1.3 | Adoption of relevant parts from Iur | 430d | 2000-11-06 A | 2002-06-28 A | 100% | 2000-11-06 | 2002-06-28 | 430d | finish no earlier than 2002-06-28 | GP | 3440h | 3440h | Paolo |  |  |  |
| 1824 | 109.2.1.4 | Complementation with GERAN specifics | 430d | 2000-11-06 A | 2002-06-28 A | 100% | 2000-11-06 | 2002-06-28 | 430d | finish no earlier than 2002-06-28 | GP | 3440h | 3440h | Paolo |  |  |  |
| 1825 | 109.2.1.5 | Stage 3 | 430d | 2000-11-06 A | 2002-06-28 A | 100% | 2000-11-06 | 2002-06-28 | 430d | finish no earlier than 2002-06-28 | GP | 3440h | 3440h | Paolo |  |  |  |
| 1826 | 109.2.2 | **Inter BSS-RNS interface** | 430d | 2000-11-06 A | 2002-06-28 A | 100% | 2000-11-06 | 2002-06-28 | 430d |  | GP,RP | 15480h | 15480h | Paolo |  |  |  |
| 1827 | 109.2.2.1 | Identification of requirements | 430d | 2000-11-06 A | 2002-06-28 A | 100% | 2000-11-06 | 2002-06-28 | 430d | start no earlier than 2000-11-06 | GP,R3 | 3440h | 3440h | Paolo |  |  |  |
| 1828 | 109.2.2.2 | Stage 2 | 430d | 2000-11-06 A | 2002-06-28 A | 100% | 2000-11-06 | 2002-06-28 | 430d | finish no earlier than 2002-06-28 | GP,R3 | 3440h | 3440h | Paolo |  |  |  |
| 1829 | 109.2.2.3 | Adoption of relevant parts from Iur | 430d | 2000-11-06 A | 2002-06-28 A | 100% | 2000-11-06 | 2002-06-28 | 430d | finish no earlier than 2002-06-28 | GP,R3 | 3440h | 3440h | Paolo |  |  |  |
| 1830 | 109.2.2.4 | Complementation with GERAN specifics | 107.5d | 2002-01-30 A | 2002-06-28 A | 100% | 2002-01-30 | 2002-06-28 | 107.5d | finish no earlier than 2002-06-28 | GP,R3 | 860h | 860h | Paolo |  |  |  |
| 1831 | 109.2.2.5 | Stage 3 | 107.5d | 2002-01-30 A | 2002-06-28 A | 100% | 2002-01-30 | 2002-06-28 | 107.5d | finish no earlier than 2002-06-28 | GP,R3 | 860h | 860h | Paolo |  |  |  |
| 1832 | 109.3 | **Voice over GERAN PS and CS concept** | 430d | 2000-11-06 A | 2002-06-28 A | 100% | 2000-11-06 | 2002-06-28 | 430d |  | GP,R3 | 18520h | 18520h | Paolo |  |  |  |
| 1833 | 109.3.1 | Architecture for A, Iu cs and Iu ps | 430d | 2000-11-06 A | 2002-06-28 A | 100% | 2000-11-06 | 2002-06-28 | 430d | finish no earlier than 2002-06-28 | GP,R3 | 3440h | 3440h | Paolo |  |  |  |
| 1834 | 109.3.2 | Transcoder position/operation | 115d | 2000-11-06 A | 2001-04-13 A | 100% | 2000-11-06 | 2001-04-13 | 115d | finish no earlier than 2001-04-13 | GP | 920h | 920h | Paolo |  |  |  |
| 1835 | 109.3.3 | Handover | 430d | 2000-11-06 A | 2002-06-28 A | 100% | 2000-11-06 | 2002-06-28 | 430d | finish no earlier than 2002-06-28 | GP,R3 | 3440h | 3440h | Paolo |  |  |  |
| 1836 | 109.3.4 | RTP payload | 430d | 2000-11-06 A | 2002-06-28 A | 100% | 2000-11-06 | 2002-06-28 | 430d | finish no earlier than 2002-06-28 | GP,R3 | 3440h | 3440h | Paolo |  |  |  |
| 1837 | 109.3.5 | Codec renegotiation concept | 365d | 2000-11-06 A | 2002-03-29 A | 100% | 2000-11-06 | 2002-03-29 | 365d | finish no earlier than 2002-03-29 | GP,R3 | 2920h | 2920h | Paolo |  |  |  |
| 1838 | 109.3.6 | LA | 115d | 2000-11-06 A | 2001-04-13 A | 100% | 2000-11-06 | 2001-04-13 | 115d | finish no earlier than 2001-04-13 | GP | 920h | 920h | Paolo |  |  |  |

Notes:
- 1819: AWS, Nokia, Ericsson, Nortel, Siemens, Vodafone

| ID | WBS | Task | Duration | Start | Finish | Complete | Baseline start | Baseline finish | Baseline duration | Total slack | Constraint | Resources | Work | Actual work | Text8 | Text12 | Text1 | Text4 | Text5 | Text6 |
| --- | --- | --- | --- | --- | --- | --- | --- | --- | --- | --- | --- | --- | --- | --- | --- | --- | --- | --- | --- | --- |
| 1839 | 109.4 | **Deleted - GERAN MS Conformance test for GERAN interface evolution** | 660d | 2001-06-11 A | 2003-12-19 A | 100% | 2001-06-11 | 2003-12-19 | 660d |  |  | GP | 10560h | 10560h | Paolo | GP-17 |  |  |  |  |
| 1840 | 109.4.1 | Deleted - MS test | 660d | 2001-06-11 A | 2003-12-19 A | 100% | 2001-06-11 | 2003-12-19 | 660d |  | finish no earlier than 2003-12-19 | GP | 5280h | 5280h | Paolo | GP-17 |  |  |  |  |
| 1841 | 109.5 | **GERAN BSS Conformance test for GERAN interface evolution** | 922d | 2000-06-08 A | 2003-12-19 A | 100% | 2000-06-08 | 2003-12-19 | 922d |  |  | GP | 14752h | 14752h | Paolo |  |  |  |  |  |
| 1842 | 109.5.1 | Deleted - BSS test | 922d | 2000-06-08 A | 2003-12-19 A | 100% | 2000-06-08 | 2003-12-19 | 922d |  | finish no earlier than 2003-12-19 | GP | 7376h | 7376h | Paolo | GP-17 |  |  |  |  |
| 1843 | 110 | **GERAN support for IMS** | 690d | 2000-05-01 A | 2002-12-20 A | 100% | 2000-05-01 | 2002-12-20 | 690d |  |  | GP | 39198.4h | 39198.4h | Paolo |  | GERIMS | Nokia | Shkumbin Hamiti | Rel-5 |
| 1844 | 110.1 | **GERAN Header adaptation** | 690d | 2000-05-01 A | 2002-12-20 A | 100% | 2000-05-01 | 2002-12-20 | 690d |  |  | GP,S2,RP | 12302.8h | 12302.8h | Paolo |  | GERIMS-HEADAPT | Nokia | Shkumbin Hamiti |  |
| 1845 | 110.1.1 | Definition of compression and removal modes for PDCP protocol | 15.05d | 2000-05-01 A | 2000-11-10 A | 100% | 2000-05-01 | 2000-11-10 | 15.05d |  | finish no earlier than 2000-09-01 | GP,S2,RP | 120.4h | 120.4h | Paolo |  |  |  |  |  |
| 1846 | 110.1.2 | Conceptual description in stage 2 | 393d | 2000-05-01 A | 2001-10-31 A | 100% | 2000-05-01 | 2001-10-31 | 393d |  | finish no earlier than 2001-10-31 | GP,S2,RP | 3144h | 3144h | Paolo |  |  |  |  |  |
| 1847 | 110.1.3 | Necessary changes on stage 3 regarding header removal | 439.8d | 2000-11-06 A | 2002-12-20 A | 100% | 2000-11-06 | 2002-12-20 | 439.8d |  | finish no earlier than 2002-12-20 | GP,S2,RP | 3518.4h | 3518.4h | Paolo |  |  |  |  |  |
| 1848 | 110.2 | **Deleted - GERAN Radio access bearer design for IMS** | 430d | 2000-11-06 A | 2002-06-28 A | 100% | 2000-11-06 | 2002-06-28 | 430d |  |  | GP,S2,RP | 9287.6h | 9287.6h | Paolo | GP-10 | GERIMS-RABDES | Nokia | Shkumbin Hamiti |  |
| 1849 | 110.2.1 | **Deleted - MuM control signalling for conversational multimedia services** | 430d | 2000-11-06 A | 2002-06-28 A | 100% | 2000-11-06 | 2002-06-28 | 430d |  |  | GP,S2,RP | 5847.6h | 5847.6h | Paolo | GP-10 |  |  |  |  |
| 1850 | 110.2.1.1 | Deleted - Identification of requirements | 330d | 2000-11-06 A | 2002-02-08 A | 100% | 2000-11-06 | 2002-02-08 | 330d |  | finish no earlier than 2002-02-08 | GP,S2,RP | 2640h | 2640h | Paolo | GP-08 |  |  |  |  |
| 1851 | 110.2.1.2 | Deleted - Necessary modifications due to SIP | 40d | 2002-05-06 A | 2002-06-28 A | 100% | 2002-05-06 | 2002-06-28 | 40d |  | finish no earlier than 2002-06-28 | GP,S2,RP | 320h | 320h | Paolo | GP-10 |  |  |  |  |
| 1852 | 110.3 | **Deleted - GERAN MS Conformance test for support of IMS** | 400d | 2001-06-11 A | 2002-12-20 A | 100% | 2001-06-11 | 2002-12-20 | 400d |  |  | GP | 6400h | 6400h | Paolo | GP-12 | GERIMS-MSconf | Nokia | Shkumbin Hamiti |  |
| 1853 | 110.3.1 | Deleted - MS test | 400d | 2001-06-11 A | 2002-12-20 A | 100% | 2001-06-11 | 2002-12-20 | 400d |  | finish no earlier than 2002-12-20 | G4 | 3200h | 3200h | Paolo | GP-12 |  |  |  |  |
| 1854 | 110.4 | **Deleted - GERAN BTS Conformance test for support of IMS** | 400d | 2001-06-11 A | 2002-12-20 A | 100% | 2001-06-11 | 2002-12-20 | 400d |  |  | GP | 6400h | 6400h | Paolo | GP-12 | GERIMS-BTSconf | Nokia | Shkumbin Hamiti |  |
| 1855 | 110.4.1 | Deleted - BTS test | 400d | 2001-06-11 A | 2002-12-20 A | 100% | 2001-06-11 | 2002-12-20 | 400d |  | finish no earlier than 2002-12-20 | G3new | 3200h | 3200h | Ingbert | GP-12 |  |  |  |  |
| 1856 | 439 | MS Conformance Testing of Dual Transfer Mode | 65d? | 2002-11-11 A | 2003-02-07 A | 100% | 2002-11-11 | 2003-02-07 | 65d? |  | finish no earlier than 2003-02-07 | G4,G5 | 520h | 520h | Paolo |  | MSCTDTM | Vodafone | Dave Fox | NA |
| 1857 | 440 | **Handling of early UEs** | 910d? | 2000-01-03 A | 2003-06-27 A | 100% | 2000-01-03 | 2003-06-27 | 910d? |  |  | S2 | 4480h | 4480h | Maurice |  | LATE_UE |  |  | Rel-5 |
| 1858 | 440.1 | Feasibility Study | 50d? | 2002-10-07 A | 2002-12-13 A | 100% | 2002-10-07 | 2002-12-13 | 50d? |  | finish no earlier than 2002-12-13 | S2 | 400h | 400h | Maurice |  |  |  |  |  |
| 1859 | 440.2 | Stage 2 | 125d? | 2003-01-06 A | 2003-06-27 A | 100% | 2003-01-06 | 2003-06-27 | 125d? |  | start no earlier than 2003-01-06 | S2 | 1000h | 1000h | Maurice |  |  |  |  |  |
| 1860 | 440.3 | FS for the Early Mobile Handling in UTRAN | 195d | 2002-09-09 A | 2003-06-06 A | 100% | 2002-09-09 | 2003-06-06 | 195d |  | finish no earlier than 2003-06-06 | R2 | 1560h | 1560h | Joern |  | FSEarlyUE | Vodafone | Alan Law | Rel-5 |
| 1861 | 440.4 | Note: Stage 3 RAN part not shown | 1d | 2000-01-03 A | 2000-01-03 A | 100% | 2000-01-03 | 2000-01-03 | 1d |  |  |  |  |  |  |  |  |  |  |  |
| 1862 | 441 | Release 4 Features | 1d? | 2000-01-03 | 2000-01-03 |  | 2000-01-03 | 2000-01-03 | 1d? | 2659d |  | CP,GP, RP,SP,TP | 8h |  |  |  |  |  |  | Rel-4 |

Notes:
- 1839: Not started. Marked as stopped 12/2008
- 1840: Not started. Marked as stopped 12/2008
- 1841: Not started. Marked as stopped 12/2008
- 1842: Not started. Marked as stopped 12/2008
- 1843: AWS, Nokia, Ericsson, Nortel, Siemens, Motorola
- 1844: AWS, Nokia, Ericsson, Nortel, Siemens, Motorola
- 1848: TERMINATED - NOT STANDARDIZED. Marked as stopped 12/2008
- 1849: TERMINATED - NOT STANDARDIZED. Marked as stopped 12/2008
- 1850: TERMINATED - NOT STANDARDIZED
- 1851: TERMINATED - NOT STANDARDIZED
- 1852: TERMINATED - NOT STANDARDIZED. Marked as stopped 12/2008
- 1853: TERMINATED - NOT STANDARDIZED. Marked as stopped 12/2008
- 1854: TERMINATED - NOT STANDARDIZED. Marked as stopped 12/2008
- 1855: TERMINATED - NOT STANDARDIZED. Marked as stopped 12/2008
- 1856: Needed to complete DTM (R99)

| ID | WBS | Task | Duration | Start | Finish | Predecessors | Complete | Baseline start | Baseline finish | Baseline duration | Constraint | Resources | Work | Actual work | Text1 | Text6 | Text8 | Text3 | Text12 | Text4 | Text5 |
| --- | --- | --- | --- | --- | --- | --- | --- | --- | --- | --- | --- | --- | --- | --- | --- | --- | --- | --- | --- | --- | --- |
| 1863 | 15 | **Miscelleneous UE Conformance Testing Activities** | 958d | 2001-04-02 A | 2004-12-01 A |  | 100% | 2001-04-02 | 2004-12-01 | 958d |  | T1 | 36360h | 36360h | MISTST1 | NA | Ingbert |  |  |  |  |
| 1864 | 15.1 | Optimisation of Test Time, RF Aspects (FDD) | 508d | 2001-09-24 A | 2003-09-03 A |  | 100% | 2001-09-24 | 2003-09-03 | 508d | finish no earlier than 2003-09-03 | T1 | 4064h | 4064h | MISTST1-OpFDD | Rel Indep | Ingbert | 34.121 |  |  |  |
| 1865 | 15.2 | Optimisation of Test Time, RF Aspects (TDD) | 508d | 2001-09-24 A | 2003-09-03 A |  | 100% | 2001-09-24 | 2003-09-03 | 508d | finish no earlier than 2003-09-03 | T1 | 4064h | 4064h | MISTST1-OpTDD | Rel Indep | Ingbert | 34.122 |  |  |  |
| 1866 | 15.3 | Extensions to R99 Test cases | 139.4w | 2001-04-02 A | 2003-12-02 A |  | 100% | 2001-04-02 | 2003-12-02 | 139.4w | finish no earlier than 2003-12-02 | T1 | 5576h | 5576h | MISTST1-Ext |  | Ingbert | 34.123 p 1,2 |  |  |  |
| 1867 | 15.4 | Extension to R99 Test cases - TTCN | 439d | 2002-06-28 A | 2004-03-03 A |  | 100% | 2002-06-28 | 2004-03-03 | 439d | finish no earlier than 2004-03-03 | T1 | 3512h | 3512h |  |  | Ingbert |  |  |  |  |
| 1868 | 15.5 | Creation of R99 TCs for TDD - prose | 719d | 2001-10-01 A | 2004-07-01 A |  | 100% | 2001-10-01 | 2004-07-01 | 719d | finish no earlier than 2004-07-01 | T1 | 5752h | 5752h | MISTST1-TDD |  | Ingbert | 34.123-1 |  |  |  |
| 1869 | 15.6 | Deleted - Creation of R99 TCs for TDD - TTCN | 587d | 2002-09-03 A | 2004-12-01 A |  | 100% | 2002-09-03 | 2004-12-01 | 587d | finish no earlier than 2004-12-01 | T1 | 4696h | 4696h |  |  | Ingbert |  | TP-26 |  |  |
| 1870 | 15.7 | Deleted - Review all other work items for impact on new or exiting 34 series specs. | 25.8w | 2002-07-02 A | 2002-12-27 A |  | 100% | 2002-07-02 | 2002-12-27 | 25.8w | finish no earlier than 2002-12-27 | T1 | 1032h | 1032h | MISTST1 |  | Ingbert | 34.121,122,123,125 | TP-18 |  |  |
| 1871 | 46 | **Facsimile** | 89d | 2000-02-22 A | 2000-06-23 A |  | 100% | 2000-02-22 | 2000-06-23 | 89d |  | S1 | 4376h | 4376h | FAX | Rel-4 | Alain |  |  |  |  |
| 1872 | 46.1 | **Real Time Fax** | 89d | 2000-02-22 A | 2000-06-23 A |  | 100% | 2000-02-22 | 2000-06-23 | 89d |  | S2 | 3664h | 3664h | FAX-RT |  | Maurice |  |  |  |  |
| 1873 | 46.1.1 | Terminal capabilities, AT commands | 89d | 2000-02-22 A | 2000-06-23 A |  | 100% | 2000-02-22 | 2000-06-23 | 89d | finish no earlier than 2000-06-23 | T2 | 712h | 712h |  |  |  | 21.904, 27.007 |  |  |  |
| 1874 | 46.1.2 | Signalling aspects (e.g. ICM) | 89d | 2000-02-22 A | 2000-06-23 A |  | 100% | 2000-02-22 | 2000-06-23 | 89d | start no earlier than 2000-02-22 | N1 | 712h | 712h |  |  | Frederic |  |  |  |  |
| 1875 | 46.1.3 | Service provision | 89d | 2000-02-22 A | 2000-06-23 A |  | 100% | 2000-02-22 | 2000-06-23 | 89d | finish no earlier than 2000-06-23 | N3 | 712h | 712h |  |  | Gwiho | 23.146 |  |  |  |
| 1876 | 46.1.4 | Review whether service/stage 1 aspects need to be aligned | 51d | 2000-04-14 A | 2000-06-23 A |  | 100% | 2000-04-14 | 2000-06-23 | 51d | finish no earlier than 2000-12-14 | S1 | 408h | 408h |  |  | Alain |  |  |  |  |
| 1877 | 46.1.5 | Review whether architecture/stage 2 aspects need to be aligned | 51d | 2000-04-14 A | 2000-06-23 A |  | 100% | 2000-04-14 | 2000-06-23 | 51d | finish no earlier than 2000-12-14 | S2 | 408h | 408h |  |  | Maurice |  |  |  |  |
| 1878 | 47 | Transparent End-to-End PS mobile streaming application | 253d | 2000-04-03 A | 2001-03-21 A |  | 100% | 2000-04-03 | 2001-03-21 | 253d | finish no earlier than 2000-12-29 | S4 | 2024h | 2024h | PSTREAM | Rel-4 | Paolo | 26.233, 26.234 |  |  |  |
| 1879 | 48 | **Multimedia Messaging** | 277d | 2000-02-22 A | 2001-03-14 A |  | 100% | 2000-02-22 | 2001-03-14 | 277d |  | T2 | 12208h | 12208h | MMS | Rel-4 | Kimmo | 22.140, 23.140 |  | Siemens | Josef.Laumen@SAL.SIEMENS.DE |
| 1880 | 48.1 | Definition of service requirements | 72d | 2000-02-22 A | 2000-05-31 A |  | 100% | 2000-02-22 | 2000-05-31 | 72d | start no earlier than 2000-02-22 | S1 | 576h | 576h | MMS |  | Alain |  |  |  |  |
| 1881 | 48.2 | Review of definition of service requirements | 205d | 2000-06-01 A | 2001-03-14 A | 1880 | 100% | 2000-06-01 | 2001-03-14 | 205d | finish no earlier than 2000-09-08 | T2 | 1640h | 1640h |  |  |  | 22.140, 23.140 |  | Siemens |  |
| 1882 | 48.3 | **Technical Realisation** | 243d | 2000-04-10 A | 2001-03-14 A |  | 100% | 2000-04-10 | 2001-03-14 | 243d |  | T2 | 7776h | 7776h |  |  |  | 22.140, 23.140 |  | Siemens | Josef.Laumen@SAL.SIEMENS.DE |
| 1883 | 48.3.1 | Review of definition of reference Achitecture model | 243d | 2000-04-10 A | 2001-03-14 A |  | 100% | 2000-04-10 | 2001-03-14 | 243d | finish no earlier than 2001-03-14 | T2 | 1944h | 1944h |  |  |  | 22.140, 23.140 |  | Siemens | Josef.Laumen@SAL.SIEMENS.DE |
| 1884 | 48.3.2 | "Fulfill Requirements of Stage 1" | 243d | 2000-04-10 A | 2001-03-14 A |  | 100% | 2000-04-10 | 2001-03-14 | 243d | finish no earlier than 2001-03-14 | T2 | 1944h | 1944h |  |  |  | 22.140, 23.140 |  | Siemens | Josef.Laumen@SAL.SIEMENS.DE |
| 1885 | 48.3.3 | Definition of MMS primitives in Stage 2 | 243d | 2000-04-10 A | 2001-03-14 A |  | 100% | 2000-04-10 | 2001-03-14 | 243d | finish no earlier than 2001-03-14 | T2 | 1944h | 1944h |  |  |  | 22.140, 23.140 |  | Siemens | Josef.Laumen@SAL.SIEMENS.DE |
| 1886 | 49 | **Transcoder-Free Operation** | 325d | 2000-01-03 A | 2001-03-30 A |  | 100% | 2000-01-03 | 2001-03-30 | 325d |  | N4 | 13040h | 13040h | TrFO | Rel-4 | Kimmo |  |  |  |  |
| 1887 | 49.1 | **OoBTC solution** | 325d | 2000-01-03 A | 2001-03-30 A |  | 100% | 2000-01-03 | 2001-03-30 | 325d |  | N4 | 8440h | 8440h | TRFO-OOBTC |  | Kimmo |  |  | NEC | Toshiyuki Tamura (tamurato@aj.jp.nec.com) |
| 1888 | 49.1.1 | implementation in UTRAN | 145d | 2000-09-11 A | 2001-03-30 A |  | 100% | 2000-09-11 | 2001-03-30 | 145d | finish no earlier than 2001-03-30 | R3 | 1160h | 1160h | TRFO-OOBTC-UTRAN |  | Gert | 25.401, 25.410, 25.413, 25.415, 23.153 |  | Siemens | Alexander Vesely |
| 1889 | 49.1.2 | Impact on architecture, Principles and Terminology | 210d | 2000-01-03 A | 2000-10-20 A |  | 100% | 2000-01-03 | 2000-10-20 | 210d | finish no earlier than 2000-10-20 | S2 | 1680h | 1680h |  |  | Maurice |  |  |  |  |
| 1890 | 49.1.3 | Codec Negotiation between UE and MSC | 125d | 2000-08-14 A | 2001-02-02 A |  | 100% | 2000-08-14 | 2001-02-02 | 125d | finish no earlier than 2001-02-02 | N1 | 1000h | 1000h |  |  | Frederic | 24.008, 23.009, 23.108, (29.002) |  | Motorola | Andrew Howell |
| 1891 | 49.1.4 | Codec Negotiation inter MSC | 125d | 2000-07-03 A | 2000-12-22 A |  | 100% | 2000-07-03 | 2000-12-22 | 125d | finish no earlier than 2000-12-22 | N4 | 1000h | 1000h |  |  | Kimmo |  |  |  |  |
| 1892 | 49.1.5 | Bearer establishment inter MSC | 125d | 2000-07-03 A | 2000-12-22 A |  | 100% | 2000-07-03 | 2000-12-22 | 125d | finish no earlier than 2000-12-22 | N4 | 1000h | 1000h |  |  | Kimmo | 23.153 |  |  |  |

Notes:
- 1864: It is believed that the current R99 test spec. can be optimised for faster overall test times. Marked as stopped 12/2008 (was 70% complete)
- 1865: It is believed that the current R99 test spec. can be optimised for faster overall test times
- 1866: Further test coverage of the R99 specification to cover supplementry services. Marked as stopped 12/2008 (was 70% complete)
- 1867: Marked as closed 12/2008 (was marked 50% complete)
- 1868: Marked as closed 12/2008 (was marked 50% complete)
- 1869: Marked as stopped 12/2008
- 1870: Marked as stopped 12/2008
- 1872: postponed from R99 to R00, SP-000169
- 1884: e.g. minimum set of media formats, media format conversion, personalization of MMS.
- 1886: Lead given to CN4 from CN / [DAB 28/11/00]
- 1888: moved according to NP-000575
- 1889: e.g. study cascading TrFO/TFO/TrFO
- 1890: the link to NP-000085has been deleted because refering to a R99 status sheet / One common set of codec negotiation procedures will be specified as in ID1656.
- 1891: Bearer establishment inter MSC. TS 23.153 R99 part complete. capabilities moved to annex + list of open issues
- 1892: Bearer establishment inter MSC. TS 23.153 R99 part complete. capabilities moved to annex. / See NP-000127 / Open issues: / Handling of Conference Calls; / Handling of Multi Party Supplementary Services; / Handling of Handover UMTS to GSM; / Handling of Sending a ...

| ID | WBS | Task | Duration | Start | Finish | Complete | Baseline start | Baseline finish | Baseline duration | Constraint | Resources | Work | Actual work | Text1 | Text8 | Text6 | Text4 | Text5 |
| --- | --- | --- | --- | --- | --- | --- | --- | --- | --- | --- | --- | --- | --- | --- | --- | --- | --- | --- |
| 1893 | 49.2 | **Speech Transcoder: Location and Control at the UMTS Core Network Border** | 125d | 2000-04-10 A | 2000-09-29 A | 100% | 2000-04-10 | 2000-09-29 | 125d |  | S2 | 2000h | 2000h | TRFO-STLC | Maurice |  |  |  |
| 1894 | 49.2.1 | Transcoder at Edge | 125d | 2000-04-10 A | 2000-09-29 A | 100% | 2000-04-10 | 2000-09-29 | 125d | finish no earlier than 2000-09-29 | NP | 1000h | 1000h |  |  |  |  |  |
| 1895 | 50 | **GERAN improvements 1 (Gb over IP)** | 225d | 2000-05-09 A | 2001-03-19 A | 100% | 2000-05-09 | 2001-03-19 | 225d |  | GP | 6472h | 6472h | GEIMP1 | Paolo | Rel-4 |  |  |
| 1896 | 50.1 | **Gb over IP (Ip-fication of Gb)** | 225d | 2000-05-09 A | 2001-03-19 A | 100% | 2000-05-09 | 2001-03-19 | 225d |  | GP | 4672h | 4672h | GbIP | Paolo |  |  |  |
| 1897 | 50.1.1 | Concept | 134d | 2000-05-09 A | 2000-11-10 A | 100% | 2000-05-09 | 2000-11-10 | 134d |  | GP | 1072h | 1072h |  | Paolo |  |  |  |
| 1898 | 50.1.2 | Changes to 08.16, 08.18 | 225d | 2000-05-09 A | 2001-03-19 A | 100% | 2000-05-09 | 2001-03-19 | 225d |  | GP | 1800h | 1800h |  | Paolo |  |  |  |
| 1899 | 51 | **GERAN improvements 2 (NACC)** | 815d | 2000-11-06 A | 2003-12-19 A | 100% | 2000-11-06 | 2003-12-19 | 815d |  | GP | 21432h | 21432h | GEIMP2 | Paolo | Rel-4 |  |  |
| 1900 | 51.1 | **Gb enhancements** | 155d | 2000-11-06 A | 2001-06-08 A | 100% | 2000-11-06 | 2001-06-08 | 155d |  | GP | 7440h | 7440h | Gben | Paolo |  |  |  |
| 1901 | 51.1.1 | **Intra BSC NACC (Network Assisted Cell Change)** | 155d | 2000-11-06 A | 2001-06-08 A | 100% | 2000-11-06 | 2001-06-08 | 155d |  | GP | 6200h | 6200h |  | Paolo |  |  |  |
| 1902 | 51.1.1.1 | Concept | 155d | 2000-11-06 A | 2001-06-08 A | 100% | 2000-11-06 | 2001-06-08 | 155d | finish no earlier than 2001-06-08 | GP | 1240h | 1240h |  | Paolo |  |  |  |
| 1903 | 51.1.1.2 | Changes in 03.64 | 155d | 2000-11-06 A | 2001-06-08 A | 100% | 2000-11-06 | 2001-06-08 | 155d | finish no earlier than 2001-06-08 | GP | 1240h | 1240h |  | Paolo |  |  |  |
| 1904 | 51.1.1.3 | Changes in 04.60 | 155d | 2000-11-06 A | 2001-06-08 A | 100% | 2000-11-06 | 2001-06-08 | 155d | finish no earlier than 2001-06-08 | GP | 1240h | 1240h |  | Paolo |  |  |  |
| 1905 | 51.1.1.4 | Changes in 44.008 | 155d | 2000-11-06 A | 2001-06-08 A | 100% | 2000-11-06 | 2001-06-08 | 155d | finish no earlier than 2001-06-08 | GP | 1240h | 1240h |  | Paolo |  |  |  |
| 1906 | 51.3 | **MS conformance test for Intra BSC NACC** | 536d | 2001-11-30 A | 2003-12-19 A | 100% | 2001-11-30 | 2003-12-19 | 536d |  | GP | 7472h | 7472h | GEIMP2-Msconf | Paolo |  |  |  |
| 1907 | 51.3.1 | Changes in 51.010 | 398d | 2001-11-30 A | 2003-12-19 A | 100% | 2001-11-30 | 2003-12-19 | 398d | finish no earlier than 2003-12-19 | G5,G4 | 3184h | 3184h |  | Paolo |  |  |  |
| 1908 | 52 | **GERAN improvements 4 (Delayed TBF)** | 105d | 2001-01-15 A | 2001-06-08 A | 100% | 2001-01-15 | 2001-06-08 | 105d |  | GP | 3960h | 3960h | GEIMP4 | Paolo | Rel-4 |  |  |
| 1909 | 52.1 | **Gb enhancements 2** | 105d | 2001-01-15 A | 2001-06-08 A | 100% | 2001-01-15 | 2001-06-08 | 105d |  | GP | 3120h | 3120h | GEIMP4-Gben2 | Paolo |  |  |  |
| 1910 | 52.1.1 | stage 2 | 105d | 2001-01-15 A | 2001-06-08 A | 100% | 2001-01-15 | 2001-06-08 | 105d | finish no earlier than 2001-06-08 | GP | 840h | 840h |  | Paolo |  |  |  |
| 1911 | 52.1.2 | **Stage 3 (changes in 44.060)** | 60d | 2001-01-15 A | 2001-04-06 A | 100% | 2001-01-15 | 2001-04-06 | 60d |  | G2 | 1440h | 1440h |  | Juha |  |  |  |
| 1912 | 52.1.2.1 | Definition of enhanced countdown procedure | 60d | 2001-01-15 A | 2001-04-06 A | 100% | 2001-01-15 | 2001-04-06 | 60d | finish no earlier than 2001-04-06 | G2 | 480h | 480h |  | Juha |  |  |  |
| 1913 | 52.1.2.2 | Definition of enhanced TBF release procedure | 60d | 2001-01-15 A | 2001-04-06 A | 100% | 2001-01-15 | 2001-04-06 | 60d | finish no earlier than 2001-04-06 | G2 | 480h | 480h |  | Juha |  |  |  |
| 1914 | 52.1.2.3 | Definition of USF=FREE type polling mechanism on PDCH | 60d | 2001-01-15 A | 2001-04-06 A | 100% | 2001-01-15 | 2001-04-06 | 60d | finish no earlier than 2001-04-06 | G2 | 480h | 480h |  | Juha |  |  |  |
| 1915 | 53 | **Low Chip Rate TDD option** | 880d | 2000-07-19 A | 2003-12-02 A | 100% | 2000-07-19 | 2003-12-02 | 880d |  | R1 | 25872h | 25872h | LCRTDD | Patrick | Rel-4 | CWTS | G. Yang |
| 1916 | 53.1 | Physical layer | 183d | 2000-07-19 A | 2001-03-30 A | 100% | 2000-07-19 | 2001-03-30 | 183d | finish no earlier than 2001-03-30 | R1 | 1464h | 1464h | LCRTDD-Phys | Patrick |  | CWTS | G. Yang |
| 1917 | 53.2 | Layer 2 and layer 3 protocol aspects | 183d | 2000-07-19 A | 2001-03-30 A | 100% | 2000-07-19 | 2001-03-30 | 183d | finish no earlier than 2001-03-30 | R2 | 1464h | 1464h | LCRTDD-L23 | Joern |  | CWTS | Y. Liu |
| 1918 | 53.3 | RF radio transmission/reception, system performance requirements and conformance testing | 165d | 2000-08-14 A | 2001-03-30 A | 100% | 2000-08-14 | 2001-03-30 | 165d | finish no earlier than 2001-03-30 | R4 | 1320h | 1320h | LCRTDD-RF | Stefania |  | CWTS | D. Zhang |
| 1919 | 53.4 | UE radio access capability | 165d | 2000-08-14 A | 2001-03-30 A | 100% | 2000-08-14 | 2001-03-30 | 165d | finish no earlier than 2001-03-30 | R2 | 1320h | 1320h | LCRTDD-UErac | Joern |  | CWTS | Y. Liu |
| 1920 | 53.5 | Iub/Iur protocol aspects | 165d | 2000-08-14 A | 2001-03-30 A | 100% | 2000-08-14 | 2001-03-30 | 165d | finish no earlier than 2001-03-30 | R3 | 1320h | 1320h | LCRTDD-IubIur | Gert |  | CWTS | Y. Liu |

Notes:
- 1893: WI description and Tdoc S2-99352 / Speech Transcoder: Location and Control at the UMTS Core Network Border
- 1894: WI description and Tdoc S2-99352...
- 1906: Started
- 1907: az 05/08: duplicated UID_50099 => 50299. Marked as closed 12/2008 (was marked 50% complete)

| ID | WBS | Task | Duration | Start | Finish | Predecessors | Complete | Baseline start | Baseline finish | Baseline duration | Constraint | Resources | Work | Actual work | Text8 | Text3 | Text12 | Text1 | Text4 | Text5 | Text6 |
| --- | --- | --- | --- | --- | --- | --- | --- | --- | --- | --- | --- | --- | --- | --- | --- | --- | --- | --- | --- | --- | --- |
| 1921 | 53.6 | **Low chiprate TDD interworking with GERAN** | 101d | 2000-09-01 A | 2001-01-19 A | 1920 | 100% | 2000-09-01 | 2001-01-19 | 101d |  |  |  |  | Paolo |  |  |  |  |  |  |
| 1922 | 53.6.1 | Handover and Cell Selection / Reselection to UTRA 1.28 Mcps TDD | 101d | 2000-09-01 A | 2001-01-19 A |  | 100% | 2000-09-01 | 2001-01-19 | 101d | finish no earlier than 2001-01-19 |  |  |  |  |  |  |  |  |  |  |
| 1923 | 53.8 | **Conformance Test Aspects - Low Chip Rate TDD** | 577d | 2001-09-17 A | 2003-12-02 A | 1921 | 100% | 2001-09-17 | 2003-12-02 | 577d |  | T1 | 12088h | 12088h | Ingbert | 0% |  |  |  |  |  |
| 1924 | 53.8.1 | Testing Layer 2 and layer 3 protocol aspects | 468d | 2001-09-17 A | 2003-07-02 A |  | 100% | 2001-09-17 | 2003-07-02 | 468d | finish no earlier than 2003-07-02 | T1 | 3744h | 3744h | Ingbert | 34.123-1, 34.123-2 |  |  |  |  |  |
| 1925 | 53.8.2 | Deleted - Testing Layer 2 and layer 3 protocol aspects - TTCN | 261d | 2002-12-03 A | 2003-12-02 A |  | 100% | 2002-12-03 | 2003-12-02 | 261d | finish no earlier than 2003-12-02 | T1 | 2088h | 2088h | Ingbert | 34.123-3 | TP-22 |  |  |  |  |
| 1926 | 53.8.3 | Testing RF Radio Transmission and Reception | 205d | 2001-09-17 A | 2002-06-28 A |  | 100% | 2001-09-17 | 2002-06-28 | 205d | finish no earlier than 2002-06-28 | T1 | 1640h | 1640h | Ingbert |  |  |  |  |  |  |
| 1927 | 54 | **Enable bearer independent CS architecture** | 565d | 2000-01-03 A | 2002-03-01 A |  | 100% | 2000-01-03 | 2002-03-01 | 565d |  | S2 | 20176h | 20176h | Maurice |  |  | CSSPLIT | Siemens | Alexander Milinski | Rel-4 |
| 1928 | 54.1 | **Enable bearer-independent call control** | 424d | 2000-01-03 A | 2001-08-16 A |  | 100% | 2000-01-03 | 2001-08-16 | 424d |  | N4 | 12336h | 12336h | Kimmo |  |  |  | Ericsson | Heinz-Peter.Keutmann@eed.ericsson.se |  |
| 1929 | 54.1.1 | Architecture and Stage 2 description | 180d | 2000-01-03 A | 2000-09-08 A |  | 100% | 2000-01-03 | 2000-09-08 | 180d | finish no earlier than 2000-09-08 | S2 | 1440h | 1440h | Maurice | 23.002 |  |  |  |  |  |
| 1930 | 54.1.2 | Standardisation of protocols (control & user planes) over Nb interface | 64d | 2001-01-02 A | 2001-03-30 A |  | 100% | 2001-01-02 | 2001-03-30 | 64d | finish no earlier than 2001-03-30 | N3 | 512h | 512h | Gwiho |  |  |  |  |  |  |
| 1931 | 54.1.3 | Standardisation of protocols over reference points between MSC server and Gateway MSC server | 130d | 2000-09-25 A | 2001-03-23 A |  | 100% | 2000-09-25 | 2001-03-23 | 130d | finish no earlier than 2001-03-23 | N4 | 1040h | 1040h | Kimmo |  |  |  |  |  |  |
| 1932 | 54.1.4 | Standardisation of detailed stage 2 description | 180d | 2000-07-17 A | 2001-03-23 A |  | 100% | 2000-07-17 | 2001-03-23 | 180d | finish no earlier than 2001-03-23 | N4 | 1440h | 1440h | Kimmo |  |  |  |  |  |  |
| 1933 | 54.1.5 | **Bearer control between MSC server and MGW** | 250d | 2000-09-01 A | 2001-08-16 A |  | 100% | 2000-09-01 | 2001-08-16 | 250d |  | N4 | 4512h | 4512h | Kimmo |  |  |  |  |  |  |
| 1934 | 54.1.5.1 | stage 3 - protocol issues | 250d | 2000-09-01 A | 2001-08-16 A |  | 100% | 2000-09-01 | 2001-08-16 | 250d | finish no earlier than 2001-08-16 | N4 | 2000h | 2000h | Kimmo |  |  |  |  |  |  |
| 1935 | 54.1.5.2 | stage 3 - parameter value issues | 64d | 2001-01-02 A | 2001-03-30 A |  | 100% | 2001-01-02 | 2001-03-30 | 64d | finish no earlier than 2001-03-30 | N3 | 512h | 512h | Gwiho |  |  |  |  |  |  |
| 1936 | 54.2 | Lawful interception | 155d | 2000-08-21 A | 2001-03-23 A |  | 100% | 2000-08-21 | 2001-03-23 | 155d | finish no earlier than 2001-03-23 | S3 | 1240h | 1240h | Dionisio |  |  |  |  |  |  |
| 1937 | 54.4 | Deleted - Conformance Test Aspects - Enable bearer independent CS architecture | 260d | 2001-03-05 A | 2002-03-01 A |  | 100% | 2001-03-05 | 2002-03-01 | 260d |  | T1 | 2080h | 2080h | Ingbert |  | TP-15 | CSSPLIT-TEST |  |  |  |
| 1938 | 55 | **MExE enhancements Rel-4** | 510d | 2000-01-03 A | 2001-12-14 A |  | 100% | 2000-01-03 | 2001-12-14 | 510d |  | T2 | 19024h | 19024h | Kimmo |  |  | MEXE |  |  | Rel-4 |
| 1939 | 55.1 | **MExE Security Analysis Activity** | 474d | 2000-02-22 A | 2001-12-14 A |  | 100% | 2000-02-22 | 2001-12-14 | 474d |  | S3 | 8464h | 8464h | Dionisio |  |  | MEXE-SEC | BT | colin.blanchard@bt.com |  |
| 1940 | 55.1.1 | Stage 3 | 370d | 2000-07-17 A | 2001-12-14 A |  | 100% | 2000-07-17 | 2001-12-14 | 370d | finish no earlier than 2001-12-14 | S3 | 2960h | 2960h | Dionisio |  |  | MEXE1-SEC |  |  |  |
| 1941 | 55.1.2 | Terminal aspects | 214d | 2000-02-22 A | 2000-12-15 A |  | 100% | 2000-02-22 | 2000-12-15 | 214d | finish no earlier than 2000-12-15 | T2 | 1712h | 1712h |  |  |  |  |  |  |  |
| 1942 | 55.2 | **MExE Rel4 Improvements and Investigations** | 250d | 2000-01-03 A | 2000-12-15 A |  | 100% | 2000-01-03 | 2000-12-15 | 250d |  | T2 | 6480h | 6480h |  | 22.057, 23.057 |  | MEXE-ENHANC | Motorola | Mark Cataldo |  |
| 1943 | 55.2.1 | 3rd MExE classmark | 250d | 2000-01-03 A | 2000-12-15 A |  | 100% | 2000-01-03 | 2000-12-15 | 250d | finish no earlier than 2000-12-15 | T2 | 2000h | 2000h |  | 22.057, 23.057 |  |  | Motorola | Mark Cataldo |  |
| 1944 | 55.2.2 | FS on Secure download mechanism and capabilities to support SDR concepts | 225d | 2000-02-07 A | 2000-12-15 A |  | 100% | 2000-02-07 | 2000-12-15 | 225d | finish no earlier than 2000-12-15 | T2 | 1800h | 1800h |  | 22.057, 23.057 |  |  | Motorola | Mark Cataldo |  |
| 1945 | 55.2.3 | FS on Support of MP3/MPEG4 content | 225d | 2000-02-07 A | 2000-12-15 A |  | 100% | 2000-02-07 | 2000-12-15 | 225d | finish no earlier than 2000-12-15 | T2 | 1800h | 1800h |  | 22.057, 23.057 |  |  | Motorola | Mark Cataldo |  |

Notes:
- 1924: Marked as closed 12/2008 (was marked 60% complete)
- 1925: Marked as stopped 12/2008
- 1926: duration set to 6 months (was 0), finish date set
- 1928: DAB 12.12.01 should be 100% hence closed
- 1929: R00 stage 2 at least 80 % complete in TSGS #8 21.-23.6.2000
- 1936: Requirements capture: S3#14 (Aug 00), Feature specification: S3#15 (Sep 00), Definition of architecture. Should be included in general LI work mentioned above.
- 1937: Marked as stopped 12/2008
- 1939: Presentation to S3 of threats and countermeasures analysis: S3#15, Feature specification: S3#16. S3#18: WID updated
- 1940: Analysis undertaken by T2. No additional analysis needed for Rel-4
- 1943: Additional features for MExE R2000

| ID | WBS | Task | Duration | Start | Finish | Complete | Baseline start | Baseline finish | Baseline duration | Constraint | Resources | Work | Actual work | Text1 | Text6 | Text8 | Text3 | Text4 | Text5 |
| --- | --- | --- | --- | --- | --- | --- | --- | --- | --- | --- | --- | --- | --- | --- | --- | --- | --- | --- | --- |
| 1946 | 56 | **Tandem Free aspects for 3G and between 2G and 3G systems** | 344d | 2000-02-22 A | 2001-06-15 A | 100% | 2000-02-22 | 2001-06-15 | 344d |  | S4 | 9696h | 9696h | TFO | Rel-4 | Paolo |  |  |  |
| 1947 | 56.1 | **Tandem Free AMR** | 344d | 2000-02-22 A | 2001-06-15 A | 100% | 2000-02-22 | 2001-06-15 | 344d |  | S4 | 6944h | 6944h | TFO-AMR |  | Paolo |  |  |  |
| 1948 | 56.1.1 | Specification | 284d | 2000-02-22 A | 2001-03-23 A | 100% | 2000-02-22 | 2001-03-23 | 284d | start no earlier than 2000-02-22 | S4 | 2272h | 2272h |  |  | Paolo | 28.062 |  |  |
| 1949 | 56.1.2 | **Impact on:** | 115d | 2001-01-08 A | 2001-06-15 A | 100% | 2001-01-08 | 2001-06-15 | 115d |  | NP | 1920h | 1920h |  |  | Kimmo |  |  |  |
| 1950 | 56.1.2.1 | CN | 60d | 2001-03-26 A | 2001-06-15 A | 100% | 2001-03-26 | 2001-06-15 | 60d | finish no earlier than 2001-06-15 | NP | 480h | 480h |  |  | Kimmo |  |  |  |
| 1951 | 56.1.2.2 | GERAN | 65d | 2001-01-08 A | 2001-04-06 A | 100% | 2001-01-08 | 2001-04-06 | 65d | finish no earlier than 2001-04-06 | GP | 520h | 520h |  |  | Paolo |  |  |  |
| 1952 | 57 | **Advanced Speech Call Items enhancements_REL-4** | 334d | 2000-12-03 A | 2002-03-14 A | 100% | 2000-12-03 | 2002-03-14 | 334d |  | N1 | 5925.6h | 5925.6h | ASCI | Rel-4 | Frederic |  | Nortel | sonia.garapaty@nortelnetworks.com |
| 1953 | 57.1 | Stage 2 | 326.7d | 2000-12-03 A | 2002-03-14 A | 100% | 2000-12-03 | 2002-03-14 | 326.7d | finish no earlier than 2002-03-14 | N4 | 2613.6h | 2613.6h |  |  | Kimmo | 23.067, 24.067 | Sagem | Vivien Perlic |
| 1954 | 57.2 | Stages 2 and 3 on A interface | 80d | 2000-12-03 A | 2001-03-23 A | 100% | 2000-12-03 | 2001-03-23 | 80d | finish no earlier than 2001-03-23 | N1 | 640h | 640h |  |  | Frederic | 44.068, 44.069, 24.008 | Nortel | sonia.garapaty@nortelnetworks.com |
| 1955 | 58 | **700 MHz spectrum support** | 775d | 2000-01-03 A | 2002-12-20 A | 100% | 2000-01-03 | 2002-12-20 | 775d |  | GP | 25000h | 25000h | 700SS | Rel-4 | Paolo |  |  |  |
| 1956 | 58.1 | **GERAN support for the 700 MHz band** | 275d | 2000-01-03 A | 2001-01-19 A | 100% | 2000-01-03 | 2001-01-19 | 275d |  | GP | 8800h | 8800h |  |  | Paolo |  |  |  |
| 1957 | 58.1.1 | Signalling support | 275d | 2000-01-03 A | 2001-01-19 A | 100% | 2000-01-03 | 2001-01-19 | 275d | finish no earlier than 2001-01-19 | GP | 2200h | 2200h |  |  | Paolo |  |  |  |
| 1958 | 58.1.2 | Physical layer definitions | 275d | 2000-01-03 A | 2001-01-19 A | 100% | 2000-01-03 | 2001-01-19 | 275d | finish no earlier than 2001-01-19 | GP | 2200h | 2200h |  |  | Paolo |  |  |  |
| 1959 | 58.1.3 | Receiver performance and RF budget | 275d | 2000-01-03 A | 2001-01-19 A | 100% | 2000-01-03 | 2001-01-19 | 275d | finish no earlier than 2001-01-19 | GP | 2200h | 2200h |  |  | Paolo |  |  |  |
| 1960 | 58.2 | **GERAN MS Conformance test for 700 MHz band** | 175d | 2001-04-02 A | 2001-11-30 A | 100% | 2001-04-02 | 2001-11-30 | 175d |  | GP | 2800h | 2800h |  |  | Paolo |  |  |  |
| 1961 | 58.2.1 | MS test | 175d | 2001-04-02 A | 2001-11-30 A | 100% | 2001-04-02 | 2001-11-30 | 175d | finish no earlier than 2001-11-30 | GP | 1400h | 1400h |  |  | Paolo |  |  |  |
| 1962 | 58.3 | **GERAN BTS Conformance test for 700 MHz band** | 450d | 2001-04-02 A | 2002-12-20 A | 100% | 2001-04-02 | 2002-12-20 | 450d |  | GP | 7200h | 7200h |  |  | Paolo |  |  |  |
| 1963 | 58.3.1 | BTS test | 450d | 2001-04-02 A | 2002-12-20 A | 100% | 2001-04-02 | 2002-12-20 | 450d | finish no earlier than 2002-12-20 | GP | 3600h | 3600h |  |  | Paolo |  |  |  |
| 1964 | 59 | Operator Determined Barring for Packet Oriented Services | 208d | 2000-06-01 A | 2001-03-19 A | 100% | 2000-06-01 | 2001-03-19 | 208d | finish no earlier than 2001-03-19 | NP | 1664h | 1664h | ODB | Rel-4 |  |  | NEC | Toshiyuki Tamura (tamurato@aj.jp.nec.com) |
| 1965 | 60 | **UMTS QoS Architecture for PS Domain** | 758d | 2000-01-03 A | 2002-11-27 A | 100% | 2000-01-03 | 2002-11-27 | 758d |  | S2 | 41296h | 41296h | QoSPS | Rel-4 | Maurice |  | Ericsson | Ina.widegren@era.ericsson.se |
| 1966 | 60.1 | Architecture | 153d | 2000-06-05 A | 2001-01-03 A | 100% | 2000-06-05 | 2001-01-03 | 153d | finish no earlier than 2001-01-03 | S2 | 1224h | 1224h |  |  | Maurice | 23.107 |  |  |
| 1967 | 60.2 | Charging and OAM&P for QoS Management | 201d | 2001-09-21 A | 2002-06-28 A | 100% | 2001-09-21 | 2002-06-28 | 201d | finish no earlier than 2002-06-28 | S5 | 1608h | 1608h | QoSPS-OAM | Rel-4 | Dionisio | 32-series | VoiceStream, Motorola |  |
| 1968 | 60.3 | **RAB Quality of Service (re)Negotiation over Iu** | 155d | 2000-08-21 A | 2001-03-23 A | 100% | 2000-08-21 | 2001-03-23 | 155d |  | R3 | 3648h | 3648h | QoSPS-MAPEND-RABQoS |  | Gert | 25.413 | Ericsson | A. Molander |
| 1969 | 60.3.1 | RAB Quality of Service Negotiation over Iu | 155d | 2000-08-21 A | 2001-03-23 A | 100% | 2000-08-21 | 2001-03-23 | 155d | finish no earlier than 2001-03-23 | R3 | 1240h | 1240h | QoSPS-MAPEND-RABQoS-Negot |  | Gert |  | Ericsson | A. Molander |
| 1970 | 60.3.2 | RAB Quality of Service Negotiation over Iu during relocation | 16d | 2001-03-02 A | 2001-03-23 A | 100% | 2001-03-02 | 2001-03-23 | 16d | start no earlier than 2001-03-02 | R3 | 128h | 128h | QoSPS-MAPEND-RABQoS-NegotReloc |  | Gert |  |  |  |
| 1971 | 60.3.3 | RAB Quality of Service Re-Negotiation over Iu | 130d | 2000-09-25 A | 2001-03-23 A | 100% | 2000-09-25 | 2001-03-23 | 130d | finish no earlier than 2001-03-23 | R3 | 1040h | 1040h | QoSPS-MAPEND-RABQoS-ReNegot |  | Gert |  | Motorola | S. Irwin |

Notes:
- 1946: RAN and CN to verify no problems for GSM terminals roaming in 3G R99
- 1947: RAN and CN to verify UMTS_AMR_2 support
- 1949: "Implementation" changed to "Impact on:" by A. Sultan (for better wording)
- 1950: RAN and CN to verify UMTS_AMR_2 support
- 1951: End date Modified from June to March to have it in Rel4
- 1952: Approved in TSGN_10
- 1953: CN4#11 30/11/02: no inputs received in CN4
- 1964: Completed WI missing from the P-plan Added for tracking

| ID | WBS | Task | Duration | Start | Finish | Complete | Baseline start | Baseline finish | Baseline duration | Constraint | Resources | Work | Actual work | Text1 | Text8 | Text12 | Text4 | Text5 | Text3 | Text6 |
| --- | --- | --- | --- | --- | --- | --- | --- | --- | --- | --- | --- | --- | --- | --- | --- | --- | --- | --- | --- | --- |
| 1972 | 60.4 | **GERAN QoS Aspects - Handovers: maintenance of real-time QoS while moving between cells in the PLMN including inter-SGSN and SRNS relocation or possibly other mechanisms** | 500d | 2000-01-03 A | 2001-11-30 A | 100% | 2000-01-03 | 2001-11-30 | 500d |  | GP | 14440h | 14440h | GERQoS | Paolo |  |  |  |  |  |
| 1973 | 60.4.1 | **Handover Concept for the PS domain** | 500d | 2000-01-03 A | 2001-11-30 A | 100% | 2000-01-03 | 2001-11-30 | 500d |  | GP | 10440h | 10440h |  | Paolo |  |  |  |  |  |
| 1974 | 60.4.1.1 | Stable RT handover report 25.936 including header removal | 13d | 2000-01-03 A | 2000-01-19 A | 100% | 2000-01-03 | 2000-01-19 | 13d | start no earlier than 2000-01-03 | GP | 104h | 104h |  | Paolo |  |  |  |  |  |
| 1975 | 60.4.1.2 | Update of stage 2 | 292d | 2000-01-03 A | 2001-02-13 A | 100% | 2000-01-03 | 2001-02-13 | 292d | finish no earlier than 2001-02-13 | GP | 2336h | 2336h |  | Paolo |  |  |  |  |  |
| 1976 | 60.4.1.3 | Update of relevant stage 3 specs -> RRC | 500d | 2000-01-03 A | 2001-11-30 A | 100% | 2000-01-03 | 2001-11-30 | 500d | finish no earlier than 2001-11-30 | G2 | 4000h | 4000h |  | Juha |  |  |  |  |  |
| 1977 | 60.5 | **Deleted - GERAN MS Conformance test for inter-system and intra-system Packet data real-time Handover** | 324d | 2001-08-31 A | 2002-11-27 A | 100% | 2001-08-31 | 2002-11-27 | 324d |  | G4,R3 | 12960h | 12960h | GERQoS-Mstest | Paolo | GP-12 |  |  |  |  |
| 1978 | 60.5.1 | **Deleted - Handover for the PS domain** | 324d | 2001-08-31 A | 2002-11-27 A | 100% | 2001-08-31 | 2002-11-27 | 324d |  | G4,R3 | 10368h | 10368h |  | Paolo | GP-12 |  |  |  |  |
| 1979 | 60.5.1.1 | Deleted - Stable RT handover report 25.936 including header removal | 324d | 2001-08-31 A | 2002-11-27 A | 100% | 2001-08-31 | 2002-11-27 | 324d | finish no earlier than 2002-11-27 | G4,R3 | 2592h | 2592h |  | Paolo | GP-12 |  |  |  |  |
| 1980 | 60.5.1.2 | Deleted - Update of stage 2 | 324d | 2001-08-31 A | 2002-11-27 A | 100% | 2001-08-31 | 2002-11-27 | 324d | finish no earlier than 2002-11-27 | G4,R3 | 2592h | 2592h |  | Paolo | GP-12 |  |  |  |  |
| 1981 | 60.5.1.3 | Deleted - Update of relevant stage 3 specs | 324d | 2001-08-31 A | 2002-11-27 A | 100% | 2001-08-31 | 2002-11-27 | 324d | finish no earlier than 2002-11-27 | G4,R3 | 2592h | 2592h |  | Paolo | GP-12 |  |  |  |  |
| 1982 | 60.6 | PS-domain handover for real-time services | 155d | 2000-08-28 A | 2001-03-30 A | 100% | 2000-08-28 | 2001-03-30 | 155d | finish no earlier than 2001-03-30 | R3 | 1240h | 1240h | QoSPS-PSdoRTS | Gert |  | Nokia | A. Lansisalmi |  |  |
| 1983 | 60.7 | Deleted - RAB QoS Renegotiation at Relocation | 58d | 2001-01-03 A | 2001-03-23 A | 100% | 2001-01-03 | 2001-03-23 | 58d | finish no earlier than 2001-03-23 | R3 | 464h | 464h |  | Gert | RP-11 |  |  | 25.851, 25.946 |  |
| 1984 | 61 | **small Technical Enhancements and Improvements for Rel4** | 2177d? | 2000-01-03 A | 2008-05-06 A | 100% | 2000-01-03 | 2008-05-06 | 2177d? |  | All | 4024h | 4024h | TEI4 |  |  |  |  |  | Rel-4 |
| 1985 | 458.1 | Small Technical Enhancements and Improvements for Rel-4 Conformance Testing | 503d? | 2000-01-03 A | 2008-05-06 A | 100% | 2000-01-03 | 2008-05-06 | 503d? | finish no earlier than 2008-12-31 | R5 | 4024h | 4024h | TEI4_Test | Ingbert |  |  |  |  | Rel-4 |
| 1986 | 62 | **Rel-4 Evolutions of the transport in the UTRAN** | 525d | 2000-08-21 A | 2002-08-23 A | 100% | 2000-08-21 | 2002-08-23 | 525d |  | RP | 8600h | 8600h | ETRAN | Stefania |  | Alcatel | Francois Courau |  | NA |
| 1987 | 62.1 | QoS optimisation for AAL2 connections over Iub and Iur interfaces | 160d | 2000-08-21 A | 2001-03-30 A | 100% | 2000-08-21 | 2001-03-30 | 160d | finish no earlier than 2001-03-30 | R3 | 1280h | 1280h | ETRAN-QoSAAL2 | Gert |  | Japan Telecom | T. Yoshimura |  | Rel-4 |
| 1988 | 62.2 | Transport bearer modification procedure on Iub, Iur, and Iu | 130d | 2000-10-02 A | 2001-03-30 A | 100% | 2000-10-02 | 2001-03-30 | 130d | finish no earlier than 2001-03-30 | R3 | 1040h | 1040h | ETRAN-MigrMod | Gert |  | Japan Telecom | T. Yoshimura |  | Rel-4 |
| 1989 | 62.3 | **Conformance Test Aspects of Rel-4 evolutions of the transport in UTRAN** | 130d | 2002-02-25 A | 2002-08-23 A | 100% | 2002-02-25 | 2002-08-23 | 130d |  | T1 | 2080h | 2080h |  | Ingbert |  |  |  |  |  |
| 1990 | 62.3.1 | Testing RAB support enhancements | 130d | 2002-02-25 A | 2002-08-23 A | 100% | 2002-02-25 | 2002-08-23 | 130d | finish no earlier than 2002-08-23 | T1 | 1040h | 1040h | CT-RABS? | Ingbert |  |  |  | 34.108, 34. 121, 34.122, 34.123 p 1,2, 34.123 pt 3 |  |
| 1991 | 63 | **Rel-4 Evolutions of the transport in the CN** | 215d | 2000-05-29 A | 2001-03-23 A | 100% | 2000-05-29 | 2001-03-23 | 215d |  | N4 | 7968h | 7968h | CNTRSP | Kimmo |  |  |  |  | NA |
| 1992 | 63.1 | **IP Transport of CN protocols (e.g., CAP, MAP)** | 77d | 2000-12-07 A | 2001-03-23 A | 100% | 2000-12-07 | 2001-03-23 | 77d |  | N4 | 2808h | 2808h | SS7IP | Kimmo |  |  |  |  | Rel-4 |
| 1993 | 63.1.1 | **Stage 3** | 77d | 2000-12-07 A | 2001-03-23 A | 100% | 2000-12-07 | 2001-03-23 | 77d |  | N4 | 2192h | 2192h |  | Kimmo |  |  |  |  |  |
| 1994 | 63.1.1.1 | CAP | 77d | 2000-12-07 A | 2001-03-23 A | 100% | 2000-12-07 | 2001-03-23 | 77d | finish no earlier than 2001-03-23 | N2 | 616h | 616h |  | Kimmo |  |  |  |  |  |
| 1995 | 63.1.1.2 | MAP | 77d | 2000-12-07 A | 2001-03-23 A | 100% | 2000-12-07 | 2001-03-23 | 77d | finish no earlier than 2001-03-23 | N4 | 616h | 616h |  | Kimmo |  |  |  |  |  |
| 1996 | 63.1.1.3 | BSSAP+ | 43d | 2001-01-15 A | 2001-03-14 A | 100% | 2001-01-15 | 2001-03-14 | 43d | finish no earlier than 2001-03-14 | N1 | 344h | 344h | SS7IP-BSSAP+ | Frederic |  |  |  |  |  |

Notes:
- 1977: Still exist? To be clarified by GERAN4/5. Marked as stopped 12/2008
- 1978: Marked as stopped 12/2008
- 1979: Marked as stopped 12/2008
- 1980: Marked as stopped 12/2008
- 1981: Marked as stopped 12/2008
- 1983: Marked as stopped 12/2008
- 1984: "Joker" WI, to be used for a Rel 4 CR not related to any feature and with very limited impact on the system
- 1985: "Joker" WI, to be used for small modifications applicable to Rel 4 conformance testing. Moved in from the Stoyan/Testing WP
- 1990: Marked as stopped 12/2008
- 1991: WI formulation assigned to N4
- 1992: AS: corrected to Rel4 as stated at SA#10

| ID | WBS | Task | Duration | Start | Finish | Complete | Baseline start | Baseline finish | Baseline duration | Constraint | Resources | Work | Actual work | Text4 | Text5 | Text6 | Text8 | Text1 | Text12 | Text3 |
| --- | --- | --- | --- | --- | --- | --- | --- | --- | --- | --- | --- | --- | --- | --- | --- | --- | --- | --- | --- | --- |
| 1997 | 63.2 | **FS on Transport and control separation in the PS CN domain** | 215d | 2000-05-29 A | 2001-03-23 A | 100% | 2000-05-29 | 2001-03-23 | 215d |  | S2 | 3440h | 3440h | Ericsson | Juan-Antonio.Ibanez@eed.ericsson.se | Rel-4 | Maurice |  |  |  |
| 1998 | 63.2.1 | Architectural impacts | 215d | 2000-05-29 A | 2001-03-23 A | 100% | 2000-05-29 | 2001-03-23 | 215d | finish no earlier than 2001-03-23 | S2 | 1720h | 1720h |  |  |  | Maurice |  |  |  |
| 1999 | 64 | **Rel-4 Improvements of Radio Interface** | 700d | 2000-07-10 A | 2003-03-14 A | 100% | 2000-07-10 | 2003-03-14 | 700d |  | RP | 28624h | 28624h |  |  | NA | Stefania | RInImp |  |  |
| 2000 | 64.1 | UTRA repeater specification (master) | 183d | 2000-07-10 A | 2001-03-21 A | 100% | 2000-07-10 | 2001-03-21 | 183d | finish no earlier than 2001-03-21 | R4 | 1464h | 1464h | Mikom, Allgon | T. Kummetz, Mikom; Alf Ahlström, Allgon | Rel-4 | Stefania | RInImp-REP |  |  |
| 2001 | 64.2 | DSCH power control improvement in soft handover | 140d | 2000-09-11 A | 2001-03-23 A | 100% | 2000-09-11 | 2001-03-23 | 140d | finish no earlier than 2001-03-23 | R1 | 1120h | 1120h | Nokia | antti.toskala@nokia.com | Rel-4 | Patrick | RInImp-DSCHsho |  |  |
| 2002 | 64.3 | UMTS 1800 | 320d | 2000-09-25 A | 2001-12-14 A | 100% | 2000-09-25 | 2001-12-14 | 320d | finish no earlier than 2001-12-14 | R4 | 2560h | 2560h | Motorola | Howard Benn | Rel indep | Stefania | RInImp-UMTS18 |  |  |
| 2003 | 64.4 | UMTS 1900 | 195d | 2001-03-19 A | 2001-12-14 A | 100% | 2001-03-19 | 2001-12-14 | 195d | finish no earlier than 2001-12-14 | R4 | 1560h | 1560h | Motorola | Howard Benn | Rel indep | Stefania | RInImp-UMTS19 |  |  |
| 2004 | 64.5 | FS on High Speed downlink packet access | 155d | 2000-08-21 A | 2001-03-23 A | 100% | 2000-08-21 | 2001-03-23 | 155d | finish no earlier than 2001-03-23 | R2 | 1240h | 1240h | Motorola | A. Ghosh |  | Joern | RInImp-HSDPA |  |  |
| 2005 | 64.6 | FS on improved common DL channel for Cell-FACH state | 340d | 2000-09-11 A | 2001-12-28 A | 100% | 2000-09-11 | 2001-12-28 | 340d | finish no earlier than 2001-12-28 | R2 | 2720h | 2720h | GBT | J. Kwak |  | Joern | RInImp-DLCFACH | RP-14 |  |
| 2006 | 64.7 | **Conformance Test Spec. Rel-4 improvements in Radio Interface** | 375d | 2001-10-08 A | 2003-03-14 A | 100% | 2001-10-08 | 2003-03-14 | 375d |  | T1 | 12360h | 12360h |  |  |  | Ingbert |  |  |  |
| 2007 | 64.7.1 | Deleted - Testing Improved usage of downlink resource in FDD for CCTrCHs of dedicated type | 140d | 2002-02-18 A | 2002-08-30 A | 100% | 2002-02-18 | 2002-08-30 | 140d | finish no earlier than 2002-08-30 | T1 | 1120h | 1120h |  |  |  | Ingbert |  | TP-17 |  |
| 2008 | 64.7.2 | Deleted - Testing Terminal Power saving features | 140d | 2002-02-18 A | 2002-08-30 A | 100% | 2002-02-18 | 2002-08-30 | 140d | finish no earlier than 2002-08-30 | T1 | 1120h | 1120h |  |  |  | Ingbert |  | TP-17 |  |
| 2009 | 64.7.3 | Deleted - Testing DSCH power control improvement in soft handover | 140d | 2002-02-18 A | 2002-08-30 A | 100% | 2002-02-18 | 2002-08-30 | 140d | finish no earlier than 2002-08-30 | T1 | 1120h | 1120h |  |  | Rel-4 | Ingbert |  | TP-17 |  |
| 2010 | 64.7.4 | Testing UMTS 1800 | 180d | 2001-10-08 A | 2002-06-14 A | 100% | 2001-10-08 | 2002-06-14 | 180d | finish no earlier than 2002-06-14 | T1 | 1440h | 1440h |  |  | Rel indep | Ingbert |  |  | 34.108, 34,121, 34.122, 34.123-1 |
| 2011 | 64.7.5 | Testing UMTS 1900 | 180d | 2001-10-08 A | 2002-06-14 A | 100% | 2001-10-08 | 2002-06-14 | 180d | finish no earlier than 2002-06-14 | T1 | 1440h | 1440h |  |  | Rel indep | Ingbert |  |  | 34.108, 34,121, 34.122, 34.123-1 |
| 2012 | 64.7.6 | Testing UMTS 1800 - TTCN | 195d | 2002-06-17 A | 2003-03-14 A | 100% | 2002-06-17 | 2003-03-14 | 195d | finish no earlier than 2003-03-14 | T1 | 1560h | 1560h |  |  | Rel indep | Ingbert |  |  | 34.123-3 |
| 2013 | 64.7.7 | Testing UMTS 1900 - TTCN | 195d | 2002-06-17 A | 2003-03-14 A | 100% | 2002-06-17 | 2003-03-14 | 195d | finish no earlier than 2003-03-14 | T1 | 1560h | 1560h |  |  | Rel indep | Ingbert |  |  | 34.123-3 |
| 2014 | 65 | **Rel-4 RAN improvements** | 938d? | 2000-08-14 A | 2004-03-17 A | 100% | 2000-08-14 | 2004-03-17 | 938d? |  | RP | 29336h | 29336h |  |  | NA | Stefania | RANimp |  |  |
| 2015 | 65.1 | Node B synchronisation for TDD | 160d | 2000-08-14 A | 2001-03-23 A | 100% | 2000-08-14 | 2001-03-23 | 160d | finish no earlier than 2001-03-23 | R1 | 1280h | 1280h | Siemens | S. Oestreich | Rel-4 | Patrick | RANimp-NBsync |  |  |
| 2016 | 65.2 | RAB support enhancement for Rel-4 | 155d | 2000-08-21 A | 2001-03-23 A | 100% | 2000-08-21 | 2001-03-23 | 155d | finish no earlier than 2001-03-23 | R2 | 1240h | 1240h | Ericsson | M. Israelsson, A. Krishnarajah | Rel-4 | Joern | RANimp-RABSE |  |  |
| 2017 | 65.4 | **Deleted - Conformance Test Aspects - Rel-4 RAN Improvements** | 577d? | 2002-01-01 A | 2004-03-17 A | 100% | 2002-01-01 | 2004-03-17 | 577d? |  | T1 | 19312h | 19312h |  |  |  | Ingbert |  |  | 0% |
| 2018 | 65.4.1 | Deleted - Testing Radio access bearer support enhancments | 175d | 2002-01-01 A | 2002-09-02 A | 100% | 2002-01-01 | 2002-09-02 | 175d | finish no earlier than 2002-09-02 | T1 | 1400h | 1400h |  |  |  | Ingbert |  | TP-17 |  |
| 2019 | 65.4.2 | Deleted - Testing RAB support enhancements-Robust Header Compression | 332d | 2002-05-28 A | 2003-09-03 A | 100% | 2002-05-28 | 2003-09-03 | 332d | finish no earlier than 2003-09-03 | T1 | 2656h | 2656h |  |  | Rel-4 | Ingbert | RABimp-RoCH | TP-21 | 34.123-1, -2 |
| 2020 | 65.4.3 | Deleted - Testing RAB support enhancements-Robust Header Compression - TTCN | 472d | 2002-05-28 A | 2004-03-17 A | 100% | 2002-05-28 | 2004-03-17 | 472d | finish no earlier than 2004-03-17 | T1 | 3776h | 3776h |  |  | Rel-4 | Ingbert |  | TP-23 | 34.123-3 |
| 2021 | 65.4.4 | Testing of Extended Robut Header Compression | 270d | 2002-09-18 A | 2003-09-30 A | 100% | 2002-09-18 | 2003-09-30 | 270d | finish no earlier than 2003-09-30 | T1 | 2160h | 2160h |  |  | Rel-4 | Ingbert | Ext-RoHC |  | 34.123-1, -2 |
| 2022 | 65.4.5 | Deleted - Testing of Extended Robut Header Compression - TTCN | 325d | 2002-09-18 A | 2003-12-16 A | 100% | 2002-09-18 | 2003-12-16 | 325d | finish no earlier than 2003-12-16 | T1 | 2600h | 2600h |  |  | Rel-4 | Ingbert |  | TP-22 | 34.123-3 |
| 2023 | 462.3.6 | Deleted - General changes to TS34.121 corresponding to release 4 | 263d? | 2003-03-03 A | 2004-03-03 A | 100% | 2003-03-03 | 2004-03-03 | 263d? | finish no earlier than 2004-03-03 | T1 | 2104h | 2104h |  |  | Rel-4 | Ingbert | RANimp-test | TP-23 | 34.108, 34.121 |

Notes:
- 1997: Rel4 added
- 2005: Stopped at RP#14
- 2007: Marked as stopped 12/2008
- 2008: Marked as stopped 12/2008
- 2009: Marked as stopped 12/2008
- 2010: finish date set
- 2011: finish date set
- 2012: finish date set
- 2013: finish date set
- 2016: 29 Nov 2000: split into ROHC and non-ROHC part; 5 Mar 2001: splitting off of ROHC for Rel-4 agreed by R2
- 2017: Marked as stopped 12/2008
- 2018: Marked as stopped 12/2008
- 2019: UID changed. Marked as stopped 12/2008
- 2020: UID changed. Marked as stopped 12/2008
- 2021: Marked as closed 12/2008 (was marked 15% complete)
- 2022: Marked as stopped 12/2008
- 2023: Marked as stopped 12/2008

| ID | WBS | Task | Duration | Start | Finish | Complete | Baseline start | Baseline finish | Baseline duration | Constraint | Resources | Work | Actual work | Text1 | Text4 | Text6 | Text8 | Text12 | Text3 | Text5 |
| --- | --- | --- | --- | --- | --- | --- | --- | --- | --- | --- | --- | --- | --- | --- | --- | --- | --- | --- | --- | --- |
| 2024 | 66 | **Rel-4 Emergency call enhancements** | 627d | 2000-01-03 A | 2002-05-28 A | 100% | 2000-01-03 | 2002-05-28 | 627d |  | N1 | 7936h | 7936h | EMC1 | Ericsson | NA | Frederic |  |  |  |
| 2025 | 66.1 | **For CS based calls** | 627d | 2000-01-03 A | 2002-05-28 A | 100% | 2000-01-03 | 2002-05-28 | 627d |  | N1 | 3600h | 3600h | EMC1-CS | Ericsson | Rel-4 | Frederic |  |  |  |
| 2026 | 66.1.1 | Distinction in CS domain of emergency call types to different emergency services | 40d | 2000-05-01 A | 2000-06-23 A | 100% | 2000-05-01 | 2000-06-23 | 40d | finish no earlier than 2000-06-23 | S1 | 320h | 320h |  |  | Rel-4 | Alain |  |  |  |
| 2027 | 66.1.2 | Distinction in CS domain of emergency calls to different emergency types | 22d | 2000-08-24 A | 2000-09-22 A | 100% | 2000-08-24 | 2000-09-22 | 22d | finish no earlier than 2000-09-22 | N1 | 176h | 176h |  |  | Rel-4 | Frederic |  |  |  |
| 2028 | 66.1.3 | Deleted - Conformance Test Aspects - Emergency call enhancements | 150d | 2000-01-03 A | 2000-07-28 A | 100% | 2000-01-03 | 2000-07-28 | 150d |  | T1 | 1200h | 1200h |  |  |  | Ingbert | TP-08 |  |  |
| 2029 | 66.1.4 | Testing CS based emergency calls | 67d | 2002-02-25 A | 2002-05-28 A | 100% | 2002-02-25 | 2002-05-28 | 67d | finish no earlier than 2002-05-28 | T1 | 536h | 536h |  |  |  | Ingbert |  | 34.123-1 |  |
| 2030 | 66.1.5 | Testing CS based emergency calls - TTCN | 134d | 2001-11-22 A | 2002-05-28 A | 100% | 2001-11-22 | 2002-05-28 | 134d | finish no earlier than 2002-05-28 | T1 | 1072h | 1072h |  |  |  | Ingbert |  | 34.123-3 |  |
| 2031 | 67 | **Rel-4 Terminal interfaces** | 314d | 2000-01-03 A | 2001-03-15 A | 100% | 2000-01-03 | 2001-03-15 | 314d |  | T2 | 14272h | 14272h | TI |  | NA | Kimmo |  |  |  |
| 2032 | 67.1 | **AT commands enhancements** | 313d | 2000-01-03 A | 2001-03-14 A | 100% | 2000-01-03 | 2001-03-14 | 313d |  | T2 | 5008h | 5008h | TI-ATC |  | Rel-4 |  |  | 27.007 |  |
| 2033 | 67.1.1 | Specification of AT commands for new services | 313d | 2000-01-03 A | 2001-03-14 A | 100% | 2000-01-03 | 2001-03-14 | 313d | finish no earlier than 2001-03-14 | T2 | 2504h | 2504h |  |  |  |  |  | 27.007 |  |
| 2034 | 67.2 | **Wide Area Data Synchronisation** | 313d | 2000-01-03 A | 2001-03-14 A | 100% | 2000-01-03 | 2001-03-14 | 313d |  | T2 | 5008h | 5008h | TI-WADS |  | NA |  |  |  |  |
| 2035 | 67.2.1 | Continues evolution of Synchronisation protocol | 313d | 2000-01-03 A | 2001-03-14 A | 100% | 2000-01-03 | 2001-03-14 | 313d | finish no earlier than 2001-03-14 | T2 | 2504h | 2504h | TI-SYNC-EVOL |  | Rel-4 |  |  | 27.903, 27.103 |  |
| 2036 | 67.3 | Terminal local model | 218d | 2000-05-16 A | 2001-03-15 A | 100% | 2000-05-16 | 2001-03-15 | 218d | finish no earlier than 2001-03-15 | T2 | 1744h | 1744h | TLM | Ericsson | Rel-4 |  |  | 23.227 | Olga.Tome@ECS.ERICSSON.SE |
| 2037 | 68 | **Rel-4 Location Services enhancements** | 455d | 2000-04-03 A | 2001-12-28 A | 100% | 2000-04-03 | 2001-12-28 | 455d |  | S2 | 26799.2h | 26799.2h | LCS1 | Nokia | NA | Maurice |  |  | Jan Kall |
| 2038 | 68.1 | CBS interactions | 455d | 2000-04-03 A | 2001-12-28 A | 100% | 2000-04-03 | 2001-12-28 | 455d | finish no earlier than 2001-12-28 | T2 | 3640h | 3640h | LCS1-CBS |  | Rel-4 |  |  | 23.041 |  |
| 2039 | 68.2 | LCS support in the CS domain | 180d | 2000-05-15 A | 2001-01-19 A | 100% | 2000-05-15 | 2001-01-19 | 180d | finish no earlier than 2001-01-19 | S2 | 1440h | 1440h | LCS1-CS |  | Rel-4 | Maurice |  |  |  |
| 2040 | 68.3 | **LCS support in the PS domain** | 435d | 2000-05-01 A | 2001-12-28 A | 100% | 2000-05-01 | 2001-12-28 | 435d |  | S2 | 13560h | 13560h | LCS1-PS |  | Rel-4 | Maurice |  |  |  |
| 2041 | 68.3.1 | Stage 1 | 40d | 2000-07-03 A | 2000-08-25 A | 100% | 2000-07-03 | 2000-08-25 | 40d | start no earlier than 2000-07-03 | S1 | 320h | 320h |  | Pacific Bell Wireless |  | Alain |  | 22.071 | Randolph Wohlert (rwohlert@tri.sbc.com) |
| 2042 | 68.3.2 | Stage 2 | 190d | 2000-05-01 A | 2001-01-19 A | 100% | 2000-05-01 | 2001-01-19 | 190d | finish no earlier than 2001-01-19 | S2 | 1520h | 1520h |  |  |  | Maurice |  | 23.271 |  |
| 2043 | 68.3.3 | **Stage 3** | 355d | 2000-08-21 A | 2001-12-28 A | 100% | 2000-08-21 | 2001-12-28 | 355d |  | N1 | 8240h | 8240h |  |  |  | Frederic |  |  |  |
| 2044 | 68.3.3.1 | Layer 3 LCS signaling UE (MS) -SGSN (UMTS PS and and GSM-GPRS) | 355d | 2000-08-21 A | 2001-12-28 A | 100% | 2000-08-21 | 2001-12-28 | 355d | finish no earlier than 2001-12-28 | N1 | 2840h | 2840h |  | Nokia |  | Frederic |  |  | Janne Muhonen |
| 2045 | 68.3.3.2 | MAP impacts of LCS | 160d | 2000-08-21 A | 2001-03-30 A | 100% | 2000-08-21 | 2001-03-30 | 160d | finish no earlier than 2001-03-30 | N4 | 1280h | 1280h |  |  |  | Kimmo |  |  |  |
| 2046 | 68.3.3.3 | GTP signaling for LCS | 160d | 2000-08-21 A | 2001-03-30 A | 100% | 2000-08-21 | 2001-03-30 | 160d | finish no earlier than 2001-03-30 | N4 | 1280h | 1280h |  |  |  | Kimmo |  |  |  |
| 2047 | 68.4 | **UE positioning Rel-4** | 260d | 2000-04-03 A | 2001-03-30 A | 100% | 2000-04-03 | 2001-03-30 | 260d |  | RP | 4591.2h | 4591.2h | LCS1-UEpos |  | NA | Stefania |  |  |  |
| 2048 | 68.4.1 | Iub/Iur interfaces for methods Rel 99 | 233.9d | 2000-04-03 A | 2001-03-30 A | 100% | 2000-04-03 | 2001-03-30 | 233.9d | finish no earlier than 2001-03-30 | R3 | 1871.2h | 1871.2h | LCS1-UEpos-IubIur | Ericsson | Rel-4 | Gert |  |  | Yun-Chao Hu |
| 2049 | 68.4.2 | UE positioning enhancements - IPDL for TDD | 150d | 2000-08-28 A | 2001-03-23 A | 100% | 2000-08-28 | 2001-03-23 | 150d | finish no earlier than 2001-03-23 | R2 | 1200h | 1200h | LCS1-UEpos-enh | Siemens | Rel-4 | Joern |  |  | M. Beckmann |

Notes:
- 2025: WI approved in TSG_10 / CN1#15: ID 2101 REMOVE-Emergency call recalling capability enhancement, no contributions
- 2027: Calls to different emergency services such as ambulance, fire brigade, police, etc. can be routed to respective different emergency centres. / NP-000447 is the stage 3 changes for CS call control protocol.
- 2028: UID changed. Marked as stopped 12/2008
- 2033: goal not completely achieved because of missing input
- 2034: AS: Rel5 changed to Rel4 according to SA#10 decision, milestone on testing added
- 2039: Only MAP impact foreseen so far. To be further split if needed.
- 2041: To be also considered: External LCS client identity, and Privacy options when PDP-context and when no PDP-context is established
- 2042: AS: 23.271 completed at SA#10
- 2045: Missing work task
- 2047: UID changed
- 2048: 27/11: WG corrected; rapporteur corrected
- 2049: 5 Mar 2001: splitting off of IPDL for TDD for Rel-4 agreed by R2

| ID | WBS | Task | Duration | Start | Finish | Complete | Baseline start | Baseline finish | Baseline duration | Constraint | Resources | Work | Actual work | Text1 | Text6 | Text8 | Text3 | Text4 | Text5 | Text12 |
| --- | --- | --- | --- | --- | --- | --- | --- | --- | --- | --- | --- | --- | --- | --- | --- | --- | --- | --- | --- | --- |
| 2050 | 69 | **Rel-4 UICC/(U)SIM enhancements and interworking** | 175d | 2000-07-24 A | 2001-03-23 A | 100% | 2000-07-24 | 2001-03-23 | 175d |  | T3 | 2800h | 2800h | UICC1 | NA | Xavier |  |  |  |  |
| 2051 | 69.1 | Common PCN Handset Specification (CPHS) | 175d | 2000-07-24 A | 2001-03-23 A | 100% | 2000-07-24 | 2001-03-23 | 175d | finish no earlier than 2001-03-23 | T3 | 1400h | 1400h | UICC1-CPHS | Rel-4 |  | 27.103 | One2One |  |  |
| 2052 | 70 | **Rel-4 (U)SIM toolkit enhancements** | 210d | 2000-06-05 A | 2001-03-23 A | 100% | 2000-06-05 | 2001-03-23 | 210d |  | T3 | 3360h | 3360h | USAT1 | NA | Xavier |  |  |  |  |
| 2053 | 70.1 | USAT local link | 210d | 2000-06-05 A | 2001-03-23 A | 100% | 2000-06-05 | 2001-03-23 | 210d | finish no earlier than 2001-03-23 | T3 | 1680h | 1680h | USAT1-LocLnk | Rel-4 |  |  | Gemplus | Jean-Francois Rubon |  |
| 2054 | 71 | **Rel-4 Security enhancements** | 575d | 2000-01-03 A | 2002-03-15 A | 100% | 2000-01-03 | 2002-03-15 | 575d |  | S3 | 24144h | 24144h | SEC1 | NA | Dionisio |  | Vodafone | Peter.Howard@vodafone.com |  |
| 2055 | 71.1 | Evolution of GSM CS algorithms (e.g. A5/3 development and deployment) | 271d | 2000-01-03 A | 2001-01-15 A | 100% | 2000-01-03 | 2001-01-15 | 271d | finish no earlier than 2001-01-15 | S3 | 2168h | 2168h | SEC1-CSALGO1 | Rel-4 | Dionisio |  |  |  |  |
| 2056 | 71.2 | **Evolution of GSM PS algorithms (e.g. GEA 2 deployment)** | 219d | 2000-02-22 A | 2000-12-22 A | 100% | 2000-02-22 | 2000-12-22 | 219d |  | S3 | 6024h | 6024h | SEC1-PSALGO1 | Rel-4 | Dionisio |  |  |  |  |
| 2057 | 71.2.1 | Main aspects | 199d | 2000-02-22 A | 2000-11-24 A | 100% | 2000-02-22 | 2000-11-24 | 199d | finish no earlier than 2000-11-24 | S3 | 1592h | 1592h |  |  | Dionisio |  |  |  |  |
| 2058 | 71.2.2 | Impact on GTP | 200d | 2000-03-20 A | 2000-12-22 A | 100% | 2000-03-20 | 2000-12-22 | 200d | finish no earlier than 2000-12-22 | N4 | 1600h | 1600h |  |  | Kimmo |  |  |  |  |
| 2059 | 71.2.3 | GEA capability indication in MS CM | 135d | 2000-06-19 A | 2000-12-22 A | 100% | 2000-06-19 | 2000-12-22 | 135d | finish no earlier than 2000-12-22 | N1 | 1080h | 1080h | SEC1-PSALGO1-GEACAP |  | Frederic |  | Vodafone Airtouch | Duncan Mills |  |
| 2060 | 71.3 | **Deleted - MAP application layer security** | 575d | 2000-01-03 A | 2002-03-15 A | 100% | 2000-01-03 | 2002-03-15 | 575d |  | S3 | 11352h | 11352h | SEC1-MAPAL | Rel-4 | Dionisio |  |  |  | SP-15 |
| 2061 | 71.3.1 | Deleted - Main aspects | 199d | 2000-02-21 A | 2001-03-29 A | 100% | 2000-02-21 | 2001-03-29 | 199d | start no earlier than 2000-02-21 | S3 | 1592h | 1592h |  |  | Dionisio |  |  |  | SP-11 |
| 2062 | 71.3.2 | Deleted - Other stage 3 aspects | 199d | 2000-02-22 A | 2000-11-24 A | 100% | 2000-02-22 | 2000-11-24 | 199d | finish no earlier than 2000-11-24 | N4 | 1592h | 1592h |  |  | Kimmo |  |  |  | CP-10 |
| 2063 | 71.3.3 | Deleted - CHECK STATUS - Visibility and Configurability of security | 575d | 2000-01-03 A | 2002-03-15 A | 100% | 2000-01-03 | 2002-03-15 | 575d | finish no earlier than 2002-03-15 | S3 | 4600h | 4600h | SEC1-VCS | Rel-5 | Dionisio |  | France Telecom | Sebastien.nguyenngoc@rd.francetelecom.com | SP-15 |
| 2064 | 72 | **Rel-4 Charging and OAM&P** | 221d | 2000-12-01 A | 2001-10-05 A | 100% | 2000-12-01 | 2001-10-05 | 221d |  | S5 | 10472h | 10472h | OAM | Rel-4 | Dionisio | 32-series | VoiceStream, Motorola |  |  |
| 2065 | 72.1 | Rel4 Principles, high level Requirements and Architecture | 145d | 2000-12-01 A | 2001-06-21 A | 100% | 2000-12-01 | 2001-06-21 | 145d | finish no earlier than 2001-06-21 | S5 | 1160h | 1160h | OAM-AR/PR | Rel-4 | Dionisio | 32.101, 32.102 | Motorola, Telia | Michael.Truss@MOTOROLA.COM; Tommy.R.Berggren@TELIA.SE |  |
| 2066 | 72.2 | Rel4 Performance Management | 216d | 2000-12-01 A | 2001-09-28 A | 100% | 2000-12-01 | 2001-09-28 | 216d | finish no earlier than 2001-06-21 | S5 | 1728h | 1728h |  | Rel-4 | Dionisio | 32.4xy, 52.402 | T-Mobile | karl-heinz.nenner@t-mobile.de |  |
| 2067 | 72.3 | Fault Management | 221d | 2000-12-01 A | 2001-10-05 A | 100% | 2000-12-01 | 2001-10-05 | 221d | finish no earlier than 2001-06-21 | S5 | 1768h | 1768h |  | Rel-4 | Dionisio | 32.111-1/4 | Lucent |  |  |
| 2068 | 72.4 | Configuration Management | 145d | 2000-12-01 A | 2001-06-21 A | 100% | 2000-12-01 | 2001-06-21 | 145d | finish no earlier than 2001-06-21 | S5 | 1160h | 1160h | OAM-CM | Rel-4 | Dionisio | 32.106-1/8 | Ericsson | thomas.tovinger@ericsson.com |  |
| 2069 | 72.5 | Rel4 Charging Management | 216d | 2000-12-01 A | 2001-09-28 A | 100% | 2000-12-01 | 2001-09-28 | 216d | finish no earlier than 2001-06-21 | S5 | 1728h | 1728h | OAM-CH | Rel-4 | Dionisio | 32.2xy (Charging) | T-Mobile | karl-heinz.nenner@t-mobile.de |  |
| 2070 | 72.6 | UTRAN Operations and Maintenance procedures | 145d | 2000-12-01 A | 2001-06-21 A | 100% | 2000-12-01 | 2001-06-21 | 145d | finish no earlier than 2001-06-21 | S5 | 1160h | 1160h | UOAM | Rel-4 | Dionisio | 32.800 | Mannesmann Mobilfunk | bert.boden@d2mannesmann.de |  |
| 2071 | 73 | **Global Text Telephony** | 2348d? | 2000-01-01 A | 2008-12-31 A | 100% | 2000-01-01 | 2008-12-31 | 2348d? |  | S2 | 22176h | 22176h | GTT | Rel Indep | Maurice |  | Ericsson | gunnar.hellstrom@omnitor.se |  |
| 2072 | 73.1 | Stage 1 | 188d | 2000-04-05 A | 2000-12-22 A | 100% | 2000-04-05 | 2000-12-22 | 188d | finish no earlier than 2000-12-22 | S1 | 1504h | 1504h | GTT |  | Alain | 22.976, 22.226 |  |  |  |
| 2073 | 73.2 | Stage 2 | 205d | 2000-01-03 A | 2000-10-13 A | 100% | 2000-01-03 | 2000-10-13 | 205d |  | S2 | 1640h | 1640h | GTT |  | Maurice | 23.226 |  |  |  |

Notes:
- 2051: 28/5/2001: CRs approved at TP-11. WI complete.
- 2053: 25/5/2001:CR was approved at TP-11. WI is complete
- 2054: Added BB UE authentication and rapporteur added. TO BE DELETED
- 2055: Algorithm development go-ahead at SA3#21. Scheduled for completion in August 2002?. Approved SA#17. DELETE ENTRY FROM REL-4?
- 2056: A5/3 development will consider new GEA algorithm based on Kasumi.
- 2057: Complete TSG#09 (09/2000). S3#17: Proposed for deletion. TO BE DELETED
- 2060: TO DELETE: REPLACED BY NDS-MAP and NDS-IP. TO BE DELETED, but replacement NDS-MAP was missing. Completed Auto Key Management -> Rel-6. Marked as stopped 12/2008
- 2061: UID changed. Marked as stopped 12/2008
- 2062: UID changed. Marked as stopped 12/2008
- 2063: CR approved at SA3#21 awaiting comments from CN1. Marked as stopped 12/2008
- 2064: az: WID appr.SA#13.
- 2066: Changed Rapp email
- 2069: Changed Rapp email
- 2071: SP-000162 agreed WI. Rapporteur / Gunnar Hellström, Ericsson Radio Systems AB, / email: gunnar.hellstrom@omnitor.se tel: +46 708 204 288

| ID | WBS | Task | Duration | Start | Finish | Complete | Baseline start | Baseline finish | Baseline duration | Constraint | Resources | Work | Actual work | Text1 | Text8 | Text3 |
| --- | --- | --- | --- | --- | --- | --- | --- | --- | --- | --- | --- | --- | --- | --- | --- | --- |
| 2074 | 73.3 | **Specification of Cellular Text telephone Modem** | 136d | 2000-09-11 A | 2001-03-19 A | 100% | 2000-09-11 | 2001-03-19 | 136d |  | S4 | 2704h | 2704h | GTT-CTM | Paolo |  |
| 2075 | 73.3.1 | General description and C-code | 66d | 2000-09-11 A | 2000-12-11 A | 100% | 2000-09-11 | 2000-12-11 | 66d | finish no earlier than 2000-12-11 | S4 | 528h | 528h | GTT-CTM | Paolo | 26.226, 26.230 |
| 2076 | 73.3.2 | Minimum Performance requirements | 136d | 2000-09-11 A | 2001-03-19 A | 100% | 2000-09-11 | 2001-03-19 | 136d | finish no earlier than 2001-03-19 | S4 | 1088h | 1088h | GTT-CTM | Paolo | 26.231 |
| 2077 | 73.5 | Conformance Test Aspects - Global Text telephony | 2348d? | 2000-01-01 A | 2008-12-31 A | 100% | 2000-01-01 | 2008-12-31 | 2348d? |  | R5 |  |  | GTT_Test | Ingbert | 34.125 |
